# 3GPP_Release-2000

Schedule from MS Project, 1999-01-01 to 2012-12-14, A marks actual dates.

## Calendars

- Standard: Mon-Fri 08:00-12:00, 13:00-17:00; Sat-Sun off. Exceptions (off unless hours are given): 2000-01-15 08:00-12:00, 13:00-17:00, 2009-05-30 08:00-12:00, 13:00-17:00.

## Resources

| Resource |
| --- |
| NP |
| N1 |
| N2 |
| N3 |
| N4 |
| N5 |
| TP |
| T1 |
| T2 |
| T3 |
| RP |
| R1 |
| R2 |
| R3 |
| R4 |
| SP |
| S1 |
| S2 |
| S3 |
| S4 |
| S5 |
| PCG |
| GP |
| No |
| CN4 |
| ? |
| WG G2 |
| G2 |
| G1 |
| G4 |
| G3 |
| All |
| Generic |
| MLST |
| G5 |
| S3, G2 |
| WG T2 |
| GP,G1 |
| G4,G5 |
| OMA |
| GP-G2 |
| Yes |
| GP, |
| N4, |
| GP, N1 |
| CT5 |
| C5 |
| C1 |
| C4 |
| C3 |
| C6 |
| G1, |
| 4 |
| ct |
| c,s,r |
| CT,RAN,SA |
| G2, |
| G1, G3 |
| CT6 |
| CT1 |
| CT1, CT3, CT4 |
| C1, C3, C4 |
| CP |
| R5 |
| C |
| Rel-8 |
| GP, G2 |
| R1,R4 |
| S5,C1 |
| CT,RAN,SA,GERAN |
| S3,C1,C4 |
| 5 |
| S1,C1,C3,C4,S5 |
| S1,C1,C3,C5 |
| S1,C1,C3,C4 |
| S1,S5 |
| S2,S3 |
| RAN,SA |
| RP,S5 |
| S2,CT |
| S1,CT |
| S1,CT,GERAN |
| S1,C5 |
| S3,CT |
| S4,CT |
| C1,SA |
| S1,S2 |
| S1,S4 |
| S2,S2,S3,CT |
| S2,S3,CT |
| S1,CT,GX |
| S1,S4,CT |
| S2,S2,S3,S5,CT |
| S1,S2,CT |
| S1,S2,S3,CT |
| S1,S2,S3,S5CT |
| S1,S2,S3,S5,CT |
| S2,S5,CT |
| S4,S3 |
| S1,C1 |
| CP,C1 |
| C1,C3 |
| C1,C3,C4 |
| S1,S5,CT |
| C4,C3 |
| CP,RAN,SA,GERAN |
| S1,S2,S3,S5,CP |
| S2,S3,CP |
| S2,CP |
| S1,CP,GX |
| S1,CP |
| S1,S4,CP |
| S1,S2,CP |
| S1,S2,S3,CP |
| S2,S5,CP |
| S3,CP |
| S1,S5,CP |
| RAN,SA,GERAN |
| S1,S2,S3,S5,C1,C3,C4,C6 |
| S2,S3,C1,C3,C4 |
| S2,C4 |
| S2,C1,C3,C4 |
| S2,C1,C4 |
| S2,S3,C1,C4 |
| S1,C1,C4,G2 |
| C1,C4 |
| S1,C1,C3 |
| S1,S4,C1,C3,C4 |
| S1,S2,S3,C1,C3,C4 |
| S2,S5,C3 |
| S1,S2,C1,C4 |
| S2,C1 |
| S2,C1,C3 |
| S3,C1,C3,C4 |
| S1,S5,C1,C3,C4 |
| S2,C3,C4 |
| C3,C1 |
| R2,R4 |
| R2,R5 |
| RP,R5 |
| RP,S5,R5 |
| R1,R5 |
| S1,C1,R5 |
| S1,C1,S4,R5 |
| GERAN |
| G3new |
| G1, G3new |
| C4,C1,C3 |
| R1.R4 |
| R1, R4 |
| R2,R3 |
| C3,C4 |
| S4,C3 |
| S4,C3,C1,C4 |
| S1,S2,C1 |
| S1,S2<C1,C3,C4 |
| S1,S2,C1,C3,C4 |
| S5,C1,C3,C4 |
| GP,C4 |
| C4,C1 |
| S2,S1 |
| RP,SP,GP |
| RP,SP,CP,GP |
| CP,GP,RP,SP |
| GP,C4,S4 |
| S1,C1,C4 |
| S1,S2,C3,C1 |
| R2,R4,R3 |
| CP,GP, RP,SP |
| S2,S1,C1,S5 |
| S2,S1,C1 |
| S1,C1,S4 |
| S1,S2,GP,C4,R2 |
| S1,GP,R2 |
| S1,C6 |
| S1,S2,C1,S4 |
| S2,S3,S5,C1,C3,C4 |
| S2,S5,C1 |
| S2,S3,S5 |
| CP,GP, RP,SP,TP |
| S2,C4,C1 |
| S1,C1,C4,S3 |
| S2,S5 |
| S3,C1 |
| S3,C4 |
| S1,C4 |
| S2,S5,C3,C1 |
| S2,S1,S5,C1,C4 |
| S1,R1,C3 |
| S1,C1,R2 |
| S2,S1,C1,C4 |
| S1,C1,C6 |
| GP,S4,C4,C1,C3 |
| C3,C1,C4 |
| S1,C4,C1 |
| S1,S3 |
| S1,S2,S5,C3,C4 |
| R4,G1 |
| G1,R4 |
| RP,GP |
| R4,GP |
| R3,R2 |
| C6,RP,SP |
| R5,C6 |
| CP,RP,SP |
| RP,SP,CP |
| R3,S5 |
| S1,S2,RP |
| S1,S2,S5,RP |
| S2,S1,RP |
| Rel-9 |
| S3,C6 |
| S1,S2,S3,S5,RP |
| S2,S1,S3 |
| S1,S2,S3 |
| S1,S2,S3,S5 |
| C6,R5 |
| S1,S2,RP,GP |
| S1,S2,S4,S5,RP,GP |
| GP,G2 |
| GP,GP, N1 |
| GP,S2,G1,G2 |
| GP,R2,R3,S2,G1,G2 |
| GP,S2,S5,R2,R3,G2,G1 |
| GP,R3 |
| N4,S2 |
| GP,RP |
| GP,S2,RP |
| G5,G4 |
| G4,R3 |
| S2,R2,R4 |
| S1,S2,R2,R4 |
| GP,S5 |
| S1,S2,S5 |
| R4,R5 |
| R4,R2,R3,R5 |
| S2,S5,N4,RP |
| S1,S2,S3,S5,NP |
| S2,S4,S5 |
| T2,S1,S4,S5 |
| SP,RP |
| S2,RP |
| S1,S2,CP,G2 |
| CP,SP |
| S1,G2 |
| SP,CP |
| S1,S2,S5,C3 |
| S1,C1,S3 |
| G1,G3new |
| C4, C3, C1C4 |
| C4,C3,C1 |
| S1,S2,S3,S5,R2,R3,R4 |
| S1,S2,S3,R2 |
| S2,S3,S5,C4,R2 |
| S1,S5,C1 |
| S1,S2,S3,C1,C3,C4,R2 |
| Ggp |
| S3,S2,C1,C4,G2 G3new |
| R1,R2,R3,R4 |
| R4,R1,R2,R3 |
| R4,R2,R3 |
| S1,C1,C4,R2 |
| R4,R2 |
| S2,C4,R2,R4 |
| S2,C4,R2 |
| S2,S3,S5,C3,C4,R2 |
| S1,S2,S4,T2 |
| S1,S2,S4 |
| S1,S2,S4,R5 |
| S3,S2,C1,C4,G2,G3new |
| GP,C1 |
| S1,S5,C4 |
| S1,S2,S3,S5,R2,R3,R4,GP |
| GP,C4,C3,C1 |
| SMG9 |
| SMG1 |
| SMG2 |
| N3,R5 |
| N1, N2, N4, G1, G2, R3, S1, SMG2 |
| S1,SMG1 |
| SMG1,N4 |
| N1,C1,N4,S1,T2,G2,SMG1,SMG2,SMG3,SMG7,SMG9 |
| SMG1,N2 |
| S1,S2,N2,N4 |
| N4,N2 |
| G1,G2 |
| G1,G2,C1 |
| G1,G2,N1 |
| SMG2, SMG1, SMG3, SMG4, SMG7, SMG9, SMG10, G1, G2, G3, N1, N3, T2 |
| SMG2,G1 |
| S1,G1,G2 |
| SMG1,N1,G1,G2 |
| G2,G1 |
| G1,G2,G3,S1,S2,SMG1,SMG2,SMG7,N1,N2,N3,N4,T2 |
| 23.003, 23.008, 29.060 |
| S1, S2, SMG1, SMG2, SMG12, G2, N1, N2, N4 |
| S1,S2,SMG1,SMG2,SMG12,G2,N1,N2,N4 |
| S1,SMG2,N1,N2,N4 |
| SMG1,T2 |
| S1,N1,N2,N4 |
| S1,S2,N5 |
| SMG2,SMG7,G2,T2 |
| S3,N1,N2,N3 |
| S3,N1,N2,N4 |
| SMG9,T3 |
| SMG2,SMG3,SMG7,G2,N2 |
| SMG2,N1,G1,G2 |
| S1,N2 |
| N1,N3 |
| S2,N1 |
| N1,N2,N4 |
| N2,N1,N4 |
| N2,N4 |
| S1,T3 |
| T2,N3 |
| S3,N2 |
| T2,S1 |
| S1,N4 |
| SMG1,SMG2,SMG7 |
| N1,S1,T1 |
| SMG1,SMG3 |
| N4,S2,N1 |
| S1,S2,SMG1,SMG2,SMG7,G1,G2,G3,N1,N2,N3,N4,T2 |
| SMG1,N3 |
| S1,N3 |
| CP,SP,SMG |
| CP,SP,TP,GP,SMG |
| NP,SP,TP,GP,SMG |
| NP,GP, RP,SP,TP |
| SMG2,SMG1,SMG3,SMG4,SMG7,SMG9,SMG10,G1,G2,G3,N1,N3,T2 |
| S1,N2,N4 |
| S1,S2,S3,C1,C3,C4,R2,R3 |
| R2,R3,R1,R4 |
| R2,R3,R4 |
| R2,R1,R3,R4 |
| S2,C4,R2,R3,R4 |
| S2,C4,R2,R1,R3,R4 |
| S2,S3,S5,C3,C4,R2,R3,R4 |
| R1,R2,R4 |
| R3,R1,R4 |
| S2, |
| S2,G2, |
| S1,S2,G2, |
| S1,S2,G2,R2,R3, |
| S1,S2,C4,G2,R2,R3 |
| S1,S2,N4,G2,R2,R3 |
| S1,S2,SMG1,SMG2,SMG12,G2,N1,N2,N4,R2,R3 |
| S1,SMG1,T2 |
| S1,SMG1,S2 |
| S1,N4,N2 |
| T2,N1,N3 |
| S3,N2,N4 |
| SMG1,SMG2,SMG3,SMG7,SMG9,N1,C1,N4,S1,T2,G2 |
| SMG1,N2,N4 |
| S2,T2,N1,N2,N4 |
| S1,T2 |
| S1,S2,C4 |
| S1,S2,N4,RP |
| S2,N4 |
| S1,S2,N3,N4,RP |
| S1,S2,SMG1,SMG2,SMG12,T2,G2,N1,N2,N4,R2,R3 |
| S1,T2,N1,N3 |
| S1,S2,SMG1,SMG2,SMG12,T2,G2,N1,N2,N3,N4,R2,R3 |
| S1,S2,S3,SMG1,SMG2,SMG12,G2,N1,N2,N4,R2,R3 |
| S1,S2,SMG,G1,G2,G3,N1,N2,N3,N4,T2 |
| S1,S2,SMG,T2,G2,N1,N2,N3,N4,R2,R3 |
| S1,S3,SMG,G1,G2,G3,N1,N2,N3,N4,T2 |
| S1,S3,T2,N2,N4 |
| S1,S2,SMG,T2,G1,G2,G3,N1,N2,N3,N4 |
| G2,S2 |
| T1,R5 |
| R5,T1 |
| S1,S2,S4,T1,R5 |
| S1,S2,S4,S5,T1,RP,GP |
| S1,S2,S3,S5,R2,R3,R4,GP,C1 |
| S1,S2,S3,SMG1,SMG2,SMG12,N1,N2,N4,R2,R3 |
| S1,S2,SMG,T2,N1,N2,N3,N4,R2,R3 |
| NP,SP,TP,SMG |
| S1,S2,SMG,T2,N1,N2,N3,N4 |
| SMG,N1 |
| SMG |
| S1,S2,SMG1,SMG2,SMG7,N1,N2,N3,N4,T2 |
| SMG2,SMG1,SMG3,SMG4,SMG7,SMG9,SMG10,N1,N3,T2 |
| S1,SMG |
| SMG2,SMG7,T2 |
| SMG2,S2 |
| N1,N2,N4,R3,S1,SMG |
| SMG2,SMG3,SMG7,N2 |
| SMG1,SMG2,SMG3,SMG7,SMG9,N1,C1,N4,S1,T2 |
| S1,S2,SMG,N3,N4,RP |
| S1,S2,S4,SMG,N3,N4,RP |
| S2,C1,C4,R2,R1,R3,R4 |
| R2,S2,S4 |
| G3new,R5 |
| GP,R4 |
| S2,S4,R2 |
| SP,GP |
| RP,SP |
| S2,S1,S3,S5 |
| S3,S1 |
| N4,N1,N2,S2 |
| S2,G1,G2,R2,R3 |
| S2,G1,G2 |
| G1,G2,R2,R3 |
| N4,T3 |
| S3,S2,N1,N4,T3,OMA |
| T2,S1,S4,S5,OMA |
| S2,N3 |
| S4,S1 |
| N4,N3,S1 |
| R5,G3new |
| R4,R2,R1 |
| S2,R2 |
| C3, C4,C1 |
| S3,C1,C4,C3 |
| C1,C4,C3 |
| S2,C1,C4,C3 |
| R3,R5 |
| S1,S2,C3 |
| R1,R2 |
| S3,C1,C4,G2,G3new |
| R1,R3 |
| GP,N1 |
| R1,R2,R3 |
| R3,R2,R4 |
| R4,R3 |
| S1,S2,R2,R3 |
| S1,S2,S3,C1,C3,C4,R2,R3,R5 |
| S2,S1,S5 |
| C4, C1 |
| C3, C1, C4 |
| S2,S1,S3,S5,C4,C1 |
| S2,C3,C1,C4 |
| S2,S1,S5,C3 |
| GP,S2,C1 |
| GP,S2,C1,G2 |
| G2,S2,C1 |
| v |
| G3new,G1,G2 |
| G1,G2,C1,G3new |
| S2,S1,S5,C1,C3 |
| C1,C3,C4,R5 |
| R2,R1 |
| S1<S2,N1,R2,R5 |
| S1,S2,N1,R2,R5 |
| S2,R5 |
| S1,S2,S5,R5 |
| S2,C1,C4,R2,R1,R3,R4,R5 |
| S1,S2,S3,S5,NP,R5 |
| S1,S2,S4,S5,RP,R5,GP |
| S1,S2,S3,S5,C1,C6,R2,R3,R4 |
| S1,S2,S3,S5,C1,C6,R2,R3,R4,GP |
| S4,R2 |
| S1,S2,C1,C4,G2 |
| S4,C3,C4 |
| S5,C1,C4 |
| S2,C4,C3,C1 |
| C4, C3, C1 |
| S2,S4,R2,C4,C3,C1 |
| GP1,GP2 |
| GP,GP1,GP2 |
| GP,G1,G2 |
| G2,R3 |
| S1,S2,S3,C1,C3,C4,G2 |
| GP,G1,C1 |
| S1,S2,C4,C3,C1 |
| - |
| GP,G1,G2,G3new |
| S1,S2,S3,C1,C3,C4,G2,R2,R3 |
| S1,S2,C1,C3,C4,G2,R2,R3 |
| C1,C6 |
| GP,G2,C4 |
| S2,C3 |
| R5,R4 |
| C4,GP,G2 |
| S1,S2,C1,C4,G2,R2,R3 |
| R1,R2,R4,S3 |
| S2,S5,C3,C1,C4 |

## Schedule

| ID | WBS | Task | Type | Duration | Start | Finish | Complete | Remaining | Baseline start | Baseline finish | Baseline duration | Total slack | Constraint | Resources | Work | Actual work | Text6 | Text8 | Text1 | Text2 | Text4 | Text5 | Text7 | Text3 |
| --- | --- | --- | --- | --- | --- | --- | --- | --- | --- | --- | --- | --- | --- | --- | --- | --- | --- | --- | --- | --- | --- | --- | --- | --- |
| 1 | 1 | Version 2011 Jan 10 | milestone | 0d? | 2000-01-03 A | 2000-01-03 A | 100% |  | 2000-01-03 | 2000-01-03 | 0d? |  |  | - |  |  |  |  |  |  |  |  |  |  |
| 2 | 2 | Rel-9 Two GERAN exceptions to 03/2011 (VAMOS, AGNSSPTP) | milestone | 0d? | 2000-01-03 A | 2000-01-03 A | 100% |  | 2000-01-03 | 2000-01-03 | 0d? |  | finish no earlier than 1998-12-07 | - |  |  |  |  |  |  |  |  |  |  |
| 3 | 3 | Rel-10 Stage 3 freeze 03/2011 | milestone | 0d | 2000-01-03 A | 2000-01-03 A | 100% |  | 2000-01-03 | 2000-01-03 | 0d |  | finish no earlier than 1998-12-07 | - |  |  |  |  |  |  |  |  |  |  |
| 4 | 4 | Rel-11 Stage 1 freeze 09/2011 | milestone | 0d | 2000-01-03 A | 2000-01-03 A | 100% |  | 2000-01-03 | 2000-01-03 | 0d |  | finish no earlier than 1998-12-07 | - |  |  |  |  |  |  |  |  |  |  |
| 5 | 5 | Gantt: dark blue=done; light blue=to be done; grey: previous values; black=summary | milestone | 0d? | 2000-01-03 A | 2000-01-03 A | 100% |  | 2000-01-03 | 2000-01-03 | 0d? |  | finish no earlier than 1998-12-07 | - |  |  |  |  |  |  |  |  |  |  |
| 6 | 6 | Release 11 Features |  | 457d? | 2010-03-25 | 2011-12-23 |  |  | 2010-03-25 | 2011-12-23 | 457d? | 255d | finish no earlier than 2011-12-23 | SP,RP | 3656h |  | Rel-11 | All |  |  |  |  |  |  |
| 7 | 7 | **Support BroadBand forum Accesses Interworking** |  | 402d? | 2009-12-10 A | 2011-06-24 | 33% | 269.92d? | 2009-12-10 | 2011-06-24 | 402d? | 385d |  | S2,S1 | 13736h | 4513.01h | Rel-11 | Alain | BBAI | PCG-24 | Ericsson, Huawei | peter.bleckert@ericsson.com | SP-46 |  |
| 8 | 7.1 | TR on Stage 2 for BroadBand forum Accesses Interworking |  | 326d? | 2010-03-26 A | 2011-06-24 | 20% | 260.8d? | 2010-03-26 | 2011-06-24 | 326d? | 385d | finish no earlier than 2011-06-24 | S2 | 2608h | 521.6h | Rel-11 | Maurice | BBAI | PCG-24 | Ericsson | stefan.rommer@ericsson.com | SP-47 | new TR 23.839 |
| 9 | 7.2 | Stage 1 Building Block I for BroadBand forum Accesses Interworking |  | 76d? | 2009-12-10 A | 2010-03-25 A | 100% |  | 2009-12-10 | 2010-03-25 | 76d? |  | start no earlier than 2009-12-10 | S1 | 608h | 608h | Rel-11 | Alain | BBAI | PCG-24 | Ericsson | peter.bleckert@ericsson.com | SP-46 | 22.278 CR#0058 |
| 10 | 7.3 | Stage 2 Building Block I for BroadBand forum Accesses Interworking |  | 259d? | 2010-03-26 A | 2011-03-23 | 35% | 168.35d? | 2010-03-26 | 2011-03-23 | 259d? | 452d | finish no earlier than 2011-03-23 | S2 | 2072h | 725.2h | Rel-11 | Maurice | BBAI | PCG-24 | Ericsson | stefan.rommer@ericsson.com | SP-47 | 23.203, 23.401, 23.402 |
| 11 | 7.4 | Stage 1 Building Block II for BroadBand forum Accesses Interworking |  | 130d? | 2010-09-23 A | 2011-03-23 | 79% | 27.3d? | 2010-09-23 | 2011-03-23 | 130d? | 452d | finish no earlier than 2011-03-23 | S1 | 1040h | 821.6h | Rel-11 | Alain | BBAI | PCG-25 | Ericsson | peter.bleckert@ericsson.com | SP-49 | 22.278 |
| 12 | 7.5 | Stage 2 Building Block II for BroadBand forum Accesses Interworking |  | 197d? | 2010-09-23 | 2011-06-24 |  |  | 2010-09-23 | 2011-06-24 | 197d? | 385d | finish no earlier than 2011-06-24 | S2 | 1576h |  | Rel-11 | Maurice | BBAI | PCG-24 | Ericsson | stefan.rommer@ericsson.com | SP-47 | 23.203, 23.401, 23.402 |
| 13 | 7.6 | Stage 1 Building Block III for BroadBand forum Accesses Interworking |  | 130d? | 2010-09-23 A | 2011-03-23 | 75% | 32.5d? | 2010-09-23 | 2011-03-23 | 130d? | 452d | finish no earlier than 2011-03-23 | S1 | 1040h | 780h | Rel-11 | Alain | BBAI | PCG-25 | Huawei | Amar Deol (adeol@huawei.com) | SP-49 | 22.278 |
| 14 | 7.7 | Stage 2 Building Block III for BroadBand forum Accesses Interworking |  | 197d? | 2010-09-23 | 2011-06-24 |  |  | 2010-09-23 | 2011-06-24 | 197d? | 385d | finish no earlier than 2011-06-24 | S2 | 1576h |  | Rel-11 | Maurice | BBAI | PCG-24 | Huawei | marco.spini@huawei.com | SP-47 | 23.203, 23.401, 23.402 |
| 15 | 8 | **Advanced IP Interconnection of Services** |  | 517d? | 2010-03-25 A | 2012-03-16 | 27% | 377.05d? | 2010-03-25 | 2012-03-16 | 517d? | 195d |  | S1,S2 | 9840h | 2663.56h | Rel-11 | Alain | IPXS | PCG-24 | Telefónica | chris.friel@O2.com | SP-47 |  |
| 16 | 8.1 | Stage 1 for Advanced IP Interconnection of Services |  | 386d | 2010-03-25 A | 2011-09-15 | 50% | 193d | 2010-03-25 | 2011-09-15 | 386d | 326d | finish no earlier than 2011-09-15 | S1 | 3088h | 1544h | Rel-11 | Alain | IPXS | PCG-24 | Telefónica | chris.friel@O2.com | SP-47 | 22.101, 22.228 |
| 17 | 8.2 | Stage 2 for Advanced IP Interconnection of Services |  | 327d? | 2010-12-16 | 2012-03-16 |  |  | 2010-12-16 | 2012-03-16 | 327d? | 195d | finish no earlier than 2012-03-16 | S2 | 2616h |  | Rel-11 | Maurice | IPXS | PCG-26 | Ericsson | fredrik.lindholm@ericsson.com | SP-50 | 23.228 |
| 18 | 9 | **System Improvements to Machine-Type Communications** |  | 461d? | 2010-06-10 A | 2012-03-15 | 5% | 438.24d? | 2010-06-10 | 2012-03-15 | 461d? | 196d |  | S1,S2,S3 | 19448h | 960.5h | Rel-11 | Alain | SIMTC | PCG-25 | KPN | toon.norp@tno.nl | SP-48 |  |
| 19 | 9.1 | Stage 1 for System Improvements to Machine-Type Communications |  | 331d? | 2010-06-10 A | 2011-09-15 | 10% | 297.9d? | 2010-06-10 | 2011-09-15 | 331d? | 326d | finish no earlier than 2011-09-15 | S1 | 2648h | 264.8h | Rel-11 | Alain | SIMTC | PCG-25 | KPN | toon.norp@tno.nl | SP-48 | 22.368 |
| 20 | 9.2 | TR on Stage 2 for System Improvements to Machine-Type Communications |  | 461d? | 2010-06-10 | 2012-03-15 |  |  | 2010-06-10 | 2012-03-15 | 461d? | 196d | finish no earlier than 2012-03-15 | S2 | 3688h |  | Rel-11 | Maurice | SIMTC | PCG-25 | Samsung | erik.guttman@partner.samsung.com | SP-48 | new TR 23.888 |
| 21 | 9.3 | TR on Security aspects of System Improvements to Machine-Type Communications |  | 321d? | 2010-09-23 A | 2011-12-15 | 20% | 256.8d? | 2010-09-23 | 2011-12-15 | 321d? | 261d | finish no earlier than 2011-12-15 | S3 | 2568h | 513.6h | Rel-11 | Dionisio | SIMTC | PCG-25 | Samsung | Rajavelsamy R (rajvel@samsung.com) | SP-49 | new TR 33.8xy |
| 22 | 9.4 | Stage 2 on SA2 part for System Improvements to Machine-Type Communications |  | 461d? | 2010-06-10 | 2012-03-15 |  |  | 2010-06-10 | 2012-03-15 | 461d? | 196d | finish no earlier than 2012-03-15 | S2 | 3688h |  | Rel-11 | Maurice | SIMTC | PCG-25 | Samsung | erik.guttman@partner.samsung.com | SP-48 | Depends on the outcome of the Stage 2 TR |
| 23 | 9.5 | Stage 2 on Security part for System Improvements to Machine-Type Communications |  | 396d? | 2010-06-10 | 2011-12-15 |  |  | 2010-06-10 | 2011-12-15 | 396d? | 261d | finish no earlier than 2011-12-15 | S3 | 3168h |  | Rel-11 | Dionisio | SIMTC | PCG-25 | Samsung | Rajavelsamy R (rajvel@samsung.com) | SP-48 | Depends on the outcome of the Stage 2 Security TR |
| 24 | 10 | **Unstructured Supplementary Service Data (USSD) simulation service in IMS** |  | 0d? | 2010-06-10 A | 2010-06-10 A | 100% |  | 2010-06-10 | 2010-06-10 | 0d? |  |  | S1 |  |  | Rel-11 | Alain | USSI | PCG-25 | Deutsche Telekom | kurt.bischinger@t-mobile.at | SP-48 |  |
| 25 | 10.1 | Stage 1 for USSD simulation service in IMS | milestone | 0d? | 2010-06-10 A | 2010-06-10 A | 100% |  | 2010-06-10 | 2010-06-10 | 0d? |  | finish no earlier than 2010-06-10 | S1 |  |  | Rel-11 | Alain | USSI | PCG-25 | Deutsche Telekom | kurt.bischinger@t-mobile.at | SP-48 | 22.173 |

Notes:
- 1: -
- 2: -
- 3: -
- 4: -
- 5: -
- 6: -
- 7: SP#50 updated WID SP-100630=>SP-100881 (added WT-134 as one basis for 3GPP Stage 1. Stage 2 will be based on 3GPP Stage 1. Triggered by BBF WT 203 (interworking btw 3GPP EPS and BBF's fixed broadband accesses)
- 8: SP#50 updated WID SP-100630=>SP-100881. TR structure to follow the structure of the Building Blocks. Once a BB is completed, TR to be sent for SA Information. When all the BBs are completed, TR to be sent for SA approval.
- 9: SP#47 completed. Provide service requirements for supporting interworking between 3GPP EPS and the fixed broadband accesses defined by BBF
- 10: SP#50 updated WID SP-100630=>SP-100881
- 11: SP#50 updated WID SP-100630=>SP-100881 (include scope and references to BBF WT-134)
- 12: SP#50 updated WID SP-100630=>SP-100881
- 13: SP#50 updated WID SP-100630=>SP-100881 (include scope and references to BBF WT-134)
- 14: SP#50 updated WID SP-100630=>SP-100881
- 15: SP#50 updated WID SP-100227=>SP-100876 (added Stage 2). Triggered by Rel-10 TR 22.893 UID_380083 Study on advanced requirements for IP interconnect (FS_IPXS)
- 16: SP#50 updated WID SP-100227=>SP-100876. Completion 12/10=>09/11
- 17: SP#50 updated WID SP-100227=>SP-100876 (added Stage 2)
- 18: SP#50 updated WID SP-100637=>SP-100699. Enhancements to Rel-10 Feature UID_410031 (Network Improvements for Machine Type Communications) based on Rel-11 Study on enhancements to MTC
- 19: SP#50 completion 12/10=>09/11
- 20: SP#50 updated WID SP-100637=>SP-100699. Completion 09/11=>03/12
- 21: SP#49 updated WID SP-100447=>SP-100637 (added security TR).
- 22: SP#50 updated WID SP-100637=>SP-100699. Completion 12/11=>03/12
- 23: -
- 24: SP#48 approved WID & Stage 1 completed. Specify a "CS domain USSD" like service over IMS (see GSM Mobile User Initiated USSD)
- 25: SP#48 completed

| ID | WBS | Task | Duration | Start | Finish | Complete | Remaining | Baseline start | Baseline finish | Baseline duration | Total slack | Constraint | Resources | Work | Actual work | Text1 | Text2 | Text4 | Text5 | Text6 | Text7 | Text8 | Text11 |
| --- | --- | --- | --- | --- | --- | --- | --- | --- | --- | --- | --- | --- | --- | --- | --- | --- | --- | --- | --- | --- | --- | --- | --- |
| 26 | 11 | **SRVCC aspect of enhancements for Multimedia Priority Service** | 205d? | 2010-06-10 A | 2011-03-23 | 10% | 184.5d? | 2010-06-10 | 2011-03-23 | 205d? | 452d |  | S2 | 4920h | 492h | eMPS_SRVCC | PCG-25 | Telcordia, NTT DoCoMo | Katsutoshi Nishida | Rel-11 | SP-48 | Maurice |  |
| 27 | 11.1 | TR on SRVCC for eMPS | 205d? | 2010-06-10 A | 2011-03-23 | 20% | 164d? | 2010-06-10 | 2011-03-23 | 205d? | 452d | finish no earlier than 2011-03-23 | S2 | 1640h | 328h | eMPS_SRVCC | PCG-25 | Telcordia, NTT DoCoMo | Katsutoshi Nishida | Rel-11 | SP-48 | Maurice |  |
| 28 | 11.2 | Stage 2 on SRVCC for eMPS | 205d? | 2010-06-10 | 2011-03-23 |  |  | 2010-06-10 | 2011-03-23 | 205d? | 452d | finish no earlier than 2011-03-23 | S2 | 1640h |  | eMPS_SRVCC | PCG-25 | Telcordia, NTT DoCoMo | Katsutoshi Nishida | Rel-11 | SP-48 | Maurice |  |
| 29 | 12 | **Single Radio Video Call Continuity for 3G-CS** | 111d? | 2010-10-15 | 2011-03-18 |  |  | 2010-10-15 | 2011-03-18 | 111d? | 455d |  | S2 | 1406.8h |  | vSRVCC | PCG-26 | Samsung | Haris Zisimopoulos (haris.z@samsung.com) | Rel-11 | SP-50 | Maurice |  |
| 30 | 12.1 | Stage 2 for Single Radio Video Call Continuity for 3G-CS | 64.85d? | 2010-10-15 | 2011-03-18 |  |  | 2010-10-15 | 2011-03-18 | 64.85d? | 455d | start no earlier than 2010-10-15 | S2 | 518.8h |  | vSRVCC | PCG-26 | Samsung | Haris Zisimopoulos (haris.z@samsung.com) | Rel-11 | SP-50 | Maurice |  |
| 31 | 13 | **Network Provided Location Information for IMS** | 465d? | 2010-06-10 A | 2012-03-21 | 10% | 418.11d? | 2010-06-10 | 2011-06-23 | 271d? | 192d |  | S2,S1,S5 | 11192h | 1128.66h | NWK-PL2IMS | PCG-25 | T-Mobile | michele.zarri@t-mobile.co.uk | Rel-11 | SP-48 | Maurice |  |
| 32 | 13.1 | Stage 1 for Network Provided Location Information for IMS | 68d? | 2010-12-15 A | 2011-03-18 | 33% | 45.56d? | 2010-12-15 | 2011-03-18 | 68d? | 455d | finish no earlier than 2011-03-18 | S1 | 544h | 179.52h | NWK-PL2IMS | PCG-26 | n/a | n/a | Rel-11 | SP-50 | Alain |  |
| 33 | 13.2 | TR on network provided location information to the IMS | 205d? | 2010-06-10 A | 2011-03-23 | 35% | 133.25d? | 2010-06-10 | 2011-03-23 | 205d? | 452d | finish no earlier than 2011-03-23 | S2 | 1640h | 574h | NWK-PL2IMS | PCG-25 | T-Mobile | michele.zarri@t-mobile.co.uk | Rel-11 | SP-48 | Maurice |  |
| 34 | 13.3 | Stage 2 for Network Provided Location Information for IMS | 271d? | 2010-06-10 | 2011-06-23 |  |  | 2010-06-10 | 2011-06-23 | 271d? | 386d | finish no earlier than 2011-06-23 | S2 | 2168h |  | NWK-PL2IMS | PCG-25 | T-Mobile | michele.zarri@t-mobile.co.uk | Rel-11 | SP-48 | Maurice |  |
| 35 | 13.4 | Charging for Network Provided Location Information for IMS | 390d? | 2010-09-23 | 2012-03-21 |  |  | 2010-09-23 | 2011-03-23 | 130d? | 192d | finish no earlier than 2012-03-21 | S5 | 3120h |  | NWK-PL2IMS_CH | PCG-25 | Nokia Siemens Networks | Gerald.Goermer@nsn.com | Rel-11 | SP-49 | Dionisio | S5-103010r2 |
| 36 | 14 | **SIPTO Service Continuity of IP Data Session** | 256d? | 2010-09-23 A | 2011-09-15 | 80% | 51.19d? | 2010-09-23 | 2011-09-15 | 256d? | 326d |  | S1 | 4096h | 3276.87h | SIPTO_SC | PCG-25 | Vodafone | mona.mustapha@vodafone.com | Rel-11 | SP-49 | Alain |  |
| 37 | 14.1 | Stage 1 for SIPTO Service Continuity of IP Data Session | 256d? | 2010-09-23 A | 2011-09-15 | 80% | 51.2d? | 2010-09-23 | 2011-09-15 | 256d? | 326d | finish no earlier than 2011-09-15 | S1 | 2048h | 1638.4h | SIPTO_SC | PCG-25 | Vodafone | mona.mustapha@vodafone.com | Rel-11 | SP-49 | Alain |  |
| 38 | 15 | **LIPA Mobility and SIPTO at the Local Network** | 305d? | 2010-10-15 | 2011-12-15 |  |  | 2010-10-15 | 2011-12-15 | 305d? | 261d |  | S2 | 4510.8h |  | LIMONET | PCG-26 | Huawei | Patrice Hédé (patrice.hede@huawei.com) | Rel-11 | SP-50 | Maurice |  |
| 39 | 15.1 | Stage 2 for LIPA Mobility and SIPTO at the Local Network | 258.85d? | 2010-10-15 | 2011-12-15 |  |  | 2010-10-15 | 2011-12-15 | 258.85d? | 261d | finish no earlier than 2011-12-15 | S2 | 2070.8h |  | LIMONET | PCG-26 | Huawei | Patrice Hédé (patrice.hede@huawei.com) | Rel-11 | SP-50 | Maurice |  |
| 40 | 16 | **QoS Control Based on Subscriber Spending Limits** | 390d? | 2010-09-23 A | 2012-03-21 | 42% | 224.73d? | 2010-09-23 | 2012-03-21 | 390d? | 192d |  | S1,S5 | 7808h | 3308.68h | QoS_SSL | PCG-25 | Vodafone | mona.mustapha@vodafone.com | Rel-11 | SP-49 | Alain |  |
| 41 | 16.1 | Stage 1 for QoS Control Based on Subscriber Spending Limits | 256d? | 2010-09-23 A | 2011-09-15 | 97% | 7.68d? | 2010-09-23 | 2011-09-15 | 256d? | 326d | finish no earlier than 2011-09-15 | S1 | 2048h | 1986.56h | QoS_SSL | PCG-25 | Vodafone | mona.mustapha@vodafone.com | Rel-11 | SP-49 | Alain |  |
| 42 | 16.2 | Charging for QoS Control Based on Subscriber Spending Limits | 330d? | 2010-12-16 | 2012-03-21 |  |  | 2010-12-16 | 2012-03-21 | 330d? | 192d | finish no earlier than 2012-03-21 | S5 | 2640h |  | QoS_SSL | PCG-26 | Nokia Siemens Networks, Huawei | Gerald.Goermer@nsn.com, shan.mingjun@huawei.com | Rel-11 | SP-50 | Dionisio |  |
| 43 | 17 | **Optimized Service Charging and Allocation of Resources in IMS whilst Roaming** | 321d? | 2010-09-23 A | 2011-12-15 | 28% | 232.22d? | 2010-09-23 | 2011-12-15 | 321d? | 261d |  | S1,S2 | 9232h | 2553.44h | OSCAR | PCG-25 | Vodafone | mona.mustapha@vodafone.com | Rel-11 | SP-49 | Alain |  |
| 44 | 17.1 | TR on Stage 2 aspects of Optimized Service Charging and Allocation of Resources in IMS whilst Roaming | 256d? | 2010-09-23 A | 2011-09-15 | 20% | 204.8d? | 2010-09-23 | 2011-09-15 | 256d? | 326d | finish no earlier than 2011-09-15 | S2 | 2048h | 409.6h | OSCAR | PCG-25 | Vodafone | nick.russell@vodafone.com | Rel-11 | SP-49 | Maurice |  |
| 45 | 17.2 | Stage 1 for Optimized Service Charging and Allocation of Resources in IMS whilst Roaming | 256d? | 2010-09-23 A | 2011-09-15 | 70% | 76.8d? | 2010-09-23 | 2011-09-15 | 256d? | 326d | finish no earlier than 2011-09-15 | S1 | 2048h | 1433.6h | OSCAR | PCG-25 | Vodafone | mona.mustapha@vodafone.com | Rel-11 | SP-49 | Alain |  |
| 46 | 17.3 | Stage 2 for Optimized Service Charging and Allocation of Resources in IMS whilst Roaming | 321d? | 2010-09-23 | 2011-12-15 |  |  | 2010-09-23 | 2011-12-15 | 321d? | 261d | finish no earlier than 2011-12-15 | S2 | 2568h |  | OSCAR | PCG-25 | Vodafone | nick.russell@vodafone.com | Rel-11 | SP-49 | Maurice |  |
| 47 | 18 | **Non Voice Emergency Services** | 196d? | 2010-12-16 | 2011-09-15 |  |  | 2010-12-16 | 2011-09-15 | 196d? | 326d |  | S1 | 3136h |  | NOVES | PCG-26 | Qualcomm | dwilliams@qualcomm.com | Rel-11 | SP-50 | Alain |  |
| 48 | 18.1 | Stage 1 for NOVES | 196d? | 2010-12-16 | 2011-09-15 |  |  | 2010-12-16 | 2011-09-15 | 196d? | 326d | finish no earlier than 2011-09-15 | S1 | 1568h |  | NOVES | PCG-26 | Qualcomm | dwilliams@qualcomm.com | Rel-11 | SP-50 | Alain |  |
| 49 | 19 | **Interworking between Mobile Operators using the Evolved Packet System and Data Application Providers** | 137d? | 2010-12-16 | 2011-06-24 |  |  | 2010-12-16 | 2011-06-24 | 137d? | 385d |  | S1 | 2192h |  | MOSAP | PCG-26 | Cisco | Vojislav Vucetic (vvucetic@cisco.com) | Rel-11 | SP-50 | Alain |  |
| 50 | 19.1 | Stage 1 for MOSAP | 137d? | 2010-12-16 | 2011-06-24 |  |  | 2010-12-16 | 2011-06-24 | 137d? | 385d | finish no earlier than 2011-06-24 | S1 | 1096h |  | MOSAP | PCG-26 | Cisco | Vojislav Vucetic (vvucetic@cisco.com) | Rel-11 | SP-50 | Alain |  |

Notes:
- 26: SP#49 moved to Rel-11. Completion 09/10=>03/11. Analyze and if needed specify mechanisms for the priority handling of SRVCC with regard to LTE/EPC
- 27: SP#50 split TR work from Stage 2. Re-using / continuing TR 23.854 / Text3: 23.854
- 28: SP#50 split TR work from Stage 2 / Text3: 23.216
- 29: Complete Stage 2 to support Single Radio VIDEO Call Continuity from E-UTRAN to UTRAN-CS based on the agreed architecture alternative in TR 23.886
- 30: Triggered by Feasibility Study on video call handover capability in TR 23.886 UID_470048 Study on Single Radio Video Call Continuity for 3G-CS (FS_vSRVCC) / Text3: 23.203, 23.216, 23.237
- 31: Architecture solutions making Cell/PLMN ID (the UE is camped on) available to IMS nodes when the mobile operator needs to record this information either to fulfil legal obligations or for charging purposes.
- 32: SP#50 approved 22.115 CR#0056r3 in SP-100804 / Text3: 22.115
- 33: - / Text3: new TR 23.8bc
- 34: SP#50 both PCC and LCS based solutions progressed / Text3: 23.060, 23.203, 23.228, 23.401
- 35: Stage 2/3. Stage 1 in SA1 TS 22.115 / Text3: 32.240 (Stage 2), 32.260, 32.298, 32.299
- 36: Linked to Rel-10 Local IP Access and Selected Internet IP Traffic Offload (LIPA_SIPTO)
- 37: SP#50 completion 12/10=>09/11 / Text3: 22.101, 22.220
- 38: Linked to UID_490030 SIPTO Service Continuity of IP Data Session (SIPTO_SC), UID_450035 Local IP Access and Selected IP Traffic Offload (LIPA_SIPTO), UID_460026 Spport BBF Accesses Interworking (BBAI)
- 39: - / Text3: 23.060, 23.401, new TR 23.859
- 40: Stage 1/2/3 ?
- 41: Use cases & service requirements to allow: 1) modification of QoS based on subscribers spending limits 2) enforcing of spending limits for roaming subscribers without having dedicated support in the visited network. SP#50 completion 12/10=>09/11 / Text3: 22.115
- 42: Stage 3: Linked to CT3 TS 29.079 OMR within the IMS; Stage 3 (UID_480110) / Text3: Stage 2 (32.240, 32.296), Stage 3 (TS 32.29x for protocol specification)
- 43: SP#50 updated WID SP-100587=>SP-100701. Triggered by S1-102236/GSMA RILTE 10_007r1 (IREG LS_038 to 3GPP on Optimal Media Routing drawbacks)
- 44: SP#50 updated WID SP-100587=>SP-100701 / Text3: new TR 23.849
- 45: SP#50 completion 12/10=>09/11 / Text3: 22.115, 22.173
- 46: SP#50 updated WID SP-100587=>SP-100701 / Text3: TBD
- 47: Triggered by SA1 Rel-11 TR 22.871 Study on Non Voice Emergency Services (FS_NOVES)
- 48: - / Text3: 22.101
- 49: Linked to Rel-10 Feature UID_500006 PEST
- 50: - / Text3: 22.278

| ID | WBS | Task | Duration | Start | Finish | Complete | Remaining | Baseline start | Baseline finish | Baseline duration | Total slack | Constraint | Resources | Work | Actual work | Text1 | Text2 | Text4 | Text5 | Text6 | Text7 | Text8 | Text11 |
| --- | --- | --- | --- | --- | --- | --- | --- | --- | --- | --- | --- | --- | --- | --- | --- | --- | --- | --- | --- | --- | --- | --- | --- |
| 51 | 20 | **Service Awareness and Privacy Policies** | 178.15d? | 2010-10-12 A | 2011-06-17 | 78% | 39.42d? | 2010-10-12 | 2011-06-17 | 178.15d? | 390d |  | S2,S1 | 2833.2h | 1465.56h | SAPP | PCG-26 | Allot Communications | Alla Goldner (agoldner@llot.com) | Rel-11 | SP-50 | Maurice |  |
| 52 | 20.1 | Stage 1 for deep packet inspection (i.e. Traffic Detection Functionality) | 46.15d? | 2010-10-12 A | 2010-12-15 A | 100% |  | 2010-10-12 | 2010-12-15 | 46.15d? |  | finish no earlier than 2010-12-15 | S1 | 369.2h | 369.2h | SAPP | PCG-26 | Allot Communications | Alla Goldner (agoldner@llot.com) | Rel-11 | SP-50 | Maurice |  |
| 53 | 20.2 | Stage 2 for Service Awareness and Privacy Policies | 129.85d? | 2010-10-15 A | 2011-06-17 | 70% | 38.95d? | 2010-10-15 | 2011-06-17 | 129.85d? | 390d | finish no earlier than 2011-06-17 | S2 | 1038.8h | 727.16h | SAPP | PCG-26 | Allot Communications | Alla Goldner (agoldner@llot.com) | Rel-11 | SP-50 | Maurice |  |
| 54 | 21 | **VPLMN Autonomous CSG Roaming** | 305d? | 2010-10-15 | 2011-12-15 |  |  | 2010-10-15 | 2011-12-15 | 305d? | 261d |  | S2 | 4510.8h |  | VCSG | PCG-26 | Qualcomm | AC Mahendran (ac@qualcomm.com) | Rel-11 | SP-50 | Maurice |  |
| 55 | 21.1 | Stage 2 for VPLMN Autonomous CSG Roaming | 258.85d? | 2010-10-15 | 2011-12-15 |  |  | 2010-10-15 | 2011-12-15 | 258.85d? | 261d | finish no earlier than 2011-12-15 | S2 | 2070.8h |  | VCSG | PCG-26 | Qualcomm | AC Mahendran (ac@qualcomm.com) | Rel-11 | SP-50 | Maurice |  |
| 56 | 22 | EEA3 and EIA3 (new Encryption & Integrity EPS security Algorithms) | 661d? | 2009-06-04 A | 2011-12-15 | 40% | 396.6d? | 2009-06-04 | 2011-12-15 | 661d? | 261d | finish no earlier than 2011-12-15 | S3 | 5288h | 2115.2h | EEA3_EIA3 | PCG-23 | CATR | Yuan Qi, yuanqi@mail.ritt.com.cn | Rel-11 | SP-44 | Dionisio |  |
| 57 | 23 | Specification of Protection against Unsolicited Communication for IMS | 266d? | 2010-06-10 A | 2011-06-16 | 30% | 186.2d? | 2010-06-10 | 2011-06-16 | 266d? | 391d | finish no earlier than 2011-06-16 | S3 | 2128h | 638.4h | SPUCI | PCG-25 | NEC | Anand R. Prasad (anand@bq.jp.nec.com) | Rel-11 | SP-48 | Dionisio |  |
| 58 | 24 | **Codec for Enhanced Voice Services** | 451d? | 2010-03-25 A | 2011-12-15 | 25% | 337.5d? | 2010-03-25 | 2011-12-15 | 451d? | 261d |  | S4,S1 | 7224h | 1817.99h | EVS_codec | PCG-24 | Huawei | anisse.taleb@huawei.com | Rel-11 | SP-47 | Paolo |  |
| 59 | 24.1 | Stage 1 for EVS_codec | 1d? | 2010-03-25 A | 2010-03-25 A | 100% |  | 2010-03-25 | 2010-03-25 | 1d? |  | start no earlier than 2010-03-25 | S1 | 8h | 8h | EVS_codec | PCG-24 | Huawei | anisse.taleb@huawei.com | Rel-11 | SP-47 | Paolo |  |
| 60 | 24.2 | Codec for Enhanced Voice Services | 451d? | 2010-03-25 A | 2011-12-15 | 25% | 338.25d? | 2010-03-25 | 2011-12-15 | 451d? | 261d | finish no earlier than 2011-12-15 | S4 | 3608h | 902h | EVS_codec | PCG-24 | Huawei | anisse.taleb@huawei.com | Rel-11 | SP-47 | Paolo |  |
| 61 | 25 | **Network-Based Positioning Support in LTE** | 921d? | 2009-03-09 A | 2012-09-14 | 17% | 768.62d? | 2009-03-09 | 2012-09-14 | 921d? | 65d |  | R2,R1,R3,R4 | 16256h | 2689.65h | LCS_LTE-NBPS | PCG-22 | TruePosition | terri.brooks@trueposition.com | Rel-11 | RP-43 | Joern | RP-101102 |
| 62 | 25.1 | Core part: Network-Based Positioning Support in LTE | 455.5d? | 2009-03-09 A | 2011-12-09 | 50% | 227.75d? | 2009-03-09 | 2011-12-09 | 455.5d? | 265d | start no earlier than 2009-03-09 | R2,R1,R3,R4 | 3644h | 1822h | LCS_LTE-NBPS-Core | PCG-22 | TruePosition | terri.brooks@trueposition.com | Rel-11 | RP-43 | Joern |  |
| 63 | 25.2 | Perf. part: Network-Based Positioning Support in LTE | 921d? | 2009-03-09 | 2012-09-14 |  |  | 2009-03-09 | 2012-09-14 | 921d? | 65d | finish no earlier than 2012-09-14 | R4 | 7368h |  | LCS_LTE-NBPS-Perf | PCG-22 | TruePosition | terri.brooks@trueposition.com | Rel-11 | RP-43 | Joern |  |
| 64 | 26 | **LTE Advanced Carrier Aggregation of Band 4 and Band 17** | 396d? | 2010-12-10 | 2012-06-15 |  |  | 2010-12-10 | 2012-06-15 | 396d? | 130d |  | R4 | 8464h |  | LTE_CA_B4_B17 | PCG-26 | AT&T | Marc GRANT | Rel-11 | RP-50 | Issam |  |
| 65 | 26.1 | Core part: LTE Advanced Carrier Aggregation of Band 4 and Band 17 | 266d? | 2010-12-10 | 2011-12-16 |  |  | 2010-12-10 | 2011-12-16 | 266d? | 260d | finish no earlier than 2011-12-16 | R4 | 2128h |  | LTE_CA_B4_B17-Core | PCG-26 | AT&T | Marc GRANT | Rel-11 | RP-50 | Issam |  |
| 66 | 26.2 | Perf. part: LTE Advanced Carrier Aggregation of Band 4 and Band 17 | 396d? | 2010-12-10 | 2012-06-15 |  |  | 2010-12-10 | 2012-06-15 | 396d? | 130d | finish no earlier than 2012-06-15 | R4 | 3168h |  | LTE_CA_B4_B17-Perf | PCG-26 | AT&T | Marc GRANT | Rel-11 | RP-50 | Issam |  |
| 67 | 27 | **LTE Advanced Carrier Aggregation of Band 4 and Band 13** | 396d? | 2010-12-10 | 2012-06-15 |  |  | 2010-12-10 | 2012-06-15 | 396d? | 130d |  | R4 | 8464h |  | LTE_CA_B4_B13 | PCG-26 | Ericsson | Christian Bergljung | Rel-11 | RP-50 | Issam |  |
| 68 | 27.1 | Core part: LTE Advanced Carrier Aggregation of Band 4 and Band 13 | 266d? | 2010-12-10 | 2011-12-16 |  |  | 2010-12-10 | 2011-12-16 | 266d? | 260d | finish no earlier than 2011-12-16 | R4 | 2128h |  | LTE_CA_B4_B13-Core | PCG-26 | Ericsson | Christian Bergljung | Rel-11 | RP-50 | Issam |  |
| 69 | 27.2 | Perf. part: LTE Advanced Carrier Aggregation of Band 4 and Band 13 | 396d? | 2010-12-10 | 2012-06-15 |  |  | 2010-12-10 | 2012-06-15 | 396d? | 130d | finish no earlier than 2012-06-15 | R4 | 3168h |  | LTE_CA_B4_B13-Perf | PCG-26 | Ericsson | Christian Bergljung | Rel-11 | RP-50 | Issam |  |
| 70 | 28 | **Eight carrier HSDPA** | 526d? | 2010-12-10 | 2012-12-14 |  |  | 2010-12-10 | 2012-12-14 | 526d? | 0d |  | R1,R2,R3,R4 | 11584h |  | 8C_HSDPA | PCG-26 | Ericsson | johan.hultell@ericsson.com | Rel-11 | RP-50 | Patrick |  |
| 71 | 28.1 | Core part: Eight carrier HSDPA | 396d? | 2010-12-10 | 2012-06-15 |  |  | 2010-12-10 | 2012-06-15 | 396d? | 130d | finish no earlier than 2012-06-15 | R1,R2,R3,R4 | 3168h |  | 8C_HSDPA-Core | PCG-26 | Ericsson | johan.hultell@ericsson.com | Rel-11 | RP-50 | Patrick |  |
| 72 | 28.2 | Perf. part: Eight carrier HSDPA | 526d? | 2010-12-10 | 2012-12-14 |  |  | 2010-12-10 | 2012-12-14 | 526d? | 0d | finish no earlier than 2012-12-14 | R4 | 4208h |  | 8C_HSDPA-Perf | PCG-26 | Ericsson | johan.hultell@ericsson.com | Rel-11 | RP-50 | Issam |  |
| 73 | 29 | **UE demodulation performance requirements under multiple-cell scenario for 1.28Mcps TDD** | 201d? | 2010-12-10 | 2011-09-16 |  |  | 2010-12-10 | 2011-09-16 | 201d? | 325d |  | R4 | 3216h |  | LCR_TDD_UE_demod_mc | PCG-26 | China Mobile | Li Nan (linan@chinamobile.com) | Rel-11 | RP-50 | Issam |  |
| 74 | 29.1 | Perf. part: UE demodulation performance requirements under multiple-cell scenario for 1.28Mcps TDD | 201d? | 2010-12-10 | 2011-09-16 |  |  | 2010-12-10 | 2011-09-16 | 201d? | 325d | finish no earlier than 2011-09-16 | R4 | 1608h |  | LCR_TDD_UE_demod_mc-Perf | PCG-26 | China Mobile | Li Nan (linan@chinamobile.com) | Rel-11 | RP-50 | Issam |  |

Notes:
- 51: Triggered by the SA1,SA2 Rel-10 TR 23.813 Study on Policy solutions and enhancements (FS_PP) UID_440047. SP#50 Stage 1 completed.
- 52: SP#50 completed. For deep packet inspection (i.e. Traffic Detection Functionality) SA1 indicated that no new requirements are needed (see Objective of FS_PP SA1,SA2 Rel-10 Study on Policy solutions and enhancements UID_440047 TR 23.813) / Text3: TR 23.813
- 53: - / Text3: 23.203
- 54: Linked to Rel-10 UID_450053 Enhanced Home NodeB / eNodeB (EHNB). Implements Rel-9 requirements for CSG support in SA1 TS 22.220
- 55: - / Text3: 23.002, 23.060, 23.401
- 56: SP#49 moved to Rel-11. Develop new EPS algorithms acceptable to regions such as China / Text3: 35.xxx (EEA3 & EIA3 Algorithm Specification, Implementers’ test data, Design and evaluation report, Final project report), 33.401 (SAE Security Architecture)
- 57: SP#49 moved to Rel-11. Continuation of Rel-9 UID_410027/410029. Builds on TR 33.937 Study of Mechanisms for PUCI / Text3: new TR 33.8xy, TS 33.abc
- 58: SP#49 SA4 completion =>03/12. Moved to Rel-11. SP#47 Stage 1 completed. Develop EVS codec for EPS based on TR 22.813 recommendations. Triggered by UID_370045 Study on enhanced voice service requirements for EPS (TR 22.813)
- 59: SP#47 completed / Text3: 22.173
- 60: SP#50 completion changed back 03/12=>12/11. SP#49 completion 12/11=>03/12 / Text3: 26.xyz, 26.xyz, 26.xyz, 26.xyz, 26.xyz, 26.xyz, 26.xyz, 26.xyz, 26.xyz, 26.xyz, 26.9yz, 26.xyz
- 61: RP#50 moved to Rel-11. Updated WID RP-100135=>RP-101446 (corresponding to RP-101298 Phase 1: only SRS-based UTDOA). Split into Core & Perf parts / Text3: LTE
- 62: RP#50 moved to Rel-11. Split into Core & Perf parts / Text3: 36.111, 36.133, 36.214, 36.300, 36.305, 36.331, 36.413, 36.423, 36.455
- 63: RP#50 moved to Rel-11. Split into Core & Perf parts / Text3: 36.104, 36.111, 36.133, 36.141
- 64: Stage 3 / Text3: LTE
- 65: - / Text3: 36.101, 36.104, 36.133, 36.141, 36.307, new TR 36.8xy (LTE-Advanced CA of Band 4 and Band 13 for the DL/UL with 20 MHz/10 MHz), TR 36.8ab (LTE-Advanced CA of Band 4 and Band 13 for the DL/UL with 20 MHz/20 MHz)
- 66: - / Text3: 36.101, 36.104, 36.133, 36.307
- 67: Stage 3 / Text3: LTE
- 68: - / Text3: 36.101, 36.104, 36.133, 36.307, new TR 36.8xy (LTE-Advanced CA of Band 4 and Band 13 for the DL/UL with 20 MHz/10 MHz), TR 36.8ab (LTE-Advanced CA of Band 4 and Band 13 for the DL/UL with 20 MHz/20 MHz)
- 69: - / Text3: 36.101, 36.104, 36.133, 36.141, 36.307
- 70: Stage 3 / Text3: UTRA
- 71: - / Text3: 25.101, 25.104, 25.133, 25.211, 25.212, 25.213, 25.214, 25.215, 25.308, 25.331, 25.423, 25.433, 26.306
- 72: - / Text3: 25.101, 25.104, 25.133, 25.141
- 73: Stage 3 / Text3: UTRA
- 74: - / Text3: 25.102

| ID | WBS | Task | Duration | Start | Finish | Complete | Remaining | Baseline start | Baseline finish | Baseline duration | Total slack | Constraint | Resources | Work | Actual work | Text1 | Text2 | Text4 | Text5 | Text6 | Text7 | Text8 | Text11 |
| --- | --- | --- | --- | --- | --- | --- | --- | --- | --- | --- | --- | --- | --- | --- | --- | --- | --- | --- | --- | --- | --- | --- | --- |
| 75 | 30 | **Uplink Transmit Diversity for HSPA** | 461d? | 2010-12-10 | 2012-09-14 |  |  | 2010-12-10 | 2012-09-14 | 461d? | 65d |  | R1,R2,R3,R4 | 16360h |  | HSPA_UL_TxDiv | PCG-26 | Huawei | Wang Zongjie | Rel-11 | RP-50 | Patrick |  |
| 76 | 30.1 | Core part: Uplink Transmit Diversity for HSPA - Closed Loop | 331d? | 2010-12-10 | 2012-03-16 |  |  | 2010-12-10 | 2012-03-16 | 331d? | 195d | finish no earlier than 2012-03-16 | R1,R2,R3,R4 | 2648h |  | HSPA_UL_TxDiv-CL-Core | PCG-26 | Huawei | Wang Zongjie | Rel-11 | RP-50 | Patrick |  |
| 77 | 30.2 | Perf. part: Uplink Transmit Diversity for HSPA - Closed Loop | 461d? | 2010-12-10 | 2012-09-14 |  |  | 2010-12-10 | 2012-09-14 | 461d? | 65d | finish no earlier than 2012-09-14 | R4 | 3688h |  | HSPA_UL_TxDiv-CL-Perf | PCG-26 | Huawei | Wang Zongjie | Rel-11 | RP-50 | Issam |  |
| 78 | 30.3 | Core part: Uplink Transmit Diversity for HSPA - Open Loop | 331d? | 2010-12-10 | 2012-03-16 |  |  | 2010-12-10 | 2012-03-16 | 331d? | 195d | finish no earlier than 2012-03-16 | R1,R2,R3,R4 | 2648h |  | HSPA_UL_TxDiv-OL-Core | PCG-26 | Huawei | Wang Zongjie | Rel-11 | RP-50 | Patrick |  |
| 79 | 30.4 | Perf. part: Uplink Transmit Diversity for HSPA - Open Loop | 461d? | 2010-12-10 | 2012-09-14 |  |  | 2010-12-10 | 2012-09-14 | 461d? | 65d | finish no earlier than 2012-09-14 | R4 | 3688h |  | HSPA_UL_TxDiv-OL-Perf | PCG-26 | Huawei | Wang Zongjie | Rel-11 | RP-50 | Issam |  |
| 80 | 31 | (Small) Technical Enhancements and Improvements for Rel-11 | 402d? | 2010-06-10 | 2011-12-23 |  |  | 2010-06-10 | 2011-12-23 | 402d? | 255d | finish no earlier than 2011-12-23 | All | 3216h |  | TEI11 | PCG-25 |  |  | Rel-11 | SP-48 | All |  |
| 81 | 32 | Release 11 Studies | 335d? | 2009-12-10 A | 2011-03-23 |  | 335d? | 2009-12-10 | 2011-03-23 | 335d? | 452d | finish no earlier than 2011-03-23 | SP,GP | 1086.4h |  |  |  |  |  | Rel-11 |  | All |  |
| 82 | 33 | Study on IMS based Peer-to-Peer Content Distribution Services | 284d? | 2009-05-12 A | 2010-06-10 A | 100% |  | 2009-05-12 | 2010-06-10 | 284d? |  | finish no earlier than 2010-06-10 | S1,S2 | 2272h | 2272h | FS_IMS_P2P | PCG-23 | China Mobile | Li Gang (ligangyf@chinamobile.com) | Rel-11 | SP-45 | Alain |  |
| 83 | 34 | Study on IMS based Peer-to-Peer Content Distribution Services (Stage 2) | 321d? | 2010-09-23 A | 2011-12-15 | 10% | 288.9d? | 2010-09-23 | 2011-12-15 | 321d? | 261d | finish no earlier than 2011-12-15 | S2,S1 | 2568h | 256.8h | FS_IMS_P2P_CDS | PCG-25 | China Mobile | Yu Qing (yuqing@chinamobile.com) | Rel-11 | SP-49 | Maurice |  |
| 84 | 35 | Study on Non Voice Emergency Services | 266d? | 2009-12-10 A | 2010-12-16 A | 100% |  | 2009-12-10 | 2010-12-16 | 266d? |  | finish no earlier than 2010-12-16 | S1 | 2128h | 2128h | FS_NOVES | PCG-24 | Qualcomm | dwilliams@qualcomm.com | Rel-11 | SP-46 | Alain |  |
| 85 | 36 | Study on UICC/USIM enhancements | 335d? | 2009-12-10 A | 2011-03-23 | 50% | 167.5d? | 2009-12-10 | 2011-03-23 | 335d? | 452d | finish no earlier than 2011-03-23 | S1 | 2680h | 1340h | FS_U2e | PCG-24 | Giesecke & Devrient | Ilario ilario.macchi@gi-de.com | Rel-11 | SP-46 | Alain |  |
| 86 | 37 | Study on Alternatives to E.164 for Machine-Type Communications | 321d? | 2010-03-25 A | 2011-06-16 | 20% | 256.8d? | 2010-03-25 | 2011-06-16 | 321d? | 391d | finish no earlier than 2011-06-16 | S1 | 2568h | 513.6h | FS_AMTC | PCG-24 | T-Mobile USA | gary.jones@T-Mobile.com | Rel-11 | SP-47 | Alain |  |
| 87 | 38 | Study on enhancements for Machine-Type Communications (MTC) | 266d? | 2010-06-10 A | 2011-06-16 | 20% | 212.8d? | 2010-06-10 | 2011-06-16 | 266d? | 391d | finish no earlier than 2011-06-16 | S1 | 2128h | 425.6h | FS_MTCe | PCG-25 | Huawei | laurence.meriau@huawei.com | Rel-11 | SP-48 | Alain |  |
| 88 | 39 | Study on Support for 3GPP Voice Interworking with Enterprise IP-PBX | 191d? | 2010-09-23 A | 2011-06-16 | 70% | 57.3d? | 2010-09-23 | 2011-06-16 | 191d? | 391d | finish no earlier than 2011-06-16 | S1,S2 | 1528h | 1069.6h | FS_VINE | PCG-25 | Tatara Systems | Phillip Brown (pbrown@tatarasystems.com) | Rel-11 | SP-48 | Alain |  |
| 89 | 40 | Study on IMS Network-Independent Public User Identities | 131d? | 2010-09-23 A | 2011-03-24 | 10% | 117.9d? | 2010-09-23 | 2011-03-24 | 131d? | 451d | finish no earlier than 2011-03-24 | S1 | 1048h | 104.8h | FS_INIPUI | PCG-25 | Vodafone | mona.mustapha@vodafone.com | Rel-11 | SP-49 | Alain |  |
| 90 | 41 | Study on Integration of Single Sign-On (SSO) frameworks with 3GPP networks | 191d? | 2010-09-23 A | 2011-06-16 | 10% | 171.9d? | 2010-09-23 | 2011-06-16 | 191d? | 391d | finish no earlier than 2011-06-16 | S1 | 1528h | 152.8h | FS_SSO_Int | PCG-25 | InterDigital | christopher.wallace@interdigital.com | Rel-11 | SP-49 | Alain |  |
| 91 | 42 | Study on Security aspects of Integration of Single Sign-On (SSO) frameworks with 3GPP networks | 196d? | 2010-12-16 | 2011-09-15 |  |  | 2010-12-16 | 2011-09-15 | 196d? | 326d | finish no earlier than 2011-09-15 | S3 | 1568h |  | FS_SSO_Int_Sec | PCG-26 | Ericsson | vesa.lehtovirta@ericsson.com | Rel-11 | SP-50 | Dionisio |  |
| 92 | 43 | Study on Core Network Overload solutions | 321d? | 2010-09-23 A | 2011-12-15 | 20% | 256.8d? | 2010-09-23 | 2011-12-15 | 321d? | 261d | finish no earlier than 2011-12-15 | S2 | 2568h | 513.6h | FS_CNO | PCG-25 | Huawei | David Xiang (dxiang@huawei.com) | Rel-11 | SP-49 | Maurice |  |
| 93 | 44 | Study on Continuity of Data Sessions to Local Networks | 197d? | 2010-12-16 | 2011-09-16 |  |  | 2010-12-16 | 2011-09-16 | 197d? | 325d | finish no earlier than 2011-09-16 | S1 | 1576h |  | FS_CSN | PCG-26 | NEC | joerg.swetina@nw.neclab.eu | Rel-11 | SP-50 | Alain |  |
| 94 | 45 | Study on Non-MTC Mobile Data Applications impacts | 197d? | 2010-12-16 | 2011-09-16 |  |  | 2010-12-16 | 2011-09-16 | 197d? | 325d | finish no earlier than 2011-09-16 | S1 | 1576h |  | FS_MODAI | PCG-26 | Huawei, China Mobile | Amar Deol (adeol@huawei.com), Gang Li | Rel-11 | SP-50 | Alain |  |
| 95 | 46 | Study on System Enhancements for Energy Efficiency | 261d? | 2010-12-16 | 2011-12-15 |  |  | 2010-12-16 | 2011-12-15 | 261d? | 261d | finish no earlier than 2011-12-15 | S2 | 2088h |  | FS_SEEE | PCG-26 | Huawei | frank.mademann@huawei.com | Rel-11 | SP-50 | Maurice |  |
| 96 | 47 | Study on Solutions for GSM/EDGE BTS Energy Saving | 261d? | 2010-09-03 A | 2011-09-02 | 5% | 247.95d? | 2010-09-03 | 2011-09-02 | 261d? | 335d | finish no earlier than 2011-09-02 | G1,G2 | 2088h | 104.4h | FS_Energy_BTS | PCG-25 | Nokia Siemens Networks, Vodafone | juergen.hofmann@nsn.com, leo.patanapongpibul@vodafone.com | Rel-11 | GP-47 | Paolo |  |
| 97 | 48 | Study on Coordinated Multi-Point operation for LTE | 200d? | 2010-12-10 | 2011-09-15 |  |  | 2010-12-10 | 2011-09-15 | 200d? | 326d | finish no earlier than 2011-09-15 | R1,R2,R3 | 1600h |  | FS_CoMP_LTE | PCG-24 | Samsung | bruno.clerckx@samsung.com | Rel-11 | RP-47 | Patrick | RP-101127 |
| 98 | 49 | Study on UE Application Layer Data Throughput Performance | 200d? | 2010-12-10 | 2011-09-15 |  |  | 2010-12-10 | 2011-09-15 | 200d? | 326d | finish no earlier than 2011-09-15 | R5,R4 | 1600h |  | FS_UE_App_Data_Perf | PCG-26 | Spirent Communications | ron.borsato@spirent.com | Rel-11 | RP-50 | Ingbert |  |
| 99 | 50 | Study on Uplink MIMO | 200d? | 2010-12-10 | 2011-09-15 |  |  | 2010-12-10 | 2011-09-15 | 200d? | 326d | finish no earlier than 2011-09-15 | R1 | 1600h |  | FS_UTRA_UL_MIMO | PCG-26 | Qualcomm | Sharad Sambhwani | Rel-11 | RP-50 | Patrick |  |
| 100 | 51 | Study on HSDPA Multipoint Transmission | 200d? | 2010-12-10 | 2011-09-15 |  |  | 2010-12-10 | 2011-09-15 | 200d? | 326d | finish no earlier than 2011-09-15 | R1,R2,R3 | 1600h |  | FS_HSDPA_MP_TX | PCG-26 | Nokia Siemens Networks | Karri Ranta-aho | Rel-11 | RP-50 | Patrick |  |
| 101 | 52 | Study on Inclusion of RF Pattern Matching Technologies as a positioning method in the E-UTRAN | 266d? | 2010-12-10 | 2011-12-16 |  |  | 2010-12-10 | 2011-12-16 | 266d? | 260d | finish no earlier than 2011-12-16 | R4 | 2128h |  | FS_LCS_LTE_RFPMT | PCG-26 | Polaris Wireless | Robert Gross (rgross@polariswireless.com) | Rel-11 | RP-50 | Issam |  |
| 102 | 53 | Release 10 Features | 593d? | 2008-12-11 A | 2012-07-30 | 15% | 504.05d? | 2008-12-11 | 2012-07-30 | 593d? | 99.2d |  | CP,GP,RP,SP | 4744h | 711.6h |  |  |  |  | Rel-10 |  |  |  |

Notes:
- 75: Stage 2/3 / Text3: UTRA
- 76: - / Text3: 25.101, 25.104, 25.133, 25.211, 25.212, 25.213, 25.214, 25.215, 25.306, 25.319, 25.321, 25.331, 25.423, 25.433
- 77: - / Text3: 25.101, 25.104, 25.133, 25.141
- 78: - / Text3: 25.101, 25.133, 25.306, 25.319, 25.321, 25.331, 25.423, 25.433
- 79: - / Text3: 25.101, 25.133
- 80: SP#50 EU-Alert is introduced under Public Warning System in parallel with the already existing ETWS and CMAS. SA1 22.268 CR#9r1 adds EU-ALERT specific requirements & CT1 23.041 CRs#
- 81: -
- 82: SP#48 completed / Text3: 22.906
- 83: Triggered by TR 22.906 SA1 Study on IMS based Peer-to-Peer Content Distribution Services UID_450047 / Text3: 23.844
- 84: SP#50 completed / Text3: 22.871
- 85: SP#49 completion 09/10=>03/11? Triggered by GSMA Smart SIM and 3GNBK projects, and to evolve from traditional USAT to multimedia USIM toolkit support, particularly to Smart Card Web Server / Text3: 22.817
- 86: Determine an alternative to E.164 for identifying individual devices and route messages between those devices / Text3: 22.988
- 87: Study Network improvements for MTC Device to MTC Device communications via one or more PLMNs (direct-mode communication between devices is out of scope), etc. Align also with ETSI TC M2M work. / Text3: 22.888
- 88: SP#50 TR 22.809 v100 for Information. Support Interworking between 3GPP networks and Enterprise environments to provide enterprise voice services via 3GPP mobile devices / Text3: 22.809
- 89: - / Text3: 22.894
- 90: Linked to SA3 Study on Single Sign On (SSO) Application Security for IMS - based on SIP Digest (UID_480048), SA3 TR 33.924 Extended Identity Management (GBA-IdM) and SA3 TR 33.980 Liberty Alliance and 3GPP Security Interworking (LibSec) / Text3: 22.895
- 91: Linked to SA1 FS_SSO_Int (Study Integration of SSO frameworks with 3GPP networks),SA3 FS_SSO_APS (Study SSO Application Security for IMS - based on SIP Digest),GBA-IdM (33.924),LIBSEC (33.980 Interworking of Liberty Alliance IFF, Identity Web SF and GAA) / Text3: 33.8xx
- 92: Linked to CT4 UID_490014 Study on EPC Nodes Restoration. Support from CT4 and RAN WGs is anticipated. / Text3: 23.843
- 93: Linked to SA1 Rel-11 Feature UID_490030 SIPTO Service Continuity of IP Data Session (SIPTO_SC) / Text3: 22.8xy
- 94: Linked to UID_490036 SA2 Rel-11 TR 23.843 Study on Core Network Overload solutions (FS_CNO) / Text3: 22.801
- 95: Linked to SA5, CT, (GE(RAN) studies on Energy saving & SA5 Rel-10 implementation Work Item on Energy Saving Management architectures and management solutions / Text3: 23.8xy
- 96: GP#47 approved SID / Text3: 45.8xy
- 97: RP#50 updated WID RP-100370=>RP-101425. Work was on hold since PR#47 until RP#50. / Text3: LTE 36.8xx
- 98: LTE, UTRA / Text3: LTE, UTRA 37.901
- 99: UTRA / Text3: UTRA 25.8xy
- 100: UTRA / Text3: UTRA 25.8xy
- 101: LTE / Text3: LTE 36.8xy
- 102: -

| ID | WBS | Task | Duration | Start | Finish | Complete | Remaining | Baseline start | Baseline finish | Baseline duration | Total slack | Constraint | Resources | Work | Actual work | Text1 | Text2 | Text4 | Text5 | Text6 | Text7 | Text8 | Text9 | Text12 | Text11 |
| --- | --- | --- | --- | --- | --- | --- | --- | --- | --- | --- | --- | --- | --- | --- | --- | --- | --- | --- | --- | --- | --- | --- | --- | --- | --- |
| 103 | 54 | **Enhancements for Multimedia Priority Service** | 1311d? | 2006-03-13 A | 2011-03-18 | 94% | 83.06d? | 2006-03-13 | 2011-03-18 | 1311d? | 455d |  | S1,S2,C4,C3,C1 | 28072h | 20998.4h | eMPS | PCG-21 | Telcordia | jgarraha@telcordia.com | Rel-10 | SP-39 | Alain |  |  |  |
| 104 | 54.1 | Stage 1 on enhancements for Multimedia Priority Service | 584d? | 2006-03-13 A | 2008-06-05 A | 100% |  | 2006-03-13 | 2008-06-05 | 584d? |  | start no earlier than 2006-03-12 | S1 | 4672h | 4672h | ePRIOR | PCG-21 | Telcordia | jgarraha@telcordia.com | Rel-10 | SP-39 | Alain |  |  |  |
| 105 | 54.2 | **Stage 2 on enhancements for Multimedia Priority Service** | 206d? | 2009-12-10 A | 2010-09-23 A | 100% |  | 2009-12-10 | 2010-09-23 | 206d? |  |  | S2 | 6592h | 6592h | eMPS | PCG-24 | Telcordia, NTT DoCoMo | Vijay Varma, Katsutoshi Nishida | Rel-10 | SP-46 | Maurice |  |  |  |
| 106 | 54.2.1 | Stage 2 on eMPS for CSFB | 206d? | 2009-12-10 A | 2010-09-23 A | 100% |  | 2009-12-10 | 2010-09-23 | 206d? |  | finish no earlier than 2010-09-24 | S2 | 1648h | 1648h | eMPS | PCG-24 | Telcordia, NTT DoCoMo | Vijay Varma, Katsutoshi Nishida | Rel-10 | SP-46 | Maurice |  |  |  |
| 107 | 54.2.2 | Stage 2 on eMPS for EPS Bearer Service | 206d? | 2009-12-10 A | 2010-09-23 A | 100% |  | 2009-12-10 | 2010-09-23 | 206d? |  | finish no earlier than 2010-12-09 | S2 | 1648h | 1648h | eMPS | PCG-24 | Telcordia, NTT DoCoMo | Vijay Varma, Katsutoshi Nishida | Rel-10 | SP-46 | Maurice |  |  |  |
| 108 | 54.2.3 | Stage 2 on eMPS for IMS Aspects | 206d? | 2009-12-10 A | 2010-09-23 A | 100% |  | 2009-12-10 | 2010-09-23 | 206d? |  | finish no earlier than 2010-12-09 | S2 | 1648h | 1648h | eMPS | PCG-24 | Telcordia, NTT DoCoMo | Vijay Varma, Katsutoshi Nishida | Rel-10 | SP-46 | Maurice |  |  |  |
| 109 | 54.3 | TR on Stage 2 on enhancements for Multimedia Priority Service | 266d? | 2009-12-10 A | 2010-12-16 A | 100% |  | 2009-12-10 | 2010-12-16 | 266d? |  | finish no earlier than 2011-03-17 | S2 | 2128h | 2128h | eMPS | PCG-24 | Telcordia, NTT DoCoMo | Vijay Varma, Katsutoshi Nishida | Rel-10 | SP-46 | Maurice |  |  |  |
| 110 | 54.4 | **Stage 3 on enhancements for Multimedia Priority Service** | 131d? | 2010-09-17 A | 2011-03-18 | 70% | 39.3d? | 2010-09-17 | 2011-03-18 | 131d? | 455d |  | C4,C3,C1 | 4192h | 2934.4h | eMPS-CN | PCG-25 | Ericsson | Philip.hodges@ericsson.com | Rel-10 | CP-49 | Kimmo |  |  |  |
| 111 | 54.4.1 | CT4 part on Stage 3 on enhancements for Multimedia Priority Service | 131d? | 2010-09-17 A | 2011-03-18 | 50% | 65.5d? | 2010-09-17 | 2011-03-18 | 131d? | 455d | start no earlier than 2010-09-17 | C4 | 1048h | 524h | eMPS-CN | PCG-25 | Ericsson | Philip.hodges@ericsson.com | Rel-10 | CP-49 | Kimmo |  |  |  |
| 112 | 54.4.2 | CT3 part on Stage 3 on enhancements for Multimedia Priority Service | 131d? | 2010-09-17 A | 2011-03-18 | 70% | 39.3d? | 2010-09-17 | 2011-03-18 | 131d? | 455d | start no earlier than 2010-09-17 | C3 | 1048h | 733.6h | eMPS-CN | PCG-25 | Ericsson | Philip.hodges@ericsson.com | Rel-10 | CP-49 | Gwiho |  |  |  |
| 113 | 54.4.3 | CT1 part on Stage 3 on enhancements for Multimedia Priority Service | 131d? | 2010-09-17 A | 2011-03-18 | 90% | 13.1d? | 2010-09-17 | 2011-03-18 | 131d? | 455d | start no earlier than 2010-09-17 | C1 | 1048h | 943.2h | eMPS-CN | PCG-25 | Ericsson | Philip.hodges@ericsson.com | Rel-10 | CP-49 | Frederic |  |  |  |
| 114 | 55 | **Network Improvements for Machine-Type Communications** | 653d? | 2008-09-18 A | 2011-03-18 | 79% | 138.39d? | 2008-09-18 | 2011-03-18 | 653d? | 455d |  | S1,S2,C1,C4,G2,R2,R3 | 16793.2h | 10970.8h | NIMTC | PCG-21 | KPN | toon.norp@tno.nl | Rel-10 | SP-41 | Alain |  |  |  |
| 115 | 55.1 | Stage 1 for Network Improvements for Machine-Type Communications | 397d? | 2008-09-18 A | 2010-03-25 A | 100% |  | 2008-09-18 | 2010-03-25 | 397d? |  | finish no earlier than 2009-12-10 | S1 | 3176h | 3176h | NIMTC | PCG-21 | KPN | toon.norp@tno.nl | Rel-10 | SP-41 | Alain |  |  |  |
| 116 | 55.2 | Deleted - TR on Stage 2 for Network Improvements for Machine-Type Communications | 321d? | 2009-09-24 A | 2010-12-16 A | 100% |  | 2009-09-24 | 2010-12-16 | 321d? |  | finish no earlier than 2010-11-30 | S2 | 2568h | 2568h | NIMTC | PCG-23 | Samsung | erik.guttman@partner.samsung.com | Rel-10 | SP-45 | Maurice | PCG-26 | SP-50 |  |
| 117 | 55.3 | Stage 2 for Network Improvements for Machine-Type Communications | 19d? | 2010-08-30 A | 2010-09-23 A | 100% |  | 2010-08-30 | 2010-09-23 | 19d? |  | finish no earlier than 2010-09-17 | S2 | 152h | 152h | NIMTC | PCG-23 | Samsung | erik.guttman@partner.samsung.com | Rel-10 | SP-45 | Maurice |  |  |  |
| 118 | 55.4 | Deleted - Security for Network Improvements for Machine-Type Communications | 193.15d? | 2009-12-10 A | 2010-09-23 A | 100% |  | 2009-12-10 | 2010-09-23 | 193.15d? |  | finish no earlier than 2010-09-23 | S3 | 1545.2h | 1545.2h | NIMTC | PCG-24 | Samsung | Rajavelsamy R (rajvel@samsung.com) | Rel-10 | SP-46 | Dionisio | PCG-25 | SP-49 |  |
| 119 | 55.5 | **CN part of Stage 3 for Network Improvements for Machine-Type Communications** | 206d? | 2010-06-04 A | 2011-03-18 | 66% | 69.69d? | 2010-06-04 | 2011-03-18 | 206d? | 455d |  | C1,C4 | 5208h | 2900.8h | NIMTC | PCG-25 | Ericsson | mikael.wass@ericsson.com | Rel-10 | CP-48 | Frederic |  |  |  |
| 120 | 55.5.1 | CT1 part of Stage 3 for Network Improvements for Machine-Type Communications | 206d? | 2010-06-04 A | 2011-03-18 | 50% | 103d? | 2010-06-04 | 2011-03-18 | 206d? | 455d | finish no earlier than 2011-03-18 | C1 | 1648h | 824h | NIMTC | PCG-25 | Ericsson | mikael.wass@ericsson.com | Rel-10 | CP-48 | Frederic |  |  |  |
| 121 | 55.5.2 | CT4 part of Stage 3 for Network Improvements for Machine-Type Communications | 206d? | 2010-06-04 A | 2011-03-18 | 60% | 82.4d? | 2010-06-04 | 2011-03-18 | 206d? | 455d | finish no earlier than 2011-03-18 | C4 | 1648h | 988.8h | NIMTC | PCG-25 | Ericsson | mikael.wass@ericsson.com | Rel-10 | CP-48 | Kimmo |  |  |  |
| 122 | 55.5.3 | Deleted - CT3 part of Stage 3 for Network Improvements for Machine-Type Communications | 136d? | 2010-06-04 A | 2010-12-10 A | 100% |  | 2010-06-04 | 2010-12-10 | 136d? |  | finish no earlier than 2010-12-10 | C3 | 1088h | 1088h | NIMTC | PCG-25 | Ericsson | mikael.wass@ericsson.com | Rel-10 | CP-48 | Gwiho | PCG-26 | CP-50 |  |
| 123 | 55.6 | GERAN part of Network Improvements for Machine-Type Communications (Stage 3) | 131d? | 2010-09-03 A | 2011-03-04 | 10% | 117.9d? | 2010-09-03 | 2011-03-04 | 131d? | 465d | finish no earlier than 2011-03-04 | G2 | 1048h | 104.8h | NIMTC | PCG-25 | Vodafone, Ericsson | leo.patanapongpibul@vodafone.com, john.diachina@ericsson.com | Rel-10 | GP-47 | Gert |  |  |  |
| 124 | 55.7 | RAN mechanisms to avoid CN overload due to Machine-Type Communications | 131d? | 2010-09-17 A | 2011-03-18 | 50% | 65.5d? | 2010-09-17 | 2011-03-18 | 131d? | 455d | finish no earlier than 2011-03-18 | R2,R3 | 1048h | 524h | NIMTC-RAN_overload | PCG-25 | Huawei | Jeff Gao (gaoyq@huawei.com) | Rel-10 | RP-49 | Joern |  |  | RP-101101 |
| 125 | 56 | **Multi Access PDN Connectivity** | 527d? | 2009-03-13 A | 2011-03-18 | 80% | 105.04d? | 2009-03-13 | 2011-03-18 | 527d? | 455d |  | S2,C1 | 9592h | 7103.7h | MAPCON | PCG-22 | Telecom Italia | ivano.guardini@telecomitalia.it | Rel-10 | SP-43 | Maurice |  |  |  |
| 126 | 56.1 | Stage 2 for Multi Access PDN Connectivity | 401d? | 2009-03-13 A | 2010-09-23 A | 100% |  | 2009-03-13 | 2010-09-23 | 401d? |  |  | S2 | 3208h | 3208h | MAPCON |  | Telecom Italia | ivano.guardini@telecomitalia.it | Rel-10 |  | Maurice |  |  |  |

Notes:
- 103: SP#49 moved Stage 1 from Rel-9 & Completed Stage 2. SP#40 Stage 1 completed. Continuation of Rel-8 Feature PRIOR (UID_340044)
- 104: ePRIOR started Mar 2006 as a Rel-8 Feature. It was delayed to Rel-9 (completed at SP#40), then moved to Rel-10 at SP#49 and demoted to Building Block level. / Text3: 22.153, 22.278
- 105: SP#49 completed. Updated WID SP-100166=>SP-100647
- 106: SP#49 completed / Text3: 23.002, 23.203, 23.221, 23.228, 23.272, 23.401
- 107: SP#49 completed / Text3: 23.002, 23.203, 23.221, 23.228, 23.272, 23.401
- 108: SP#49 completed / Text3: 23.002, 23.203, 23.221, 23.228, 23.272, 23.401
- 109: SP#50 completed / Text3: new TR 23.854
- 110: CP#50 updated WID CP-100650=>CP-100878 / Text3: Stage 3
- 111: CP#50 updated WID CP-100650=>CP-100878 / Text3: 23.008, 29.002, 29.228, 29.229, 29.272, 29.274, 29.277, 29.328, 29.329
- 112: CP#50 updated WID CP-100650=>CP-100878 / Text3: 29.212, 29.213, 29.214
- 113: CP#50 updated WID CP-100650=>CP-100878 / Text3: 24.008, 24.229, 24.301
- 114: SP#50 updated WID SP-090832=>SP-100697 (document the SA2 work). SP#49 Security stopped. SP#47 Stage 1 completed. Triggered by Rel-8 UID_7027 Study on Facilitating Machine to Machine Communication in GSM and UMTS (FS_M2M) TR 22.868
- 115: SA#47 completed / Text3: 22.011, new 22.368
- 116: SP#50 updated WID SP-090832=>SP-100697 (TR 23.888 not submitted for approval to conclude Rel-10 NIMTC as it will continue to serve as basis for Rel-11 SIMTC work item) / Text3: new TR 23.888
- 117: SP#49 completed. SP#50 updated WID SP-090832=>SP-100697 (document the SA2 work) / Text3: 23.060, 23.236, 23.401
- 118: SP#49 stopped (activity moved to Rel-11 under UID_490028 TR on Security aspects of System Improvements to Machine-Type Communications (SIMTC) / Text3: new 33.868
- 119: CP#50 updated WID CP-100423=>CP-100889 / Text3: Stage 3
- 120: CP#50 updated WID CP-100423=>CP-100889. TS 24.368 v100 for Information / Text3: 23.122, 24.008, 24.301, new 24.368
- 121: CP#50 updated WID CP-100423=>CP-100889 / Text3: 23.003, 23.008, 29.002, 29.060, 29.272, 29.274, 29.275, 29.282
- 122: CP#50 stopped (no CT3 impact) / Text3: 29.061, 29.007
- 123: GP#47 approved WID / Text3: 44.018, 44.060
- 124: Stage 3 / Text3: UTRA, LTE 25.331, 25.413, 36.331, 36.413
- 125: SP#49 completed. Triggered by TR 23.861 UID_410043 FS_MAPIM. Stage 1 in Rel-9 22.278 (6.2 - IP session control)
- 126: SP#49 completed. Triggered by TR 23.861 UID_410043 FS_MAPIM. Stage 1 in Rel-9 22.278 (6.2 - IP session control) / Text3: 23.237, 23.401, 23.402

| ID | WBS | Task | Duration | Start | Finish | Complete | Remaining | Baseline start | Baseline finish | Baseline duration | Total slack | Constraint | Resources | Work | Actual work | Text1 | Text2 | Text4 | Text6 | Text7 | Text8 | Text11 |
| --- | --- | --- | --- | --- | --- | --- | --- | --- | --- | --- | --- | --- | --- | --- | --- | --- | --- | --- | --- | --- | --- | --- |
| 127 | 56.2 | **CT aspects of Multi Access PDN Connectivity** | 90d? | 2010-11-15 A | 2011-03-18 | 36% | 57.68d? | 2010-11-15 | 2011-03-18 | 90d? | 455d |  | C4,C1,C3 | 2168h | 520h | MAPCON-St3 | PCG-26 | ZTE | Rel-10 | CP-50 | Kimmo |  |
| 128 | 56.2.1 | CT4 aspects of Multi Access PDN Connectivity | 20d? | 2010-11-15 A | 2010-12-10 A | 100% |  | 2010-11-15 | 2010-12-10 | 20d? |  | start no earlier than 2010-12-10 | C4 | 160h | 160h | MAPCON-St3 | PCG-26 | ZTE | Rel-10 | CP-50 | Kimmo |  |
| 129 | 56.2.2 | CT1 aspects of Multi Access PDN Connectivity | 71d? | 2010-12-10 | 2011-03-18 |  |  | 2010-12-10 | 2011-03-18 | 71d? | 455d | start no earlier than 2010-12-10 | C1 | 568h |  | MAPCON-St3 | PCG-26 | ZTE | Rel-10 | CP-50 | Frederic |  |
| 130 | 56.2.3 | CT3 aspects of Multi Access PDN Connectivity | 90d? | 2010-11-15 A | 2011-03-18 | 50% | 45d? | 2010-11-15 | 2011-03-18 | 90d? | 455d | finish no earlier than 2011-03-18 | C3 | 720h | 360h | MAPCON-St3 | PCG-26 | ZTE | Rel-10 | CP-50 | Gwiho |  |
| 131 | 57 | **IMS Service Continuity – Inter Device Transfer enhancements** | 467d? | 2009-06-04 A | 2011-03-18 | 91% | 41.57d? | 2009-06-04 | 2011-03-18 | 467d? | 455d |  | S1,S2,C1 | 9600h | 7030h | IMS_SC_eIDT | PCG-23 | Huawei | Rel-10 | SP-44 | Alain |  |
| 132 | 57.1 | Stage 1 - IMS Service Continuity – Inter Device Transfer enhancements | 211d? | 2009-06-04 A | 2010-03-25 A | 100% |  | 2009-06-04 | 2010-03-25 | 211d? |  | finish no earlier than 2010-03-25 | S1 | 1688h | 1688h | IMS_SC_eIDT | PCG-23 | Huawei | Rel-10 | SP-44 | Alain |  |
| 133 | 57.2 | Stage 2 - IMS Inter-UE Transfer enhancements | 261d? | 2009-09-24 A | 2010-09-23 A | 100% |  | 2009-09-24 | 2010-09-23 | 261d? |  | finish no earlier than 2010-09-23 | S2 | 2088h | 2088h | IMS_SC_eIDT | PCG-23 | Huawei | Rel-10 | SP-45 | Maurice |  |
| 134 | 57.3 | Stage 3 - IMS Inter-UE Transfer enhancements | 261d? | 2010-03-19 A | 2011-03-18 | 75% | 65.25d? | 2010-03-19 | 2011-03-18 | 261d? | 455d | start no earlier than 2010-03-19 | C1 | 2088h | 1566h | IMS_SC_eIDT | PCG-24 | Huawei | Rel-10 | CP-47 | Frederic |  |
| 135 | 58 | **IP-Short-Message-Gateway enhancements for CPM-SMS Interworking** | 257d? | 2009-09-24 A | 2010-09-17 A | 100% |  | 2009-09-24 | 2010-09-17 | 257d? |  |  | S1,S2,C3 | 5792.8h | 5792.8h | CPM-SMS | PCG-23 | China Mobile | Rel-10 | SP-45 | Alain |  |
| 136 | 58.1 | Stage 1 for CPM-SMS | 131d? | 2009-09-24 A | 2010-03-25 A | 100% |  | 2009-09-24 | 2010-03-25 | 131d? |  | finish no earlier than 2010-03-25 | S1 | 1048h | 1048h | CPM-SMS | PCG-23 | China Mobile | Rel-10 | SP-45 | Alain |  |
| 137 | 58.2 | Stage 2 for CPM-SMS | 130.1d? | 2009-09-24 A | 2010-03-25 A | 100% |  | 2009-09-24 | 2010-03-25 | 130.1d? |  | finish no earlier than 2010-03-25 | S2 | 1040.8h | 1040.8h | CPM-SMS | PCG-23 | Orange | Rel-10 | SP-45 | Maurice |  |
| 138 | 58.3 | Stage 3 for IP-Short-Message-Gateway enhancements for CPM-SMS Interworking | 206d? | 2009-12-04 A | 2010-09-17 A | 100% |  | 2009-12-04 | 2010-09-17 | 206d? |  | finish no earlier than 2010-09-17 | C3 | 1648h | 1648h | CPM-SMS | PCG-24 | Ericsson | Rel-10 | CP-46 | Gwiho |  |
| 139 | 59 | **Completion of Communications on Not Logged-in** | 387d? | 2009-09-24 A | 2011-03-18 | 85% | 59.77d? | 2009-09-24 | 2011-03-18 | 387d? | 455d |  | S1,C1,C3 | 5800h | 2294.4h | CCNL | PCG-23 | Deutsche Telekom | Rel-10 | SP-45 | Alain |  |
| 140 | 59.1 | Stage 1 for Completion of Communications on Not Logged-in | 1d? | 2009-09-24 A | 2009-09-24 A | 100% |  | 2009-09-24 | 2009-09-24 | 1d? |  | start no earlier than 2009-09-24 | S1 | 8h | 8h | CCNL | PCG-23 | Deutsche Telekom | Rel-10 | SP-45 | Alain |  |
| 141 | 59.2 | CT1 part of Stage 3 for Completion of Communications on Not Logged-in | 261d? | 2010-03-19 A | 2011-03-18 | 80% | 52.2d? | 2010-03-19 | 2011-03-18 | 261d? | 455d | finish no earlier than 2011-03-18 | C1 | 2088h | 1670.4h | CCNL | PCG-24 | Deutsche Telekom | Rel-10 | CP-47 | Frederic |  |
| 142 | 59.3 | CT3 part of Stage 3 for Completion of Communications on Not Logged-in | 76d? | 2010-06-04 A | 2010-09-17 A | 100% |  | 2010-06-04 | 2010-09-17 | 76d? |  | finish no earlier than 2010-09-17 | C3 | 608h | 608h | CCNL | PCG-25 | Deutsche Telekom | Rel-10 | CP-48 | Gwiho |  |
| 143 | 60 | **Local IP Access and Selected Internet IP Traffic Offload** | 390d? | 2009-09-24 A | 2011-03-23 | 82% | 69.19d? | 2009-09-24 | 2011-03-23 | 390d? | 452d |  | S2,S1,S3,S5,C4,C1 | 28656h | 21161.5h | LIPA_SIPTO | PCG-23 | Huawei, China Mobile | Rel-10 | SP-45 | Maurice |  |
| 144 | 60.1 | Stage 1 for Local IP Access and Selected Internet IP Traffic Offload | 131d? | 2009-09-24 A | 2010-03-25 A | 100% |  | 2009-09-24 | 2010-03-25 | 131d? |  | finish no earlier than 2010-03-25 | S1 | 1048h | 1048h | LIPA_SIPTO | PCG-23 | Huawei, China Mobile | Rel-10 | SP-45 | Alain |  |
| 145 | 60.2 | TR on Local IP Access and Selected Internet IP Traffic Offload | 387d? | 2009-09-24 A | 2011-03-18 | 90% | 38.7d? | 2009-09-24 | 2011-03-18 | 387d? | 455d | finish no earlier than 2011-03-18 | S2 | 3096h | 2786.4h | LIPA_SIPTO | PCG-23 | Huawei, China Mobile | Rel-10 | SP-45 | Maurice |  |
| 146 | 60.3 | Security for Local IP Access and Selected Internet IP Traffic Offload | 261d? | 2009-09-24 A | 2010-09-23 A | 100% |  | 2009-09-24 | 2010-09-23 | 261d? |  | finish no earlier than 2010-09-23 | S3 | 2088h | 2088h | LIPA_SIPTO | PCG-23 | Huawei, Qualcomm | Rel-10 | SP-45 | Dionisio |  |
| 147 | 60.4 | OAM&P for Local IP Access and Selected Internet IP Traffic Offload | 390d? | 2009-09-24 A | 2011-03-23 | 70% | 117d? | 2009-09-24 | 2011-03-23 | 390d? | 452d | finish no earlier than 2011-03-23 | S5 | 3120h | 2184h | LIPA_SIPTO | PCG-23 | Huawei, China Mobile | Rel-10 | SP-45 | Dionisio | S5-103041 |
| 148 | 60.5 | Charging for Local IP Access and Selected Internet IP Traffic Offload | 335d? | 2009-12-10 A | 2011-03-23 | 30% | 234.5d? | 2009-12-10 | 2011-03-23 | 335d? | 452d | finish no earlier than 2011-03-23 | S5 | 2680h | 804h | LIPA_SIPTO | PCG-24 | Huawei, China Mobile | Rel-10 | SP-46 | Dionisio | S5-103010r2 |
| 149 | 60.6 | Stage 2 for Local IP Access | 261d? | 2009-09-24 A | 2010-09-23 A | 100% |  | 2009-09-24 | 2010-09-23 | 261d? |  | finish no earlier than 2010-08-10 | S2 | 2088h | 2088h | LIPA | PCG-23 | Huawei, China Mobile | Rel-10 | SP-45 | Maurice |  |
| 150 | 60.7 | **Stage 3 for Local IP Access** | 206d? | 2010-06-04 A | 2011-03-18 | 80% | 41.2d? | 2010-06-04 | 2011-03-18 | 206d? | 455d |  | C4,C1 | 4944h | 3955.2h | LIPA | PCG-25 | China Mobile | Rel-10 | CP-48 | Kimmo |  |
| 151 | 60.7.1 | CT4 part of Stage 3 for Local IP Access | 206d? | 2010-06-04 A | 2011-03-18 | 90% | 20.6d? | 2010-06-04 | 2011-03-18 | 206d? | 455d | finish no earlier than 2011-03-18 | C4 | 1648h | 1483.2h | LIPA | PCG-25 | China Mobile | Rel-10 | CP-48 | Kimmo |  |
| 152 | 60.7.2 | CT1 part of Stage 3 for Local IP Access | 206d? | 2010-06-04 A | 2011-03-18 | 70% | 61.8d? | 2010-06-04 | 2011-03-18 | 206d? | 455d | finish no earlier than 2011-03-18 | C1 | 1648h | 1153.6h | LIPA | PCG-25 | China Mobile | Rel-10 | CP-48 | Frederic |  |
| 153 | 60.8 | Stage 2 for SIPTO for macro networks | 261d? | 2009-09-24 A | 2010-09-23 A | 100% |  | 2009-09-24 | 2010-09-23 | 261d? |  | finish no earlier than 2010-09-23 | S2 | 2088h | 2088h | SIPTO | PCG-23 | Huawei, China Mobile | Rel-10 | SP-45 | Maurice |  |

Notes:
- 127: - / Text5: Xingyue (Joy) Zhou (zhou.xingyue@zte.com.cn)
- 128: CP#50 completed / Text3: 29.273, 29.272, 29.002, 23.008 / Text5: Xingyue (Joy) Zhou (zhou.xingyue@zte.com.cn)
- 129: - / Text3: 24.302, 24.312 / Text5: Xingyue (Joy) Zhou (zhou.xingyue@zte.com.cn)
- 130: - / Text3: 29.215 / Text5: Xingyue (Joy) Zhou (zhou.xingyue@zte.com.cn)
- 131: SP#47 Stage 1 completed. Rel-9 set Inter-Device Transfer requirements UID_410033 (IMS_SCC-IDT). Adding additional scenarios and requirements for IDT. / Text5: Amar Deol (adeol@huawei.com)
- 132: SA#47 completed / Text3: 22.228 / Text5: Amar Deol (adeol@huawei.com)
- 133: SP#49 completed. TR 23.831v200 for Approval / Text3: 23.237, 23.292, new 23.831 / Text5: Lee Valerius (lvalerius@huawei.com)
- 134: CP#48 revised WID CP-100100=>CP-100334. TR 24.837 v100 for Information / Text3: 24.216, 24.229, 24.237, new 24.837 / Text5: georg.mayer@huawei.com
- 135: SP#47 Stage 1 completed. IP-SM-GW enhancements for interworking with OMA CPM / Text5: Qing Huang
- 136: SA#47 completed. External requirements (Stage 1 in OMA-RD-CPM-V1_0-20090310-C) / Text3: 22.340 / Text5: Qing Huang
- 137: SP#47 completed / Text3: 23.204, new TR 23.824 / Text5: Antoine Mouquet
- 138: CP#49 completed. Linked to Rel-8 UID_340031 Service-Level Interworking for Messaging Services (MESSIW) 23.204 / Text3: 29.311 / Text5: Jan Holm
- 139: SP#45 Stage 1 completed / Text5: Kurt Bischinger
- 140: SP#45 completed / Text3: 22.173 CR#0056r1 / Text5: Kurt Bischinger
- 141: CP#50 completion 12/10=>03/11 / Text3: 24.173, 24.642 / Text5: martin.huelsemann@telekom.de
- 142: CP#49 completed / Text3: 29.165 / Text5: martin.huelsemann@telekom.de
- 143: SP#50 updated WID SP-090761=>SP-100696 (document the SA2 work). SP#49 Stage 2 & Security completed. UID_400035 Enhanced Home NodeB/eNodeB (EHNB) formerly covered Local IP Access to Internet and Local access to Home Network from the Home NodeB/eNodeB / Text5: patrice.hede@huawei.com, Tao Sun (suntao@chinamobile.com)
- 144: SP#47 completed / Text3: 22.101, 22.220 / Text5: Amar Deol (adeolf@huawei.com), Gang Li (ligangyf@chinamobile.com)
- 145: SP#50 updated WID SP-090761=>SP-100696. Completion 12/10=>03/11 / Text3: new TR 23.829 / Text5: patrice.hede@huawei.com, Tao Sun (suntao@chinamobile.com)
- 146: SP#49 completed / Text3: 33.102, 33.107, 33.108, 33.320, 33.401 / Text5: Marcus Wong (mwong@huawei.com), Brian Rosenberg (bmr@qualcomm.com)
- 147: SP#50 completion 12/10=>03/11 / Text3: 32.101, 32.102, 32.405, 32.425, 32.452, 32.453, 32.581, 32.582, 32.583, 32.584, 32.591, 32.592, 32.593, 32.594, 32.64x, 32.76x / Text5: Zou Lan (zlan@huawei.com), Chen Gang (chengang@chinamobile.com)
- 148: SP#50 completion 12/10=>03/11. SA5 study of SA2 TR 23.829=> No normative impact on SIPTO Charging. Charging Architecture not changed by LIPA Charging. / Text3: 32.240, 32.251, 32.298, 32.299 / Text5: shan.mingjun@huawei.com, Ai Chen (chenai@chinamobile.com)
- 149: SP#50 updated WID SP-090761=>SP-100696. SP#49 completed (has impacts to RAN) / Text3: 23.060, 23.401 / Text5: patrice.hede@huawei.com, Tao Sun (suntao@chinamobile.com)
- 150: - / Text5: Zhang Hao (zhanghao@chinamobile.com)
- 151: - / Text3: 23.008, 23.015, 29.002, 29.060, 29.272, 29.274, 29.281, 29.303 / Text5: Zhang Hao (zhanghao@chinamobile.com)
- 152: - / Text3: 24.008, 24.301 / Text5: Zhang Hao (zhanghao@chinamobile.com)
- 153: SP#50 updated WID SP-090761=>SP-100696. SP#49 completed (SIPTO GW selection for wild card APN and for GERAN. Serving-GW selection for SIPTO. Corrections and Clarifications of the SIPTO procedure) / Text3: 23.060, 23.401 / Text5: patrice.hede@huawei.com, Tao Sun (suntao@chinamobile.com)

| ID | WBS | Task | Type | Duration | Start | Finish | Complete | Remaining | Baseline start | Baseline finish | Baseline duration | Total slack | Constraint | Resources | Work | Actual work | Text1 | Text2 | Text4 | Text5 | Text6 | Text7 | Text8 | Text3 | Text11 |
| --- | --- | --- | --- | --- | --- | --- | --- | --- | --- | --- | --- | --- | --- | --- | --- | --- | --- | --- | --- | --- | --- | --- | --- | --- | --- |
| 154 | 60.9 | **Stage 3 for SIPTO for macro networks** |  | 206d? | 2010-06-04 A | 2011-03-18 | 94% | 12.41d? | 2010-06-04 | 2011-03-18 | 206d? | 455d |  | C4,C1 | 4384h | 4119.93h | SIPTO | PCG-25 | Huawei | Caixia Qi (qcxmay@huawei.com) | Rel-10 | CP-48 | Kimmo |  |  |
| 155 | 60.9.1 | CT4 part of Stage 3 for SIPTO for macro networks |  | 206d? | 2010-06-04 A | 2011-03-18 | 90% | 20.6d? | 2010-06-04 | 2011-03-18 | 206d? | 455d | finish no earlier than 2011-03-18 | C4 | 1648h | 1483.2h | SIPTO | PCG-25 | Huawei | Caixia Qi (qcxmay@huawei.com) | Rel-10 | CP-48 | Kimmo | 23.003, 23.008, 29.002, 29.272, 29.303 |  |
| 156 | 60.9.2 | CT1 part of Stage 3 for SIPTO for macro networks |  | 136d? | 2010-06-04 A | 2010-12-10 A | 100% |  | 2010-06-04 | 2010-12-10 | 136d? |  | finish no earlier than 2011-03-18 | C1 | 1088h | 1088h | SIPTO | PCG-25 | Huawei | Caixia Qi (qcxmay@huawei.com) | Rel-10 | CP-48 | Frederic | 24.008, 24.301 |  |
| 157 | 61 | **IP Flow Mobility and seamless WLAN offload** |  | 390d? | 2009-09-24 A | 2011-03-23 | 62% | 146.81d? | 2009-09-24 | 2011-03-23 | 390d? | 452d |  | S2,S1,S5,C1,C3 | 12680h | 6164.4h | IFOM | PCG-23 | Qualcomm | Gerardo Giaretta (gerardo@qualcomm.com) | Rel-10 | SP-45 | Maurice |  |  |
| 158 | 61.1 | Stage 1 for IP Flow Mobility and seamless WLAN offload |  | 56d? | 2009-09-24 A | 2009-12-10 A | 100% |  | 2009-09-24 | 2009-12-10 | 56d? |  | finish no earlier than 2009-12-10 | S1 | 448h | 448h | IFOM | PCG-23 | Qualcomm | David Williams (dwilliam@qualcomm.com) | Rel-10 | SP-45 | Alain | 22.278 |  |
| 159 | 61.2 | Stage 2 for IP Flow Mobility and seamless WLAN offload |  | 261d? | 2009-09-24 A | 2010-09-23 A | 100% |  | 2009-09-24 | 2010-09-23 | 261d? |  | finish no earlier than 2010-09-23 | S2 | 2088h | 2088h | IFOM | PCG-23 | Qualcomm | Gerardo Giaretta (gerardo@qualcomm.com) | Rel-10 | SP-45 | Maurice | 23.203, 23.402, new 23.261 |  |
| 160 | 61.3 | Charging for IP Flow Mobility and seamless WLAN offload |  | 260d? | 2010-03-25 A | 2011-03-23 | 40% | 156d? | 2010-03-25 | 2011-03-23 | 260d? | 452d | finish no earlier than 2011-03-23 | S5 | 2080h | 832h | IFOM | PCG-24 | Alcatel-Lucent | maryse.gardella@alcatel-lucent.com | Rel-10 | SP-47 | Dionisio | 32.240, 32.251, 32.252, 32.298, 32.299 | S5-103010r2 |
| 161 | 61.4 | **Stage 3 for IP Flow Mobility and seamless WLAN offload** |  | 206d? | 2010-06-04 A | 2011-03-18 | 48% | 108.15d? | 2010-06-04 | 2011-03-18 | 206d? | 455d |  | C1,C3 | 4944h | 2348.4h | IFOM-CT | PCG-25 | Qualcomm | Patrick Stupar (pstupar@qualcomm.com) | Rel-10 | CP-48 | Frederic | Stage 3 |  |
| 162 | 61.4.1 | CT1 part of Stage 3 for IP Flow Mobility and seamless WLAN offload |  | 206d? | 2010-06-04 A | 2011-03-18 | 60% | 82.4d? | 2010-06-04 | 2011-03-18 | 206d? | 455d | finish no earlier than 2011-03-18 | C1 | 1648h | 988.8h | IFOM-CT | PCG-25 | Qualcomm | Patrick Stupar (pstupar@qualcomm.com) | Rel-10 | CP-48 | Frederic | 24.008, 24.301, 24.302, 24.303, 24.312, 24.327 |  |
| 163 | 61.4.2 | CT3 part of Stage 3 for IP Flow Mobility and seamless WLAN offload |  | 206d? | 2010-06-04 A | 2011-03-18 | 35% | 133.9d? | 2010-06-04 | 2011-03-18 | 206d? | 455d | finish no earlier than 2011-03-18 | C3 | 1648h | 576.8h | IFOM-CT | PCG-25 | Qualcomm | Patrick Stupar (pstupar@qualcomm.com) | Rel-10 | CP-48 | Gwiho | 29.212, 29.213, 29.214, 29.215 |  |
| 164 | 62 | **Enabling Coder Selection and Rate Adaptation for UTRAN and E-UTRAN for Load Adaptive Applications** |  | 390d? | 2009-09-24 A | 2011-03-23 | 73% | 106.81d? | 2009-09-24 | 2011-03-23 | 390d? | 452d |  | S2,S4,R2,C4,C3,C1 | 14488h | 7738.13h | ECSRA_LAA | PCG-23 | Qualcomm | AC Mahendran (ac@qualcomm.com) | Rel-10 | SP-45 | Maurice | UTRA, LTE |  |
| 165 | 62.1 | TR on Enabling Coder Selection and Rate Adaptation for UTRAN and E-UTRAN for Load Adaptive Applications |  | 186d? | 2009-09-24 A | 2010-06-10 A | 100% |  | 2009-09-24 | 2010-06-10 | 186d? |  | finish no earlier than 2010-09-23 | S2,S4,R2 | 1488h | 1488h | ECSRA_LAA | PCG-23 | Qualcomm | AC Mahendran (ac@qualcomm.com) | Rel-10 | SP-45 | Maurice | new 23.860 |  |
| 166 | 62.2 | SA4 review of TR on Enabling Coder Selection and Rate Adaptation for UTRAN and E-UTRAN for Load Adaptive Applications |  | 320d? | 2009-09-24 A | 2010-12-15 A | 100% |  | 2009-09-24 | 2010-12-15 | 320d? |  | finish no earlier than 2010-12-15 | S4,R2 | 2560h | 2560h | ECSRA_LAA | PCG-23 | Qualcomm | AC Mahendran (ac@qualcomm.com) | Rel-10 | SP-45 | Paolo | new 23.860 |  |
| 167 | 62.3 | Stage 2 for Enabling Coder Selection and Rate Adaptation for UTRAN and E-UTRAN for Load Adaptive Applications |  | 261d? | 2009-09-24 A | 2010-09-23 A | 100% |  | 2009-09-24 | 2010-09-23 | 261d? |  | finish no earlier than 2010-09-23 | S2 | 2088h | 2088h | ECSRA_LAA | PCG-23 | Qualcomm | AC Mahendran (ac@qualcomm.com) | Rel-10 | SP-45 | Maurice | 23.060, 23.203, 23.228, 23.401 |  |
| 168 | 62.4 | SA4 aspects of Enabling Coder Selection and Rate Adaptation for UTRAN and E-UTRAN for Load Adaptive Applications |  | 130d? | 2010-09-23 A | 2011-03-23 | 60% | 52d? | 2010-09-23 | 2011-03-23 | 130d? | 452d | finish no earlier than 2011-03-23 | S4 | 1040h | 624h | ECSRA_LAA | PCG-25 | Qualcomm | AC Mahendran (ac@qualcomm.com) | Rel-10 | SP-49 | Paolo | 26.114 |  |
| 169 | 62.5 | **CN aspects of Enabling Coder Selection and Rate Adaptation for UTRAN and E-UTRAN for Load Adaptive Applications** |  | 131d? | 2010-09-17 A | 2011-03-18 | 23% | 100.43d? | 2010-09-17 | 2011-03-18 | 131d? | 455d |  | C4,C3,C1 | 4192h | 978.13h | ECSRA_LAA-CN | PCG-25 | Ericsson | Philip.hodges@ericsson.com | Rel-10 | CP-49 | Kimmo | Stage 2/3 |  |
| 170 | 62.5.1 | CT4 part of CN aspects of Enabling Coder Selection and Rate Adaptation for UTRAN and E-UTRAN for Load Adaptive Applications |  | 131d? | 2010-09-17 A | 2011-03-18 | 30% | 91.7d? | 2010-09-17 | 2011-03-18 | 131d? | 455d | start no earlier than 2010-09-17 | C4 | 1048h | 314.4h | ECSRA_LAA-CN | PCG-25 | Ericsson | Philip.hodges@ericsson.com | Rel-10 | CP-49 | Kimmo | 23.334, 29.334, 29.238, 23.333, 29.333, 29.232, 29.332 |  |
| 171 | 62.5.2 | CT3 part of CN aspects of Enabling Coder Selection and Rate Adaptation for UTRAN and E-UTRAN for Load Adaptive Applications |  | 131d? | 2010-09-17 A | 2011-03-18 | 40% | 78.6d? | 2010-09-17 | 2011-03-18 | 131d? | 455d | start no earlier than 2010-09-17 | C3 | 1048h | 419.2h | ECSRA_LAA-CN | PCG-25 | Ericsson | Philip.hodges@ericsson.com | Rel-10 | CP-49 | Gwiho | 29.162, 29.163, 29.213, 29.235, 29.292 |  |
| 172 | 62.5.3 | CT1 part of CN aspects of Enabling Coder Selection and Rate Adaptation for UTRAN and E-UTRAN for Load Adaptive Applications |  | 131d? | 2010-09-17 | 2011-03-18 |  |  | 2010-09-17 | 2011-03-18 | 131d? | 455d | start no earlier than 2010-09-17 | C1 | 1048h |  | ECSRA_LAA-CN | PCG-25 | Ericsson | Philip.hodges@ericsson.com | Rel-10 | CP-49 | Frederic | 24.229 |  |
| 173 | 63 | **Extended H(e)NB features** |  | 467d? | 2008-12-11 A | 2010-09-23 A | 100% |  | 2008-12-11 | 2010-09-23 | 467d? |  |  | S1,S2,S3 | 4344h | 4344h | EHNBF | PCG-23 | NEC | joerg.swetina@nw.neclab.eu | Rel-10 | SP-45 | Alain | UTRA, LTE |  |
| 174 | 63.1 | Stage 1 of Extended H(e)NB features |  | 131d? | 2009-09-24 A | 2010-03-25 A | 100% |  | 2009-09-24 | 2010-03-25 | 131d? |  | finish no earlier than 2010-03-25 | S1 | 1048h | 1048h | EHNBF | PCG-23 | NEC | joerg.swetina@nw.neclab.eu | Rel-10 | SP-45 | Alain | 22.220 |  |
| 175 | 63.2 | IMS aspects of Architecture for Home NodeB |  | 336d? | 2008-12-11 A | 2010-03-25 A | 100% |  | 2008-12-11 | 2010-03-25 | 336d? |  | finish no earlier than 2010-03-25 | S2 | 2688h | 2688h | EHNB-IMS | PCG-22 | Alcatel-Lucent | Nicolas Drevon | Rel-10 | SP-42 | Maurice | new 23.832 |  |
| 176 | 63.3 | Extended H(e)NB Security features (Stage 2) |  | 76d? | 2010-06-10 A | 2010-09-23 A | 100% |  | 2010-06-10 | 2010-09-23 | 76d? |  | finish no earlier than 2010-09-23 | S3 | 608h | 608h | EHNBF-Sec | PCG-25 | Huawei | Marcus Wong (mwong@huawei.com) | Rel-10 | SP-48 | Dionisio | 33.320 |  |
| 177 | 64 | **Optimal Media Routing** |  | 259d? | 2010-03-25 A | 2011-03-23 | 22% | 200.84d? | 2010-03-25 | 2011-03-23 | 259d? | 452d |  | S2,S5,C3,C1,C4 | 9224h | 1648h | OMR | PCG-24 | Alcatel-Lucent | andy.bennett@alcatel-lucent.com | Rel-10 | SP-46 | Maurice |  |  |
| 178 | 64.1 | Stage 2 for Optimal Media Routing | milestone | 0d? | 2010-03-25 A | 2010-03-25 A | 100% |  | 2010-03-25 | 2010-03-25 | 0d? |  |  | S2 |  |  | OMR | PCG-24 | Alcatel-Lucent | andy.bennett@alcatel-lucent.com | Rel-10 | SP-46 | Maurice | 23.228 |  |

Notes:
- 154: -
- 155: -
- 156: CP#50 completed
- 157: Triggered by Rel-10 TR 23.861 (UID_410043 Study on Multi Access PDN connectivity and IP flow mobility - MAPIM)
- 158: SP#46completed
- 159: SP#49 completed
- 160: -
- 161: CP#50 updated WID CP-100332=>CP-100715
- 162: CP#50 updated WID CP-100332=>CP-100715 (added impacted TSs 24.008, 24.301)
- 163: CP#50 updated WID CP-100332=>CP-100715
- 164: SP#49 SA2 completed. Updated WID SP-090617=>SP-100467 (added SA4 specification part). Triggered by Rel-9 UID_440013 Vocoder rate adaptation for LTE
- 165: SP#48 completed
- 166: SP#50 completed
- 167: SP#49 completed
- 168: SP#50 completion 12/10=>03/11
- 169: CP#50 updated WID CP-100472=>CP-100702
- 170: CP#50 updated WID CP-100472=>CP-100702
- 171: CP#50 updated WID CP-100472=>CP-100702
- 172: CP#50 updated WID CP-100472=>CP-100702
- 173: SP#49 completed. Adds extensions to Rel-9 functionality in UID_400035 Enhanced Home NodeB / eNodeB (EHNB)
- 174: SP#47 completed
- 175: SP#47 completed. Chosen solution has no normative impacts
- 176: SP#49 completed
- 177: SP#47 Stage 2 completed. Triggered by TR 23.894 (UID_370050 Study on System enhancements for the use of IMS services in local breakout)
- 178: SP#47 completed

| ID | WBS | Task | Type | Duration | Start | Finish | Complete | Remaining | Baseline start | Baseline finish | Baseline duration | Total slack | Constraint | Resources | Work | Actual work | Text1 | Text2 | Text4 | Text5 | Text6 | Text7 | Text8 |
| --- | --- | --- | --- | --- | --- | --- | --- | --- | --- | --- | --- | --- | --- | --- | --- | --- | --- | --- | --- | --- | --- | --- | --- |
| 179 | 64.2 | **Stage 3 for Optimal Media Routing** |  | 206d? | 2010-06-04 A | 2011-03-18 | 25% | 154.5d? | 2010-06-04 | 2011-03-18 | 206d? | 455d |  | C3,C1,C4 | 6592h | 1648h | OMR | PCG-25 | Alcatel-Lucent | jim.calme@alcatel-lucent.com | Rel-10 | CP-48 | Gwiho |
| 180 | 64.2.1 | CT3 part of Stage 3 for Optimal Media Routeing |  | 206d? | 2010-06-04 A | 2011-03-18 | 75% | 51.5d? | 2010-06-04 | 2011-03-18 | 206d? | 455d | finish no earlier than 2011-03-18 | C3 | 1648h | 1236h | OMR | PCG-25 | Alcatel-Lucent | jim.calme@alcatel-lucent.com | Rel-10 | CP-48 | Gwiho |
| 181 | 64.2.2 | CT1 part of Stage 3 for Optimal Media Routeing |  | 206d? | 2010-06-04 | 2011-03-18 |  |  | 2010-06-04 | 2011-03-18 | 206d? | 455d | finish no earlier than 2011-03-18 | C1 | 1648h |  | OMR | PCG-25 | Alcatel-Lucent | jim.calme@alcatel-lucent.com | Rel-10 | CP-48 | Frederic |
| 182 | 64.2.3 | CT4 part of Stage 3 for Optimal Media Routeing |  | 206d? | 2010-06-04 | 2011-03-18 |  |  | 2010-06-04 | 2011-03-18 | 206d? | 455d | finish no earlier than 2011-03-18 | C4 | 1648h |  | OMR | PCG-25 | Alcatel-Lucent | jim.calme@alcatel-lucent.com | Rel-10 | CP-48 | Kimmo |
| 183 | 64.3 | Charging for Optimal Media Routing |  | 70d? | 2010-12-16 | 2011-03-23 |  |  | 2010-12-16 | 2011-03-23 | 70d? | 452d | finish no earlier than 2011-03-23 | S5 | 560h |  | OMR | PCG-26 | Alcatel-Lucent | maryse.gardella@alcatel-lucent.com | Rel-10 | SP-50 | Dionisio |
| 184 | 65 | **IMS Emergency Session Enhancements** |  | 257d? | 2010-03-25 A | 2011-03-18 | 90% | 26.97d? | 2010-03-25 | 2011-03-18 | 257d? | 455d |  | S2,S1 | 3680h | 3293.86h | IESE | PCG-24 | Deutsche Telekom, T-Mobile | michele.zarri@t-mobile.co.uk | Rel-10 | SP-47 | Maurice |
| 185 | 65.1 | Stage 1 for IMS Emergency Session Enhancements |  | 1d? | 2010-03-25 A | 2010-03-25 A | 100% |  | 2010-03-25 | 2010-03-25 | 1d? |  | start no earlier than 2010-03-25 | S1 | 8h | 8h | IESE | PCG-24 | Deutsche Telekom, T-Mobile | Kurt Bischinger | Rel-10 | SP-47 | Alain |
| 186 | 65.2 | Stage 2 for IMS Emergency Session Enhancements |  | 131d? | 2010-03-25 A | 2010-09-23 A | 100% |  | 2010-03-25 | 2010-09-23 | 131d? |  | finish no earlier than 2010-09-23 | S2 | 1048h | 1048h | IESE | PCG-24 | Deutsche Telekom, T-Mobile | michele.zarri@t-mobile.co.uk | Rel-10 | SP-47 | Maurice |
| 187 | 65.3 | Stage 3 for IMS Emergency Session Enhancements |  | 71d? | 2010-12-10 A | 2011-03-18 | 70% | 21.3d? | 2010-12-10 | 2011-03-18 | 71d? | 455d |  | C1 | 568h | 397.6h | IESE | PCG-26 | Deutsche Telekom | reinhard.lauster@t-mobile.at | Rel-10 | CP-50 | Frederic |
| 188 | 66 | **User Data Convergence - Data Model** |  | 257d? | 2010-03-25 A | 2011-03-18 | 16% | 214.94d? | 2010-03-25 | 2011-03-18 | 257d? | 455d |  | S1,C4 | 5800h | 949.32h | UDC_DM | PCG-25 | Telecom Italia |  | Rel-10 | CP-48 | Kimmo |
| 189 | 66.1 | Stage 1 for UDC Data Model |  | 56d? | 2010-03-25 A | 2010-06-10 A | 100% |  | 2010-03-25 | 2010-06-10 | 56d? |  | finish no earlier than 2010-06-10 | S1 | 448h | 448h | UDC_DM | PCG-25 | Telecom Italia | mauro.ficaccio@telecomitalia.it | Rel-10 | CP-48 | Alain |
| 190 | 66.2 | Study on User Data Convergence (UDC) Data Model |  | 206d? | 2010-06-04 A | 2011-03-18 | 10% | 185.4d? | 2010-06-04 | 2011-03-18 | 206d? | 455d | finish no earlier than 2011-03-18 | C4 | 1648h | 164.8h | UDC_DM | PCG-25 | Telecom Italia | mauro.ficaccio@telecomitalia.it | Rel-10 | CP-48 | Kimmo |
| 191 | 66.3 | User Data Convergence (UDC) Data Model |  | 206d? | 2010-06-04 | 2011-03-18 |  |  | 2010-06-04 | 2011-03-18 | 206d? | 455d | finish no earlier than 2011-03-18 | C4 | 1648h |  | UDC_DM | PCG-25 | Telecom Italia | mauro.ficaccio @ telecomitalia.it | Rel-10 | CP-48 | Kimmo |
| 192 | 67 | **S2b Mobility based on GTP** |  | 202d? | 2010-06-10 A | 2011-03-18 | 93% | 14.59d? | 2010-06-10 | 2011-03-18 | 202d? | 455d |  | S2,C4,C3,C1 | 5856h | 5415.21h | SMOG | PCG-25 | Alcatel-Lucent | bruno.landais@alcatel-lucent.com | Rel-10 | SP-48 | Maurice |
| 193 | 67.1 | Stage 2 for S2b Mobility based on GTP |  | 76d? | 2010-06-10 A | 2010-09-23 A | 100% |  | 2010-06-10 | 2010-09-23 | 76d? |  | finish no earlier than 2010-09-23 | S2 | 608h | 608h | SMOG | PCG-25 | Alcatel-Lucent | bruno.landais@alcatel-lucent.com | Rel-10 | SP-48 | Maurice |
| 194 | 67.2 | **Stage 3 for S2b Mobility based on GTP** |  | 131d? | 2010-09-17 A | 2011-03-18 | 91% | 11.69d? | 2010-09-17 | 2011-03-18 | 131d? | 455d |  | C4,C3,C1 | 3632h | 3307.93h | SMOG-St3 | PCG-25 | Alcatel-Lucent | bruno.landais@alcatel-lucent.com | Rel-10 | CP-49 | Kimmo |
| 195 | 67.2.1 | CT4 part of Stage 3 for S2b Mobility based on GTP |  | 131d? | 2010-09-17 A | 2011-03-18 | 98% | 2.62d? | 2010-09-17 | 2011-03-18 | 131d? | 455d | finish no earlier than 2011-03-18 | C4 | 1048h | 1027.04h | SMOG-St3 | PCG-25 | Alcatel-Lucent | bruno.landais@alcatel-lucent.com | Rel-10 | CP-49 | Kimmo |
| 196 | 67.2.2 | CT3 part of Stage 3 for S2b Mobility based on GTP |  | 131d? | 2010-09-17 A | 2011-03-18 | 80% | 26.2d? | 2010-09-17 | 2011-03-18 | 131d? | 455d | finish no earlier than 2011-03-18 | C3 | 1048h | 838.4h | SMOG-St3 | PCG-25 | Alcatel-Lucent | bruno.landais@alcatel-lucent.com | Rel-10 | CP-49 | Gwiho |
| 197 | 67.2.3 | CT1 part of Stage 3 for S2b Mobility based on GTP |  | 61d? | 2010-09-17 A | 2010-12-10 A | 100% |  | 2010-09-17 | 2010-12-10 | 61d? |  | finish no earlier than 2010-12-10 | C1 | 488h | 488h | SMOG-St3 | PCG-25 | Alcatel-Lucent | bruno.landais@alcatel-lucent.com | Rel-10 | CP-49 | Frederic |
| 198 | 68 | **Policy Enhancements for Sponsored Connectivity and Coherent Access to Policy related Data Bases** |  | 113.15d? | 2010-10-12 A | 2011-03-18 | 65% | 39.6d? | 2010-10-12 | 2011-03-18 | 113.15d? | 455d |  | S2,C3 | 1473.2h | 369.2h | PEST | PCG-26 | Qualcomm | AC Mahendran (ac@qualcomm.com) | Rel-10 | SP-50 | Maurice |
| 199 | 68.1 | Stage 2 for Policy Enhancements for Sponsored Connectivity and Coherent Access to Policy related Data Bases | milestone | 0d? | 2010-10-12 A | 2010-12-15 A | 100% |  | 2010-10-12 | 2010-12-15 | 0d? |  | finish no earlier than 2010-12-15 | S2 |  |  | PEST | PCG-26 | Qualcomm | AC Mahendran (ac@qualcomm.com) | Rel-10 | SP-50 | Maurice |
| 200 | 68.2 | CT3 aspects of Policy Enhancements for Sponsored Connectivity and Coherent Access to Policy related Data Bases |  | 71d? | 2010-12-10 A | 2011-03-18 | 65% | 24.85d? | 2010-12-10 | 2011-03-18 | 71d? | 455d | finish no earlier than 2011-03-18 | C3 | 568h | 369.2h | PEST-CT3 | PCG-26 | ZTE | zhou.xiaoyun@zte.com.cn | Rel-10 | CP-50 | Gwiho |
| 201 | 69 | Lawful Interception in the 3GPP Rel-10 |  | 260d? | 2010-03-25 A | 2011-03-23 | 70% | 78d? | 2010-03-25 | 2011-03-23 | 260d? | 452d | finish no earlier than 2011-03-23 | S3 | 2080h | 1456h | LI10 | PCG-24 | PIDS, Nortel | Koen Jaspers, Ronald Ryan | Rel-10 | SP-47 | Dionisio |
| 202 | 70 | Optimization of IMS based PSS and MBMS User Service |  | 260d? | 2010-03-25 A | 2011-03-23 | 45% | 142.55d? | 2010-03-25 | 2011-03-23 | 260d? | 452d | finish no earlier than 2011-03-23 | S4 | 2080h | 939.6h | OPT_IMS_PSS_MBMS_US | PCG-24 | Ericsson | markus.kampmann@ericsson.com | Rel-10 | SP-47 | Paolo |
| 203 | 71 | HTTP-based Streaming and Download Services |  | 260d? | 2010-03-25 A | 2011-03-23 | 40% | 156d? | 2010-03-25 | 2011-03-23 | 260d? | 452d | finish no earlier than 2011-03-23 | S4 | 2080h | 832h | HTTP_SDS | PCG-24 | Qualcomm | Thomas Stockhammer (c_tstock@qualcomm.com) | Rel-10 | SP-47 | Paolo |
| 204 | 72 | PSS and MBMS enhancements |  | 205d? | 2010-06-10 A | 2011-03-23 | 40% | 123d? | 2010-06-10 | 2011-03-23 | 205d? | 452d | finish no earlier than 2011-03-23 | S4 | 1640h | 656h | MBS_Enh | PCG-25 | Ericsson | Markus.Kampmann@ericsson.com | Rel-10 | SP-48 | Paolo |
| 205 | 73 | Enhancements and Addition of Audio Tests to 26.131 and 26.132 |  | 205d? | 2010-06-10 A | 2011-03-23 | 25% | 153.75d? | 2010-06-10 | 2011-03-23 | 205d? | 452d | finish no earlier than 2011-03-23 | S4 | 1640h | 410h | EAAT | PCG-25 | Vodafone | ramin.afchar@vodafone.com | Rel-10 | SP-48 | Paolo |

Notes:
- 179: -
- 180: CP#50 TS 29.079 v 100 for Information / Text3: 29.162, 29.163, 29.165, 29.235, new TS 29.079
- 181: - / Text3: 24.229
- 182: - / Text3: 23.334
- 183: Stage 3: Linked to CT3 TS 29.079 OMR within the IMS; Stage 3 (UID_480110) / Text3: 32.260, 32.298, 32.299
- 184: SP#49 completed. Source of external requirements: ETSI TISPAN TS 181.019 (Business Communication Requirements)
- 185: SP#47 completed / Text3: 22.101 CR#0343
- 186: SP#49 completed / Text3: 23.167
- 187: - / Text3: 24.229
- 188: CP#50 no progress since CP#49. SP#48 Stage 1 completed
- 189: SP#48 completed / Text3: 22.101
- 190: CP#50 no progress since CP#49. Completion 12/10=>03/11 / Text3: new TR 29.935
- 191: CP#50 no progress since CP#49 / Text3: 29.335
- 192: SP#49 Stage 2 completed. Related to Rel-10 UID_470049 Study on S2b mobility based on GTP (TR23.834), UID_350027 SAE for support for non-3GPP accesses(SAES-SA-FP_n3GPP). Stage1 in Rel-8 UID_320022 Reqs for evolution of 3GPP system architecture (AIPN-SAE)
- 193: SP#49 completed / Text3: 23.002, 23.203, 23.402
- 194: Stage 3
- 195: CP#50 completion 12/10=>03/11 / Text3: 23.003, 23.007, 23.008, 29.273, 29.274, 29.281, 29.303
- 196: CP#50 completion 12/10=>03/11 / Text3: 29.212, 29.213, 29.215
- 197: CP#50 completed / Text3: 24.302
- 198: Triggered by the SA1,SA2 Rel-10 TR 23.813 Study on Policy solutions and enhancements (FS_PP) UID_440047. Provides Video Call seamless service continuity for 3G/LTE terminal user.
- 199: SA#49 work completed as SA2 CRs approved under TEI10 (SP-10557). SP#50 approved WID / Text3: 23.002, 23.203
- 200: - / Text3: 29.212, 29.213, 29.214, 29.215
- 201: SP#50 completion 12/10=>03/11. LI for CAT & CRS, VCC, IMS Media security, H(e)NB also with LIPA-SIPTO, eMBMS, LCLS, IMS/EPS enhancements / Text3: 33.106 (LI requirements), 33.107 (LI architecture and functions), 33.108 (Handover interface for LI)
- 202: Work to enhance UID_430046 Rel-9 IMS_PSS_MBMS_US_EXT / Text3: 26.237
- 203: SP#49 for Information TS 26.247v100 Progressive Download and Dynamic Adaptive Streaming over HTTP (3GP-DASH). Work to enhance UID_430038 Rel-9 PSS and MBMS extensions / Text3: 26.234, 26.244, 26.346, new 26.247 (Progressive Download and Dynamic Adaptive Streaming over HTTP (3GP-DASH))
- 204: Linked to Rel-9 Feature UID_430038 PSS and MBMS extensions (PMA-MBS_Ext). / Text3: 26.234, 26.346
- 205: Reduce fragmentation in acoustic testing (3GPP SA4, ETSI STQ, GCF CAG, CTIA) & Review existing acoustic tests to determine need for new spec (if need, be proactive to review/introduce test material and drive alignment between the bodies in charge) / Text3: 26.131, 26.132

| ID | WBS | Task | Duration | Start | Finish | Complete | Remaining | Baseline start | Baseline finish | Baseline duration | Total slack | Constraint | Resources | Work | Actual work | Text1 | Text2 | Text6 | Text7 | Text8 | Text4 | Text11 |
| --- | --- | --- | --- | --- | --- | --- | --- | --- | --- | --- | --- | --- | --- | --- | --- | --- | --- | --- | --- | --- | --- | --- |
| 206 | 74 | **OAM&P 10** | 335d? | 2009-12-10 A | 2011-03-23 | 56% | 146.29d? | 2009-12-10 | 2011-03-23 | 335d? | 452d |  | S5 | 36440h | 20619.1h | OAM10 | PCG-24 | Rel-10 | SP-46 | Dionisio |  |  |
| 207 | 74.1 | **Network Infrastructure Management** | 335d? | 2009-12-10 A | 2011-03-23 | 48% | 174.44d? | 2009-12-10 | 2011-03-23 | 335d? | 452d |  | S5 | 11160h | 5348.9h | OAM10-NIM | PCG-24 | Rel-10 | SP-46 | Dionisio |  |  |
| 208 | 74.1.1 | Common RAT Network Resource Model (NRM) | 335d? | 2009-12-10 A | 2011-03-23 | 35% | 217.75d? | 2009-12-10 | 2011-03-23 | 335d? | 452d | finish no earlier than 2011-03-23 | S5 | 2680h | 938h | RAT_NRM_common | PCG-24 | Rel-10 | SP-46 | Dionisio | Ericsson | S5-103042 |
| 209 | 74.1.2 | IRP Solution Set specification organisation improvements | 260d? | 2010-03-25 A | 2011-03-23 | 98% | 5.2d? | 2010-03-25 | 2011-03-23 | 260d? | 452d | finish no earlier than 2011-03-23 | S5 | 2080h | 2038.4h | OAM-IRP-SS | PCG-24 | Rel-10 | SP-47 | Dionisio | Nokia Siemens Networks, Huawei | S5-103043 |
| 210 | 74.1.3 | Service Oriented Architecture (SOA) for IRP continuation from Rel-9 | 260d? | 2010-03-25 A | 2011-03-23 | 5% | 247d? | 2010-03-25 | 2011-03-23 | 260d? | 452d | finish no earlier than 2011-03-23 | S5 | 2080h | 104h | OAM-SOA-IRP | PCG-24 | Rel-10 | SP-47 | Dionisio | Nokia Siemens Networks, Ericsson |  |
| 211 | 74.1.4 | IRP Overview, Profiles & Usage Guide | 205d? | 2010-06-10 A | 2011-03-23 | 60% | 82d? | 2010-06-10 | 2011-03-23 | 205d? | 452d | finish no earlier than 2011-03-23 | S5 | 1640h | 984h | OAM-NIM-IRP_OPU | PCG-25 | Rel-10 | SP-48 | Dionisio | Nokia Siemens Networks | S5-103045 |
| 212 | 74.2 | **Self-Organizing Networks (SON) - OAM aspects** | 335d? | 2009-12-10 A | 2011-03-23 | 57% | 145.44d? | 2009-12-10 | 2011-03-23 | 335d? | 452d |  | S5 | 10120h | 5726.51h | OAM10-SON | PCG-24 | Rel-10 | SP-46 | Dionisio |  |  |
| 213 | 74.2.1 | SON Self-optimization management continuation | 335d? | 2009-12-10 A | 2011-03-23 | 45% | 184.25d? | 2009-12-10 | 2011-03-23 | 335d? | 452d | finish no earlier than 2011-03-23 | S5 | 2680h | 1206h | LTE-SON-OAM_SO | PCG-24 | Rel-10 | SP-46 | Dionisio | Huawei | S5-103050 |
| 214 | 74.2.2 | SON Self-healing management | 335d? | 2009-12-10 A | 2011-03-23 | 50% | 167.5d? | 2009-12-10 | 2011-03-23 | 335d? | 452d | finish no earlier than 2011-03-23 | S5 | 2680h | 1340h | LTE-SON-OAM_SH | PCG-24 | Rel-10 | SP-46 | Dionisio | ZTE | S5-103051r1 |
| 215 | 74.2.3 | OAM aspects of Energy Saving in Radio Networks | 260d? | 2010-03-25 A | 2011-03-23 | 80% | 52d? | 2010-03-25 | 2011-03-23 | 260d? | 452d | finish no earlier than 2011-03-23 | S5 | 2080h | 1664h | OAM-ES | PCG-24 | Rel-10 | SP-47 | Dionisio | Nokia Siemens Networks | S5-103052r1 |
| 216 | 74.3 | Subscription Management (SuM) evolution | 260d? | 2010-03-25 A | 2011-03-23 | 30% | 182d? | 2010-03-25 | 2011-03-23 | 260d? | 452d | finish no earlier than 2011-03-23 | S5 | 2080h | 624h | OAM10-SuM | PCG-24 | Rel-10 | SP-47 | Dionisio | Ericsson | S5-103053 |
| 217 | 74.4 | **Performance Management** | 260d? | 2010-03-25 A | 2011-03-23 | 71% | 74.75d? | 2010-03-25 | 2011-03-23 | 260d? | 452d |  | S5 | 10400h | 7410h | OAM10-PM | PCG-24 | Rel-10 | SP-47 | Dionisio |  |  |
| 218 | 74.4.1 | Key Performance Indicators (KPIs) for IMS | 260d? | 2010-03-25 A | 2011-03-23 | 90% | 26d? | 2010-03-25 | 2011-03-23 | 260d? | 452d | finish no earlier than 2011-03-23 | S5 | 2080h | 1872h | OAM-PM-KPI_IMS | PCG-24 | Rel-10 | SP-47 | Dionisio | China Mobile | S5-103046 |
| 219 | 74.4.2 | Key Performance Indicators (KPIs) for EPC | 260d? | 2010-03-25 A | 2011-03-23 | 70% | 78d? | 2010-03-25 | 2011-03-23 | 260d? | 452d | finish no earlier than 2011-03-23 | S5 | 2080h | 1456h | OAM-PM-KPI_EPC | PCG-24 | Rel-10 | SP-47 | Dionisio | China Mobile | S5-103047 |
| 220 | 74.4.3 | Management of UE based network performance measurements | 260d? | 2010-03-25 A | 2011-03-23 | 75% | 65d? | 2010-03-25 | 2011-03-23 | 260d? | 452d | finish no earlier than 2011-03-23 | S5 | 2080h | 1560h | OAM-PM-UE | PCG-24 | Rel-10 | SP-47 | Dionisio | Huawei, Nokia Siemens Networks, Ericsson | S5-103048 |
| 221 | 74.4.4 | 3G HNB and LTE HeNB Subsystem performance measurements | 260d? | 2010-03-25 A | 2011-03-23 | 50% | 130d? | 2010-03-25 | 2011-03-23 | 260d? | 452d | finish no earlier than 2011-03-23 | S5 | 2080h | 1040h | OAM-PM-HeNS | PCG-24 | Rel-10 | SP-47 | Dionisio | China Mobile | S5-103049 |
| 222 | 75 | **Charging Management small Enhancements** | 470d? | 2009-06-04 A | 2011-03-23 | 66% | 157.74d? | 2009-06-04 | 2011-03-23 | 470d? | 452d |  | S5 | 9600h | 6378.08h | CH10 | PCG-24 | Rel-10 | SP-47 | Dionisio |  | S5-103010r2 |
| 223 | 75.1 | IWLAN mobility charging | 470d? | 2009-06-04 A | 2011-03-23 | 70% | 141d? | 2009-06-04 | 2011-03-23 | 470d? | 452d | finish no earlier than 2011-03-23 | S5 | 3760h | 2632h | eIWLAN_Mob | PCG-23 | Rel-10 | SP-44 | Dionisio | Orange | S5-103010r2 |
| 224 | 75.2 | Add solutions for Rc - reference point within the Online Charging System (OCS) | 260d? | 2010-03-25 A | 2011-03-23 | 60% | 104d? | 2010-03-25 | 2011-03-23 | 260d? | 452d | finish no earlier than 2011-03-23 | S5 | 2080h | 1248h | CH-Rc | PCG-24 | Rel-10 | SP-47 | Dionisio | Huawei | S5-103010r2 |
| 225 | 76 | **Advice of Charge (AoC) service support enhancements** | 260d? | 2010-03-25 A | 2011-03-23 | 63% | 95.29d? | 2010-03-25 | 2011-03-23 | 260d? | 452d |  | S5,C1 | 5208h | 3299.29h | eAoC | PCG-24 | Rel-10 | SP-47 | Dionisio | Deutsche Telekom |  |
| 226 | 76.1 | SA5 part - AoC enhancements | 260d? | 2010-03-25 A | 2011-03-23 | 60% | 104d? | 2010-03-25 | 2011-03-23 | 260d? | 452d | finish no earlier than 2011-03-23 | S5 | 2080h | 1248h | eAoC | PCG-24 | Rel-10 | SP-47 | Dionisio | Deutsche Telekom | S5-103010r2 |
| 227 | 76.2 | CT1 part - AoC enhancements (Stage 3) | 131d? | 2010-09-17 A | 2011-03-18 | 70% | 39.3d? | 2010-09-17 | 2011-03-18 | 131d? | 455d | finish no earlier than 2011-03-18 | C1 | 1048h | 733.6h | eAoC | PCG-25 | Rel-10 | CP-49 | Frederic | Deutsche Telekom |  |
| 228 | 77 | IMS Stage 3 - IETF Protocol Alignment | 261d? | 2010-03-19 A | 2011-03-18 | 70% | 78.3d? | 2010-03-19 | 2011-03-18 | 261d? | 455d | finish no earlier than 2011-03-18 | C1 | 2088h | 1461.6h | IMSProtoc4 | PCG-24 | Rel-10 | CP-47 | Frederic | Alcatel-Lucent |  |
| 229 | 78 | Enhanced User Data Convergence (UDC) Model | 206d? | 2010-06-04 A | 2011-03-18 | 5% | 195.7d? | 2010-06-04 | 2011-03-18 | 206d? | 455d | finish no earlier than 2011-03-18 | C4 | 1648h | 82.4h | eUDC | PCG-25 | Rel-10 | CP-48 | Kimmo | China Mobile |  |
| 230 | 79 | Further improvements of II-NNI Stage 3 based on operational feedback and evolution of other specifications | 206d? | 2010-06-04 A | 2011-03-18 | 55% | 92.7d? | 2010-06-04 | 2011-03-18 | 206d? | 455d | start no earlier than 2010-06-04 | C3 | 1648h | 906.4h | II-NNI2 | PCG-25 | Rel-10 | CP-48 | Gwiho | Orange |  |
| 231 | 80 | AT Commands for IMS-configuration | 206d? | 2010-06-04 A | 2011-03-18 | 80% | 41.2d? | 2010-06-04 | 2011-03-18 | 206d? | 455d |  | C1 | 1648h | 1318.4h | AT_IMS | PCG-25 | Rel-10 | CP-48 | Frederic | Ericsson |  |
| 232 | 81 | AT Commands for USIM Application Toolkit (USAT) | 131d? | 2010-09-17 A | 2011-03-18 |  | 131d? | 2010-09-17 | 2011-03-18 | 131d? | 455d |  | C1 | 52.4h |  | AT_UICC | PCG-25 | Rel-10 | CP-49 | Frederic | ST-Ericsson |  |
| 233 | 82 | USAT using AT Commands | 71d? | 2010-12-10 | 2011-03-18 |  |  | 2010-12-10 | 2011-03-18 | 71d? | 455d | finish no earlier than 2011-03-18 | C6 | 568h |  | USAT_AT | PCG-26 | Rel-10 | CP-50 | Xavier | Giesecke & Devrient |  |
| 234 | 83 | Communication Control for IMS by USIM (Stage 3) | 131d? | 2010-09-17 A | 2011-03-18 | 75% | 32.75d? | 2010-09-17 | 2011-03-18 | 131d? | 455d | start no earlier than 2010-09-17 | C6 | 1048h | 786h | CC_IMS_USIM | PCG-25 | Rel-10 | CP-49 | Xavier | Gemalto |  |
| 235 | 84 | Introduction of Smart Card Web Server launch functionality | 71d? | 2010-12-10 | 2011-03-18 |  |  | 2010-12-10 | 2011-03-18 | 71d? | 455d | finish no earlier than 2011-03-18 | C6 | 568h |  | SCWS_L | PCG-26 | Rel-10 | CP-50 | Xavier | Telecom Italia |  |
| 236 | 85 | SRVCC in alerting phase (Stage 3) | 71d? | 2010-12-10 A | 2011-03-18 | 65% | 24.85d? | 2010-12-10 | 2011-03-18 | 71d? | 455d | finish no earlier than 2011-03-18 | C1 | 426h | 227.2h | aSRVCC | PCG-26 | Rel-10 | CP-50 | Frederic | ZTE |  |

Notes:
- 206: umbrella Feature
- 207: umbrella BB
- 208: SP#50 TS 32.791 v100 for Information. Share equipment btw several RATs (RET,TMA,repeaters) to reduce costs. With existing modelling is difficult to see that several cells are affected when an antenna tilt is changed etc / Text3: 32.616, 32.642, 32.646, 32.652, 32.656, 32.762, 32.766 new (32.791, 32.792, 32.796) / Text5: robert.petersen@ericsson.com
- 209: SP#50 completion 12/10=>03/11. Updated WID SP-100294=>SP-100774. TS 32.526 v100 for Information + Approval / Text3: 32.153, new (32.111-6,32.126,32.176,32.306,32.316,32.326,32.336,32.346,32.356,32.366,32.376,32.386,32.396,32.416,32.446,32.506/26/36,32.606,32.616,32.626,32.636,32.646,32.656,32.666,32.676,32.696,32.716,32.726,32.736,32.746,32.756,32.766,32.776,32.786) / Text5: Jörg Schmidt (joerg@cox.net), Lan Zou (zlan@huawei.com)
- 210: SP#50 completion 12/10=>03/11 (No progress since SP#49). Continuation of Rel-9 UID_440065 SOA for IRP (covering SOA Architecture & SOA-supporting Solution Set) to address SOA conforming Registration & Discovery capabilities / Text3: 32.101, 32.150 / Text5: Jörg Schmidt (joerg@cox.net), edwin.tse@ericsson.com
- 211: SP#50 completion 12/10=>03/11. Updated WID SP-100388=>SP-100777. TS 32.103 v100 for Information / Text3: new TS 32.103 / Text5: Jörg Schmidt (joerg@cox.net)
- 212: umbrella BB
- 213: SP#50 completion 12/10=>03/11. Cont'd Rel-9 SON self-optimization management UID_390007 / Text3: 32.425, 32.521, 32.522, 32.752, 32.753, 32.755, 32.762, 32.763, 32.765 / Text5: Lan Zou (zlan@huawei.com)
- 214: SP#50 completion 12/10=>03/11. Updated WID SP-090757=>SP-100776. Work moved to Rel-10 after split of the Rel-9 UID_390007 SON self-optimization (removed Self-Healing handling) / Text3: 32.522, 32.526, 32.752, 32.753, 32.755, 32.762, 32.763, 32.765, new TS 32.541 / Text5: zhu.weihong@zte.com.cn
- 215: SP#50 TS 32.551v200 for Approval. Triggered by Rel-10 TR 32.826 Study on Telecommunication Management; Energy Savings Management (FS_OAM_ESM) UID_430044 / Text3: 32.425, 32.762, 32.763, 32.765, 32.767, new (32.551, 32.522) / Text5: clemens.suerbaum@nsn.com
- 216: SP#50 completion 12/10=>03/11 / Text3: 32.172, 32.175, 32.176 / Text5: leo.yang@ericsson.com
- 217: umbrella BB
- 218: SP#50 completion 12/10=>03/11. TS 32.454 v100 for Information / Text3: new 32.454 / Text5: Li Jian (lijian@chinamobile.com), Liang Shuangchun (liangshuangchun@cmdi.chinamobile.com)
- 219: SP#50 TS 32.455 v100 for Information / Text3: new 32.455 / Text5: Li Jian (lijian@chinamobile.com), Liang Shuangchun (liangshuangchun@cmdi.chinamobile.com)
- 220: Stage 2/3. Linked to UID_460003 Minimization of drive tests for E-UTRAN and UTRAN (MDT_UMTSLTE) / Text3: 32.421, 32.422, 32.423, 32.441, 32.442, 32.446 / Text5: Zou Lan (zlan@huawei.com), gyula.bodog@nsn.com, ulf.hubinette@ericsson.com
- 221: SP#50 completion 12/10=>03/11. / Text3: 32.582, 32.592, new (32.452, 32.453) / Text5: Chen Gang (chengang@chinamobile.com)
- 222: umbrella Feature
- 223: RAT differentiation for charging. Completes Rel-8 Feature IWLAN_Mob UID_370049 Mobility between 3GPP-WLAN Interworking and 3GPP Systems. Cooperation with CT1,CT3 on affected protocols / Text3: 32.240, 32.252, 32.298, 32.299 / Text5: Jean-Luc Garcia (jl.garcia@orange-ftgroup.com)
- 224: Stage 3 (Stage 1 in 22.115). Triggered by Rel-10 TR 32.825 SA5 Study on Rc Reference Point Functionalities and Message Flows (UID_410044) / Text3: 32.296, 32.299 / Text5: shan.mingjun@huawei.com
- 225: Continuation of Rel-8 BB UID_80042: Advice of Charge (AoC) support in IMS Charging (IMSTSS). Stage 2/3 work / Text5: matthias.seibel@telekom.de
- 226: SA1 Stage 1 in 22.115 / Text3: 32.275, 32.280, 32.298, 32.299 / Text5: matthias.seibel@telekom.de
- 227: CP#50 completion 12/10=>03/11. SA1 Stage 1 in 22.115, 22.173, 22.024. Add mobile-specific CAI format and volume charging elements. Extensions to existing AoC XML / Text3: 24.647 / Text5: reinhard.lauster@t-mobile.at
- 228: Ensure protocol alignment between 3GPP Stage 3 IMS work and IETF. Review capabilities provided in SIP by IETF and document whether these capabilities are supported in the IM CN Subsystem or not / Text3: 23.218, 24.229, 24.930 / Text5: keith.drage@alcatel-lucent.com
- 229: CP#50 no progress since CP#49. To specify the CRUD (Create/Read/Update/Delete) operations based on SOAP protocol, which may be used by the applications having no high real-time requirement to the data access operations / Text3: 29.335 / Text5: Lan Sizhong (lansizhong@chinamobile.com)
- 230: Improvements of Rel-9 Feature UID_440027 Operational description of the Inter-IMS Network to Network Interface (II-NNI) / Text3: 29.165 / Text5: beata.dobrowolska@orange-ftgroup.com
- 231: Specify 1) IMS-related AT-commands to configure MT and 2) IMS-related unsolicited response codes from MT to present to end-user / Text3: 27.007 / Text5: atle.monrad@ericsson.com
- 232: - / Text3: 27.007 / Text5: magnus.mk.karlsson@stericsson.com
- 233: Stage 3 based on SA1 22.038CR#37r1 (Make USAT proactive capability reqs applicable to ME as a whole without regard to any particular configuration; e.g. it may consist of a modem connected to an external display). Linked to CT1 Feature UID_ / Text3: Stage 3 31.102, 31.111 / Text5: enric.fort@gi-de.com
- 234: Stage 1 in TS 22.038 USAT service description. Linked to CT6's UID_1273 Rel-5 BB Provisioning of IP-based multimedia services (24.229, 31.103) and UID_390021 Rel-8 BB CT6 aspects of SAE (31.102, 31.111) / Text3: 31.102, 31.103, 31.111 / Text5: Denis L'Heriteau (Denis.Lheriteau@gemalto.com)
- 235: Define a solution which allows enabling to launch Smart Card Web Server services in an easy and simple manner / Text3: 31.102 / Text5: davide.pratone@telecomitalia.it
- 236: Builds on Rel-8 UID_390057 (IMS-Cont) TS 23.216 IMS Service Continuity Stage 2. Provide Stage 3 for SRVCC PS-CS transfer of a call in alerting phase for Rel-10 Stage 2 TEI10 in TS 23.237 (clauses 6.3.2.1.4c/d, 6.3.2.1.7a/b) / Text3: 24.008, 24.237 / Text5: li.shitao@zte.com.cn

| ID | WBS | Task | Duration | Start | Finish | Complete | Remaining | Baseline start | Baseline finish | Baseline duration | Total slack | Constraint | Resources | Work | Actual work | Text1 | Text2 | Text4 | Text5 | Text6 | Text7 | Text8 | Text11 |
| --- | --- | --- | --- | --- | --- | --- | --- | --- | --- | --- | --- | --- | --- | --- | --- | --- | --- | --- | --- | --- | --- | --- | --- |
| 237 | 86 | **PCRF failure and restoration** | 71d? | 2010-12-10 A | 2011-03-18 | 6% | 66.94d? | 2010-12-10 | 2011-03-18 | 71d? | 455d |  | C4,C3 | 1562h | 56.8h | PCRF_FR | PCG-26 | NEC | Toshiyuki Tamura (tamurato@aj.jp.nec.com) | Rel-10 | CP-50 | Kimmo |  |
| 238 | 86.1 | CT4 part of PCRF failure and restoration | 71d? | 2010-12-10 A | 2011-03-18 | 10% | 63.9d? | 2010-12-10 | 2011-03-18 | 71d? | 455d | finish no earlier than 2011-03-18 | C4 | 568h | 56.8h | PCRF_FR | PCG-26 | NEC | Toshiyuki Tamura (tamurato@aj.jp.nec.com) | Rel-10 | CP-50 | Kimmo |  |
| 239 | 86.2 | CT3 part of PCRF failure and restoration | 53.25d? | 2010-12-10 | 2011-03-18 |  |  | 2010-12-10 | 2011-03-18 | 53.25d? | 455d | start no earlier than 2010-12-10 | C3 | 426h |  | PCRF_FR | PCG-26 | NEC | Toshiyuki Tamura (tamurato@aj.jp.nec.com) | Rel-10 | CP-50 | Gwiho |  |
| 240 | 87 | Dynamic view of SIP message for II-NNI (Stage 3) | 71d? | 2010-12-10 A | 2011-03-18 | 10% | 63.9d? | 2010-12-10 | 2011-03-18 | 71d? | 455d |  | C3 | 568h | 56.8h | NNI_DV | PCG-26 | NTT | arai.kenjiro@lab.ntt.co.jp | Rel-10 | CP-50 | Gwiho |  |
| 241 | 88 | 1.28 Mcps TDD Repeater | 599d? | 2007-12-04 A | 2010-03-19 A | 100% |  | 2007-12-04 | 2010-03-19 | 599d? |  | finish no earlier than 2010-03-19 | R4 | 4792h | 4792h | RANimp-Repeaters1.28TDD | PCG-21 | RITT | qinyan@chinattl.com | Rel-10 | RP-38 | Issam | RP-100039 |
| 242 | 89 | 1.28 Mcps TDD Multi-carrier HSUPA | 321d? | 2009-09-18 A | 2010-12-10 A | 100% |  | 2009-09-18 | 2010-12-10 | 321d? |  | finish no earlier than 2010-12-10 | R1,R2,R3,R4 | 2568h | 2568h | TDD_MC_HSUPA | PCG-23 | CATR | Aihui Song (songaihui@mail.ritt.com.cn) | Rel-10 | RP-45 | Patrick | RP-101079 |
| 243 | 90 | **1.28 Mcps TDD Home NodeB RF requirements** | 266d? | 2009-12-04 A | 2010-12-10 A | 100% |  | 2009-12-04 | 2010-12-10 | 266d? |  |  | R4 | 5304h | 5304h | HNB_LCRTDD_RF | PCG-24 | TD Tech | Li Rong (lirong@td-tech.com) | Rel-10 | RP-46 | Issam |  |
| 244 | 90.1 | Core part: 1.28Mcps TDD Home NodeB RF requirements | 131d? | 2009-12-04 A | 2010-06-04 A | 100% |  | 2009-12-04 | 2010-06-04 | 131d? |  | finish no earlier than 2010-12-10 | R4 | 1048h | 1048h | HNB_LCRTDD_RF-Core | PCG-24 | TD Tech | Li Rong (lirong@td-tech.com) | Rel-10 | RP-46 | Issam | RP-100446 |
| 245 | 90.2 | Perf. part: 1.28Mcps TDD Home NodeB RF requirements | 266d? | 2009-12-04 A | 2010-12-10 A | 100% |  | 2009-12-04 | 2010-12-10 | 266d? |  | finish no earlier than 2010-12-10 | R4 | 2128h | 2128h | HNB_LCRTDD_RF-Perf | PCG-24 | TD Tech | Li Rong (lirong@td-tech.com) | Rel-10 | RP-46 | Issam | RP-101081 |
| 246 | 91 | UE Over The Air (Antenna) conformance testing methodology - Laptop mounted equipment Free Space test | 521d? | 2009-09-18 A | 2011-09-16 | 55% | 234.45d? | 2009-09-18 | 2011-09-16 | 521d? | 325d | finish no earlier than 2011-09-16 | R4 | 4168h | 2292.4h | UEAnt_FSTest | PCG-23 | CATR | Guo Lin (guolin@emcite.com) | Rel-10 | RP-45 | Issam | RP-101080 |
| 247 | 92 | **AGNSS Minimum Performance for UTRAN** | 391d? | 2009-09-18 A | 2011-03-18 | 92% | 30.57d? | 2009-09-18 | 2011-03-18 | 391d? | 455d |  | R4,R5 | 7344h | 6769.86h | AGNSSPerf_UTRAN | PCG-23 | Thales | Michel.monnerat@thalesaleniaspace.com | Rel-10 | RP-45 | Issam |  |
| 248 | 92.1 | AGNSS Minimum Performance Specification Development | 321d? | 2009-09-18 A | 2010-12-10 A | 100% |  | 2009-09-18 | 2010-12-10 | 321d? |  | finish no earlier than 2010-12-10 | R4 | 2568h | 2568h | AGNSSPerf_UTRAN | PCG-23 | Thales | Michel.monnerat@thalesaleniaspace.com | Rel-10 | RP-45 | Issam | RP-101078 |
| 249 | 92.2 | AGNSS test case development for UMTS | 206d? | 2010-06-04 A | 2011-03-18 | 80% | 41.2d? | 2010-06-04 | 2011-03-18 | 206d? | 455d | finish no earlier than 2011-03-18 | R5 | 1648h | 1318.4h | AGNSSTest_UTRAN | PCG-25 | Thales | Michel.monnerat@thalesaleniaspace.com | Rel-10 | RP-48 | Ingbert | RP-101070 |
| 250 | 93 | **Inclusion of RF Pattern Matching Technologies as positioning method in the UTRAN** | 336d? | 2009-12-04 A | 2011-03-18 | 90% | 33.6d? | 2009-12-04 | 2011-03-18 | 336d? | 455d |  | R2,R3 | 5376h | 4838.4h | LCS_UMTS_RFPMT | PCG-24 | Polaris Wireless | Norman Shaw (nshaw@polariswireless.com) | Rel-10 | RP-46 | Joern | RP-101084 |
| 251 | 93.1 | Core part: Inclusion of RF Pattern Matching Technologies as positioning method in the UTRAN | 336d? | 2009-12-04 A | 2011-03-18 | 90% | 33.6d? | 2009-12-04 | 2011-03-18 | 336d? | 455d | finish no earlier than 2011-03-18 | R2,R3 | 2688h | 2419.2h | LCS_UMTS_RFPMT-Core | PCG-24 | Polaris Wireless | Norman Shaw (nshaw@polariswireless.com) | Rel-10 | RP-46 | Joern | RP-101084 |
| 252 | 94 | **Four carrier HSDPA** | 401d? | 2009-12-04 A | 2011-06-17 | 53% | 189.11d? | 2009-12-04 | 2011-06-17 | 401d? | 390d |  | R1,R2,R3,R4 | 9104h | 4810.54h | 4C_HSDPA | PCG-24 | Qualcomm | Arjun Bharadwaj (arjunb@qualcomm.com) | Rel-10 | RP-46 | Patrick |  |
| 253 | 94.1 | Core part: Four carrier HSDPA | 336d? | 2009-12-04 A | 2011-03-18 | 98% | 6.72d? | 2009-12-04 | 2011-03-18 | 336d? | 455d | finish no earlier than 2011-03-18 | R1,R2,R3,R4 | 2688h | 2634.24h | 4C_HSDPA-Core | PCG-24 | Qualcomm | Arjun Bharadwaj (arjunb@qualcomm.com) | Rel-10 | RP-46 | Patrick | RP-101082 |
| 254 | 94.2 | Perf. part: Four carrier HSDPA | 401d? | 2009-12-04 A | 2011-06-17 | 15% | 340.85d? | 2009-12-04 | 2011-06-17 | 401d? | 390d | finish no earlier than 2011-06-17 | R4 | 3208h | 481.2h | 4C_HSDPA-Perf | PCG-24 | Qualcomm | Arjun Bharadwaj (arjunb@qualcomm.com) | Rel-10 | RP-46 | Issam | RP-101083 |
| 255 | 95 | **Multi-User Multiple-Input and Multiple-Output (MU-MIMO) for 1.28Mcps TDD** | 316d? | 2010-03-19 A | 2011-06-03 | 38% | 196.95d? | 2010-03-19 | 2011-06-03 | 316d? | 400d |  | R1,R2,R3,R4 | 6584h | 2480.36h | MUMIMO_LCR_TDD | PCG-24 | CATT | Yanping Xing (xingyanping@datangmobile.cn) | Rel-10 | RP-47 | Patrick |  |
| 256 | 95.1 | Core part: MU-MIMO for 1.28Mcps TDD | 191d? | 2010-03-19 A | 2010-12-10 A | 100% |  | 2010-03-19 | 2010-12-10 | 191d? |  | finish no earlier than 2010-12-10 | R1,R2,R3 | 1528h | 1528h | MUMIMO_LCR_TDD-Core | PCG-24 | CATT | Yanping Xing (xingyanping@datangmobile.cn) | Rel-10 | RP-47 | Patrick | RP-101085 |
| 257 | 95.2 | Perf. part: MU-MIMO for 1.28Mcps TDD | 316d? | 2010-03-19 | 2011-06-03 |  |  | 2010-03-19 | 2011-06-03 | 316d? | 400d | finish no earlier than 2011-06-03 | R4 | 2528h |  | MUMIMO_LCR_TDD-Perf | PCG-24 | CATT | Sanjun Feng (fengsanjun@datangmobile.cn) | Rel-10 | RP-47 | Issam | RP-101086 |
| 258 | 96 | **Performance Requirements for two-antenna 1.28Mcps TDD Type 1 and Type 2 UE receiver** | 261d? | 2010-03-19 A | 2011-03-18 | 67% | 85.96d? | 2010-03-19 | 2011-03-18 | 261d? | 455d |  | R4 | 4624h | 3101.14h | 2ant_UE_LCR_TDD | PCG-24 | TD Tech | dafei.wang@td-tech.com | Rel-10 | RP-47 | Issam |  |
| 259 | 96.1 | Core part: Performance Requirements for two-antenna 1.28Mcps TDD Type 1 and Type 2 UE receiver | 56d? | 2010-03-19 A | 2010-06-04 A | 100% |  | 2010-03-19 | 2010-06-04 | 56d? |  | finish no earlier than 2010-06-04 | R4 | 448h | 448h | 2ant_UE_LCR_TDD-Core | PCG-24 | TD Tech | dafei.wang@td-tech.com | Rel-10 | RP-47 | Issam | RP-100454 |
| 260 | 96.2 | Perf. part: Performance Requirements for two-antenna 1.28Mcps TDD Type 1 and Type 2 UE receiver | 261d? | 2010-03-19 A | 2011-03-18 | 60% | 104.4d? | 2010-03-19 | 2011-03-18 | 261d? | 455d | finish no earlier than 2010-12-10 | R4 | 2088h | 1252.8h | 2ant_UE_LCR_TDD-Perf | PCG-24 | TD Tech | dafei.wang@td-tech.com | Rel-10 | RP-47 | Issam | RP-101308 |

Notes:
- 237: Triggered by CT3 TR 29.816 Study on Policy and Charging Rules Function (PCRF) failure and restoration (FS_PCRF-FR) UID_450013 / Text3: Stage 2/3 work
- 238: - / Text3: Stage 2 23.007, Stage 3 29.230
- 239: - / Text3: Stage 3 29.212, 29.213, 29.214, 29.215
- 240: Linked to CT3 Rel-10 Feature UID_480014 Further improvements of II-NNI Stage 3 based on operational feedback and evolution of other specifications (II-NNI2) / Text3: 29.165
- 241: RP#47 completed / Text3: UTRA 25.113, new 25.116, 25.153 (testing)
- 242: RP#50 completed / Text3: UTRA 25.102, 25.105, 25.123, 25.221, 25.222, 25.223, 25.224, 25.225, 25.306, 25.319, 25.321, 25.331, 25.423, 25.427, 25.433
- 243: RP#50 completed. Triggered by FS_RAN-HNBLCRTDD UID_410016 Study on 1.28 Mcps TDD Home NodeB (TR 25.866) / Text3: UTRA
- 244: RP#48 completed / Text3: 25.105
- 245: RP#50 completed. TR 25.968 v100 for Approval / Text3: 25.142, new TR 25.968
- 246: - / Text3: UTRA 25.144, 25.914, 34.114
- 247: Triggered by Rel-7 UID_20050 (GNSS in UTRAN) and Rel-8 UID_400051 (Support for Additional NSS). Linked to GERAN Rel-9 UID_38002 (A-GNSS Performances and Testing Procedures) / Text3: UTRA
- 248: RP#50 completed. Updated WID RP-100363=>RP-101405 / Text3: new 25.172
- 249: RP#50 updated WID RP-100609=>RP-101405. TS 34.172 v100 for Information / Text3: 34.108, 34.109, 34.123-1, 34.123-2, 34.123-3, 36.37.571-5, new 34.172
- 250: Triggered by Study UID_380079 Evaluation of the inclusion of Path Loss Based Technology in the UTRAN (25.907) / Text3: UTRA
- 251: RP#50 completion 12/10=>03/11 / Text3: 25.305, 25.453
- 252: - / Text3: UTRA
- 253: RP#50 completion 12/10=>03/11 / Text3: 25.101, 25.104, 25.133, 25.211, 25.212, 25.213, 25.214, 25.215, 25.308, 25.331, 25.423, 25.433, 26.306, new TR 25.864
- 254: - / Text3: 25.101, 25.104, 25.133, 25.141
- 255: - / Text3: UTRA
- 256: RP#50 completed / Text3: 25.221, 25.222, 25.224, 25.306, 25.308, 25.319, 25.331, 25.423, 25.425, 25.433, 25.435
- 257: RP#50 completion 03/11=>06/11 / Text3: 25.102, 25.105, 25.142
- 258: Stage 3 / Text3: UTRA
- 259: RP#48 completed / Text3: 25.102
- 260: RP#50 completion 12/10=>03/11 / Text3: 25.102

| ID | WBS | Task | Duration | Start | Finish | Complete | Remaining | Baseline start | Baseline finish | Baseline duration | Total slack | Constraint | Resources | Work | Actual work | Text1 | Text2 | Text4 | Text5 | Text6 | Text7 | Text8 | Text11 | Text9 | Text12 |
| --- | --- | --- | --- | --- | --- | --- | --- | --- | --- | --- | --- | --- | --- | --- | --- | --- | --- | --- | --- | --- | --- | --- | --- | --- | --- |
| 261 | 97 | **Automatic Neighbour Relation (ANR) for UTRAN** | 206d? | 2010-06-04 A | 2011-03-18 | 55% | 92.7d? | 2010-06-04 | 2011-03-18 | 206d? | 455d |  | R3,R2 | 3296h | 1812.8h | ANR_UTRAN | PCG-25 | ZTE | Zhai hengxing | Rel-10 | RP-48 | Juha |  |  |  |
| 262 | 97.1 | Core part: Automatic Neighbour Relation (ANR) for UTRAN | 206d? | 2010-06-04 A | 2011-03-18 | 55% | 92.7d? | 2010-06-04 | 2011-03-18 | 206d? | 455d | finish no earlier than 2011-03-18 | R3,R2 | 1648h | 906.4h | ANR_UTRAN-Core | PCG-25 | ZTE | Zhai hengxing | Rel-10 | RP-48 | Juha | RP-101410 |  |  |
| 263 | 98 | **Support of New Band Combinations for Dual-Band Dual Cell HSDPA** | 206d? | 2010-06-04 A | 2011-03-18 | 49% | 105.34d? | 2010-06-04 | 2011-03-18 | 206d? | 455d |  | R4,R2 | 3904h | 1907.7h | DB_DC_HSDPA | PCG-25 | AT&T | Vince Spatafora (vs5785@att.com) | Rel-10 | RP-48 | Issam |  |  |  |
| 264 | 98.1 | Core part: Support of New Band Combinations for Dual-Band Dual Cell HSDPA | 206d? | 2010-06-04 A | 2011-03-18 | 30% | 144.2d? | 2010-06-04 | 2011-03-18 | 206d? | 455d | finish no earlier than 2011-03-18 | R4,R2 | 1648h | 494.4h | DB_DC_HSDPA-Core | PCG-25 | AT&T | Vince Spatafora (vs5785@att.com) | Rel-10 | RP-48 | Issam | RP-101395 |  |  |
| 265 | 98.2 | Deleted - Perf. part: Support of New Band Combinations for Dual-Band Dual Cell HSDPA | 76d? | 2010-06-04 A | 2010-09-17 A | 100% |  | 2010-06-04 | 2010-09-17 | 76d? |  | finish no earlier than 2010-09-17 | R4,R2 | 608h | 608h | DB_DC_HSDPA-Perf | PCG-25 | AT&T | Vince Spatafora (vs5785@att.com) | Rel-10 | RP-48 | Issam | RP-100759 | PCG-25 | RP-49 |
| 266 | 99 | **MIMO operation with non-MIMO coexistence in HSDPA** | 271d? | 2010-06-04 A | 2011-06-17 | 60% | 108.4d? | 2010-06-04 | 2011-06-17 | 271d? | 390d |  | R4 | 5384h | 3230.4h | MIMO_HSDPA | PCG-25 | Qualcomm | Heechoon Lee | Rel-10 | RP-48 | Issam |  |  |  |
| 267 | 99.1 | Core part: MIMO operation with non-MIMO coexistence in HSDPA | 131d? | 2010-09-17 A | 2011-03-18 | 60% | 52.4d? | 2010-09-17 | 2011-03-18 | 131d? | 455d | finish no earlier than 2011-03-18 | R4 | 1048h | 628.8h | MIMO_HSDPA-Core | PCG-25 | Qualcomm | Heechoon Lee | Rel-10 | RP-49 | Issam | RP-101089 |  |  |
| 268 | 99.2 | Perf. part: MIMO operation with non-MIMO coexistence in HSDPA | 271d? | 2010-06-04 A | 2011-06-17 | 60% | 108.4d? | 2010-06-04 | 2011-06-17 | 271d? | 390d | finish no earlier than 2011-06-17 | R4 | 2168h | 1300.8h | MIMO_HSDPA-Perf | PCG-25 | Qualcomm | Heechoon Lee | Rel-10 | RP-48 | Issam | RP-101393 |  |  |
| 269 | 100 | Interfrequency detected set measurements for UMTS | 61d? | 2010-09-17 A | 2010-12-10 A | 100% |  | 2010-09-17 | 2010-12-10 | 61d? |  | finish no earlier than 2010-12-10 | R2,R4 | 488h | 488h | Interf_dset_meas_UMTS | PCG-25 | Nokia | Chris Callender | Rel-10 | RP-49 | Joern | RP-101093 |  |  |
| 270 | 101 | **Carrier Aggregation for LTE** | 400d? | 2009-12-04 A | 2011-06-16 | 50% | 201.3d? | 2009-12-04 | 2011-06-16 | 400d? | 391d |  | R1,R2,R3,R4 | 9088h | 4514.36h | LTE_CA | PCG-24 | Nokia | Asbjorn.grovlen@nokia.com | Rel-10 | RP-46 | Patrick |  |  |  |
| 271 | 101.1 | Core part: Carrier Aggregation for LTE | 336d? | 2009-12-04 A | 2011-03-18 | 85% | 50.4d? | 2009-12-04 | 2011-03-18 | 336d? | 455d | finish no earlier than 2011-03-18 | R1,R2,R3,R4 | 2688h | 2284.8h | LTE_CA-Core | PCG-24 | Nokia | Asbjorn.grovlen@nokia.com | Rel-10 | RP-46 | Patrick | RP-101415 |  |  |
| 272 | 101.2 | Perf. part: Carrier Aggregation for LTE | 400d? | 2009-12-04 A | 2011-06-16 | 20% | 320d? | 2009-12-04 | 2011-06-16 | 400d? | 391d | finish no earlier than 2011-06-16 | R4 | 3200h | 640h | LTE_CA-Perf | PCG-24 | Nokia | Asbjorn.grovlen@nokia.com | Rel-10 | RP-46 | Issam | RP-101416 |  |  |
| 273 | 102 | **Enhanced Downlink Multiple Antenna Transmission for LTE** | 400d? | 2009-12-04 A | 2011-06-16 | 49% | 204.78d? | 2009-12-04 | 2011-06-16 | 400d? | 391d |  | R1,R2,R4 | 9088h | 4435.34h | LTE_eDL_MIMO | PCG-24 | NTT DoCoMo | Hidekazu Taoka (taoka@nttdocomo.com) | Rel-10 | RP-46 | Patrick |  |  |  |
| 274 | 102.1 | Core part: Enhanced Downlink Multiple Antenna Transmission for LTE | 336d? | 2009-12-04 A | 2011-03-18 | 95% | 16.8d? | 2009-12-04 | 2011-03-18 | 336d? | 455d | finish no earlier than 2011-03-18 | R1,R2,R4 | 2688h | 2553.6h | LTE_eDL_MIMO-Core | PCG-24 | NTT DoCoMo | Hidekazu Taoka (taoka@nttdocomo.com) | Rel-10 | RP-46 | Patrick | RP-101104 |  |  |
| 275 | 102.2 | Perf. part: Enhanced Downlink Multiple Antenna Transmission for LTE | 400d? | 2009-12-04 A | 2011-06-16 | 10% | 360d? | 2009-12-04 | 2011-06-16 | 400d? | 391d | finish no earlier than 2011-06-16 | R4 | 3200h | 320h | LTE_eDL_MIMO-Perf | PCG-24 | NTT DoCoMo | Hidekazu Taoka (taoka@nttdocomo.com) | Rel-10 | RP-46 | Issam | RP-101105 |  |  |
| 276 | 103 | **Uplink Multiple Antenna Transmission for LTE** | 400d? | 2009-12-04 A | 2011-06-16 | 52% | 190.43d? | 2009-12-04 | 2011-06-16 | 400d? | 391d |  | R1,R2,R4 | 9088h | 4761.32h | LTE_UL_MIMO | PCG-24 | Huawei | Mattias.wennstrom@huawei.com | Rel-10 | RP-46 | Patrick |  |  |  |
| 277 | 103.1 | Core part: UL multiple antenna transmission for LTE | 336d? | 2009-12-04 A | 2011-03-18 | 85% | 50.4d? | 2009-12-04 | 2011-03-18 | 336d? | 455d | finish no earlier than 2011-03-18 | R1,R2,R4 | 2688h | 2284.8h | LTE_UL_MIMO-Core | PCG-24 | Huawei | Mattias.wennstrom@huawei.com | Rel-10 | RP-46 | Patrick | RP-101106 |  |  |
| 278 | 103.2 | Perf. part: UL multiple antenna transmission for LTE | 400d? | 2009-12-04 A | 2011-06-16 | 25% | 300d? | 2009-12-04 | 2011-06-16 | 400d? | 391d | finish no earlier than 2011-06-16 | R4 | 3200h | 800h | LTE_UL_MIMO-Perf | PCG-24 | Huawei | Mattias.wennstrom@huawei.com | Rel-10 | RP-46 | Issam | RP-101107 |  |  |
| 279 | 104 | **Fixed Wireless Customer-Premises Equipment (CPE) RF Requirements** | 401d? | 2009-12-04 A | 2011-06-17 | 23% | 309.59d? | 2009-12-04 | 2011-06-17 | 401d? | 390d |  | R4,R5 | 9104h | 2075.27h | FW_CPE_RF | PCG-24 | Verizon Wireless | zheng.zhao@verizonwireless.com | Rel-10 | RP-46 | Issam |  |  |  |
| 280 | 104.1 | Core part: Fixed Wireless Customer-Premises Equipment (CPE) RF Requirements | 336d? | 2009-12-04 A | 2011-03-18 | 50% | 168d? | 2009-12-04 | 2011-03-18 | 336d? | 455d | finish no earlier than 2011-03-18 | R4 | 2688h | 1344h | FW_CPE_RF-Core | PCG-24 | Verizon Wireless | zheng.zhao@verizonwireless.com | Rel-10 | RP-46 | Issam | RP-101103 |  |  |
| 281 | 104.2 | Test part: Fixed Wireless Customer-Premises Equipment (CPE) RF Requirements | 401d? | 2009-12-04 | 2011-06-17 |  |  | 2009-12-04 | 2011-06-17 | 401d? | 390d | finish no earlier than 2011-06-17 | R5 | 3208h |  | FW_CPE_RF-UEConTest | PCG-24 | Verizon Wireless | zheng.zhao@verizonwireless.com | Rel-10 | RP-46 | Ingbert | RP-101067 |  |  |
| 282 | 105 | **Relays for LTE** | 466d? | 2009-12-04 A | 2011-09-16 | 32% | 315.14d? | 2009-12-04 | 2011-09-16 | 466d? | 325d |  | R1,R2,R4,S3 | 11581.6h | 2602.8h | LTE_Relay | PCG-24 | Ericsson | christian.hoymann@ericsson.com | Rel-10 | RP-46 | Patrick |  |  |  |
| 283 | 105.1 | Core part: Relays for LTE | 401d? | 2009-12-04 A | 2011-06-17 | 65% | 140.35d? | 2009-12-04 | 2011-06-17 | 401d? | 390d | finish no earlier than 2011-06-17 | R1,R2,R4 | 3208h | 2085.2h | LTE_Relay-Core | PCG-24 | Ericsson | christian.hoymann@ericsson.com | Rel-10 | RP-46 | Patrick | RP-101110 |  |  |
| 284 | 105.2 | Perf. part: Relays for LTE | 466d? | 2009-12-04 A | 2011-09-16 | 5% | 442.7d? | 2009-12-04 | 2011-09-16 | 466d? | 325d | finish no earlier than 2011-09-16 | R4 | 3728h | 186.4h | LTE_Relay-Perf | PCG-24 | Ericsson | christian.hoymann@ericsson.com | Rel-10 | RP-46 | Issam | RP-101111 |  |  |
| 285 | 105.3 | TR on LTE Relay Nodes Security | 69d? | 2010-12-16 A | 2011-03-23 | 60% | 27.6d? | 2010-12-16 | 2011-03-23 | 69d? | 453d | finish no earlier than 2011-03-23 | S3 | 552h | 331.2h | LTE_Relay-Sec | PCG-26 | Qualcomm | Adrian Escott (aescott@qualcomm.com) | Rel-10 | SP-50 | Dionisio |  |  |  |
| 286 | 105.4 | Security for LTE Relay Nodes (Stage 2) | 69d? | 2010-12-16 | 2011-03-23 |  |  | 2010-12-16 | 2011-03-23 | 69d? | 453d | finish no earlier than 2011-03-23 | S3 | 552h |  | LTE_Relay-Sec | PCG-26 | Qualcomm | Adrian Escott (aescott@qualcomm.com) | Rel-10 | SP-50 | Dionisio |  |  |  |

Notes:
- 261: Automatic Neighbour Relation (ANR) function for UTRAN relieves operators from the burden of manually managing the Neighbour cell Relations (NRs) / Text3: UTRA
- 262: RP#50 completion 12/10=>03/11 / Text3: 25.331, 25.413, 25.423, new TS 25.484 (Stage 2)
- 263: Rel-9 Dual-Band Dual-Cell HSDPA (UID_430015 Support for different bands for Dual-Cell HSDPA) has one combination per region in principle. This work adds additional combinations: Band I and XI (Region 3) and Band II and V (Region 2) / Text3: UTRA
- 264: - / Text3: 25.101, 25.104, 25.141, 25.317
- 265: RP#49 stopped (Reason: no need for Perforance work) / Text3: 25.101, 25.104, 25.141, 25.317
- 266: RP#49 updated WID RP-100687=>RP-100993 (added Core WID, changed WID: Title MIMO Testing in HSDPA => MIMO operation with non-MIMO coexistence in HSDPA) / Text3: UTRA
- 267: RP#49 added Core WID / Text3: 25.104
- 268: RP#49 updated WID RP-100687=>RP-100993 (added Core WID, changed WID: Title MIMO Testing in HSDPA => MIMO operation with non-MIMO coexistence in HSDPA) / Text3: 25.101, 25.141
- 269: RP#50 completed / Text3: UTRA 25.133, 25.331
- 270: RP#48 updated WID RP-091440=>RP-100661. Triggered by FS_RAN_LTEA (Study on LTE-Advanced) 36.912, 36. 814 / Text3: LTE
- 271: RP#50 completion 12/10=>03/11. New Rapp: Asbjorn.grovlen@nokia.com=> / Text3: 36.101, 36.104, 36.133, 36.211, 36.212, 36.213, 36.300, 36.302, 36.306, 36.321, 36.331, 36.413, 36.423, 37.104
- 272: RP#50 TR 36.808 v1.0.0 for Information / Text3: 36.101, 36.104, 36.133, 36.141, 37.141, new TR (36.807, 36.808)
- 273: Triggered by FS_RAN_LTEA (Study on LTE-Advanced) 36.912, 36. 814 / Text3: LTE
- 274: RP#50 completion 12/10=>03/11 / Text3: 36.101, 36.104, 36.133, 36.201, 36.211, 36.212, 36.213, 36.300, 36.306, 36.321, 36.331
- 275: - / Text3: 36.101, 36.104, 36.133, 36.141
- 276: Triggered by FS_RAN_LTEA (Study on LTE-Advanced) 36.912, 36. 814 / Text3: LTE
- 277: RP#50 completion 12/10=>03/11 / Text3: 36.101, 36.104, 36.133, 36.201, 36.211, 36.212, 36.213, 36.300, 36.306, 36.321, 36.331, new RAN4 TR 36.817
- 278: - / Text3: 36.101, 36.104, 36.133, 36.141, 36.817
- 279: Add new power classes in E-UTRAN UL to allow CPE type applications to be operated at higher max output power / Text3: LTE
- 280: RP#49 completion 09/10=>03/11 / Text3: 36.101
- 281: RP#49 completion 12/10=>06/11 / Text3: 36.521-1
- 282: Triggered by FS_RAN_LTEA (Study on LTE-Advanced) 36.912, 36. 814. SA#50 Stage 2 exception granted until 03/2011 / Text3: LTE
- 283: RP#50 completion 12/10=>06/11. RP#50 updated WID RP-100953=>RP-101417 (added new RAN4 36.116, 36.826) / Text3: 36.133, 36.201, 36.211, 36.212, 36.213, 36.300, 36.321, 36.323, 36.331, new RAN1 TS 36.216, new RAN4 (36.116, 36.826)
- 284: RP#50 completion 03/11=>09/11. RP#50 updated WID RP-100953=>RP-101417 (added new TS 36.117) / Text3: 36.133, new TS 36.117 (E-UTRA Relay conformance testing)
- 285: SA#50 Stage 2 exception granted until 03/2011. LS_out to SA3 in SP-100874 / Text3: 33.816
- 286: SA#50 Stage 2 exception granted until 03/2011 (SA3 Stage 2 impacting Stage 3 in CT and RAN). LS_out to SA3 in SP-100874 / Text3: 33.401, CT1 24.301, RAN2 36.331, RAN3 36.413, CT4 29.272, CT6 31.102, RAN2 36.323, CT4 29.274

| ID | WBS | Task | Duration | Start | Finish | Complete | Remaining | Baseline start | Baseline finish | Baseline duration | Total slack | Constraint | Resources | Work | Actual work | Text1 | Text2 | Text4 | Text5 | Text6 | Text7 | Text8 | Text11 |
| --- | --- | --- | --- | --- | --- | --- | --- | --- | --- | --- | --- | --- | --- | --- | --- | --- | --- | --- | --- | --- | --- | --- | --- |
| 287 | 106 | **Enhanced Inter-Cell Interference Control (ICIC) for non-Carrier Aggregation (CA) based deployments of heterogeneous networks for LTE** | 326d? | 2010-03-19 A | 2011-06-17 | 44% | 181.08d? | 2010-03-19 | 2011-06-17 | 326d? | 390d |  | R1,R2,R3,R4 | 7304h | 3246.98h | eICIC_LTE | PCG-24 | China Mobile | Xiaodong XU (xuxiaodong@chinamobile.com) | Rel-10 | RP-47 | Patrick |  |
| 288 | 106.1 | Core part: Enhanced ICIC for non-CA based deployments of heterogeneous networks for LTE | 261d? | 2010-03-19 A | 2011-03-18 | 75% | 65.25d? | 2010-03-19 | 2011-03-18 | 261d? | 455d | finish no earlier than 2011-03-18 | R1,R2,R3,R4 | 2088h | 1566h | eICIC_LTE-Core | PCG-24 | China Mobile | Xiaodong XU (xuxiaodong@chinamobile.com) | Rel-10 | RP-47 | Patrick | RP-101400 |
| 289 | 106.2 | Perf. part: Enhanced ICIC for non-CA based deployments of heterogeneous networks for LTE | 326d? | 2010-03-19 A | 2011-06-17 | 20% | 260.8d? | 2010-03-19 | 2011-06-17 | 326d? | 390d | finish no earlier than 2011-06-17 | R4 | 2608h | 521.6h | eICIC_LTE-Perf | PCG-24 | China Mobile | Xiaodong XU (xuxiaodong@chinamobile.com) | Rel-10 | RP-47 | Issam | RP-101114 |
| 290 | 107 | **LTE TDD in 2600MHz for US** | 191d? | 2010-03-19 A | 2010-12-10 A | 100% |  | 2010-03-19 | 2010-12-10 | 191d? |  |  | R4,R2,R3,R5 | 4712h | 4712h | LTE_TDD_2600_US | PCG-24 | Clearwire | michael.hart@clearwire.com | Rel-10 | RP-47 | Issam |  |
| 291 | 107.1 | Core part: LTE TDD in 2600MHz for US | 131d? | 2010-03-19 A | 2010-09-17 A | 100% |  | 2010-03-19 | 2010-09-17 | 131d? |  | finish no earlier than 2010-09-17 | R4,R2,R3 | 1048h | 1048h | LTE_TDD_2600_US-Core | PCG-24 | Clearwire | michael.hart@clearwire.com | Rel-10 | RP-47 | Issam | RP-100782 |
| 292 | 107.2 | Perf. part: LTE TDD in 2600MHz for US | 131d? | 2010-03-19 A | 2010-09-17 A | 100% |  | 2010-03-19 | 2010-09-17 | 131d? |  | finish no earlier than 2010-09-17 | R4 | 1048h | 1048h | LTE_TDD_2600_US-Perf | PCG-24 | Clearwire | michael.hart@clearwire.com | Rel-10 | RP-47 | Issam | RP-100783 |
| 293 | 107.3 | UE conformance test part: LTE TDD in 2600MHz for US | 136d? | 2010-06-04 A | 2010-12-10 A | 100% |  | 2010-06-04 | 2010-12-10 | 136d? |  | finish no earlier than 2010-12-10 | R5 | 1088h | 1088h | LTE_TDD_2600_US-UEConTest | PCG-25 | Clearwire | michael.hart@clearwire.com | Rel-10 | RP-48 | Ingbert | RP-101071 |
| 294 | 108 | **Adding 2 GHz band LTE for Ancillary Terrestrial Component (ATC) of Mobile Satellite Service (MSS) in North America** | 326d? | 2010-03-19 A | 2011-06-17 | 41% | 191.93d? | 2010-03-19 | 2011-06-17 | 326d? | 390d |  | R2,R4 | 7304h | 2192h | S_Band_LTE_ATC_MSS | PCG-24 | TerreStar, DBSD (formerly ICO) | Rhys.Robinson@terrestar.com, Mariam.Sorond@ico.com | Rel-10 | RP-47 | Joern |  |
| 295 | 108.1 | Core part: Adding 2 GHz band LTE for ATC of MSS in North America | 261d? | 2010-03-19 A | 2011-03-18 | 80% | 52.2d? | 2010-03-19 | 2011-03-18 | 261d? | 455d | finish no earlier than 2011-03-18 | R4,R2 | 2088h | 1670.4h | S_Band_LTE_ATC_MSS-Core | PCG-24 | TerreStar, DBSD (formerly ICO) | Rhys.Robinson@terrestar.com, Mariam.Sorond@ico.com | Rel-10 | RP-47 | Issam | RP-101115 |
| 296 | 108.2 | Perf. part: Adding 2 GHz band LTE for ATC of MSS in North America | 326d? | 2010-03-19 A | 2011-06-17 | 10% | 293.4d? | 2010-03-19 | 2011-06-17 | 326d? | 390d | finish no earlier than 2011-06-17 | R4 | 2608h | 260.8h | S_Band_LTE_ATC_MSS-Perf | PCG-24 | TerreStar, DBSD (formerly ICO) | Rhys.Robinson@terrestar.com, Mariam.Sorond@ico.com | Rel-10 | RP-47 | Issam | RP-101116 |
| 297 | 109 | **Adding L-Band LTE for Ancillary Terrestrial Component (ATC) of Mobile Satellite Service (MSS) in North America** | 326d? | 2010-03-19 A | 2011-06-17 | 46% | 174.73d? | 2010-03-19 | 2011-06-17 | 326d? | 390d |  | R4,R2 | 6744h | 3129.37h | L_Band_LTE_ATC_MSS | PCG-24 | LightSquared | Eric.Jacks@lightsquared.com, Maqbool.Aliani@lightsquared.com | Rel-10 | RP-47 | Issam |  |
| 298 | 109.1 | Core part: Adding L-Band LTE for ATC of MSS in North America | 191d? | 2010-03-19 A | 2010-12-10 A | 100% |  | 2010-03-19 | 2010-12-10 | 191d? |  | finish no earlier than 2010-12-10 | R4,R2 | 1528h | 1528h | L_Band_LTE_ATC_MSS-Core | PCG-24 | LightSquared | Eric.Jacks@lightsquared.com, Maqbool.Aliani@lightsquared.com | Rel-10 | RP-47 | Issam | RP-101117 |
| 299 | 109.2 | Perf. part: Adding L-Band LTE for ATC of MSS in North America | 326d? | 2010-03-19 A | 2011-06-17 | 15% | 277.1d? | 2010-03-19 | 2011-06-17 | 326d? | 390d | finish no earlier than 2011-06-17 | R4 | 2608h | 391.2h | L_Band_LTE_ATC_MSS-Perf | PCG-24 | LightSquared | Eric.Jacks@lightsquared.com, Maqbool.Aliani@lightsquared.com | Rel-10 | RP-47 | Issam | RP-101118 |
| 300 | 110 | **LTE Self Optimizing Networks (SON) enhancements** | 261d? | 2010-03-19 A | 2011-03-18 | 80% | 52.2d? | 2010-03-19 | 2011-03-18 | 261d? | 455d |  | R3,R2,R4 | 4176h | 3340.8h | SONenh_LTE | PCG-24 | Nokia Siemens Networks | krzysztof.kordybach@nsn.com | Rel-10 | RP-47 | Juha |  |
| 301 | 110.1 | Core part: LTE Self Optimizing Networks (SON) enhancements | 261d? | 2010-03-19 A | 2011-03-18 | 80% | 52.2d? | 2010-03-19 | 2011-03-18 | 261d? | 455d | finish no earlier than 2011-03-18 | R3,R2,R4 | 2088h | 1670.4h | SONenh_LTE-Core | PCG-24 | Nokia Siemens Networks | krzysztof.kordybach@nsn.com | Rel-10 | RP-47 | Juha | RP-101119 |
| 302 | 111 | **LTE-Advanced Carrier Aggregation of Band 3 and Band 7** | 266d? | 2010-12-10 | 2011-12-16 |  |  | 2010-12-10 | 2011-12-16 | 266d? | 260d |  | R4 | 6384h |  | LTE_CA_B3_B7 | PCG-25 | TeliaSonera | Ralf.Schuh@TeliaSonera.com | Rel-10 | RP-48 | Issam |  |
| 303 | 111.1 | Core part: LTE-Advanced Carrier Aggregation of Band 3 and Band 7 | 266d? | 2010-12-10 | 2011-12-16 |  |  | 2010-12-10 | 2011-12-16 | 266d? | 260d | start no earlier than 2010-12-10 | R4 | 2128h |  | LTE_CA_B3_B7-Core | PCG-25 | TeliaSonera | Ralf.Schuh@TeliaSonera.com | Rel-10 | RP-48 | Issam | RP-101120 |
| 304 | 111.2 | Perf. part: LTE-Advanced Carrier Aggregation of Band 3 and Band 7 | 266d? | 2010-12-10 | 2011-12-16 |  |  | 2010-12-10 | 2011-12-16 | 266d? | 260d | start no earlier than 2010-12-10 | R4 | 2128h |  | LTE_CA_B3_B7-Perf | PCG-25 | TeliaSonera | Ralf.Schuh@TeliaSonera.com | Rel-10 | RP-48 | Issam | RP-101121 |
| 305 | 112 | **Service continuity in connected mode and location information for MBMS for LTE** | 271d? | 2010-06-04 | 2011-06-17 |  |  | 2010-06-04 | 2011-06-17 | 271d? | 390d |  | R2,R3 | 4336h |  | MBMS_LTE_SC | PCG-25 | Huawei | Zhao Junhui | Rel-10 | RP-48 | Joern |  |
| 306 | 112.1 | Core part: Service continuity in connected mode and location information for MBMS for LTE | 271d? | 2010-06-04 | 2011-06-17 |  |  | 2010-06-04 | 2011-06-17 | 271d? | 390d | finish no earlier than 2011-06-17 | R2,R3 | 2168h |  | MBMS_LTE_SC-Core | PCG-25 | Huawei | Zhao Junhui | Rel-10 | RP-48 | Joern | RP-101123 |
| 307 | 113 | **Further enhancements to MBMS for LTE** | 206d? | 2010-06-04 A | 2011-03-18 | 80% | 41.2d? | 2010-06-04 | 2011-03-18 | 206d? | 455d |  | R2,R3 | 3296h | 2636.8h | MBMS_LTE_enh | PCG-25 | Huawei | Zhao Junhui | Rel-10 | RP-48 | Joern |  |
| 308 | 113.1 | Core part: Further enhancements to MBMS for LTE | 206d? | 2010-06-04 A | 2011-03-18 | 80% | 41.2d? | 2010-06-04 | 2011-03-18 | 206d? | 455d | finish no earlier than 2011-03-18 | R2,R3 | 1648h | 1318.4h | MBMS_LTE_enh-Core | PCG-25 | Huawei | Zhao Junhui | Rel-10 | RP-48 | Joern | RP-101122 |
| 309 | 114 | **UMTS/LTE 3500 MHz** | 992d? | 2007-11-30 A | 2011-09-16 | 31% | 686.22d? | 2007-11-30 | 2011-09-16 | 992d? | 325d |  | R4,R2,R3,R5 | 23434h | 7223.45h | RInImp8-UMTSLTE3500 | PCG-21 | Ericsson | johan.skold@ericsson.com | Rel-10 | RP-38 | Issam |  |
| 310 | 114.1 | UMTS/LTE 3500 MHz | 850d? | 2007-11-30 A | 2011-03-18 | 75% | 212.5d? | 2007-11-30 | 2011-03-18 | 850d? | 455d | finish no earlier than 2011-03-18 | R4,R2,R3 | 6800h | 5100h | RInImp8-UMTSLTE3500 | PCG-21 | Ericsson | Jjohan.skold@ericsson.com | Rel-10 | RP-38 | Issam | RP-101094 |
| 311 | 114.2 | Conformance Test Aspects – LTE 3500 | 727d? | 2008-12-05 A | 2011-09-16 | 5% | 690.65d? | 2008-12-05 | 2011-09-16 | 727d? | 325d | finish no earlier than 2011-09-16 | R5 | 5816h | 290.8h | LTE-UEConTest_LTE3500 | PCG-22 | Ericsson | fredrik.sundstrom@ericsson.com | Rel-10 | RP-42 | Ingbert | RP-101065 |
| 312 | 114.3 | Conformance Test Aspects – UMTS 3500 | 727d? | 2008-12-05 A | 2011-09-16 | 5% | 690.65d? | 2008-12-05 | 2011-09-16 | 727d? | 325d | finish no earlier than 2011-09-16 | R5 | 5816h | 290.8h | RInImp-UEConTest_UMTS3500 | PCG-22 | Nokia | jukka.vikstedt@nokia.com | Rel-10 | RP-42 | Ingbert | RP-101066 |

Notes:
- 287: Stage 3 Triggered by FS_RAN_LTEA (Study on LTE-Advanced) 36.912, 36.814 / Text3: LTE
- 288: RP#49 completion 12/10=>03/11 / Text3: 36.101, 36.133, 36.201, 36.211, 36.212, 36.213, 36.214, 36.300, 36.321, 36.331, 36.413, 36.423
- 289: - / Text3: 36.101, 36.133
- 290: RP#50Testing completed. RP#49 Core+Perf completed. Stage 3. Updated WID RP-100694=>RP-101003 / Text3: LTE
- 291: RP#49 completed (TR 36.812 v1.0.0 for Approval). Updated WID RP-100694=>RP-101003 / Text3: 25.461, 25.466, 36.101, 36.104, 36.113, 36.124, 36.133, 36.141, 36.307, 36.331, 37.104, 37.113, 37.141, new TR 36.812
- 292: RP#49 completed (TR 36.812 v1.0.0 for Approval). Updated WID RP-100694=>RP-101003 / Text3: 36.101, 36.104, 36.133, 36.141, 36.307, 37.104, 37.141, new TR 36.812
- 293: RP#50 completed / Text3: 36.508, 36.521-1, 36.521-2, 36.521-3, 36.523-1, 36.523-2, 36.523-3
- 294: Stage 3 / Text3: LTE
- 295: RP#50 completion 12/10=>03/11. Updated WID RP-100376=>RP-101401. RP#49 TR 36.811v100 for information / Text3: 25.101, 25.104, 25.141, 25.461, 25.466, 36.101, 36.104, 36.113, 36.124, 36.133, 36.307, 37.104, 37.141, new TR 36.811
- 296: - / Text3: 36.101, 36.104, 36.113, 36.124, 36.133, 36.141, 36.307, new 36.811
- 297: RP#49 changed Skyterra => LightSquared / Text3: LTE
- 298: RP#50 completed (but WI is still open until Mar 2011/provide SR). Updated WID RP-100640=>RP-101284. TR 36.813 v200 for Approval / Text3: 25.101, 25.104, 25.141, 25.461, 25.466, 34.124, 36.101, 36.104, 36.113, 36.124, 36.133, 36.307, 37.104, 37.141, new RAN4 TR 36.813
- 299: RP#50 updated WID RP-100640=>RP-101284 / Text3: 34.121-1, 36.101, 36.104, 36.113, 36.124, 36.133, 36.141, 36.307, 36.521-1, 36.813
- 300: RP#50 completion 12/10=>03/11. Stage 1,2,3 / Text3: LTE
- 301: RP#50 completion 12/10=>03/11 / Text3: 36.300, 36.331, 36.413, 36.423
- 302: RP#49 Work start on hold until RP#50. In Europe Band 3, Band 7 and Band 20 are interesting for LTE and LTE-Advanced deployment. Different CA combinations for these bands are of high priority for Region 1. This work covers the Band 3 and Band 7 combination / Text3: LTE
- 303: RP#49 Work start on hold until RP#50 / Text3: 36.101, 36.104, 36.113, 36.124, 36.133, 36.141, 36.307, 36.331, new TR 36.cde (LTE-Advanced CA of Band 3 and Band 7 for DL/UL with 40 MHz/20 MHz)
- 304: RP#49 Work start on hold until RP#50 / Text3: 36.101, 36.104, 36.133, 36.307, new TR 36.cde (LTE-Advanced CA of Band 3 and Band 7 for DL/UL with 40 MHz/20 MHz)
- 305: RP#50 on hold until 03/11 / Text3: LTE
- 306: RP#50 on hold until 03/11 / Text3: 25.446, 36.300, 36.321, 36.322, 36.323, 36.331, 36.440, 36.441, 36.442, 36.443, 36.444, 36.445
- 307: RP#50 updated WID RP-100691=>RP-101244. SA2 decided not to support MBR>GBR in Rel-10 MBMS. For SA2, MBR=GBR in Rel-10 MBMS. Hence RAN removed enabling statistical multiplexing gains for variable bit rate services in Objectives / Text3: LTE
- 308: RP#50 completion 12/10=>03/11. Updated WID RP-100691=>RP-101244. SA2 decided not to support MBR>GBR in Rel-10 MBMS. For SA2, MBR=GBR in Rel-10 MBMS. Hence RAN removed enabling statistical multiplexing gains for variable bit rate services in Objectives / Text3: 25.446, 36.300, 36.321, 36.322, 36.323, 36.331, 36.440, 36.441, 36.442, 36.443, 36.444, 36.445
- 309: - / Text3: UTRA, LTE
- 310: RP#50 completion 12/10=>03/11 / Text3: 25.101, 25.104, 25.113, 25.133, 25.141, 25.307, 25.307, 25.331, 25.461, 25.463, 34.124, 36.101, 36.104, 36.113, 36.141, 36.331, new 37.801
- 311: RP#50 completion 12/10=>09/11 / Text3: 36.508, 36.521-1, 36.521-2, 36.521-3
- 312: RP#50 completion 12/10=>09/11 / Text3: 34.108, 34.121-1, 34.121-2

| ID | WBS | Task | Duration | Start | Finish | Complete | Remaining | Baseline start | Baseline finish | Baseline duration | Total slack | Constraint | Resources | Work | Actual work | Text1 | Text2 | Text4 | Text5 | Text6 | Text7 | Text8 | Text11 | Text9 | Text12 |
| --- | --- | --- | --- | --- | --- | --- | --- | --- | --- | --- | --- | --- | --- | --- | --- | --- | --- | --- | --- | --- | --- | --- | --- | --- | --- |
| 313 | 115 | **Minimization of Drive Tests for E-UTRAN and UTRAN** | 336d? | 2009-12-04 A | 2011-03-18 | 85% | 50.4d? | 2009-12-04 | 2011-03-18 | 336d? | 455d |  | R2,R4,R3 | 5376h | 4569.6h | MDT_UMTSLTE | PCG-24 | Nokia Siemens Networks | malgorzata.tomala@nsn.com | Rel-10 | RP-46 | Joern |  |  |  |
| 314 | 115.1 | Core part: Minimization of Drive Tests for E-UTRAN and UTRAN | 336d? | 2009-12-04 A | 2011-03-18 | 85% | 50.4d? | 2009-12-04 | 2011-03-18 | 336d? | 455d | finish no earlier than 2011-03-18 | R2,R4,R3 | 2688h | 2284.8h | MDT_UMTSLTE-Core | PCG-24 | Nokia Siemens Networks | malgorzata.tomala@nsn.com | Rel-10 | RP-46 | Joern | RP-101095 |  |  |
| 315 | 116 | **HNB and HeNB Mobility Enhancements** | 191d? | 2010-03-19 A | 2010-12-10 A | 100% |  | 2010-03-19 | 2010-12-10 | 191d? |  |  | R3,R2 | 3056h | 3056h | HNB_HENB_mob_enh | PCG-24 | Alcatel-Lucent | Martin,Warner@alcatel-lucent.com | Rel-10 | RP-47 | Juha |  |  |  |
| 316 | 116.1 | Core part: HNB and HeNB Mobility Enhancements | 191d? | 2010-03-19 A | 2010-12-10 A | 100% |  | 2010-03-19 | 2010-12-10 | 191d? |  | start no earlier than 2010-03-19 | R3,R2 | 1528h | 1528h | HNB_HENB_mob_enh-Core | PCG-24 | Alcatel-Lucent | Martin.Warner@alcatel-lucent.com | Rel-10 | RP-47 | Juha | RP-101096 |  |  |
| 317 | 117 | **Expanded 1900 MHz Band for UTRA and LTE** | 206d? | 2010-06-04 A | 2011-03-18 | 20% | 164.8d? | 2010-06-04 | 2011-03-18 | 206d? | 455d |  | R4,R2 | 4944h | 988.8h | E1900 | PCG-25 | Sprint | nick.j.baustert@sprint.com | Rel-10 | RP-48 | Issam |  |  |  |
| 318 | 117.1 | Core part: Expanded 1900 MHz Band for UTRA and LTE | 206d? | 2010-06-04 A | 2011-03-18 | 20% | 164.8d? | 2010-06-04 | 2011-03-18 | 206d? | 455d | finish no earlier than 2011-03-18 | R4,R2 | 1648h | 329.6h | E1900-Core | PCG-25 | Sprint | nick.j.baustert@sprint.com | Rel-10 | RP-48 | Issam | RP-101097 |  |  |
| 319 | 117.2 | Perf. part: Expanded 1900 MHz Band for UTRA and LTE | 206d? | 2010-06-04 A | 2011-03-18 | 20% | 164.8d? | 2010-06-04 | 2011-03-18 | 206d? | 455d | finish no earlier than 2011-03-18 | R4,R2 | 1648h | 329.6h | E1900-Perf | PCG-25 | Sprint | nick.j.baustert@sprint.com | Rel-10 | RP-48 | Issam | RP-101098 |  |  |
| 320 | 118 | **Multi-standard radio Base Station RF requirements for non-contiguous spectrum deployments** | 336d? | 2010-06-04 A | 2011-09-16 | 21% | 266.46d? | 2010-06-04 | 2011-09-16 | 336d? | 325d |  | R4,G1 | 9112h | 1885.94h | MSR_NC | PCG-25 | Ericsson | johan.skold@ericsson.com | Rel-10 | RP-48 | Issam |  |  |  |
| 321 | 118.1 | Core part: Multi-standard radio Base Station RF requirements for non-contiguous spectrum deployments | 206d? | 2010-06-04 A | 2011-03-18 | 30% | 144.2d? | 2010-06-04 | 2011-03-18 | 206d? | 455d | finish no earlier than 2011-03-18 | R4 | 1648h | 494.4h | MSR_NC-Core | PCG-25 | Ericsson | johan.skold@ericsson.com | Rel-10 | RP-48 | Issam | RP-101099 |  |  |
| 322 | 118.2 | Perf. part: Multi-standard radio Base Station RF requirements for non-contiguous spectrum deployments | 336d? | 2010-06-04 | 2011-09-16 |  |  | 2010-06-04 | 2011-09-16 | 336d? | 325d | finish no earlier than 2011-09-16 | R4 | 2688h |  | MSR_NC-Perf | PCG-25 | Ericsson | johan.skold@ericsson.com | Rel-10 | RP-48 | Issam | RP-101100 |  |  |
| 323 | 118.3 | GERAN part: Multi-standard radio Base Station RF requirements for non-contiguous spectrum deployments | 261d? | 2010-09-03 A | 2011-09-02 | 40% | 156.6d? | 2010-09-03 | 2011-09-02 | 261d? | 335d | finish no earlier than 2011-09-02 | G1 | 2088h | 835.2h | MSR_NC-GERAN | PCG-25 | Ericsson | mats.y.samuelsson@ericsson.com | Rel-10 | GP-47 | Paolo |  |  |  |
| 324 | 119 | **Extending 850 MHz Upper Band (814 – 849 MHz)** | 71d? | 2010-12-10 | 2011-03-18 |  |  | 2010-12-10 | 2011-03-18 | 71d? | 455d |  | R4,R2,R3 | 1704h |  | e850_UB | PCG-26 | Sprint | John.J.Humbert@Sprint.com | Rel-10 | RP-50 | Issam |  |  |  |
| 325 | 119.1 | Core part: Extending 850 MHz Upper Band (814 – 849 MHz) | 71d? | 2010-12-10 | 2011-03-18 |  |  | 2010-12-10 | 2011-03-18 | 71d? | 455d | finish no earlier than 2011-03-18 | R4,R2,R3 | 568h |  | e850_UB-Core | PCG-26 | Sprint | John.J.Humbert@Sprint.com | Rel-10 | RP-50 | Issam |  |  |  |
| 326 | 119.2 | Perf. part: Extending 850 MHz Upper Band (814 – 849 MHz) | 71d? | 2010-12-10 | 2011-03-18 |  |  | 2010-12-10 | 2011-03-18 | 71d? | 455d | finish no earlier than 2011-03-18 | R4,R2,R3 | 568h |  | e850_UB-Perf | PCG-26 | Sprint | John.J.Humbert@Sprint.com | Rel-10 | RP-50 | Issam |  |  |  |
| 327 | 120 | **Local Call Local Switch** | 1055.8d? | 2007-05-07 A | 2011-05-20 | 80% | 211.16d? | 2007-05-07 | 2011-05-20 | 1055.8d? | 410d |  | C4,GP,G2 | 13134.4h | 10507.5h | LCLS | PCG-22 | Huawei | wang_zhixi@huawei.com | Rel-10 | GP-41 | Paolo |  |  |  |
| 328 | 120.1 | Local Call Local Switch | 586d? | 2007-05-07 A | 2011-05-20 | 80% | 117.2d? | 2007-05-07 | 2011-05-20 | 586d? | 410d | finish no earlier than 2011-05-20 | GP,G2 | 4688h | 3750.4h | LCLS | PCG-22 | Huawei | wang_zhixi@huawei.com | Rel-10 | GP-41 | Paolo |  |  |  |
| 329 | 121 | **CN aspects of Local Call Local Switch** | 472d? | 2009-05-29 A | 2011-03-18 | 95% | 24.11d? | 2009-05-29 | 2011-03-18 | 472d? | 455d |  | C4 | 13008h | 11488.4h | LCLS-CN | PCG-23 | Vodafone | David Hutton | Rel-10 | CP-44 | Kimmo |  |  |  |
| 330 | 121.1 | TR on CN aspects of Local Call Local Switch | 341d? | 2009-05-29 A | 2010-09-17 A | 100% |  | 2009-05-29 | 2010-09-17 | 341d? |  | finish no earlier than 2010-09-17 | C4 | 2728h | 2728h | LCLS-CN | PCG-23 | Vodafone | David Hutton | Rel-10 | CP-44 | Kimmo |  |  |  |
| 331 | 121.2 | CN aspects of Local Call Local Switch | 131d? | 2010-09-17 A | 2011-03-18 | 55% | 58.95d? | 2010-09-17 | 2011-03-18 | 131d? | 455d | finish no earlier than 2011-03-18 | C4 | 1048h | 576.4h | LCLS-CN | PCG-25 | Vodafone | David Hutton | Rel-10 | CP-49 | Kimmo |  |  |  |
| 332 | 121.3 | Deleted - CT3 aspects of Local Call Local Switch | 341d? | 2009-05-29 A | 2010-09-17 A | 100% |  | 2009-05-29 | 2010-09-17 | 341d? |  | finish no earlier than 2010-09-17 | C3 | 2728h | 2728h | LCLS-CN | PCG-23 | Vodafone | David Hutton | Rel-10 | CP-44 | Gwiho |  | PCG-25 | CP-49 |
| 333 | 121.4 | Deleted - CT1 aspects of Local Call Local Switch | 341d? | 2009-05-29 A | 2010-09-17 A | 100% |  | 2009-05-29 | 2010-09-17 | 341d? |  | finish no earlier than 2010-09-17 | C1 | 2728h | 2728h | LCLS-CN | PCG-23 | Vodafone | David Hutton | Rel-10 | CP-44 | Frederic |  | PCG-25 | CP-49 |
| 334 | 122 | **Tightened Link Level Performance Requirements for Single Antenna MS** | 261d? | 2010-09-03 A | 2011-09-02 | 7% | 241.76d? | 2010-09-03 | 2011-09-02 | 261d? | 335d |  | G1,G2,C1,G3new | 6352h | 468.36h | TIGHTER | PCG-25 | Nokia | Carsten.Juncker@nokia.com | Rel-10 | GP-46 | Paolo |  |  |  |
| 335 | 122.1 | CT1 part for TIGHTER | 141d? | 2010-09-03 | 2011-03-18 |  |  | 2010-09-03 | 2011-03-18 | 141d? | 455d | finish no earlier than 2011-03-18 | C1 | 1128h |  | TIGHTER | PCG-25 | Nokia | Carsten.Juncker@nokia.com | Rel-10 | GP-46 | Frederic |  |  |  |
| 336 | 122.2 | TIGHTER Performance Requirements | 131d? | 2010-09-03 A | 2011-03-04 | 30% | 91.7d? | 2010-09-03 | 2011-03-04 | 131d? | 465d | finish no earlier than 2011-03-04 | G1,G2 | 1048h | 314.4h | TIGHTER | PCG-25 | Nokia | Carsten.Juncker@nokia.com | Rel-10 | GP-46 | Paolo |  |  |  |
| 337 | 122.3 | TIGHTER Testing | 261d? | 2010-09-03 | 2011-09-02 |  |  | 2010-09-03 | 2011-09-02 | 261d? | 335d | finish no earlier than 2011-09-02 | G3new,G1,G2 | 2088h |  | TIGHTER | PCG-25 | Nokia | Carsten.Juncker@nokia.com, Shrihari.Varadaraju@nokia.com | Rel-10 | GP-46 | Ingbert |  |  |  |

Notes:
- 313: Triggered by UID_430021 TR 36.805 (Study on Minimization of drive-tests in NGN) / Text3: UTRA, LTE
- 314: RP#50 completion 12/10=>03/11. RP#49 Stage 2 TS 37.320 v200 for Approval / Text3: 25.133, 25.215, 25.304, 25.331, 25.423, 36.133, 36.214, 36.300, 36.304, 36.331, 36.413, 36.423, new 37.320 (Stage 2)
- 315: RP#50 completed. Updated WID RP-100874=>RP-101426. Common UTRA and E-UTRA Work Item to ensure that divergence between the systems is minimized / Text3: UTRA, LTE
- 316: RP#50 completed. Updated WID RP-100874=>RP-101426 (UMTS Changes: New protocol TS needed for direct interface solution. CELL_FACH support removed/postponed to Rel-11. LTE Changes: eNB- HeNB mobility, Inter-CSG mobility removed/postponed to Rel-11) / Text3: 25.413, 25.467, 25.469, 36.300, 36.413, 36.423, new 25.471
- 317: RP#50 completion 12/10=>03/11. Create a new band that expands UTRA and E-UTRA band 2 to include frequencies between 1910 1915 MHz and 1990-1995 MHz (US FCC allocation) / Text3: UTRA, LTE
- 318: RP#50 completion 12/10=>03/11 / Text3: 25.101, 25.104, 25.113, 25.133, 25.141, 25.461, 25.466, 36.101, 36.104, 36.113, 36.124, 36.133, 36.141, 36.307, 36.331, new TR 36.8xy (Expanding 1900MHz Technical report)
- 319: RP#50 completion 12/10=>03/11 / Text3: 25.101, 25.104, 25.113, 25.133, 25.141, 25.461, 25.466, 36.101, 36.104, 36.113, 36.124, 36.133, 36.141, 36.307, 36.331, new TR 36.8xy (Expanding 1900MHz Technical report)
- 320: RP#50 updated WID RP-100960=>RP-101402 (Ensure: no modification on MSR contiguous allocation performance, avoid unnecessary add-ons for non-contiguous allocation) / Text3: UTRA, LTE, GERA
- 321: RP#50 updated WID RP-100960=>RP-101402 (Ensure: no modification on MSR contiguous allocation performance, avoid unnecessary add-ons for non-contiguous allocation) / Text3: 25.104, 36.104, 37.104, new TR 37.802
- 322: RP#50 updated WID RP-100960=>RP-101402 (Ensure: no modification on MSR contiguous allocation performance, avoid unnecessary add-ons for non-contiguous allocation) / Text3: 25.141, 36.141, 37.141, 37.802
- 323: GP#47 approved WID / Text3: 45.005, 51.021
- 324: Stage 3 Triggered by R4 Rel-10 LTE TR 37.806 Study on Extending 850 MHz (UID_440016) / Text3: UTRA
- 325: - / Text3: 25.101, 25.104, 25.113, 25.133, 25.141, 25.461, 25.466, 36.101, 36.104, 36.113, 36.124, 36.133, 36.141, 36.307, 36.331, 37.104, 37.113, 37.141
- 326: - / Text3: 25.101, 25.104, 25.113, 25.133, 25.141, 25.461, 25.466, 36.101, 36.104, 36.124, 36.133, 36.141, 36.307, 36.331, 37.104, 37.113, 37.141
- 327: CP#50 updated WID CP-100470=>CP-100867. GP#48 updated WID GP-090457=>GP-101989 / Text3: GERA Stage 2/3
- 328: GP#48 completion 03/11=>05/11. Updated WID GP-090457=>GP-101989. GP#41 WID approved / Text3: Stage 3: 48.008, 48.103
- 329: CP#50 updated WID CP-100470=>CP-100867 / Text3: Stage 2/3
- 330: CT#49 completed / Text3: new TR 23.889
- 331: CP#50 updated WID CP-100470=>CP-100867. Stage 2 TS 23.284 v100 for Information / Text3: 23.003, 23.205, 23.231, 29.002, 29.205, 29.232, new TS 23.284
- 332: CP#49 stopped. Result of study TR 23.889: no CT3 specification impact
- 333: CP#49 stopped. Result of study TR 23.889: no CT1 specification impact
- 334: GP#46 approved WID. Tighten single antenna MS link level performance reqs by at least 2dB for all relevant GSM services (Speech, AMR-NB GMSK, AMR-WB GMSK, GPRS, EGPRS, and EGPRS2, thereby improving the spectral efficiency) / Text3: GERA
- 335: - / Text3: 24.008
- 336: - / Text3: 45.005, 45.015
- 337: - / Text3: 51.010

| ID | WBS | Task | Duration | Start | Finish | Complete | Remaining | Baseline start | Baseline finish | Baseline duration | Total slack | Constraint | Resources | Work | Actual work | Text1 | Text2 | Text3 | Text4 | Text6 | Text7 | Text8 | Text11 | Text9 | Text12 |
| --- | --- | --- | --- | --- | --- | --- | --- | --- | --- | --- | --- | --- | --- | --- | --- | --- | --- | --- | --- | --- | --- | --- | --- | --- | --- |
| 338 | 123 | **Support of Multi-Operator Core Network by GERAN** | 206d? | 2010-05-21 A | 2011-03-04 | 98% | 3.23d? | 2010-05-21 | 2011-03-04 | 206d? | 465d |  | G2,S2,C1 | 5096h | 5016.19h | MOCN-GERAN | PCG-25 | GERA | Alcatel-Lucent | Rel-10 | GP-47 | Gert |  |  |  |
| 339 | 123.1 | Stage 2 for Support of Multi-Operator Core Network by GERAN | 150d? | 2010-05-21 A | 2010-12-16 A | 100% |  | 2010-05-21 | 2010-12-16 | 150d? |  | finish no earlier than 2010-12-15 | S2 | 1200h | 1200h | MOCN-GERAN | PCG-25 | 23.251 | Alcatel-Lucent | Rel-10 | GP-47 | Maurice |  |  |  |
| 340 | 123.2 | CT1 part of Stage 3 for Support of Multi-Operator Core Network by GERAN | 146d? | 2010-05-21 A | 2010-12-10 A | 100% |  | 2010-05-21 | 2010-12-10 | 146d? |  | finish no earlier than 2010-12-10 | C1 | 1168h | 1168h | MOCN-GERAN | PCG-25 | 24.008 | Alcatel-Lucent | Rel-10 | GP-47 | Frederic |  |  |  |
| 341 | 123.3 | GERAN2 part of Stage 3 for Support of Multi-Operator Core Network by GERAN | 135d? | 2010-08-30 A | 2011-03-04 | 95% | 6.75d? | 2010-08-30 | 2011-03-04 | 135d? | 465d | finish no earlier than 2011-03-04 | G2 | 1080h | 1026h | MOCN-GERAN | PCG-25 | 48.008, 48.018 | Alcatel-Lucent | Rel-10 | GP-47 | Gert |  |  |  |
| 342 | 124 | **Enhancements of Iur-g interface** | 206d? | 2010-09-03 A | 2011-06-17 | 31% | 142.49d? | 2010-09-03 | 2011-06-17 | 206d? | 390d |  | G2,R3 | 4344h | 1339.29h | eIurg | PCG-25 | GERA,UTRA | China Mobile, ZTE | Rel-10 | GP-47 | Gert |  |  |  |
| 343 | 124.1 | GERAN part for Enhancements of Iur-g interface (Stage 2/3) | 131d? | 2010-09-03 A | 2011-03-04 | 40% | 78.6d? | 2010-09-03 | 2011-03-04 | 131d? | 465d | finish no earlier than 2011-03-04 | G2 | 1048h | 419.2h | eIurg-GERAN | PCG-25 | 43.130, 48.008 | China Mobile, ZTE | Rel-10 | GP-47 | Gert |  |  |  |
| 344 | 124.2 | Core part: Enhancements of Iur-g interface (Stage 2/3) | 206d? | 2010-09-03 A | 2011-06-17 | 25% | 154.5d? | 2010-09-03 | 2011-06-17 | 206d? | 390d | finish no earlier than 2011-06-17 | R3 | 1648h | 412h | eIurg-RAN | PCG-25 | UTRA Stage 2 (25.401, 25.420), Stage 3 (25.423) | ZTE | Rel-10 | RP-49 | Juha | RP-101092 |  |  |
| 345 | 125 | (Small) Technical Enhancements and Improvements for Rel-10 | 466d? | 2009-06-04 A | 2011-03-17 | 60% | 186.4d? | 2009-06-04 | 2011-03-17 | 466d? | 456d | finish no earlier than 2011-03-17 | All | 3728h | 2236.8h | TEI10 | PCG-23 |  |  | Rel-10 | SP-44 |  |  |  |  |
| 346 | 126 | **Deleted - Registration in Densely-populated area (RED)** | 665d? | 2007-03-12 A | 2009-09-24 A | 100% |  | 2007-03-12 | 2009-09-24 | 665d? |  |  | S1 | 9544h | 9544h | RED |  | WID identifies also impacted CT1 24.008, RAN2 25.331 | NTT DoCoMo | Rel-10 | SP-35 | Alain |  | PCG-24 | SP-46 |
| 347 | 126.1 | Deleted - Stage 1 for RED | 4d? | 2007-03-12 A | 2007-03-15 A | 100% |  | 2007-03-12 | 2007-03-15 | 4d? |  | start no earlier than 2007-03-12 | S1 | 32h | 32h | RED |  | 22.101 CR#0207 | NTT DoCoMo | Rel-10 | SP-35 | Alain |  | PCG-24 | SP-46 |
| 348 | 126.2 | Deleted - Stage 2 for RED | 524d? | 2007-09-25 A | 2009-09-24 A | 100% |  | 2007-09-25 | 2009-09-24 | 524d? |  | finish no earlier than 2009-09-24 | S2 | 4192h | 4192h | RED |  | draft TR 23.880 withdrawn, 23.002, 23.060, 23.221, 23.236 | NTT DoCoMo | Rel-10 | SP-37 | Maurice |  | PCG-23 | SP-45 |
| 349 | 127 | **Deleted - Network Selection for non-3GPP Access** | 471d? | 2007-12-07 A | 2009-09-24 A | 100% |  | 2007-12-07 | 2009-09-24 | 471d? |  |  | S1,C6 | 10452.8h | 10452.8h | N3GtoNSP | PCG-21 |  | Telefonica O2 | Rel-10 | SP-38 | Alain |  | PCG-23 | SP-45 |
| 350 | 127.1 | Deleted - Stage 1 for N3GtoNSP | 471d? | 2007-12-07 A | 2009-09-24 A | 100% |  | 2007-12-07 | 2009-09-24 | 471d? |  | finish no earlier than 2009-12-10 | S1 | 3768h | 3768h | N3GtoNSP | PCG-21 | 22.011 | Telefonica O2 | Rel-10 | SP-38 | Alain |  | PCG-23 | SP-45 |
| 351 | 127.2 | Deleted - CT6 issues for N3GtoNSP | 471d? | 2007-12-07 A | 2009-09-24 A | 100% |  | 2007-12-07 | 2009-09-24 | 471d? |  | finish no earlier than 2009-12-04 | C6 | 3768h | 3768h | N3GtoNSP | PCG-21 | 36.300 | Telefonica O2 | Rel-10 | CP-38 | Xavier |  | PCG-23 | CP-45 |
| 352 | 128 | **Deleted - GTP-based S8 chaining** | 337d? | 2008-12-11 A | 2010-03-25 A | 100% |  | 2008-12-11 | 2010-03-25 | 337d? |  |  | S2 | 5392h | 5392h | GTPchaining | PCG-22 |  | Huawei | Rel-10 | SP-42 | Maurice |  | PCG-24 | SP-47 |
| 353 | 128.1 | Deleted - Stage 2 for GTPchaining | 337d? | 2008-12-11 A | 2010-03-25 A | 100% |  | 2008-12-11 | 2010-03-25 | 337d? |  | finish no earlier than 2010-03-25 | S2 | 2696h | 2696h | GTPchaining | PCG-22 | 23.402 | Huawei | Rel-10 | SP-42 | Maurice |  | PCG-24 | SP-47 |
| 354 | 129 | Deleted - UTRAN 2 ms TTI uplink range improvement | 272d? | 2009-03-06 A | 2010-03-19 A | 100% |  | 2009-03-06 | 2010-03-19 | 272d? |  | finish no earlier than 2010-03-19 | R1,R2,R3,R4 | 2176h | 2176h | RANimp-2mTTI_ULimp | PCG-22 | 25.133, 25.212, 25.214, 25.321, 25.331 | Nokia Siemens Networks | Rel-10 | RP-43 | Patrick | RP-100040 | PCG-24 | RP-47 |
| 355 | 130 | Deleted - Enhanced Home NodeB / eNodeB continuation of Rel-9 | 337d? | 2008-12-11 A | 2010-03-25 A | 100% |  | 2008-12-11 | 2010-03-25 | 337d? |  |  | S2 | 2696h | 2696h | eEHNB | PCG-23 |  | Alcatel-Lucent | Rel-10 | SP-44 | Maurice |  | PCG-24 | SP-47 |
| 356 | 131 | **Deleted - Enhanced Interference Management for Home NodeBs** | 131d? | 2010-03-19 A | 2010-09-17 A | 100% |  | 2010-03-19 | 2010-09-17 | 131d? |  |  | R3 | 2096h | 2096h | HNB_IM | PCG-24 | UTRA | Qualcomm | Rel-10 | RP-47 | Juha | RP-100754 | PCG-25 | RP-49 |
| 357 | 131.1 | Deleted - Core part: Enhanced Interference Management for Home NodeBs | 131d? | 2010-03-19 A | 2010-09-17 A | 100% |  | 2010-03-19 | 2010-09-17 | 131d? |  | finish no earlier than 2010-09-17 | R3 | 1048h | 1048h | HNB_IM-Core | PCG-24 | 25.413, 25.467, 25.469 | Qualcomm | Rel-10 | RP-47 | Juha | RP-100754 | PCG-25 | RP-49 |
| 358 | 132 | **Deleted - Latency reductions for LTE** | 266d? | 2009-12-04 A | 2010-12-10 A | 100% |  | 2009-12-04 | 2010-12-10 | 266d? |  |  | R2,R1 | 4256h | 4256h | LTE_LATRED | PCG-24 | LTE | Ericsson | Rel-10 | RP-46 | Joern |  | PCG-26 | RP-50 |
| 359 | 132.1 | Deleted - Core part: Latency reductions for LTE | 266d? | 2009-12-04 A | 2010-12-10 A | 100% |  | 2009-12-04 | 2010-12-10 | 266d? |  | finish no earlier than 2010-12-10 | R2,R1 | 2128h | 2128h | LTE_LATRED-Core | PCG-24 | 36.213, 36.300, 36.306, 36.321, 36.331 | Ericsson | Rel-10 | RP-46 | Joern | RP-101112 | PCG-26 | RP-50 |
| 360 | 133 | Release 10 Studies | 531d? | 2009-03-12 A | 2011-03-23 | 80% | 106.2d? | 2009-03-12 | 2011-03-23 | 531d? | 452d | finish no earlier than 2011-03-23 | CP,GP,RP,SP | 4248h | 3398.4h |  |  |  |  | Rel-10 |  |  |  |  |  |
| 361 | 134 | **Study on enhanced voice service requirements for the Evolved Packet System (EPS)** | 670d? | 2007-09-03 A | 2010-03-25 A | 100% |  | 2007-09-03 | 2010-03-25 | 670d? |  |  | S1,S4 | 13384h | 13384h | FS_EV_EPS |  | 22.813 | France Telecom | Rel-10 | SP-37 | Alain |  |  |  |
| 362 | 134.1 | Use cases definition and service and system requirements | 334d? | 2007-09-03 A | 2008-12-11 A | 100% |  | 2007-09-03 | 2008-12-11 | 334d? |  | finish no earlier than 2008-12-11 | S1 | 2672h | 2672h | FS_EV_EPS-S1 |  | 22.813 | France Telecom | Rel-10 | SP-37 | Alain |  |  |  |
| 363 | 134.2 | Codec specific part of FS_EV_EPS | 669d? | 2007-09-03 A | 2010-03-25 A | 100% |  | 2007-09-03 | 2010-03-25 | 669d? |  | finish no earlier than 2010-03-25 | S4 | 5352h | 5352h | FS_EV_EPS-S4 |  | 22.813 | Ericsson | Rel-10 | SP-37 | Paolo |  |  |  |
| 364 | 135 | Study on advanced requirements for IP interconnect | 528d? | 2007-12-04 A | 2009-12-10 A | 100% |  | 2007-12-04 | 2009-12-10 | 528d? |  | finish no earlier than 2009-12-10 | S1 | 4224h | 4224h | FS_IPXS | PCG-21 | 22.893 | Telefonica O2 | Rel-10 | SP-38 | Alain |  |  |  |
| 365 | 136 | Study on Personal Broadcast Service | 397d? | 2008-09-18 A | 2010-03-25 A | 100% |  | 2008-09-18 | 2010-03-25 | 397d? |  | finish no earlier than 2010-03-25 | S1 | 3168h | 3168h | FS_PBS | PCG-21 | 22.947 | ETRI | Rel-10 | SP-41 | Alain |  |  |  |
| 366 | 137 | Study on LCS support in SAE for non-3GPP accesses | 397d? | 2008-09-18 A | 2010-03-25 A | 100% |  | 2008-09-18 | 2010-03-25 | 397d? |  | finish no earlier than 2010-03-25 | S1 | 3168h | 3168h | FS_LCS_n3GPP | PCG-21 | 22.814 | SK Telecom | Rel-10 | SP-41 | Alain |  |  |  |
| 367 | 138 | Study on Haptic Services | 272d? | 2009-03-12 A | 2010-03-25 A | 100% |  | 2009-03-12 | 2010-03-25 | 272d? |  | finish no earlier than 2010-03-25 | S1 | 2168h | 2168h | FS_Haptics | PCG-22 | 22.987 | SK Telecom | Rel-10 | SP-43 | Alain |  |  |  |
| 368 | 139 | Study on System enhancements for the use of IMS services in Local BreakOut and Optimal Routing of Media | 575d? | 2007-10-01 A | 2009-12-10 A | 100% |  | 2007-10-01 | 2009-12-10 | 575d? |  | finish no earlier than 2009-12-10 | S2 | 4600h | 4600h | FS_IMS_LBO_ORM |  | 23.894 | Telecom Italia, BT | Rel-10 | SP-37 | Maurice |  |  |  |
| 369 | 140 | Study on Intra Domain Connection of RAN Nodes to Multiple CN Nodes | 533d? | 2008-03-12 A | 2010-03-25 A | 100% |  | 2008-03-12 | 2010-03-25 | 533d? |  | finish no earlier than 2010-03-25 | S2 | 4264h | 4264h | FS_IDC | PCG-21 | 23.924 (was 23.823) | China Mobile | Rel-10 | SP-39 | Maurice |  |  |  |
| 370 | 141 | Study on IMS Evolution | 656d? | 2008-09-18 A | 2011-03-23 | 80% | 131.2d? | 2008-09-18 | 2011-03-23 | 656d? | 452d | finish no earlier than 2011-03-23 | S2 | 5248h | 4198.4h | FS_eIMS | PCG-21 | 23.812 | China Mobile | Rel-10 | SP-41 | Maurice |  |  |  |
| 371 | 142 | Study on Multi Access PDN connectivity and IP flow Mobility | 656d? | 2008-09-18 A | 2011-03-23 | 75% | 164d? | 2008-09-18 | 2011-03-23 | 656d? | 452d | finish no earlier than 2011-03-23 | S2,S1 | 5248h | 3936h | FS_MAPIM | PCG-21 | 23.861 | Qualcomm | Rel-10 | SP-41 | Maurice |  |  |  |
| 372 | 143 | Study on Policy solutions and enhancements | 470d? | 2009-06-04 A | 2011-03-23 | 75% | 117.5d? | 2009-06-04 | 2011-03-23 | 470d? | 452d | finish no earlier than 2011-03-23 | S2,S1 | 3760h | 2820h | FS_PP | PCG-23 | 23.813 | AT&T | Rel-10 | SP-44 | Maurice |  |  |  |
| 373 | 144 | Study on IPv6 Migration | 470d? | 2009-06-04 A | 2011-03-23 | 80% | 94d? | 2009-06-04 | 2011-03-23 | 470d? | 452d | finish no earlier than 2011-03-23 | S2 | 3760h | 3008h | FS_IP6M | PCG-23 | 23.975 | China Mobile | Rel-10 | SP-44 | Maurice |  |  |  |
| 374 | 145 | Study on Single Radio Voice Call Continuity enhancements | 341d? | 2009-06-04 A | 2010-09-23 A | 100% |  | 2009-06-04 | 2010-09-23 | 341d? |  | finish no earlier than 2010-09-23 | S2 | 2728h | 2728h | FS_eSRVCC | PCG-23 | 23.856 | China Mobile | Rel-10 | SP-44 | Maurice |  |  |  |
| 375 | 146 | Study on Single Radio Voice Call Continuity from UTRAN/GERAN to E-UTRAN/HSPA | 335d? | 2009-12-10 A | 2011-03-23 | 70% | 100.5d? | 2009-12-10 | 2011-03-23 | 335d? | 452d | finish no earlier than 2011-03-23 | S2 | 2680h | 1876h | FS_rSRVCC | PCG-24 | 23.885 | Orange | Rel-10 | SP-46 | Maurice |  |  |  |
| 376 | 147 | Study on Single Radio Video Call Continuity for 3G-CS | 131d? | 2010-03-25 A | 2010-09-23 A | 100% |  | 2010-03-25 | 2010-09-23 | 131d? |  | finish no earlier than 2010-09-23 | S2 | 1048h | 1048h | FS_vSRVCC | PCG-24 | 23.886 | Samsung | Rel-10 | SP-47 | Maurice |  |  |  |
| 377 | 148 | Study on S2b Mobility based on GTP | 56d? | 2010-03-25 A | 2010-06-10 A | 100% |  | 2010-03-25 | 2010-06-10 | 56d? |  | finish no earlier than 2010-06-07 | S2 | 448h | 448h | FS_SMOG | PCG-24 | 23.834 | Alcatel-Lucent | Rel-10 | SP-47 | Maurice |  |  |  |
| 378 | 149 | Study on UTRAN key management enhancements | 851d? | 2007-12-20 A | 2011-03-23 | 80% | 170.2d? | 2007-12-20 | 2011-03-23 | 851d? | 452d | finish no earlier than 2011-03-23 | S3 | 6808h | 5446.4h | FS_UKM | PCG-21 | 33.859 | Ericsson | Rel-10 | SP-38 | Dionisio |  |  |  |
| 379 | 150 | Study on Extended IMS Media Plane Security features | 205d? | 2010-06-10 A | 2011-03-23 | 40% | 123d? | 2010-06-10 | 2011-03-23 | 205d? | 452d | finish no earlier than 2011-03-23 | S3 | 1640h | 656h | FS_eMEDIASEC | PCG-25 | 33.8xy | Vodafone | Rel-10 | SP-48 | Dionisio |  |  |  |
| 380 | 151 | Study on Single Sign On (SSO) Application Security for IMS - based on SIP Digest | 205d? | 2010-06-10 A | 2011-03-23 | 50% | 102.5d? | 2010-06-10 | 2011-03-23 | 205d? | 452d | finish no earlier than 2011-03-23 | S3 | 1640h | 820h | FS_SSO_APS | PCG-25 | 33.914 | Nokia | Rel-10 | SP-48 | Dionisio |  |  |  |
| 381 | 152 | Study on Surround Sound codec extension for PSS and MBMS | 530d? | 2009-03-12 A | 2011-03-23 | 85% | 78.65d? | 2009-03-12 | 2011-03-23 | 530d? | 452d | finish no earlier than 2011-03-23 | S4 | 4240h | 3610.8h | FS_SS_PSS_MBMS | PCG-22 | 26.950 | Fraunhofer Gesellschaft | Rel-10 | SP-43 | Paolo |  |  |  |
| 382 | 153 | Study on Improved Video Coding Support | 205d? | 2010-06-10 A | 2011-03-23 | 50% | 102.5d? | 2010-06-10 | 2011-03-23 | 205d? | 452d | finish no earlier than 2011-03-23 | S4 | 1640h | 820h | FS_IVCS | PCG-25 | 26.904 | Nokia, ETRI | Rel-10 | SP-48 | Paolo |  |  |  |
| 383 | 154 | Study on Rc Reference Point Functionalities and Message Flows | 397d? | 2008-09-18 A | 2010-03-25 A | 100% |  | 2008-09-18 | 2010-03-25 | 397d? |  | finish no earlier than 2010-03-23 | S5 | 3170.08h | 3170.08h | FS_OAM_Rc | PCG-21 | 32.825 | Huawei | Rel-10 | SP-41 | Dionisio |  |  |  |
| 384 | 155 | Study on Telecommunication Management; Energy Savings Management | 271d? | 2009-03-12 A | 2010-03-25 A | 100% |  | 2009-03-12 | 2010-03-25 | 271d? |  | finish no earlier than 2010-03-25 | S5 | 2168h | 2168h | FS_OAM_ESM | PCG-22 | 32.826 | Orange, Vodafone | Rel-10 | SP-43 | Dionisio |  |  |  |
| 385 | 156 | Study on Integration of Device Management Information with Itf-N | 211d? | 2009-06-04 A | 2010-03-25 A | 100% |  | 2009-06-04 | 2010-03-25 | 211d? |  | finish no earlier than 2010-03-25 | S5 | 1688h | 1688h | FS_IDMI_Itf-N | PCG-23 | 32.827 | Motorola | Rel-10 | SP-44 | Dionisio |  |  |  |
| 386 | 157 | Study on Alignment of 3GPP Generic NRM IRP and TMF Shared Information Data (SID) model | 335d? | 2009-12-10 A | 2011-03-23 | 85% | 50.25d? | 2009-12-10 | 2011-03-23 | 335d? | 452d | finish no earlier than 2011-03-23 | S5 | 2680h | 2278h | FS_3GNRM_TMFSID | PCG-24 | 32.828 | Nokia Siemens Networks | Rel-10 | SP-46 | Dionisio | S5-103054 |  |  |
| 387 | 158 | Study on Harmonization of 3GPP Alarm IRP and TMF Interface Program (TIP) Fault Management | 335d? | 2009-12-10 A | 2011-03-23 | 81% | 63.65d? | 2009-12-10 | 2011-03-23 | 335d? | 452d | finish no earlier than 2011-03-23 | S5 | 2680h | 2170.8h | FS_3G_TMF_FM | PCG-24 | 32.829 | Nokia Siemens Networks, Alcatel-Lucent | Rel-10 | SP-46 | Dionisio | S5-103055r1 |  |  |
| 388 | 159 | Study on version handling | 260d? | 2010-03-25 A | 2011-03-23 | 55% | 117d? | 2010-03-25 | 2011-03-23 | 260d? | 452d | finish no earlier than 2011-03-23 | S5 | 2080h | 1144h | FS_OAM_VH | PCG-24 | 32.830 | Ericsson | Rel-10 | SP-47 | Dionisio | S5-103056 |  |  |
| 389 | 160 | Study on Alarm Correlation and Alarm Root Cause Analysis | 205d? | 2010-06-10 A | 2011-03-23 | 55% | 92.25d? | 2010-06-10 | 2011-03-23 | 205d? | 452d | finish no earlier than 2011-03-23 | S5 | 1640h | 902h | FS_AC_ARCA | PCG-25 | 32.832 | Ericsson | Rel-10 | SP-48 | Dionisio | S5-103057 |  |  |
| 390 | 161 | Study on Alignment of 3GPP PM IRP and TMF Interface Program (TIP) PM | 205d? | 2010-06-10 A | 2011-03-23 | 5% | 194.75d? | 2010-06-10 | 2011-03-23 | 205d? | 452d | finish no earlier than 2011-03-23 | S5 | 1640h | 82h | FS_3G_TMF_PM | PCG-25 | 32.831 | Alcatel-Lucent | Rel-10 | SP-48 | Dionisio |  |  |  |
| 391 | 162 | Study on Management of Converged Networks | 205d? | 2010-06-10 A | 2011-03-23 | 15% | 174.25d? | 2010-06-10 | 2011-03-23 | 205d? | 452d | finish no earlier than 2011-03-23 | S5 | 1640h | 246h | FS_ManCon | PCG-25 | 32.833 | Nokia Siemens Networks | Rel-10 | SP-48 | Dionisio | S5-103059 |  |  |
| 392 | 163 | Study on User Data Convergence (UDC) information model handling and provisioning: Example Use Cases | 130d? | 2010-09-23 | 2011-03-23 |  |  | 2010-09-23 | 2011-03-23 | 130d? | 452d | finish no earlier than 2011-03-23 | S5 | 1040h |  | FS_UDC_AppUseCase | PCG-25 | 32.9xy | Alcatel-Lucent | Rel-10 | SP-49 | Dionisio |  |  |  |
| 393 | 164 | Study on Policy and Charging Rules Function (PCRF) failure and restoration | 261d? | 2009-08-18 A | 2010-09-17 A | 100% |  | 2009-08-18 | 2010-09-17 | 261d? |  | finish no earlier than 2010-09-17 | C3 | 2088h | 2088h | FS_PCRF-FR | PCG-23 | 29.816 | NEC | Rel-10 | CP-45 | Gwiho |  |  |  |
| 394 | 165 | Study on impacts on UE-Core Network signalling from Energy Saving | 206d? | 2010-06-04 A | 2011-03-18 | 50% | 103d? | 2010-06-04 | 2011-03-18 | 206d? | 455d | finish no earlier than 2011-03-18 | C1 | 1648h | 824h | FS_UE-CN_ES | PCG-25 | 24.826 | NEC | Rel-10 | CP-48 | Frederic |  |  |  |
| 395 | 166 | Study on User Data Convergence (UDC) evolution | 206d? | 2010-06-04 A | 2011-03-18 | 30% | 144.2d? | 2010-06-04 | 2011-03-18 | 206d? | 455d | finish no earlier than 2011-03-18 | C4 | 1648h | 494.4h | FS_UDCe | PCG-25 | 23.845 | Alcatel-Lucent | Rel-10 | CP-48 | Kimmo |  |  |  |
| 396 | 167 | Study on UICC access to IMS | 206d? | 2010-06-04 A | 2011-03-18 | 75% | 51.5d? | 2010-06-04 | 2011-03-18 | 206d? | 455d | finish no earlier than 2011-03-18 | C6 | 1648h | 1236h | FS_IMS-UICC | PCG-25 | 31.828 | Gemalto | Rel-10 | CP-48 | Xavier |  |  |  |
| 397 | 168 | Study on EPC Nodes Restoration | 131d? | 2010-09-17 A | 2011-03-18 | 60% | 52.4d? | 2010-09-17 | 2011-03-18 | 131d? | 455d | finish no earlier than 2011-03-18 | C4 | 1048h | 628.8h | FS_EPC_NR | PCG-25 | 23.857 | ZTE | Rel-10 | CP-49 | Kimmo |  |  |  |
| 398 | 169 | Study on Uplink Tx Diversity for HSPA | 208.4d? | 2009-08-18 A | 2010-06-04 A | 100% |  | 2009-08-18 | 2010-06-04 | 208.4d? |  | finish no earlier than 2010-06-04 | R4 | 1667.2h | 1667.2h | FS_UL-TxDiv-HSPA | PCG-23 | UTRA 25.863 | Qualcomm | Rel-10 | RP-45 | Issam | RP-100499 |  |  |
| 399 | 170 | Study on Solutions for Energy Saving within UTRA Node B | 206d? | 2009-12-04 A | 2010-09-17 A | 100% |  | 2009-12-04 | 2010-09-17 | 206d? |  | finish no earlier than 2010-09-17 | R1,R3 | 1648h | 1648h | FS_Energy_UMTS | PCG-24 | UTRA 25.927 | Vodafone | Rel-10 | RP-46 | Patrick | RP-100796 |  |  |
| 400 | 171 | Study on Improvements of distributed antenna for 1.28Mcps TDD | 191d? | 2010-03-05 A | 2010-12-10 A | 100% |  | 2010-03-05 | 2010-12-10 | 191d? |  | finish no earlier than 2010-12-10 | R1,R2,R3 | 1528h | 1528h | FS_distr_ant_LCR_TDD | PCG-24 | UTRA 25.865 | ZTE | Rel-10 | RP-47 | Patrick | RP-101287 |  |  |
| 401 | 172 | Study on Network Energy Saving for E-UTRAN | 261d? | 2010-02-02 A | 2011-03-18 | 70% | 78.3d? | 2010-02-02 | 2011-03-18 | 261d? | 455d | finish no earlier than 2011-03-18 | R3,R2 | 2088h | 1461.6h | FS_Energy_LTE | PCG-24 | LTE 36.927 | China Mobile | Rel-10 | RP-47 | Juha | RP-101128 |  |  |
| 402 | 173 | Study on Signalling and procedure for interference avoidance for in-device coexistence | 206d? | 2010-06-04 A | 2011-03-18 | 60% | 82.4d? | 2010-06-04 | 2011-03-18 | 206d? | 455d | finish no earlier than 2011-03-18 | R2,R4 | 1648h | 988.8h | FS_SPIA_IDC | PCG-25 | LTE 36.816 | China Mobile | Rel-10 | RP-48 | Joern | RP-101130 |  |  |
| 403 | 174 | Study on Measurement of Radiated Performance for MIMO and multi-antenna reception for HSPA and LTE terminals | 461.8d? | 2009-03-06 A | 2011-03-18 | 60% | 184.72d? | 2009-03-06 | 2011-03-18 | 461.8d? | 455d | finish no earlier than 2011-03-18 | R4 | 3694.4h | 2216.64h | FS_HSPA_LTE_measRP_MIMO_multi-antenna | PCG-22 | UTRA, LTE 37.976 | Vodafone | Rel-10 | RP-43 | Issam | RP-101124 |  |  |
| 404 | 175 | Study on Extending 850 MHz | 531d? | 2009-05-30 A | 2011-06-10 | 55% | 238.95d? | 2009-05-30 | 2011-06-10 | 531d? | 395d | finish no earlier than 2011-06-10 | R4 | 4248h | 2336.4h | FS_e850 | PCG-23 | UTRA, LTE TR 37.806 | Ericsson | Rel-10 | RP-44 | Issam | RP-101125 |  |  |
| 405 | 176 | Study on RAN improvements for Machine-Type Communications | 391d? | 2009-09-18 A | 2011-03-18 | 40% | 234.6d? | 2009-09-18 | 2011-03-18 | 391d? | 455d | finish no earlier than 2011-03-18 | R2,R1,R3,R4 | 3128h | 1251.2h | FS_NIMTC_RAN | PCG-23 | UTRA, LTE 37.868 | Huawei | Rel-10 | RP-45 | Joern | RP-101126 |  |  |
| 406 | 177 | Study on GERAN improvements for Machine-Type Communications | 327.5d? | 2010-05-24 A | 2011-09-02 | 15% | 278.38d? | 2010-05-24 | 2011-09-02 | 327.5d? | 335d | finish no earlier than 2011-09-02 | G1,G2 | 2620h | 393h | FS_NIMTC_GERAN | PCG-24 | GERA 43.868 | Ericsson | Rel-10 | GP-44 | Paolo |  |  |  |
| 407 | 178 | Study on Signal Precoding enhancements for EGPRS2 DL | 131d? | 2010-09-03 A | 2011-03-04 | 40% | 78.6d? | 2010-09-03 | 2011-03-04 | 131d? | 465d | finish no earlier than 2011-03-04 | G1,G2 | 1048h | 419.2h | FS_SPEED | PCG-25 | GERA 45.860 | Ericsson | Rel-10 | GP-46 | Paolo |  |  |  |

Notes:
- 338: GP#47 approved WID. 900 MHz spectrum re-farming to other RATs lead operators to reduce GSM capacity and therefore share their GSM networks. Hence the need for the most suitable (GE)RAN sharing method. / Text5: michel.robert@alcatel-lucent.com
- 339: SP#50 completed / Text5: michel.robert@alcatel-lucent.com
- 340: CP#50 completed / Text5: michel.robert@alcatel-lucent.com
- 341: GP#48 completion 11/10=>03/11 / Text5: michel.robert@alcatel-lucent.com
- 342: RP#50 updated WID RP-101013=>RP-101232. GP#48 updated WID GP-101659=>GP-101758 (restricting the scope to GERAN BSC and TD-SCDMA RNC only). GP#47 approved WID / Text5: Ms Juan Deng (dengjuan@chinamobile.com), Xinhui Wang (wangxinhui@zte.com.cn)
- 343: GP#48 updated WID GP-101659=>GP-101758 (restricting the scope to GERAN BSC and TD-SCDMA RNC only). GP#47 approved WID / Text5: Ms Juan Deng (dengjuan@chinamobile.com), Xinhui Wang (wangxinhui@zte.com.cn)
- 344: RP#50 decision: completion 03/11=>06/11. Updated WID RP-101013=>RP-101232 (support Iur-g interface only between GERAN BSC operating in A/Gb mode and LCR TDD RNC) / Text5: Liu Junqiang (liu.junqiang@zte.com.cn)
- 345: -
- 346: SP#35 Stage 1 completed. SP#45 Stage 2 work stopped. SP#46 work stopped/abandoned / Text5: tanakai@nttdocomo.co.jp
- 347: SP#35 completed. SP#46 work stopped/abandoned / Text5: takakurat@s1.nttdocomo.co.jp
- 348: SP#45 Stage 2 work stopped / Text5: tanakai@nttdocomo.co.jp
- 349: SP#45 work stopped/abandoned / Text5: chris.friel@O2.com
- 350: SP#45 work stopped/abandoned / Text5: chris.friel@O2.com
- 351: SP#45 work stopped/abandoned / Text5: chris.friel@O2.com
- 352: SP#47 work stopped (depending on ongoing related CT4 work). Stage 1 in UID_320022 Rel-8 Requirements for evolution of the 3GPP system architecture (AIPN-SAE): 22.278, 22.011, 22.246 / Text5: Haining Wang (wanghaining@huawei.com)
- 353: SP#47 work stopped / Text5: Haining Wang (wanghaining@huawei.com)
- 354: RP#47 work stopped/abandoned (no CR approved). Cell sets the TTI (Transmission Time Interval) to 2 ms / Text5: Karri Ranta-aho (karri.ranta-aho@nsn.com)
- 355: SP#47 deleted (SA2 work moved under SA1 UID_450053). SP#44 Umbrella Feature created to host WIs moved out of Rel-9 (SA2 UID_420034 on IMS aspects of Architecture for Home NodeB) / Text5: Nicolas Drevon
- 356: RP#49 stopped (no further standardization needed). Ensure that Enhanced Interference Management methods identified in Rel-9 for HNBs do not fail in deployments with a large penetration of CSG-aware UEs / Text5: Andrei Radulescu (aradules@qualcomm.com)
- 357: RP#49 stopped (no further standardization needed) / Text5: Andrei Radulescu (aradules@qualcomm.com)
- 358: RP#50 work stopped (RP-101266) / Text5: henrik.enbuske@ericsson.com
- 359: RP#50 work stopped (RP-101266) / Text5: henrik.enbuske@ericsson.com
- 360: -
- 361: SP#47 completed. TR 22.813-100 for Approval. Spin-off Feature UID_470030 Codec for Enhanced Voice Services / Text5: LOTTIN, Philippe
- 362: SP#47 completed. TR 22.813-100 for Approval / Text5: LOTTIN, Philippe
- 363: SP#47 completed. TR 22.813-100 for Approval / Text5: stefan.bruhn@ericson.com
- 364: SP#46 completed. Linked to Rel-8 Feature UID_380060 IP Interconnection of Services (IPinterc). Spin-off Feature Rel-11 UID_470051 Advanced IP Interconnection of Services / Text5: chris.friel@O2.com
- 365: SP#47 completed / Text5: Jaihyung Cho
- 366: SP#47 completed / Text5: jinhan.song@sktelecom.com
- 367: SP#47 completed. Covers Mobile/Fixed/Cordless/etc terminals. Haptic (human-machine tactile communication) extend service offering & richness of user experience beyond current visual & auditory senses / Text5: jinhan.song@sktelecom.com
- 368: SP#46 completed. Spin-off Feature UID_460028 Optimal Media Routeing (OMR). Linked to Study on Multimedia Session Continuity UID_350051, Study on Centralized IMS Service Control UID_330012, IMS inter-operator service interconnection interface UID_360011 / Text5: mario.madella@telecomitalia.it, victor.kueh@bt.com
- 369: SP#47 completed. Concluded no further normative work expected. Linked to 23.236 / Text5: LIU HONG (liuhongyfw@chinamobile.com)
- 370: SP#50 completion 12/10=>03/11 / Text5: Li Gang (ligangyf@chinamobile.com), Yu Qing (yuqing@chinamobile.com)
- 371: SP#50 completion 12/10=>03/11. Spin-off UID_430035 MAPCON and UID_450041 IFOM / Text5: Gerardo Giaretta (gerardog@qualcomm.com)
- 372: SP#50 completion 12/10=>03/11 / Text5: farooq.bari@att.com
- 373: SP#49 completion 09/10=>03/11. Some of these solutions may have impacts on 3GPP network elements and terminals. / Text5: Li Lianyuan (lilianyuan@chinamobile.com), Liu Hong (liuhongyfw@chinamobile.com)
- 374: SP#49 completed (Conclusion: select the SIP anchoring based solution for normative work CR (TEI10) introducing and completing stage-2). Analyzed performance of Rel-8 SRVCC solution from E-UTRAN/HSPA to UTRAN/GERAN / Text5: Hou zhiqiang (houzhiqiang@chinamobile.com), Jiang Yi (jiangyi@chinamobile.com)
- 375: SP#49 completion 09/10=>03/11. SP#49 TR 23.885v100 for Information. Study on "reverse direction" from UTRAN/GERAN to E-UTRAN/HSPA (Rel-8 SRVCC was in the other direction E-UTRAN/HSPA to GERAN/UTRAN) / Text5: delphin.barankanira@orange-ftgroup.com
- 376: SP#49 completed. TR 23.886v100 for Approval. Related to Rel-8 UID_350030 Single Radio Voice Call Continuity for 3GPP (SAES-SRVCC). Study how to provide Video Call seamless service continuity for 3G/LTE terminal user / Text5: Haris Zisimopoulos (haris.z@samsung.com)
- 377: SP#48 completed. Triggered by Rel-8 UID_350027 SAE for support for non-3GPP accesses. Nature of relationship: S2b one of the interfaces defined for non-3GPP accesses support in EPS. Stage 1 in Rel-8 UID_320022 (AIPN-SAE) 22.278,22.101 / Text5: bruno.landais@alcatel-lucent.com
- 378: SP#50 TR 33.859 v100 for Information. Completion 12/10=>03/11 / Text5: Karl Norrman
- 379: Continuation of Rel-9 Feature UID_430036 IMS Media Plane Security (MEDIASEC). Study solutions and extensions to features and functionality described in TR 33.828 and TS 33.328. / Text5: Peter.Howard@vodafone.com
- 380: SP#50 changed TR# from 33.804=>33.914. Study reuse of non-UICC credentials (in particular SIP Digest) to provide security for the access to applications. Provide reference material for IMS based non-UICC based SSO to applications / Text5: Silke.Holtmanns@nokia.com
- 381: SP#50 completion 12/10=>03/11. Extend Rel-8 UID_34043 (Extending PSS and MBMS User Services for optimized Mobile TV) / Text5: jan.plogsties@iis.franhofer.de
- 382: SP#50 TR 26.904 v100 for Information. Extends Rel-9 Improved Video Support for PSS and MBMS (UID_430039) / Text5: imed.bouazizi@nokia.com, jaihyung@etri.re.kr
- 383: SP#47 completed / Text5: shan.mingjun@huawei.com
- 384: SP#47 completed. Study result might impact Feature UID_420011 Self Organising Networks (SON) / Text5: Jean-Michel Cornilly (Orange)
- 385: SP#47 completed. TR 32.827 v100 for Information + Approval. WID updated SP-090462=>SP-100088. Study the missing Itf-N part in the Framework. Study changes to Itf-N to utilize UE based measurements / Text5: Yizhi Yao (yzyao@motorola.com)
- 386: SP#50 completion 12/10=>03/11. SP#48 TR 32.828 v100 for Information / Text5: olaf.pollakowski@nsn.com
- 387: SP#50 completion 12/10=>03/11. SP#48 TR 32.829 v100 for Information / Text5: olaf.pollakowski@nsn.com, Padma.Sudarsan@alcatel-lucent.com
- 388: SP#49 completion 09/10=>03/11. TR 32.830 v100 for Information / Text5: thomas.tovinger@ericsson.com
- 389: SP#49 updated WID SP-100376=>SP-100775. TR 32.832 v100 for Information / Text5: edwin.tse@ericsson.com
- 390: SP#50 completion 12/10=>03/11 (No progress since SP#49) / Text5: Padma.Sudarsan@alcatel-lucent.com
- 391: - / Text5: olaf.pollakowski@nsn.com
- 392: SP#50 No progress since SP#49 / Text5: Linda.Garbanati@alcatel-lucent.com
- 393: CP#49 completed (the solution will be choosen during a separate implementation work) / Text5: gottfried.punz@nw.neclab.eu
- 394: Linked to SA5 UID_430044 (FS_OAM-ESM) & UID_470037 (OAM-ES), RAN3 UID_470015 (FS_Energy_LTE), RAN1 UID_460016 (FS_Energy_UMTS) / Text5: gottfried.punz@nw.neclab.eu
- 395: CP#50 completion 12/10=>03/11. Study UDC evolution from Features in Rel-9 UID_400034 and Rel-10 UID_480011 UDC Data Model / Text5: jean-jacques.trottin@alcatel-lucent.com
- 396: CP#50 completion 12/10=>03/11. TR 31.828 v100 for Information / Text5: Denis L'Heriteau (Denis.Lheriteau@gemalto.com)
- 397: CP#50 updated WID CP-100473=>CP-100700. TR 23.857 v100 for Information. Linked to SA2 UID_490036 Study on Core Network Overload solutions / Text5: lu.fei1@zte.com.cn
- 398: RP#48 completed / Text5: Heechoon Lee (heechoon@qualcomm.com)
- 399: RP#49 completed. Based on ETSI EE TS 102 706. / Text5: Prakash.bhat@vodafone.com
- 400: RP#50 completed. TR 25.865 v101 for Approval / Text5: huang.he4@zte.com.cn
- 401: RP#50 completion 12/10=>03/11. TR 36.927 v100 for Information / Text5: Yang Ning (yangning@chinamobile.com)
- 402: RP#50 completion 12/10=>03/11. TR 36.816 v.100 for Information. Study coexistence scenario of LTE and Industrial, Scientific and Medical (ISM) Radio within the same device working in adjacent frequencies / Text5: Zhenping Hu (huzhenping@chinamobile.com)
- 403: RP#50 completion 12/10=>03/11 / Text5: soonleh.ling@vodafone.com
- 404: RP#50 completion 12/10=>06/11 / Text5: christian.bergljung@stericsson.com
- 405: On hold until closing WI UID_490023 NIMTC-RAN_overload. Triggered by UID_7027 Study on Facilitating Machine to Machine Communication in GSM and UMTS (M2M) TR 22.868 and Rel-10 UID_410030 Network Improvements for Machine-Type Communications (NIMTC) / Text5: Jeff Gao (gaoyq@huawei.com)
- 406: GP#48 completion 03/11=>09/11. GP#44 approved SID / Text5: paul.schliwa-bertling@ericsson.com
- 407: GP#48 completion 11/10=>03/11. GP#46 approved SID. Precoded EGPRS2 DL provides significant performance gains for EGPRS2 (in interference and sensitivity limited scenarios, allowing significant increase to data capacity and spectral efficiency) / Text5: marten.sundberg@ericsson.com

| ID | WBS | Task | Type | Duration | Start | Finish | Complete | Remaining | Baseline start | Baseline finish | Baseline duration | Total slack | Constraint | Resources | Work | Actual work | Text1 | Text2 | Text4 | Text5 | Text6 | Text7 | Text8 | Text9 | Text12 | Text11 |
| --- | --- | --- | --- | --- | --- | --- | --- | --- | --- | --- | --- | --- | --- | --- | --- | --- | --- | --- | --- | --- | --- | --- | --- | --- | --- | --- |
| 408 | 179 | Deleted - Study on Unauthenticated PS Emergency Calls |  | 471d? | 2008-06-05 A | 2010-03-25 A | 100% |  | 2008-06-05 | 2010-03-25 | 471d? |  | finish no earlier than 2010-03-25 | S1 | 3768h | 3768h | FS_UAPSEC | PCG-21 | Nokia Siemens Networks | Juergen Merkel | Rel-10 | SP-40 | Alain | PCG-24 | SP-47 |  |
| 409 | 180 | Deleted - Study on enhancements to IMS border functions for IMS Interconnection of services |  | 586d? | 2008-09-18 A | 2010-12-15 A | 100% |  | 2008-09-18 | 2010-12-15 | 586d? |  | finish no earlier than 2010-12-15 | S2 | 4688h | 4688h | FS_eIMS_IBCF | PCG-21 | Starent Networks | Rajat Ghai (rghai@starentnetworks.com) | Rel-10 | SP-41 | Maurice | PCG-26 | SP-50 |  |
| 410 | 181 | Deleted - Study on EPC Charging enhancement |  | 211d? | 2009-06-04 A | 2010-03-25 A | 100% |  | 2009-06-04 | 2010-03-25 | 211d? |  | finish no earlier than 2010-03-25 | S5 | 1688h | 1688h | FS_EPCcharg | PCG-23 | Nokia Siemens Networks | Gerald.Goermer@nsn.com | Rel-10 | SP-44 | Dionisio | PCG-24 | SP-47 |  |
| 411 | 182 | Deleted - Study on Interworking Proxy between GTP based and PMIP based interfaces |  | 186d? | 2009-09-18 A | 2010-06-04 A | 100% |  | 2009-09-18 | 2010-06-04 | 186d? |  | finish no earlier than 2010-06-04 | C4 | 1488h | 1488h | FS_GTP-MIP-IW | PCG-23 | NTT DoCoMo | takaaki.matsuura.sp@s1.nttdocomo.com | Rel-10 | CP-45 | Kimmo | PCG-25 | CP-48 |  |
| 412 | 183 | Release 9 Features | milestone | 0d? | 2008-06-05 A | 2008-06-05 A | 100% |  | 2008-06-05 | 2008-06-05 | 0d? |  |  | CP,GP,RP,SP |  |  |  |  |  |  | Rel-9 |  |  |  |  |  |
| 413 | 184 | **Enhanced Home NodeB / eNodeB** |  | 923d? | 2008-06-05 A | 2011-12-16 | 89% | 98.62d? | 2008-06-05 | 2011-12-16 | 923d? | 260d |  | S1,S2,S3,S5,C1,C6,R2,R3,R4,GP | 37416h | 28694.4h | EHNB | PCG-21 | T-Mobile | michael.kurz@t-mobile.at | Rel-9 | SP-40 | Alain |  |  |  |
| 414 | 184.1 | Stage 1 for EHNB |  | 261d? | 2008-06-05 A | 2009-06-04 A | 100% |  | 2008-06-05 | 2009-06-04 | 261d? |  | finish no earlier than 2009-06-04 | S1 | 2088h | 2088h | EHNB | PCG-21 | T-Mobile | michael.kurz@t-mobile.at | Rel-9 | SP-40 | Alain |  |  |  |
| 415 | 184.2 | Architecture aspects of EHNB |  | 266d? | 2008-09-18 A | 2009-09-24 A | 100% |  | 2008-09-18 | 2009-09-24 | 266d? |  | finish no earlier than 2009-09-22 | S2 | 2128h | 2128h | EHNB | PCG-21 | T-Mobile | Sebastian Speicher | Rel-9 | SP-41 | Maurice |  |  |  |
| 416 | 184.3 | Security aspects of Enhanced Home NodeB / eNodeB |  | 262d? | 2008-12-11 A | 2009-12-10 A | 100% |  | 2008-12-11 | 2009-12-10 | 262d? |  | finish no earlier than 2009-12-10 | S3 | 2096h | 2096h | EHNB-Sec | PCG-22 | Huawei | Marcus Wong (mwong@huawei.com) | Rel-9 | SP-42 | Dionisio |  |  |  |
| 417 | 184.4 | CT1 aspects - Support of Home NB and Home eNB enhancements |  | 321d? | 2009-09-18 A | 2010-12-10 A | 100% |  | 2009-09-18 | 2010-12-10 | 321d? |  | finish no earlier than 2010-12-10 | C1 | 2568h | 2568h | EHNB-CT1 | PCG-23 | Qualcomm | Ramachandran Subramanian (rsubrama@qualcomm.com) | Rel-9 | CP-45 | Frederic |  |  |  |
| 418 | 184.5 | CT6 aspects - Support of Home NB and Home eNB enhancements |  | 131d? | 2009-09-18 A | 2010-03-19 A | 100% |  | 2009-09-18 | 2010-03-19 | 131d? |  | finish no earlier than 2010-03-19 | C6 | 1048h | 1048h | EHNB-CT6 | PCG-23 | Qualcomm | Alfredo Ruvacalba | Rel-9 | CP-45 | Xavier |  |  |  |
| 419 | 184.6 | 3G HNB Gateway and LTE HeNB Gateway OAM&P |  | 336d? | 2008-12-11 A | 2010-03-25 A | 100% |  | 2008-12-11 | 2010-03-25 | 336d? |  | finish no earlier than 2010-03-25 | S5 | 2688h | 2688h | HNB-OAM_GW | PCG-22 | China Mobile | GangChen (chengang@chinamobile.com) | Rel-9 | SP-42 | Dionisio |  |  |  |
| 420 | 184.7 | 3G HNB and LTE HeNB OAM&P Type 1 Interface |  | 272d? | 2009-03-12 A | 2010-03-25 A | 100% |  | 2009-03-12 | 2010-03-25 | 272d? |  | finish no earlier than 2010-03-25 | S5 | 2168h | 2168h | HNB_eHNB-OAM_Type1 | PCG-22 | Huawei | Zou Lan (zlan@huawei.com) | Rel-9 | SP-43 | Dionisio |  |  |  |
| 421 | 184.8 | 3G HNB and LTE HeNB OAM&P Type 2 Interface |  | 225d? | 2009-05-15 A | 2010-03-25 A | 100% |  | 2009-05-15 | 2010-03-25 | 225d? |  | finish no earlier than 2010-03-25 | S5 | 1800h | 1800h | HNB_eHNB-OAM_Type2 | PCG-23 | Ericsson | edwin.tse@ericsson.com | Rel-9 | SP-44 | Dionisio |  |  |  |
| 422 | 184.9 | LTE FDD Home eNodeB RF Requirements |  | 336d? | 2008-12-05 A | 2010-03-19 A | 100% |  | 2008-12-05 | 2010-03-19 | 336d? |  | finish no earlier than 2010-03-19 | R4 | 2688h | 2688h | HeNB-RF_FDD | PCG-22 | Motorola | Ying Cai (yingcai@motorola.com) | Rel-9 | RP-42 | Issam |  |  | RP-100035 |
| 423 | 184.10 | LTE TDD Home eNodeB RF Requirements |  | 271d? | 2009-03-06 A | 2010-03-19 A | 100% |  | 2009-03-06 | 2010-03-19 | 271d? |  | finish no earlier than 2010-03-19 | R4 | 2168h | 2168h | HeNB-RF_TDD | PCG-22 | China Mobile | Nan Li (linan@chinamobile.com) | Rel-9 | RP-43 | Issam |  |  | RP-100036 |
| 424 | 184.11 | Home NB and Home eNB enhancements - RAN3 aspects |  | 197d? | 2009-03-06 A | 2009-12-04 A | 100% |  | 2009-03-06 | 2009-12-04 | 197d? |  | finish no earlier than 2009-12-04 | R3 | 1576h | 1576h | EHNB-RAN3 | PCG-22 | Alcatel-Lucent | Martin Warner (mw15@alcatel-lucent.com) | Rel-9 | RP-43 | Juha |  |  | RP-091050 |
| 425 | 184.12 | Home NB and Home eNB enhancements - RAN2 aspects |  | 271d? | 2009-03-06 A | 2010-03-19 A | 100% |  | 2009-03-06 | 2010-03-19 | 271d? |  | finish no earlier than 2010-03-19 | R2 | 2168h | 2168h | EHNB-RAN2 | PCG-22 | Huawei | Yang Xudong (yangxudong@huawei.com) | Rel-9 | RP-43 | Joern |  |  | RP-100037 |
| 426 | 184.13 | Conformance Test Aspects – Home NB enhancements for FDD |  | 326d? | 2010-09-17 A | 2011-12-16 | 30% | 228.2d? | 2010-09-17 | 2011-12-16 | 326d? | 260d | finish no earlier than 2011-12-16 | R5 | 2608h | 782.4h | EHNB-UTRA_FDD_UEConTest | PCG-25 | Huawei | trica_li@huawei.com | Rel-9 | RP-49 | Ingbert |  |  | RP-101077 |
| 427 | 184.14 | Conformance Test Aspects – Home eNB enhancements |  | 201d? | 2010-12-10 | 2011-09-16 |  |  | 2010-12-10 | 2011-09-16 | 201d? | 325d | finish no earlier than 2011-09-16 | R5 | 1608h |  | EHNB-LTE_UEConTest | PCG-26 | Qualcomm | Mrs Lena Chaponniere (lchaponn@qualcomm.com) | Rel-9 | RP-50 | Ingbert |  |  |  |
| 428 | 184.15 | Home NB and Home eNB enhancements - GERAN aspects |  | 341d? | 2009-05-18 A | 2010-09-03 A | 100% |  | 2009-05-18 | 2010-09-03 | 341d? |  | finish no earlier than 2010-09-03 | GP | 2728h | 2728h | EHNB-GERAN | PCG-23 | Nokia Siemens Networks | Leonardo Provvedi | Rel-9 | GP-42 | Paolo |  |  |  |
| 429 | 185 | **Value-Added Services for Short Message Service** |  | 586d? | 2007-09-10 A | 2009-12-04 A | 100% |  | 2007-09-10 | 2009-12-04 | 586d? |  |  | S1,C4,C1 | 10888h | 10888h | VAS4SMS |  | China Mobile | Wu Bin (wubin@chinamobile.com) | Rel-9 | SP-37 | Alain |  |  |  |
| 430 | 185.1 | Stage 1 for VAS4SMS |  | 133d? | 2007-09-10 A | 2008-03-12 A | 100% |  | 2007-09-10 | 2008-03-12 | 133d? |  | finish no earlier than 2008-03-21 | S1 | 1064h | 1064h | VAS4SMS |  | China Mobile | Wu Bin (wubin@chinamobile.com) | Rel-9 | SP-37 | Alain |  |  |  |
| 431 | 185.2 | CT4 aspects of VAS4SMS Interface and Signalling Flow |  | 322d? | 2008-09-12 A | 2009-12-04 A | 100% |  | 2008-09-12 | 2009-12-04 | 322d? |  | finish no earlier than 2009-12-04 | C4 | 2568h | 2568h | VAS4SMS | PCG-21 | China Mobile | Wu Bin (wubin@chinamobile.com) | Rel-9 | CP-41 | Kimmo |  |  |  |
| 432 | 185.3 | CT1 aspects of VAS4SMS Interface and Signalling Flow |  | 321d? | 2008-09-09 A | 2009-12-04 A | 100% |  | 2008-09-09 | 2009-12-04 | 321d? |  | finish no earlier than 2009-12-04 | C1 | 2568h | 2568h | VAS4SMS | PCG-21 | China Mobile | Wu Bin (wubin@chinamobile.com) | Rel-9 | CP-41 | Frederic |  |  |  |

Notes:
- 408: SP#47 work stopped/abandoned / Text3: 22.984
- 409: SP#50 work stopped. Additional work may be addressed as part of the Rel-11 Feature UID_470051 Advanced IP Interconnection of Services (AIPX) / Text3: 23.848
- 410: SP#47 work stopped. Issue covered by Rel-10 UID_460039 Charging for LIPA_SIPTO and UID_4700xy Charging for IFOM
- 411: CP#48 work stopped/abandoned / Text3: 29.875
- 412: -
- 413: CP#50 Core specification completed. Testing ongoing / Text3: UTRA, LTE
- 414: CP#49 the SA1-reqs are moving. CT1 will align when the work in SA1 is clear. (was SP#44 completed.) / Text3: 22.220, 22.011
- 415: SP#45 completed / Text3: 23.401, 23.402, 23.060, new 23.830
- 416: SP#46 completed / Text3: new 33.320
- 417: CP#50 completed (Roaming aspects for manual CSG selection, Support of temporary users and CSG membership changes, Support of user controlled and operator controlled lists) / Text3: 23.122, 24.008, 24.285, 24.301
- 418: CP#47 completed. Storing of CSG related data items on the USIM / Text3: 31.102
- 419: SP#47 completed / Text3: 32.632, 32.633, 32.635, new (32.771, 32.772, 32.773, 32.775, 32.781, 32.782, 32.783, 32.785)
- 420: SP#47 completed / Text3: 32.581, 32.582, 32.583, 32.584, new (32.591, 32.592, 32.593, 32.594)
- 421: SP#47 completed / Text3: new 32.571, 32.572
- 422: RP#47 completed / Text3: new TR 36.921, 36.104, 36.141
- 423: RP#47 completed / Text3: new TR 36.922, 36.104, 36.141, 36.300, 36.331, 36.413
- 424: RP#46 completed (based on high priority items specified in RP-090995) / Text3: 25.413, 25.467, 25.467, 25.468, 25.469, 25.469, 36.401, 36.413, new 25.444
- 425: RP#47 completed / Text3: 25.304, 25.331, 25.367, 36.300, 36.304, 36.331
- 426: UTRA. Testing for UID_430026 Support of Home NB and Home eNB enhancements RAN2 aspects (25.304, 25.331, 25.367) / Text3: 34.108, 34.123-1, 34.123-2, 34.123-3
- 427: - / Text3: 36.508, 36.523-1, 36.523-2, 36.523-3
- 428: GP#47 completed. GP#42 WID approved / Text3: 43.055, 43.129, 44.018, 44.060, 45.008, 48.008, 48.018
- 429: CP#46 completed
- 430: SP#39 completed. SP#43 Feature moved to Rel-9 / Text3: 22.142
- 431: CP#46 completed / Text3: new 23.142
- 432: CP#46 completed / Text3: 23.040

| ID | WBS | Task | Type | Duration | Start | Finish | Complete | Baseline start | Baseline finish | Baseline duration | Constraint | Resources | Work | Actual work | Text1 | Text4 | Text6 | Text7 | Text8 | Text2 | Text3 | Text11 |
| --- | --- | --- | --- | --- | --- | --- | --- | --- | --- | --- | --- | --- | --- | --- | --- | --- | --- | --- | --- | --- | --- | --- |
| 433 | 186 | **Definition of End-User Identity** |  | 334d? | 2007-09-03 A | 2008-12-11 A | 100% | 2007-09-03 | 2008-12-11 | 334d? |  | S1 | 5344h | 5344h | EUI | Nokia Siemens Networks | Rel-9 | SP-38 | Alain |  |  |  |
| 434 | 186.1 | Definition of End-User Identity |  | 334d? | 2007-09-03 A | 2008-12-11 A | 100% | 2007-09-03 | 2008-12-11 | 334d? | finish no earlier than 2008-12-11 | S1 | 2672h | 2672h | EUI | Nokia Siemens Networks | Rel-9 | SP-38 | Alain | PCG-21 | 21.905 |  |
| 435 | 187 | **Customized Ringing Signal** |  | 653d? | 2007-12-06 A | 2010-06-04 A | 100% | 2007-12-06 | 2010-06-04 | 653d? |  | S1,C1 | 8168h | 8168h | CRS | SK Telecom, China Mobile | Rel-9 | SP-38 | Alain | PCG-21 |  |  |
| 436 | 187.1 | Stage 1 for Customized Ringing Signal |  | 266d? | 2007-12-06 A | 2008-12-11 A | 100% | 2007-12-06 | 2008-12-11 | 266d? | finish no earlier than 2008-12-11 | S1 | 2128h | 2128h | CRS | SK Telecom, China Mobile | Rel-9 | SP-38 | Alain | PCG-21 | 22.173, new 22.183 |  |
| 437 | 187.2 | Stage 3 for IMS Customized Ringing Signal (CRS) Service |  | 267d? | 2009-05-29 A | 2010-06-04 A | 100% | 2009-05-29 | 2010-06-04 | 267d? | finish no earlier than 2010-06-04 | C1 | 816h | 816h | CRS | China Mobile | Rel-9 | CP-44 | Frederic | PCG-23 | 24.173, new 24.183 |  |
| 438 | 188 | **Public Warning System** |  | 523d? | 2007-12-06 A | 2009-12-04 A | 100% | 2007-12-06 | 2009-12-04 | 523d? |  | S1,C1,C4,R2 | 10232h | 10232h | PWS | T-Mobile | Rel-9 | SP-38 | Alain | PCG-21 | GERA, UTRA, LTE |  |
| 439 | 188.1 | Stage 1 for Public Warning System |  | 266d? | 2007-12-06 A | 2008-12-11 A | 100% | 2007-12-06 | 2008-12-11 | 266d? | finish no earlier than 2008-12-11 | S1 | 2128h | 2128h | PWS | T-Mobile | Rel-9 | SP-38 | Alain | PCG-21 | 22.268 |  |
| 440 | 188.2 | **Stage 3 for Public Warning System** |  | 137d? | 2009-05-29 A | 2009-12-04 A | 100% | 2009-05-29 | 2009-12-04 | 137d? |  | C1,C4 | 3272h | 3272h | PWS-St3 | Qualcomm | Rel-9 | CP-44 | Frederic | PCG-23 |  |  |
| 441 | 188.2.1 | CT1 aspects of Stage 3 for Public Warning System |  | 137d? | 2009-05-29 A | 2009-12-04 A | 100% | 2009-05-29 | 2009-12-04 | 137d? | finish no earlier than 2009-12-04 | C1 | 1088h | 1088h | PWS-St3 | Qualcomm | Rel-9 | CP-44 | Frederic | PCG-23 | 23.041 |  |
| 442 | 188.2.2 | CT4 aspects of Stage 3 for Public Warning System |  | 136d? | 2009-05-30 A | 2009-12-04 A | 100% | 2009-05-30 | 2009-12-04 | 136d? | finish no earlier than 2009-12-04 | C4 | 1088h | 1088h | PWS-St3 | Qualcomm | Rel-9 | CP-44 | Kimmo | PCG-23 | 29.168 |  |
| 443 | 188.3 | Public Warning System (PWS) – RAN aspects |  | 81d? | 2009-05-30 A | 2009-12-04 A | 100% | 2009-05-30 | 2009-12-04 | 81d? | finish no earlier than 2009-12-04 | R2,R3 | 648h | 648h | PWS-RAN | AT&T | Rel-9 | RP-44 | Joern | PCG-23 | LTE 36.300, 36.302, 36.331, 36.413 | RP-091052 |
| 444 | 189 | **Support of Personal Area Networks and Enhancements to Personal Network Management** |  | 523d? | 2008-06-05 A | 2010-06-04 A | 100% | 2008-06-05 | 2010-06-04 | 523d? |  | S1,C1 | 8360h | 8360h | PAN_EPNM | Vodafone | Rel-9 | SP-40 | Alain | PCG-21 |  |  |
| 445 | 189.1 | Stage 1 for PAN_EPNM | milestone | 0d? | 2008-06-05 A | 2008-06-05 A | 100% | 2008-06-05 | 2008-06-05 | 0d? | finish no earlier than 2008-06-05 | S1 |  |  | PAN_EPNM | Vodafone | Rel-9 | SP-40 | Alain | PCG-21 | 22.259 |  |
| 446 | 189.2 | Stage 2 for Support of Personal Area Networks and Enhancements to Personal Network Managemen |  | 196d? | 2009-03-06 A | 2009-12-04 A | 100% | 2009-03-06 | 2009-12-04 | 196d? | finish no earlier than 2009-12-04 | C1 | 1568h | 1568h | PAN_EPNM | Huawei | Rel-9 | CP-43 | Frederic | PCG-22 | 23.259 |  |
| 447 | 189.3 | Stage 3 for Support of Personal Area Networks and Enhancements to Personal Network Managemen |  | 326d? | 2009-03-09 A | 2010-06-04 A | 100% | 2009-03-09 | 2010-06-04 | 326d? | finish no earlier than 2010-06-04 | C1 | 2608h | 2608h | PAN_EPNM | Huawei | Rel-9 | CP-43 | Frederic | PCG-22 | 24.259 |  |
| 448 | 190 | **Multi-Media Telephony Service enhancements** |  | 472d? | 2008-06-05 A | 2010-03-25 A | 100% | 2008-06-05 | 2010-03-25 | 472d? |  | S1,S5,C1 | 10288h | 10288h | eMMTel | France Telecom | Rel-9 | SP-40 | Alain | PCG-21 |  |  |
| 449 | 190.1 | Stage 1 for eMMTel |  | 136d? | 2008-06-05 A | 2008-12-11 A | 100% | 2008-06-05 | 2008-12-11 | 136d? | start no earlier than 2008-06-05 | S1 | 1088h | 1088h | eMMTel | France Telecom | Rel-9 | SP-40 | Alain | PCG-21 | 22.173 |  |
| 450 | 190.2 | Multimedia Telephony (MMTel) Service and Supplementary Services - Online Charging and completion for Offline Charging (all supplementary services) |  | 272d? | 2009-03-12 A | 2010-03-25 A | 100% | 2009-03-12 | 2010-03-25 | 272d? | finish no earlier than 2010-03-25 | S5 | 2168h | 2168h | eMMTel-SS-CH | Alcatel-Lucent | Rel-9 | SP-43 | Dionisio | PCG-22 | 32.275, 32.298, 32.299 |  |
| 451 | 190.3 | Support of Real-time Transfer of Tariff Information (RTTI) in IMS charging |  | 271d? | 2009-03-12 A | 2010-03-25 A | 100% | 2009-03-12 | 2010-03-25 | 271d? | finish no earlier than 2010-03-25 | S5 | 2168h | 2168h | IMSTSS-RTTI-CH | Orange | Rel-9 | SP-43 | Dionisio | PCG-22 | 32.240, 32.280, 32.298, 32.299 |  |
| 452 | 190.4 | Stage 3 - Enhancements for Completion of Communications Supplementary service |  | 136d? | 2009-05-30 A | 2009-12-04 A | 100% | 2009-05-30 | 2009-12-04 | 136d? | finish no earlier than 2009-12-04 | C1 | 1088h | 1088h | eMMTel-CC | France Telecom | Rel-9 | CP-44 | Frederic | PCG-23 | 24.642 |  |
| 453 | 191 | **User Data Convergence (UDC)** |  | 527d? | 2008-06-05 A | 2010-06-10 A | 100% | 2008-06-05 | 2010-06-10 | 527d? |  | S1,S5,C4 | 14456h | 14456h | UDC | Nokia Siemens Networks | Rel-9 | SP-40 | Alain | PCG-21 |  |  |
| 454 | 191.1 | Stage 1 for User Data Convergence (UDC) |  | 136d? | 2008-06-05 A | 2008-12-11 A | 100% | 2008-06-05 | 2008-12-11 | 136d? | start no earlier than 2008-06-05 | S1 | 1088h | 1088h | UDC | Nokia Siemens Networks | Rel-9 | SP-40 | Alain | PCG-21 | 22.985, 22.101 |  |
| 455 | 191.2 | User Data Convergence (UDC) Technical Realization (Stage 2) |  | 271d? | 2009-03-06 A | 2010-03-19 A | 100% | 2009-03-06 | 2010-03-19 | 271d? | finish no earlier than 2010-03-19 | C4 | 2168h | 2168h | UDC-CN | Ericsson | Rel-9 | CP-43 | Kimmo | PCG-22 | new 23.335 |  |
| 456 | 191.3 | User Data Convergence (UDC) Protocol Description |  | 130d? | 2009-09-18 A | 2010-03-19 A | 100% | 2009-09-18 | 2010-03-19 | 130d? | finish no earlier than 2010-03-19 | C4 | 1040h | 1040h | UDC-CN | China Mobile, Ericsson | Rel-9 | CP-45 | Kimmo | PCG-23 | new 29.335 |  |

Notes:
- 433: SP#42 closed. Stage 1 work closed at 5% completion due to lack of input (added only the EUI definition in 21.905) / Text5: Juergen.Merkel@nsn.com
- 434: SP#42 closed. Stage 1 work closed at 5% completion due to lack of input (added only the EUI definition in 21.905) / Text5: Juergen.Merkel@NSN.com
- 435: CP#48 completed / Text5: Donghee Shim (SK Telecom), Jianping Zheng (China Mobile)
- 436: SP#42 completed. / Text5: Donghee Shim (SK Telecom), Jianping Zheng (China Mobile)
- 437: CP#48 completed / Text5: wangzhao
- 438: TSG#46 completed. Larger scope than Rel-8 Feature UID_370051 (ETWS). Triggered by TR 22.968 Study UID_320025 (FS_PWS) / Text5: Mark.Younge@t-mobile.com
- 439: SP#42 completed / Text5: Mark.Younge@t-mobile.com
- 440: RP#46 completed / Text5: Ramachandran Subramanian (rsubrama@qualcomm.com)
- 441: CP#46 completed / Text5: Ramachandran Subramanian (rsubrama@qualcomm.com)
- 442: CP#46 completed / Text5: Ramachandran Subramanian (rsubrama@qualcomm.com)
- 443: RP#46 completed / Text5: don.zelmer@att.com
- 444: CP#48 completed / Text5: armin.toepfer@vodafone.com
- 445: SP#40 completed / Text5: armin.toepfer@vodafone.com
- 446: CP#46 completed / Text5: Lili Yang (kadyyang@huawei.com)
- 447: CP#48 completed / Text5: Lili Yang (kadyyang@huawei.com)
- 448: SP#47 completed / Text5: Philippe Lottin
- 449: SP#42 completed / Text5: Philippe Lottin
- 450: SA#47 completed / Text5: maryse.gardella@alcatel-lucent.com
- 451: SA#47 completed. Linked to SA5 Rel-8 UID_380042 AoC support in IMS Charging (IMSTSS) / Text5: Jean-Luc Garcia (jl.garcia@orange-ftgroup.com)
- 452: CP#46 completed / Text5: Youssef.chadli@orange-ftgroup.com
- 453: SP#48 completed. Triggered by Rel-8 SA5 Study of Common Profile Storage Framework of User Data for network services and management (UID_320006) TR 32.808 / Text5: juergen.merkel@nsn.com
- 454: SP#42 completed / Text5: juergen.merkel@nsn.com
- 455: CP#47 completed
- 456: CP#47 completed / Text5: Lan Si Zhong (lansizhong@chinamobile.com), emiliano.merino@ericsson.com

| ID | WBS | Task | Duration | Start | Finish | Complete | Remaining | Baseline start | Baseline finish | Baseline duration | Total slack | Constraint | Resources | Work | Actual work | Text1 | Text2 | Text4 | Text6 | Text7 | Text8 | Text11 |
| --- | --- | --- | --- | --- | --- | --- | --- | --- | --- | --- | --- | --- | --- | --- | --- | --- | --- | --- | --- | --- | --- | --- |
| 457 | 191.4 | **User Data Convergence (UDC) Modelling and Management** | 266d? | 2009-06-04 A | 2010-06-10 A | 100% |  | 2009-06-04 | 2010-06-10 | 266d? |  |  | S5 | 5944h | 5944h | UDC-MMAN | PCG-23 | T-Mobile, China Mobile, Ericsson | Rel-9 | SP-44 | Dionisio |  |
| 458 | 191.4.1 | UDC – Framework for Model Handling and Management | 266d? | 2009-06-04 A | 2010-06-10 A | 100% |  | 2009-06-04 | 2010-06-10 | 266d? |  | finish no earlier than 2010-06-10 | S5 | 2128h | 2128h | UDC-MMAN-MFRM | PCG-23 | T-Mobile | Rel-9 | SP-44 | Dionisio |  |
| 459 | 191.4.2 | UDC – Common Baseline Information Model | 211d? | 2009-06-04 A | 2010-03-25 A | 100% |  | 2009-06-04 | 2010-03-25 | 211d? |  | finish no earlier than 2010-03-25 | S5 | 1688h | 1688h | UDC-MMAN-CBIM | PCG-23 | China Mobile, Ericsson | Rel-9 | SP-44 | Dionisio |  |
| 460 | 192 | **IMS Services Centralization and Continuity** | 393d? | 2008-09-18 A | 2010-03-19 A | 100% |  | 2008-09-18 | 2010-03-19 | 393d? |  |  | S1,S2,C1 | 12160h | 12160h | IMS_SCC | PCG-21 | NEC | Rel-9 | SP-41 | Alain |  |
| 461 | 192.1 | Stage 1 - Inter-Device Transfer – Requirements | 61d? | 2008-09-18 A | 2008-12-11 A | 100% |  | 2008-09-18 | 2008-12-11 | 61d? |  | finish no earlier than 2009-06-18 | S1 | 488h | 488h | IMS_SCC-IDT | PCG-21 | NEC | Rel-9 | SP-41 | Alain |  |
| 462 | 192.2 | Stage 2 - IMS Service Continuity Enhancements: Service, Policy and Interactions | 186d? | 2008-09-18 A | 2009-06-04 A | 100% |  | 2008-09-18 | 2009-06-04 | 186d? |  | finish no earlier than 2009-06-04 | S2 | 1488h | 1488h | IMS_SCC-SPI | PCG-21 | Huawei | Rel-9 | SP-41 | Maurice |  |
| 463 | 192.3 | Stage 3 - IMS Service Continuity Enhancements: Service, Policy, Interactions and Inter UE Transfer | 212d? | 2009-05-29 A | 2010-03-19 A | 100% |  | 2009-05-29 | 2010-03-19 | 212d? |  | finish no earlier than 2010-03-19 | C1 | 1696h | 1696h | IMS_SCC-SPI | PCG-23 | Qualcomm | Rel-9 | CP-44 | Frederic |  |
| 464 | 192.4 | Stage 2 - IMS Centralized Services | 186d? | 2008-09-18 A | 2009-06-04 A | 100% |  | 2008-09-18 | 2009-06-04 | 186d? |  | finish no earlier than 2009-06-04 | S2 | 1488h | 1488h | IMS_SCC-ICS | PCG-21 | Alcatel-Lucent | Rel-9 | SP-41 | Maurice |  |
| 465 | 192.5 | Stage 3 - Enhancements to IMS Centralized Services | 212d? | 2009-05-29 A | 2010-03-19 A | 100% |  | 2009-05-29 | 2010-03-19 | 212d? |  | finish no earlier than 2010-03-19 | C1 | 1688h | 1688h | IMS_SCC-ICS | PCG-23 | Nokia Siemens Networks | Rel-9 | CP-44 | Frederic |  |
| 466 | 192.6 | Stage 3 - IMS Centralized Services support via I1 interface | 271d? | 2009-03-06 A | 2010-03-19 A | 100% |  | 2009-03-06 | 2010-03-19 | 271d? |  | finish no earlier than 2010-03-19 | C1 | 2168h | 2168h | IMS_SCC-ICS_I1 | PCG-22 | Huawei | Rel-9 | CP-43 | Frederic |  |
| 467 | 193 | **Service Specific Access Control in EPS** | 333d? | 2008-12-11 A | 2010-03-19 A | 100% |  | 2008-12-11 | 2010-03-19 | 333d? |  |  | S1,C1 | 4368h | 4368h | SSAC | PCG-22 | NTT DoCoMo | Rel-9 | SP-42 | Alain |  |
| 468 | 193.1 | Stage 1 for Service Specific Access Control in EPS | 1d? | 2008-12-11 A | 2008-12-11 A | 100% |  | 2008-12-11 | 2008-12-11 | 1d? |  | start no earlier than 2008-12-11 | S1 | 8h | 8h | SSAC | PCG-22 | NTT DoCoMo | Rel-9 | SP-42 | Alain |  |
| 469 | 193.2 | Stage 3 for Service Specific Access Control in EPS | 212d? | 2009-05-29 A | 2010-03-19 A | 100% |  | 2009-05-29 | 2010-03-19 | 212d? |  | finish no earlier than 2010-03-19 | C1 | 1696h | 1696h | SSAC | PCG-23 | NTT DoCoMo | Rel-9 | CP-44 | Frederic |  |
| 470 | 194 | **Support for IMS Emergency Calls over GPRS and EPS** | 831d? | 2008-01-14 A | 2011-03-18 | 94% | 45.72d? | 2008-01-14 | 2011-03-18 | 831d? | 455d |  | S1,S2,S3,C1,C3,C4,R2,R3,R5 | 32483.7h | 23474.1h | IMS_EMER_GPRS_EPS | PCG-21 | Alcatel-Lucent | Rel-9 | SP-38 | Maurice |  |
| 471 | 194.1 | Stage 1 for IMS Emergency Calls over GPRS and EPS | 239d? | 2008-01-14 A | 2008-12-11 A | 100% |  | 2008-01-14 | 2008-12-11 | 239d? |  | finish no earlier than 2008-12-11 | S1 | 1912h | 1912h | IMS_EMER_GPRS_EPS | PCG-21 | Alcatel-Lucent | Rel-9 | SP-38 | Alain |  |
| 472 | 194.2 | Stage 2 for IMS Emergency Calls over GPRS and EPS | 364d? | 2008-01-14 A | 2009-06-04 A | 100% |  | 2008-01-14 | 2009-06-04 | 364d? |  | finish no earlier than 2009-06-04 | S2 | 2912h | 2912h | IMS_EMER_GPRS_EPS | PCG-21 | Alcatel-Lucent | Rel-9 | SP-38 | Maurice |  |
| 473 | 194.3 | Security aspects for IMS Emergency Calls over GPRS and EPS | 391d? | 2008-12-12 A | 2010-06-10 A | 100% |  | 2008-12-12 | 2010-06-10 | 391d? |  | finish no earlier than 2010-03-25 | S3 | 3128h | 3128h | IMS_EMER_GPRS_EPS-Sec | PCG-22 | Alcatel-Lucent | Rel-9 | SP-42 | Dionisio |  |
| 474 | 194.4 | **Stage 3 for IMS Emergency Calls over GPRS and EPS** | 472d? | 2009-05-29 A | 2011-03-18 | 77% | 106.85d? | 2009-05-29 | 2011-03-18 | 472d? | 455d |  | C1,C3,C4,R5 | 8867.68h | 4594.08h | IMS_EMER_GPRS_EPS | PCG-23 | Alcatel-Lucent | Rel-9 | CP-44 | Frederic |  |
| 475 | 194.4.1 | CT1 aspects - Stage 3 for IMS Emergency Calls over GPRS and EPS | 212d? | 2009-05-29 A | 2010-03-19 A | 100% |  | 2009-05-29 | 2010-03-19 | 212d? |  | finish no earlier than 2010-03-19 | C1 | 1696h | 1696h | IMS_EMER_GPRS_EPS | PCG-23 | Alcatel-Lucent | Rel-9 | CP-44 | Frederic |  |
| 476 | 194.4.2 | Conformance Test Aspects - CT1 aspects for IMS Emergency Calls over GPRS and EPS | 206d? | 2010-06-04 A | 2011-03-18 | 30% | 144.2d? | 2010-06-04 | 2011-03-18 | 206d? | 455d | finish no earlier than 2011-03-18 | R5 | 1648h | 494.4h | IMS_EMER_GPRS_EPS_UEConTest | PCG-25 | Samsung | Rel-9 | RP-48 | Ingbert | RP-101072 |
| 477 | 194.4.3 | CT3 aspects - Stage 3 for IMS Emergency Calls over GPRS and EPS | 82d? | 2009-05-29 A | 2009-09-18 A | 100% |  | 2009-05-29 | 2009-09-18 | 82d? |  | start no earlier than 2009-05-29 | C3 | 651.68h | 651.68h | IMS_EMER_GPRS_EPS | PCG-23 | Alcatel-Lucent | Rel-9 | CP-44 | Gwiho |  |
| 478 | 194.4.4 | CT4 aspects - Stage 3 for IMS Emergency Calls over GPRS and EPS | 137d? | 2009-05-29 A | 2009-12-04 A | 100% |  | 2009-05-29 | 2009-12-04 | 137d? |  | finish no earlier than 2009-12-04 | C4 | 1096h | 1096h | IMS_EMER_GPRS_EPS | PCG-23 | Alcatel-Lucent | Rel-9 | CP-44 | Kimmo |  |
| 479 | 194.5 | Support for IMS Emergency Calls over LTE | 206d? | 2008-12-05 A | 2009-09-18 A | 100% |  | 2008-12-05 | 2009-09-18 | 206d? |  |  | R2,R3 | 1648h | 1648h | IMS_EMER_LTE | PCG-22 | Alcatel-Lucent | Rel-9 | RP-42 | Joern |  |
| 480 | 194.6 | Conformance Test Aspects – Support for IMS Emergency Calls over LTE | 187d? | 2010-03-25 A | 2010-12-10 A | 100% |  | 2010-03-25 | 2010-12-10 | 187d? |  | finish no earlier than 2010-12-10 | R5 | 1496h | 1496h | IMS_EMER_LTE_UEConTest | PCG-24 | Ericsson | Rel-9 | RP-47 | Ingbert | RP-101068 |

Notes:
- 457: SP#48 completed / Text5: istvan.aba@t-mobile.at, lansizhong@chinamobile.com, miguel.a.garcia@ericsson.com
- 458: SP#48 completed / Text3: 32.172, new 32.181 / Text5: istvan.aba@t-mobile.at
- 459: SP#47 completed / Text3: 32.172, new 32.182 / Text5: Lan Si Zhong, Miguel Garcia
- 460: CP#47 completed / Text5: Joerg Swetina (joerg.swetina@nw.neclab.eu)
- 461: SP#42 completed / Text3: 22.101, 22.228 / Text5: Joerg Swetina (joerg.swetina@nw.neclab.eu)
- 462: SP#44 completed. TR 23.838 for Approval / Text3: 23.838, 23.237, 23.292, 23.216 / Text5: HengLiang Zhang (hl_zhang@huawei.com)
- 463: CP#47 completed / Text3: 24.216, 24.229, 24.237 / Text5: Roozbeh Atarius (ratarius@qualcomm.com)
- 464: SP#44 completed. TR 23.883 for Information + Approval / Text3: 23.292, new 23.883 / Text5: Andy Bennett (andybennett@alcatel-lucent.com)
- 465: CP#47 completed / Text3: 24.292, 24.604, 24.607, 24.608, 24.611, 24.623 / Text5: Peter.Leis@nsn.com
- 466: CP#47 completed / Text3: 24.237, 24.292, new 24.294 / Text5: Lili Yang(kadyyang@huawei.com)
- 467: CP#47 completed. Triggered by Study UID_400036 on Service Specific Access Control in EPS (FS_SSAC) / Text5: Frederic Thepot (thepot@docomolab-euro.com)
- 468: SP#42 completed / Text3: 22.011 CR0136 / Text5: Frederic Thepot (thepot@docomolab-euro.com)
- 469: CP#47 completed / Text3: 24.173, 27.007 / Text5: Hideyuki Yamashita (yamashitahi@s1.nttdocomo.co.jp)
- 470: SP#48 completed / Text3: GERA, LTE / Text5: Deborah Barclay
- 471: SP#42 completed / Text3: 22.101 / Text5: Deborah Barclay
- 472: SP#44 completed / Text3: 23.869, 23.060, 23.167, 23.203, 23.221, 23.228, 23.271, 23.401, 23.402 / Text5: Deborah Barclay
- 473: SP#48 completed / Text3: 33.401, 33.402 / Text5: Deborah Barclay
- 474: CP#47 completed / Text3: GERA, LTE / Text5: Frank Alfano (falfano@alcatel-lucent.com)
- 475: CP#47 completed / Text3: 23.122, 24.008, 24.229, 24.301, 24.302 / Text5: Frank Alfano (falfano@alcatel-lucent.com)
- 476: Testing for UID_440036 CT1 aspects - Stage 3 of Support for IMS Emergency Calls over GPRS and EPS / Text3: 34.108, 34.123-1, 34.123-2, 34.123-3, 34.229-1, 34.229-2, 34.229-3, 36.508, 36.523-1, 36.523-2, 36.523-3 / Text5: stoyan.baev@partner.samsung.com
- 477: CP#45 completed / Text3: 29.212, 29.213, 29.214, 29.215 / Text5: Frank Alfano (falfano@alcatel-lucent.com)
- 478: CP#46 completed / Text3: 23.003, 23.008, 29.060, 29.272, 29.273, 29.274, 29.275, 29.276 / Text5: Frank Alfano (falfano@alcatel-lucent.com)
- 479: RP#45 completed / Text3: 36.331, 36.413 / Text5: Sudeep Palat (spalat@alcatel-lucent.com)
- 480: RP#50 completed. Testing for UID_420041 Support for IMS Emergency Calls over LTE / Text3: 36.508, 36.523-1, 36.523-2, 36.523-3 / Text5: leif.mattisson@ericsson.com

| ID | WBS | Task | Duration | Start | Finish | Complete | Remaining | Baseline start | Baseline finish | Baseline duration | Total slack | Constraint | Resources | Work | Actual work | Text1 | Text2 | Text4 | Text5 | Text6 | Text7 | Text8 | Text11 |
| --- | --- | --- | --- | --- | --- | --- | --- | --- | --- | --- | --- | --- | --- | --- | --- | --- | --- | --- | --- | --- | --- | --- | --- |
| 481 | 194.7 | **SRVCC support for IMS Emergency Calls** | 322d? | 2008-09-18 A | 2009-12-10 A | 100% |  | 2008-09-18 | 2009-12-10 | 322d? |  |  | S2,C1,C4,C3 | 5872h | 5872h | IMS_EMER_GPRS_EPS-SRVCC | PCG-21 | China Mobile | Yu Qing (Yuqing@chinamobile.com) | Rel-9 | SP-41 | Maurice |  |
| 482 | 194.7.1 | SRVCC support for IMS Emergency Calls | 322d? | 2008-09-18 A | 2009-12-10 A | 100% |  | 2008-09-18 | 2009-12-10 | 322d? |  | finish no earlier than 2009-12-10 | S2 | 2576h | 2576h | IMS_EMER_GPRS_EPS-SRVCC | PCG-21 | China Mobile | Yu Qing (Yuqing@chinamobile.com) | Rel-9 | SP-41 | Maurice |  |
| 483 | 194.7.2 | **CT aspects of SRVCC support for IMS Emergency Calls** | 137d? | 2009-05-29 A | 2009-12-04 A | 100% |  | 2009-05-29 | 2009-12-04 | 137d? |  |  | C1,C4,C3 | 3296h | 3296h | IMS_EMER_GPRS_EPS-SRVCC | PCG-24 | China Mobile | jiangyi@chinamobile.com | Rel-9 | CP-46 | Frederic |  |
| 484 | 194.7.2.1 | CT1 aspects of SRVCC support for IMS Emergency Calls | 137d? | 2009-05-29 A | 2009-12-04 A | 100% |  | 2009-05-29 | 2009-12-04 | 137d? |  | finish no earlier than 2009-12-04 | C1 | 1096h | 1096h | IMS_EMER_GPRS_EPS-SRVCC | PCG-23 | China Mobile | jiangyi@chinamobile.com | Rel-9 | CP-44 | Frederic |  |
| 485 | 194.7.2.2 | CT4 aspects of SRVCC support for IMS Emergency Calls | 137d? | 2009-05-29 A | 2009-12-04 A | 100% |  | 2009-05-29 | 2009-12-04 | 137d? |  | finish no earlier than 2009-12-04 | C4 | 1096h | 1096h | IMS_EMER_GPRS_EPS-SRVCC | PCG-23 | China Mobile | jiangyi@chinamobile.com | Rel-9 | CP-44 | Kimmo |  |
| 486 | 194.7.2.3 | CT3 aspects of SRVCC support for IMS Emergency Calls | 1d? | 2009-12-04 A | 2009-12-04 A | 100% |  | 2009-12-04 | 2009-12-04 | 1d? |  | finish no earlier than 2009-12-04 | C3 | 8h | 8h | IMS_EMER_GPRS_EPS-SRVCC | PCG-24 | China Mobile | jiangyi@chinamobile.com | Rel-9 | CP-46 | Kimmo |  |
| 487 | 195 | **LCS for LTE and EPS** | 858d? | 2008-06-05 A | 2011-09-16 | 89% | 91.41d? | 2008-06-05 | 2011-09-16 | 858d? | 325d |  | S2,C1,C4,R2,R1,R3,R4,R5 | 22352h | 16332.8h | LCS_LTE_EPS | PCG-22 |  |  | Rel-9 | SP-43 | Maurice |  |
| 488 | 195.1 | **LCS Control Plane Solution for EPS** | 468d? | 2008-06-05 A | 2010-03-19 A | 100% |  | 2008-06-05 | 2010-03-19 | 468d? |  |  | S2,C4,C1 | 9224h | 9224h | LCS_EPS-CPS | PCG-21 | Polaris Wireless | Robert Gross | Rel-9 | SP-40 | Maurice |  |
| 489 | 195.1.1 | Stage 2 for LCS Control Plane Solution for EPS | 261d? | 2008-06-05 A | 2009-06-04 A | 100% |  | 2008-06-05 | 2009-06-04 | 261d? |  | finish no earlier than 2009-06-04 | S2 | 2088h | 2088h | LCS_EPS-CPS | PCG-21 | Polaris Wireless | Robert Gross | Rel-9 | SP-40 | Maurice |  |
| 490 | 195.1.2 | CT4 aspects of Control Plane LCS in the EPC | 212d? | 2009-05-29 A | 2010-03-19 A | 100% |  | 2009-05-29 | 2010-03-19 | 212d? |  | finish no earlier than 2010-03-19 | C4 | 1696h | 1696h | LCS_EPS-CPS | PCG-23 | Polaris Wireless | Robert Gross | Rel-9 | CP-44 | Kimmo |  |
| 491 | 195.1.3 | CT1 aspects of Control Plane LCS in the EPC | 212d? | 2009-05-29 A | 2010-03-19 A | 100% |  | 2009-05-29 | 2010-03-19 | 212d? |  | finish no earlier than 2010-03-19 | C1 | 1696h | 1696h | LCS_EPS-CPS | PCG-23 | Polaris Wireless | Robert Gross | Rel-9 | CP-44 | Frederic |  |
| 492 | 195.2 | Positioning Support for LTE | 392d? | 2008-12-05 A | 2010-06-04 A | 100% |  | 2008-12-05 | 2010-06-04 | 392d? |  | finish no earlier than 2010-06-04 | R2,R1,R3,R4 | 3136h | 3136h | LCS_LTE | PCG-22 | Qualcomm | Nathan Tenny (ntenny@qualcomm.com) | Rel-9 | RP-42 | Joern | RP-100442 |
| 493 | 195.3 | Conformance Test Aspects – Positioning Support for LTE | 391d? | 2010-03-19 A | 2011-09-16 | 60% | 156.4d? | 2010-03-19 | 2011-09-16 | 391d? | 325d | finish no earlier than 2011-09-16 | R5 | 3128h | 1876.8h | LCS_LTE_UEConTest | PCG-24 | Alcatel-Lucent | nidal.khrais@alcatel-lucent.com | Rel-9 | RP-47 | Ingbert | RP-101404 |
| 494 | 196 | **MBMS support in EPS** | 988d? | 2008-06-05 A | 2012-03-16 | 79% | 204.52d? | 2008-06-05 | 2012-03-16 | 988d? | 195d |  | S2,S3,S5,C3,C4,R2,R3,R4 | 20688h | 16403.8h | MBMS_EPS | PCG-21 | China Mobile | Liu Hong (liuhongyfw@chinamobile.com) | Rel-9 | SP-40 | Maurice |  |
| 495 | 196.1 | Stage 2 for MBMS support in EPS | 261d? | 2008-06-05 A | 2009-06-04 A | 100% |  | 2008-06-05 | 2009-06-04 | 261d? |  | finish no earlier than 2009-06-04 | S2 | 2088h | 2088h | MBMS_EPS | PCG-21 | China Mobile | Liu Hong (liuhongyfw@chinamobile.com) | Rel-9 | SP-40 | Maurice |  |
| 496 | 196.2 | Security for MBMS support in EPS | 261d? | 2008-12-11 A | 2009-12-10 A | 100% |  | 2008-12-11 | 2009-12-10 | 261d? |  | finish no earlier than 2009-12-10 | S3 | 2088h | 2088h | MBMS_EPS | PCG-22 | China Mobile | Liu Hong (liuhongyfw@chinamobile.com) | Rel-9 | SP-42 | Dionisio |  |
| 497 | 196.3 | MBMS Charging in EPS | 201d? | 2009-03-06 A | 2009-12-10 A | 100% |  | 2009-03-06 | 2009-12-10 | 201d? |  | finish no earlier than 2009-12-10 | S5 | 1600h | 1600h | MBMS_EPS | PCG-22 | ZTE | guo.wenjie1@zte.com.cn | Rel-9 | SP-43 | Dionisio |  |
| 498 | 196.4 | CT4 aspects of MBMS support in EPS (Stage 3) | 137d? | 2009-05-29 A | 2009-12-04 A | 100% |  | 2009-05-29 | 2009-12-04 | 137d? |  | finish no earlier than 2009-12-04 | C4 | 1096h | 1096h | MBMS_EPS | PCG-23 | China Mobile, ZTE | wangjingyf@chinamobile.com, lu.fei1@zte.com.cn | Rel-9 | CP-44 | Kimmo |  |
| 499 | 196.5 | CT3 aspects of MBMS support in EPS (Stage 3) | 137d? | 2009-05-29 A | 2009-12-04 A | 100% |  | 2009-05-29 | 2009-12-04 | 137d? |  | start no earlier than 2009-05-29 | C3 | 1096h | 1096h | MBMS_EPS | PCG-23 | ZTE, China Mobile | zhou.xiaoyun@zte.com.cn, wangjingyf@chinamobile.com | Rel-9 | CP-44 | Gwiho |  |
| 500 | 196.6 | MBMS support in LTE | 271d? | 2009-03-06 A | 2010-03-19 A | 100% |  | 2009-03-06 | 2010-03-19 | 271d? |  | finish no earlier than 2010-03-19 | R2,R3,R4 | 2168h | 2168h | MBMS_LTE | PCG-22 | Huawei | arnaud.meylan@huawei.com | Rel-9 | RP-43 | Joern | RP-100033 |
| 501 | 196.7 | Conformance Test Aspects – MBMS support in LTE | 331d? | 2010-12-10 | 2012-03-16 |  |  | 2010-12-10 | 2012-03-16 | 331d? | 195d | finish no earlier than 2012-03-16 | R5 | 2648h |  | MBMS_LTE-UEConTest | PCG-26 | Huawei | Zhang Xin (zhangxin0208@huawei.com) | Rel-9 | RP-50 | Ingbert |  |
| 502 | 197 | **Access Network Discovery and Selection Function enhancements** | 333d? | 2008-12-11 A | 2010-03-19 A | 100% |  | 2008-12-11 | 2010-03-19 | 333d? |  |  | S2,C1 | 4720h | 4720h | eANDSF | PCG-22 | Motorola | Apostolis Salkintzis (salki@motorola.com) | Rel-9 | SP-42 | Maurice |  |
| 503 | 197.1 | Stage 2 for Access Network Discovery and Selection Function enhancements | 126d? | 2008-12-11 A | 2009-06-04 A | 100% |  | 2008-12-11 | 2009-06-04 | 126d? |  | finish no earlier than 2009-06-04 | S2 | 1008h | 1008h | eANDSF | PCG-22 | Motorola | Apostolis Salkintzis (salki@motorola.com) | Rel-9 | SP-42 | Maurice |  |
| 504 | 197.2 | CT1 aspects of Access Network Discovery and Selection Function enhancements | 131d? | 2009-09-18 A | 2010-03-19 A | 100% |  | 2009-09-18 | 2010-03-19 | 131d? |  | finish no earlier than 2010-03-19 | C1 | 1048h | 1048h | eANDSF | PCG-23 | Panasonic | benjamin.limck@sg.panasonic.com | Rel-9 | CP-45 | Frederic |  |

Notes:
- 481: CP/SP#46 completed
- 482: SP#46 completed. SP#43 WID updated SP-080562=>SP-090099 (added location continuity aspects) / Text3: 23.870, 23.216, 23.237
- 483: CP#46 completed. WID updated CP-090436=>CP-090882 (added CT3 part)
- 484: CP#46 completed / Text3: 24.229, 24.237
- 485: CP#46 completed / Text3: 29.205, 29.280
- 486: CP#46 completed / Text3: 29.163
- 487: RP#48 Core completed/Test ongoing / Text3: LTE
- 488: Triggered by abandoned Study UID_380068 (FS_LCS_EPS). Linked to Feature UID_380064 Support for IMS Emergency Calls over GPRS and EPS
- 489: SP#44 completed / Text3: 23.891, 23.271, 23.401, 23.402
- 490: CP#47 completed (IANA registrations outstanding). Stage 3 SLs and SLg interfaces & transport of positioning messages between E-SMLC and MME in the scope of UID_420006 (Positioning Support for LTE) / Text3: 24.080, 29.002, 29.272, 29.230, new 24.171, 29.171, 29.172, 29.173
- 491: CP#47 completed / Text3: 24.301
- 492: RP#48 completed. UID_400038 (LCS Control Plane Solution for EPS) depends on this WI / Text3: 34.213, 36.133, 36.211, 36.214, 36.300, 36.305, 36.331, 36.355, 36.410, 36.413, 36.455, new 36.171
- 493: RP#50 completion 03/11=>09/11. TS 37.571-5 v100 for Information / Text3: 36.508, 36.509, 36.521-3, new (36.571-1/2/3/4, 37.571-5)
- 494: RP#47 completed. SP#46, CP#46 completed / Text3: LTE
- 495: SP#44 completed / Text3: 23.246
- 496: SP#46 completed / Text3: 33.246
- 497: SP#46 completed / Text3: 32.273, 32.251, 32.298, 32.299
- 498: CP#46 completed / Text3: 29.274, 29.281, 23.007, 23.008
- 499: CP#46 completed / Text3: 29.061
- 500: RP#47 completed / Text3: 25.446, 36.101, 36.104, 36.141, 36.300, 36.304, 36.321, 36.322, 36.323, 36.331, 36.440, 36.441, 36.442, 36.444, 36.445
- 501: - / Text3: 36.508, 36.521-1, 36.521-2, 36.523-1, 36.523-2, 36.523-3
- 502: CP#47 completed. No new Rel-9 use cases defined. Implement service requirements not covered in Rel-8 / Text3: 22.278, SA3 33.402 CR#0055
- 503: SP#44 completed / Text3: 23.402, 23.002
- 504: CP#47 completed / Text3: 24.302, 24.312

| ID | WBS | Task | Duration | Start | Finish | Complete | Baseline start | Baseline finish | Baseline duration | Constraint | Resources | Work | Actual work | Text1 | Text2 | Text4 | Text5 | Text6 | Text7 | Text8 | Text3 | Text11 |
| --- | --- | --- | --- | --- | --- | --- | --- | --- | --- | --- | --- | --- | --- | --- | --- | --- | --- | --- | --- | --- | --- | --- |
| 505 | 198 | **Multiple PDN Connection to the Same APN for PMIP-based Interfaces** | 267d? | 2009-03-13 A | 2010-03-19 A | 100% | 2009-03-13 | 2010-03-19 | 267d? |  | S2,C4,C1 | 4120h | 4120h | MUPSAP | PCG-22 | Samsung | erik.guttman@partner.samsung.com | Rel-9 | SP-43 | Maurice |  |  |
| 506 | 198.1 | Stage 2 for Multiple PDN Connection to the Same APN for PMIP-based Interfaces | 61d? | 2009-03-13 A | 2009-06-04 A | 100% | 2009-03-13 | 2009-06-04 | 61d? | finish no earlier than 2009-06-04 | S2 | 488h | 488h | MUPSAP | PCG-22 | Samsung | erik.guttman@partner.samsung.com | Rel-9 | SP-43 | Maurice | 23.060, 23.203, 23.401, 23.402 |  |
| 507 | 198.2 | CT4 aspects of Multiple PDN Connection to the Same APN for PMIP-based Interfaces | 56d? | 2009-09-18 A | 2009-12-04 A | 100% | 2009-09-18 | 2009-12-04 | 56d? | finish no earlier than 2009-12-04 | C4 | 448h | 448h | MUPSAP | PCG-23 | Samsung | Surjyakanta Mohapatra (surjya.kanta@samsung.com) | Rel-9 | CP-45 | Kimmo | 29.275, 23.008, 29.282 |  |
| 508 | 198.3 | CT1 aspects of Multiple PDN Connection to the Same APN for PMIP-based Interfaces | 131d? | 2009-09-18 A | 2010-03-19 A | 100% | 2009-09-18 | 2010-03-19 | 131d? | finish no earlier than 2010-03-19 | C1 | 1048h | 1048h | MUPSAP | PCG-23 | Samsung | Surjyakanta Mohapatra (surjya.kanta@samsung.com) | Rel-9 | CP-45 | Frederic | 24.302 |  |
| 509 | 199 | **System aspects of vocoder rate adaptation for LTE** | 140d? | 2009-05-30 A | 2009-12-10 A | 100% | 2009-05-30 | 2009-12-10 | 140d? |  | S2,S4,R2 | 3504h | 3504h | LTEimp-Vocoder | PCG-23 | Qualcomm | AC Mahendran (ac@qualcomm.com) | Rel-9 | SP-45 | Maurice | LTE |  |
| 510 | 199.1 | SA2 system aspects of vocoder rate adaptation for LTE | 81d? | 2009-06-04 A | 2009-09-24 A | 100% | 2009-06-04 | 2009-09-24 | 81d? | start no earlier than 2009-06-04 | S2 | 648h | 648h | LTEimp-Vocoder | PCG-23 | Qualcomm | AC Mahendran (ac@qualcomm.com) | Rel-9 | SP-45 | Maurice | 23.401 CR#1103r3 |  |
| 511 | 199.2 | SA4 system aspects of vocoder rate adaptation for LTE | 136d? | 2009-06-04 A | 2009-12-10 A | 100% | 2009-06-04 | 2009-12-10 | 136d? | finish no earlier than 2009-12-07 | S4 | 1088h | 1088h | LTEimp-Vocoder | PCG-23 | Qualcomm | Nikolai Leung | Rel-9 | SP-45 | Paolo | 26.114 |  |
| 512 | 199.3 | Vocoder rate adaptation for LTE | 81d? | 2009-05-30 A | 2009-09-18 A | 100% | 2009-05-30 | 2009-09-18 | 81d? | finish no earlier than 2009-09-18 | R2 | 648h | 648h | LTEimp-Vocoder | PCG-23 | Alcatel-Lucent | Sudeep Palat (spalat@alcatel-lucent.com) | Rel-9 | RP-44 | Joern | 36.300 CR#0114 | RP-090704 |
| 513 | 200 | Access Security Enhancements | 505d? | 2007-07-02 A | 2009-06-04 A | 100% | 2007-07-02 | 2009-06-04 | 505d? | finish no earlier than 2009-06-03 | S3 | 4040h | 4040h | ACCSEC2 |  | Ericsson | Bengt.Sahlin@ericsson.com | Rel-9 | SP-26 | Dionisio | 33.102, 43.020 |  |
| 514 | 201 | **Protection against Unsolicited Communication for IMS (PUCI)** | 322d? | 2008-09-18 A | 2009-12-10 A | 100% | 2008-09-18 | 2009-12-10 | 322d? |  | S3,S1 | 5640h | 5640h | PUCI | PCG-21 | NEC | Anand R. Prasad (anand@bq.jp.nec.com) | Rel-9 | SP-41 | Alain |  |  |
| 515 | 201.1 | Stage 1 for PUCI | 61d? | 2008-09-18 A | 2008-12-11 A | 100% | 2008-09-18 | 2008-12-11 | 61d? | finish no earlier than 2009-06-18 | S1 | 488h | 488h | PUCI | PCG-21 | NEC | Anand R. Prasad (anand@bq.jp.nec.com) | Rel-9 | SP-41 | Alain | 22.228 |  |
| 516 | 201.2 | SA3 work on PUCI | 322d? | 2008-09-18 A | 2009-12-10 A | 100% | 2008-09-18 | 2009-12-10 | 322d? | finish no earlier than 2009-12-10 | S3 | 2576h | 2576h | PUCI | PCG-21 | NEC | Anand R. Prasad (anand@bq.jp.nec.com) | Rel-9 | SP-41 | Dionisio | new 33.937 |  |
| 517 | 202 | **IMS Media Plane Security** | 322d? | 2009-03-13 A | 2010-06-04 A | 100% | 2009-03-13 | 2010-06-04 | 322d? |  | S3,C1,C4,C3 | 7755.2h | 7755.2h | MEDIASEC | PCG-22 | Vodafone | Peter.Howard@vodafone.com | Rel-9 | SP-43 | Dionisio |  |  |
| 518 | 202.1 | SA3 aspects of IMS Media Plane Security | 271d? | 2009-03-13 A | 2010-03-25 A | 100% | 2009-03-13 | 2010-03-25 | 271d? | finish no earlier than 2010-03-25 | S3 | 2168h | 2168h | MEDIASEC | PCG-22 | Vodafone | Peter.Howard@vodafone.com | Rel-9 | SP-43 | Dionisio | new 33.828, 33.328 |  |
| 519 | 202.2 | **CN aspects of IMS Media Plane Security** | 186d? | 2009-09-18 A | 2010-06-04 A | 100% | 2009-09-18 | 2010-06-04 | 186d? |  | C1,C4,C3 | 3011.2h | 3011.2h | MEDIASEC_CORE | PCG-23 | Vodafone | peter.dawes@vodafone.com | Rel-9 | CP-45 | Frederic |  |  |
| 520 | 202.2.1 | CT1 aspects of IMS Media Plane Security | 33d? | 2009-09-18 A | 2010-03-19 A | 100% | 2009-09-18 | 2010-03-19 | 33d? | finish no earlier than 2010-03-19 | C1 | 264h | 264h | MEDIASEC_CORE | PCG-23 | Vodafone | peter.dawes@vodafone.com | Rel-9 | CP-45 | Frederic | 23.218, 24.229 |  |
| 521 | 202.2.2 | CT4 aspects of IMS Media Plane Security | 131d? | 2009-09-18 A | 2010-03-19 A | 100% | 2009-09-18 | 2010-03-19 | 131d? | finish no earlier than 2010-03-19 | C4 | 1048h | 1048h | MEDIASEC_CORE | PCG-23 | Vodafone | peter.dawes@vodafone.com | Rel-9 | CP-45 | Kimmo | 29.238, 23.334, 29.334 |  |
| 522 | 202.2.3 | CT3 aspects of IMS Media Plane Security | 131d? | 2009-12-04 A | 2010-06-04 A | 100% | 2009-12-04 | 2010-06-04 | 131d? | finish no earlier than 2010-06-04 | C3 | 1048h | 1048h | MEDIASEC_CORE | PCG-24 | Vodafone | peter.dawes@vodafone.com | Rel-9 | CP-46 | Gwiho | 29.162 |  |
| 523 | 203 | **GBAPush enhancements (Generic push layer)** | 533d? | 2008-03-12 A | 2010-03-25 A | 100% | 2008-03-12 | 2010-03-25 | 533d? |  | S3 | 8528h | 8528h | eGBAPush | PCG-23 | Ericsson | Rolf Blom | Rel-9 | SP-44 | Dionisio | new 33.224 |  |
| 524 | 203.1 | SA3 part of eGBAPush (Generic push layer) | 533d? | 2008-03-12 A | 2010-03-25 A | 100% | 2008-03-12 | 2010-03-25 | 533d? | finish no earlier than 2010-03-25 | S3 | 4264h | 4264h | eGBAPush | PCG-21 | Ericsson | Rolf Blom | Rel-9 | SP-39 | Dionisio | new 33.224 |  |
| 525 | 204 | Extended Identity Management | 136d? | 2009-06-04 A | 2009-12-10 A | 100% | 2009-06-04 | 2009-12-10 | 136d? | finish no earlier than 2009-12-10 | S3 | 1088h | 1088h | GBA-IdM | PCG-23 | Nokia | Silke.Holtmanns@nokia.com | Rel-9 | SP-44 | Dionisio | new 33.924, CT4 29.109 (added service code) |  |
| 526 | 205 | **Network Domain Security (NDS) enhancements to support backhaul security** | 211d? | 2009-06-04 A | 2010-03-25 A | 100% | 2009-06-04 | 2010-03-25 | 211d? |  | S3,C4 | 4432h | 4432h | NDS_Backhaul | PCG-23 | Vodafone | Peter Howard | Rel-9 | SP-44 | Dionisio |  |  |
| 527 | 205.1 | SA3 part of Network Domain Security (NDS) enhancements to support backhaul security | 211d? | 2009-06-04 A | 2010-03-25 A | 100% | 2009-06-04 | 2010-03-25 | 211d? | finish no earlier than 2010-03-25 | S3 | 1688h | 1688h | NDS_Backhaul | PCG-23 | Vodafone | Peter Howard | Rel-9 | SP-44 | Dionisio | 33.102, 33.210, 33.310, 33.401, 33.402 |  |
| 528 | 205.2 | CT4 part of Network Domain Security (NDS) enhancements to support backhaul security | 132d? | 2009-06-04 A | 2009-12-04 A | 100% | 2009-06-04 | 2009-12-04 | 132d? | finish no earlier than 2009-12-04 | C4 | 1056h | 1056h | NDS_Backhaul | PCG-23 | Vodafone | Peter Howard | Rel-9 | SP-44 | Kimmo |  |  |

Notes:
- 505: CP#47 completed. Continues Rel-8 SAES Stage 2 UID_320005. Stage 1 in 22.278 (EPS Service requirements)
- 506: SP#44 completed
- 507: CP#46 completed
- 508: CP#47 completed
- 509: SP#46 completed. Triggered by RAN2 UID_440013 Vocoder rate adaptation for LTE
- 510: SP#45 completed (CR adding support for Explicit Congestion Notification)
- 511: SP#46 completed
- 512: RP#45 completed
- 513: SP#44 completed. Stopped TR 33.801. CRs 33.102,43.020 on A5/2 removal done long time ago. A5/4 introduction CRs will be done under UID_440057 128 bit encryption for GSM and GPRS. SP#26 approved WID (improved GERAN security)
- 514: SP#46 TR 33.937 completed but no specification work done in Rel-9. Related work in OMA Categorization Based Content Screening
- 515: SP#42 completed
- 516: SP#46 completed. No normative work done in Rel-9
- 517: CP#48 completed
- 518: SP#47 completed
- 519: CP#48 completed
- 520: CP#47 completed
- 521: CP#47 completed
- 522: CP#48 completed
- 523: SP#43 umbrella to host 33.224, moved from Rel-8 to Rel-9. SP#47 completed
- 524: SP#47 completed
- 525: SP#46 completed. Stage 1 not identified (GBA Liberty Interworking has been outlined and GBAOpenID interworking is analogous)
- 526: SP#47 completed. Continuation of Rel-8 UID_390044 SAE security architecture. Covers gaps in backhaul security in SAE (also applicable to UTRAN and GERAN backhaul)
- 527: SP#47 completed
- 528: CP#46 completed. No impact on CT4 specs

| ID | WBS | Task | Duration | Start | Finish | Complete | Baseline start | Baseline finish | Baseline duration | Constraint | Resources | Work | Actual work | Text1 | Text2 | Text4 | Text6 | Text7 | Text8 | Text9 | Text12 |
| --- | --- | --- | --- | --- | --- | --- | --- | --- | --- | --- | --- | --- | --- | --- | --- | --- | --- | --- | --- | --- | --- |
| 529 | 206 | **128 bit encryption for GSM and GPRS** | 136d? | 2009-06-04 A | 2009-12-10 A | 100% | 2009-06-04 | 2009-12-10 | 136d? |  | S3,C1,C4,G2,G3new | 6040h | 6040h | A5/4-GEA4 | PCG-23 | Ericsson | Rel-9 | SP-44 | Dionisio |  |  |
| 530 | 206.1 | SA3 part of 128 bit encryption for GSM and GPRS | 136d? | 2009-06-04 A | 2009-12-10 A | 100% | 2009-06-04 | 2009-12-10 | 136d? | finish no earlier than 2010-01-06 | S3 | 1088h | 1088h | A5/4-GEA4 | PCG-23 | Ericsson | Rel-9 | SP-44 | Dionisio |  |  |
| 531 | 206.2 | CT1 part of 128 bit encryption for GSM and GPRS | 77d? | 2009-06-04 A | 2009-09-18 A | 100% | 2009-06-04 | 2009-09-18 | 77d? | start no earlier than 2009-06-04 | C1 | 616h | 616h | A5/4-GEA4 | PCG-23 | Ericsson | Rel-9 | SP-44 | Frederic |  |  |
| 532 | 206.3 | CT4 part of 128 bit encryption for GSM and GPRS | 136d? | 2009-06-04 A | 2009-12-10 A | 100% | 2009-06-04 | 2009-12-10 | 136d? | start no earlier than 2009-06-04 | C4 | 1088h | 1088h | A5/4-GEA4 | PCG-23 | Ericsson | Rel-9 | SP-44 | Kimmo |  |  |
| 533 | 206.4 | GERAN2 part of 128 bit encryption for GSM and GPRS | 67d? | 2009-06-04 A | 2009-09-04 A | 100% | 2009-06-04 | 2009-09-04 | 67d? | finish no earlier than 2009-09-04 | G2 | 536h | 536h | A5/4-GEA4 | PCG-23 | Ericsson | Rel-9 | SP-44 | Gert |  |  |
| 534 | 206.5 | GERAN3new (testing) part of 128 bit encryption for GSM and GPRS | 122d? | 2009-06-04 A | 2009-11-20 A | 100% | 2009-06-04 | 2009-11-20 | 122d? | finish no earlier than 2009-11-20 | G3new | 976h | 976h | A5/4-GEA4 | PCG-23 | Ericsson | Rel-9 | SP-44 | Ingbert |  |  |
| 535 | 206.6 | Deleted - SA2 part of 128 bit encryption for GSM and GPRS | 81d? | 2009-06-04 A | 2009-09-24 A | 100% | 2009-06-04 | 2009-09-24 | 81d? | finish no earlier than 2009-09-24 | S2 | 648h | 648h | A5/4-GEA4 | PCG-23 | Ericsson | Rel-9 | SP-44 | Maurice | PCG-23 | SP-45 |
| 536 | 207 | Timed Graphics | 337d? | 2008-12-11 A | 2010-03-25 A | 100% | 2008-12-11 | 2010-03-25 | 337d? | finish no earlier than 2010-03-25 | S4 | 2696h | 2696h | TG | PCG-22 | Ericsson | Rel-9 | SP-42 | Paolo |  |  |
| 537 | 208 | Managing MTSI Media Adaptation | 272d? | 2009-03-12 A | 2010-03-25 A | 100% | 2009-03-12 | 2010-03-25 | 272d? | finish no earlier than 2009-12-10 | S4 | 1568h | 1568h | M3A | PCG-22 | Samsung | Rel-9 | SP-43 | Paolo |  |  |
| 538 | 209 | **PSS and MBMS Aspects** | 272d? | 2009-03-12 A | 2010-03-25 A | 100% | 2009-03-12 | 2010-03-25 | 272d? |  | S4 | 6512h | 6512h | PMA | PCG-23 | Ericsson, Nokia | Rel-9 | SP-44 | Paolo |  |  |
| 539 | 209.1 | PSS and MBMS extensions | 271d? | 2009-03-12 A | 2010-03-25 A | 100% | 2009-03-12 | 2010-03-25 | 271d? | finish no earlier than 2010-03-25 | S4 | 2168h | 2168h | PMA-MBS_Ext | PCG-22 | Ericsson | Rel-9 | SP-43 | Paolo |  |  |
| 540 | 209.2 | Improved Video Support for PSS and MBMS | 271d? | 2009-03-12 A | 2010-03-25 A | 100% | 2009-03-12 | 2010-03-25 | 271d? | finish no earlier than 2010-03-25 | S4 | 2168h | 2168h | PMA-IVS | PCG-22 | Nokia | Rel-9 | SP-43 | Paolo |  |  |
| 541 | 210 | IMS based PSS and MBMS User Service extensions | 197d? | 2009-03-12 A | 2009-12-10 A | 100% | 2009-03-12 | 2009-12-10 | 197d? | finish no earlier than 2009-12-10 | S4 | 1576h | 1576h | IMS_PSS_MBMS_US_EXT | PCG-22 | Ericsson | Rel-9 | SP-43 | Paolo |  |  |
| 542 | 211 | Syndicated Feed Reception within 3GPP environments | 136d? | 2009-06-04 A | 2009-12-10 A | 100% | 2009-06-04 | 2009-12-10 | 136d? | start no earlier than 2009-06-04 | S4 | 1088h | 1088h | SFR | PCG-23 | Ericsson | Rel-9 | SP-44 | Paolo |  |  |
| 543 | 212 | Distortion Measurement Test Methods and Requirements | 131d? | 2009-09-24 A | 2010-03-25 A | 100% | 2009-09-24 | 2010-03-25 | 131d? | finish no earlier than 2010-03-25 | S4 | 1048h | 1048h | DTMR | PCG-23 | Motorola | Rel-9 | SP-45 | Paolo |  |  |
| 544 | 213 | **OAM&P 9** | 601d? | 2008-02-22 A | 2010-06-10 A | 100% | 2008-02-22 | 2010-06-10 | 601d? |  | S5 | 36890.4h | 36890.4h | OAM9 | PCG-22 |  | Rel-9 | SP-42 | Dionisio |  |  |
| 545 | 213.1 | **Network Infrastructure Management** | 337d? | 2008-12-11 A | 2010-03-25 A | 100% | 2008-12-11 | 2010-03-25 | 337d? |  | S5 | 8760h | 8760h | OAM9-NIM | PCG-22 |  | Rel-9 | SP-42 | Dionisio |  |  |
| 546 | 213.1.1 | Software Management for Network Elements | 336d? | 2008-12-11 A | 2010-03-25 A | 100% | 2008-12-11 | 2010-03-25 | 336d? | finish no earlier than 2010-03-25 | S5 | 2688h | 2688h | OAM9-NE_SWM | PCG-22 | Huawei, Nokia Siemens Networks | Rel-9 | SP-42 | Dionisio |  |  |
| 547 | 213.1.2 | Service Oriented Architecture (SOA) for IRP | 211d? | 2009-06-04 A | 2010-03-25 A | 100% | 2009-06-04 | 2010-03-25 | 211d? | finish no earlier than 2010-03-25 | S5 | 1688h | 1688h | OAM9 | PCG-23 | Ericsson, Nokia Siemens Networks | Rel-9 | SP-44 | Dionisio |  |  |
| 548 | 213.1.3 | IRP SOAP Solution Sets continuation from Rel-8 | 211d? | 2009-06-04 A | 2010-03-25 A | 100% | 2009-06-04 | 2010-03-25 | 211d? | finish no earlier than 2010-03-25 | S5 | 1688h | 1688h | OAM9 | PCG-23 | Ericsson | Rel-9 | SP-44 | Dionisio |  |  |
| 549 | 213.2 | **Performance Management** | 327d? | 2009-03-12 A | 2010-06-10 A | 100% | 2009-03-12 | 2010-06-10 | 327d? |  | S5 | 7890.41h | 7890.41h | OAM9-PM | PCG-22 |  | Rel-9 | SP-42 | Dionisio |  |  |
| 550 | 213.2.1 | Enhancement of UTRAN Performance Measurements | 136d? | 2009-06-04 A | 2009-12-10 A | 100% | 2009-06-04 | 2009-12-10 | 136d? | start no earlier than 2009-06-04 | S5 | 1088h | 1088h | OAM9 | PCG-23 | China Mobile | Rel-9 | SP-44 | Dionisio |  |  |
| 551 | 213.2.2 | Enhancement of E-UTRAN Performance Measurements | 327d? | 2009-03-12 A | 2010-06-10 A | 100% | 2009-03-12 | 2010-06-10 | 327d? | finish no earlier than 2010-06-10 | S5 | 2616h | 2616h | OAM9 | PCG-22 | Motorola, Huawei | Rel-9 | SP-43 | Dionisio |  |  |
| 552 | 213.2.3 | Enhancement of EPC Performance Measurements | 197d? | 2009-03-12 A | 2009-12-10 A | 100% | 2009-03-12 | 2009-12-10 | 197d? | finish no earlier than 2010-03-25 | S5 | 1570.41h | 1570.41h | OAM9 | PCG-22 | China Mobile | Rel-9 | SP-43 | Dionisio |  |  |

Notes:
- 529: Allow 128 as an alternative to 64 bit keys (Stage 2/3 + Test spec) / Text5: Karl Norrman
- 530: SP#46 completed / Text3: 33.102,43.020, new 55.226 / Text5: Karl Norrman
- 531: CP#45 completed / Text3: 24.008,44.064 / Text5: Karl Norrman
- 532: CP#46 completed. Kc128 enhancements are carried as UMTS keys => no impact on CT4 29.002, 29.060 / Text5: Karl Norrman
- 533: GP#43 WID approved + completed / Text3: 44.018,48.008,48.018,48.058 / Text5: Karl Norrman
- 534: GP#44 completed. GP#43 WID approved / Text3: 51.010 / Text5: Karl Norrman
- 535: SP#45 work stopped/abandoned / Text3: 23.060 / Text5: Karl Norrman
- 536: SP#47 completed. Provide graphics in parallel to a video stream (without requiring an umbrella scene descriptor such as 3GPP DIMS in TS 26.142) / Text3: 26.114, 26.140, 26.234, 26.244, 26.245, 26.346, new 26.430 / Text5: clinton.priddle@ericsson.com
- 537: SP#46 completed. Work extending Rel-8 UID_34041 MTSI Video - Dynamic Rate Adaptation/Signalling of Image Size. Update speech/video adaptation algorithms used by network to control MTSI client terminal in congestion or poor transmission conditions. / Text3: 26.114 / Text5: kyunghun.jung@samsung.com
- 538: Umbrella WI / Text5: Clinton.Priddle@ericsson.com, imed.bouazizi@nokia.com
- 539: SP#47 completed. Extends Rel-8 UID_34043 (PSS_MBMS_OMTV) & ensures compatibility with UID_34046 (IMS_PSS_MBMS_US) / Text3: 26.234, 26.346 / Text5: Clinton.Priddle@ericsson.com
- 540: SP#47 completed / Text3: 26.234, 26.244, 26.346, new 26.903 / Text5: imed.bouazizi@nokia.com
- 541: SP#46 completed. Work extending Rel-8 UID_34046 (IMS_PSS_MBMS_US), SA2 UID_410034 IMSSCC-SPI (IMS Service Continuity Enhancements: Service, Policy and Interactions) / Text3: 26.237 / Text5: Markus Kampmann
- 542: SP#46 completed. TS 26.150v100 for Approval. RSS optimized for mobile use. Reuse/reference OMA's enabler DCD. / Text3: 26.150 / Text5: Thorsten.Lohmar@ericsson.com
- 543: SP#47 completed / Text3: 26.131, 26.132 / Text5: Stephen Kendall (wcsk01@motorola.com)
- 544: SP#42 umbrella Feature created to host OAM WIs / Text3: TR 30.819
- 545: SP#42 umbrella BB created to host OAM WIs
- 546: SP#47 completed / Text3: 32.531, 32.532, 32.533, new 32.537 / Text5: Bidipta Das (bidipta@huawei.com), Clemens Suerbaum (clemens.suerbaum@nsn.com)
- 547: SP#47 completed (covering SOA Architecture & SOA-supporting Solution Set). Triggered by UID_400029 Study on Service Oriented Architecture (SOA) for IRP (TR 32.824) / Text3: 32.101, 32.102, 32.150 / Text5: edwin.tse@ericsson.com, Jörg Schmidt (joerg@cox.net)
- 548: SP#47 completed. Continuation of Rel-8 UID_400030 IRP SOAP Solution Sets / Text3: New (32.127/ 327/ 337/ 357/ 387/ 397/ 447/ 397/ 447/ 507/ 537), 32.121,32.122,32.123,32,32.321,32.322,32.323,32.325,32.331,32.332,32.333,32.335,32.351,32.352,32.353,32.381,32.382,32.383,32.385,32.391,32.392,32.393,32.395,32.441,32.442,32.443 / Text5: John Power
- 549: SP#42 umbrella BB created to host OAM WIs
- 550: SP#46 completed / Text3: 32.405 / Text5: Liang Shuangchun (liangshuangchun@cmdi.chinamobile.com), Li Jian (lijian@chinamobile.com), Bao Haitao
- 551: SP#48 completed / Text3: 32.425 / Text5: Yizhi Yao (yzyao@motorola.com),Lan Zou (zlan@huawei.com)
- 552: SP#46 completed / Text3: 32.426 / Text5: Li Jian (lijian@chinamobile.com), Liang Shuangchun (liangshuangchun@cmdi.chinamobile.com)

| ID | WBS | Task | Duration | Start | Finish | Complete | Baseline start | Baseline finish | Baseline duration | Constraint | Resources | Work | Actual work | Text1 | Text2 | Text6 | Text7 | Text8 | Text3 | Text4 | Text5 | Text9 | Text12 |
| --- | --- | --- | --- | --- | --- | --- | --- | --- | --- | --- | --- | --- | --- | --- | --- | --- | --- | --- | --- | --- | --- | --- | --- |
| 553 | 213.3 | **Self-Organizing Networks (SON) - OAM aspects** | 601d? | 2008-02-22 A | 2010-06-10 A | 100% | 2008-02-22 | 2010-06-10 | 601d? |  | S5 | 11736h | 11736h | OAM9-SON | PCG-22 | Rel-9 | SP-43 | Dionisio |  |  |  |  |  |
| 554 | 213.3.1 | SON self-optimization management | 600d? | 2008-02-22 A | 2010-06-10 A | 100% | 2008-02-22 | 2010-06-10 | 600d? | finish no earlier than 2010-06-10 | S5 | 4800h | 4800h | LTE_SON-OAM | PCG-21 | Rel-9 | SP-39 | Dionisio | 32.425, new (32.521, 32.522, 32.523, 32.525) | Huawei | Lan Zou (zlan@huawei.com) |  |  |
| 555 | 213.3.2 | Automatic Radio Network Configuration Data Preparation | 266d? | 2009-06-04 A | 2010-06-10 A | 100% | 2009-06-04 | 2010-06-10 | 266d? | finish no earlier than 2010-06-10 | S5 | 2128h | 2128h | OAM9 | PCG-23 | Rel-9 | SP-44 | Dionisio | 32.501, 32.502, 32.503, 32.505, new 32.507 | Nokia Siemens Networks | clemens.suerbaum@nsn.com |  |  |
| 556 | 213.4 | Subscription Management (SuM) evolution | 266d? | 2009-06-04 A | 2010-06-10 A | 100% | 2009-06-04 | 2010-06-10 | 266d? | finish no earlier than 2010-06-10 | S5 | 2128h | 2128h | OAM9-SuM | PCG-23 | Rel-9 | SP-44 | Dionisio | 32.140, 32.141, 32.152, 32.172, 32.175 | Ericsson | frode.nergard@ericsson.com |  |  |
| 557 | 213.5 | Deleted - Trace | 196d? | 2009-03-13 A | 2009-12-10 A | 100% | 2009-03-13 | 2009-12-10 | 196d? | finish no earlier than 2009-12-10 | S5 | 1568h | 1568h | OAM9-Trace | PCG-22 | Rel-9 | SP-42 | Dionisio |  |  |  | PCG-24 | SP-46 |
| 558 | 214 | Charging Management small Enhancements | 211d? | 2009-06-04 A | 2010-03-25 A | 100% | 2009-06-04 | 2010-03-25 | 211d? |  | S5 | 1688h | 1688h | CH9 | PCG-23 | Rel-9 | SP-44 | Dionisio | TR 30.819 |  |  |  |  |
| 559 | 215 | **CS-IBCF and CS-TrGW definition in 3GPP specifications** | 472d? | 2008-05-30 A | 2010-03-19 A | 100% | 2008-05-30 | 2010-03-19 | 472d? |  | C3,C4 | 10714.3h | 10714.3h | CS-IBCF | PCG-21 | Rel-9 | CP-40 | Gwiho |  | Telecom Italia | mauro.ficaccio@telecomitalia.it |  |  |
| 560 | 215.1 | CT3 aspects of CS-IBCF and CS-TrGW definition in 3GPP specifications | 472d? | 2008-05-30 A | 2010-03-19 A | 100% | 2008-05-30 | 2010-03-19 | 472d? | finish no earlier than 2009-12-04 | C3 | 3770.34h | 3770.34h | CS-IBCF | PCG-21 | Rel-9 | CP-40 | Gwiho | 29.235 | Telecom Italia | mauro.ficaccio@telecomitalia.it |  |  |
| 561 | 215.2 | CT4 aspects of CS-IBCF and CS-TrGW definition in 3GPP specifications | 396d? | 2008-05-30 A | 2009-12-04 A | 100% | 2008-05-30 | 2009-12-04 | 396d? | finish no earlier than 2009-12-04 | C4 | 3168h | 3168h | CS-IBCF | PCG-21 | Rel-9 | CP-40 | Kimmo | 23.231, 29.232, new 29.238 | Telecom Italia | mauro.ficaccio@telecomitalia.it |  |  |
| 562 | 216 | **IMS – Interconnection Border Control Function (IBCF) – Transition Gateway (TrGW); Ix Interface; Stage 3** | 322d? | 2008-09-12 A | 2009-12-04 A | 100% | 2008-09-12 | 2009-12-04 | 322d? |  | C4,C3 | 6858.4h | 6858.4h | IMS_IBCF | PCG-21 | Rel-9 | CP-41 | Kimmo |  | Alcatel-Lucent | Bruno.Landais@alcatel-lucent.fr |  |  |
| 563 | 216.1 | CT4 part of IMS – Interconnection Border Control Function (IBCF) – Transition Gateway (TrGW); Ix Interface; Stage 3 | 321d? | 2008-09-12 A | 2009-12-04 A | 100% | 2008-09-12 | 2009-12-04 | 321d? | finish no earlier than 2009-12-04 | C4 | 2568h | 2568h | IMS_IBCF | PCG-21 | Rel-9 | CP-41 | Kimmo | new 29.238 | Alcatel-Lucent | Bruno.Landais@alcatel-lucent.fr |  |  |
| 564 | 216.2 | CT3 part of IMS – Interconnection Border Control Function (IBCF) – Transition Gateway (TrGW); Ix Interface; Stage 3 | 295.8d? | 2008-09-12 A | 2009-12-04 A | 100% | 2008-09-12 | 2009-12-04 | 295.8d? | finish no earlier than 2010-03-19 | C3 | 2366.4h | 2366.4h | IMS_IBCF | PCG-21 | Rel-9 | CP-41 | Gwiho | 29.162, 29.235 | Alcatel-Lucent | Bruno.Landais@alcatel-lucent.fr |  |  |
| 565 | 217 | IMS Application Level Gateway Control Function (ALGCF) – IMS Access Media Gateway (IMA-MGW); Iq Interface; Stage 2 and Stage 3 | 321d? | 2008-09-12 A | 2009-12-04 A | 100% | 2008-09-12 | 2009-12-04 | 321d? | finish no earlier than 2009-12-04 | C4 | 2568h | 2568h | IMS_AGCF | PCG-21 | Rel-9 | CP-41 | Kimmo | new 23.334, 29.334 | Alcatel-Lucent | bruno.landais@alcatel-lucent.fr |  |  |
| 566 | 218 | **Enhancements of IMS Customized Alerting Tone (CAT) Service** | 392d? | 2008-12-05 A | 2010-06-04 A | 100% | 2008-12-05 | 2010-06-04 | 392d? |  | C1 | 5846.4h | 5846.4h | eCAT | PCG-22 | Rel-9 | CP-42 | Frederic |  | China Mobile | Jiang Yi |  |  |
| 567 | 218.1 | Stage 3 for Enhancements of IMS Customized Alerting Tone (CAT) Service | 391d? | 2008-12-05 A | 2010-06-04 A | 100% | 2008-12-05 | 2010-06-04 | 391d? | finish no earlier than 2010-06-04 | C1 | 3128h | 3128h | eCAT-SS | PCG-22 | Rel-9 | CP-42 | Frederic | 24.182 | China Mobile | Jiang Yi |  |  |
| 568 | 219 | **Completion of IMS Restoration Procedures** | 212d? | 2009-05-29 A | 2010-03-19 A | 100% | 2009-05-29 | 2010-03-19 | 212d? |  | C3, C4,C1 | 6784h | 6784h | eIMS_RP | PCG-23 | Rel-9 | CP-44 | Kimmo |  | Ericsson | Emiliano Merino (emiliano.merino@ericsson.com) |  |  |
| 569 | 219.1 | CT4 aspects of Completion of IMS Restoration Procedures | 212d? | 2009-05-29 A | 2010-03-19 A | 100% | 2009-05-29 | 2010-03-19 | 212d? | finish no earlier than 2010-03-19 | C4 | 1696h | 1696h | eIMS_RP | PCG-23 | Rel-9 | CP-44 | Kimmo | 23.380, 23.820 | Ericsson | Emiliano Merino (emiliano.merino@ericsson.com) |  |  |
| 570 | 219.2 | CT1 aspects of Completion of IMS Restoration Procedures | 212d? | 2009-05-29 A | 2010-03-19 A | 100% | 2009-05-29 | 2010-03-19 | 212d? | finish no earlier than 2010-03-19 | C1 | 1696h | 1696h | eIMS_RP | PCG-23 | Rel-9 | CP-44 | Kimmo | 24.229 | Ericsson | Emiliano Merino (emiliano.merino@ericsson.com) |  |  |
| 571 | 219.3 | CT3 aspects of Completion of IMS Restoration Procedures | 212d? | 2009-05-29 A | 2010-03-19 A | 100% | 2009-05-29 | 2010-03-19 | 212d? | finish no earlier than 2010-03-19 | C3 | 1696h | 1696h | eIMS_RP | PCG-24 | Rel-9 | CP-46 | Kimmo | 29.061, 29.212, 29.213, 29.214, 29.215 | Ericsson | Emiliano Merino (emiliano.merino@ericsson.com) |  |  |
| 572 | 220 | IMS Stage 3 - IETF Protocol Alignment | 212d? | 2009-05-29 A | 2010-03-19 A | 100% | 2009-05-29 | 2010-03-19 | 212d? | finish no earlier than 2010-03-19 | C1 | 1696h | 1696h | IMSProtoc3 | PCG-23 | Rel-9 | CP-44 | Frederic | 23.218, 24.229, 24.930 | Alcatel-Lucent | Keith Drage (drage@alcatel-lucent.com) |  |  |
| 573 | 221 | Operational description of the Inter-IMS Network to Network Interface (II-NNI) | 267d? | 2009-05-29 A | 2010-06-04 A | 100% | 2009-05-29 | 2010-06-04 | 267d? | finish no earlier than 2010-06-04 | C3 | 2136h | 2136h | II-NNI | PCG-23 | Rel-9 | CP-44 | Gwiho | 29.165 | Orange | sebastien.daudet@orange-ftgroup.com |  |  |
| 574 | 222 | Definition of Ml interface for Control Plane LCS (Stage 3) | 131d? | 2009-09-18 A | 2010-03-19 A | 100% | 2009-09-18 | 2010-03-19 | 131d? | finish no earlier than 2010-03-19 | C1 | 1048h | 1048h | EMC2 | PCG-23 | Rel-9 | CP-45 | Frederic | 24.229 | Alcatel-Lucent | Keith Drage (drage@alcatel-lucent.com) |  |  |
| 575 | 223 | PCC enhancements | 56d? | 2009-09-18 A | 2009-12-04 A | 100% | 2009-09-18 | 2009-12-04 | 56d? | finish no earlier than 2009-12-04 | C3 | 448h | 448h | PCC-Enh | PCG-23 | Rel-9 | CP-45 | Gwiho | 29.212, 29.213, 29.215 | Huawei | Wei Weihua (weiwh@huawei.com) |  |  |
| 576 | 224 | 3GPP IMS Conferencing Management Object (MO) | 2d? | 2009-12-03 A | 2009-12-04 A | 100% | 2009-12-03 | 2009-12-04 | 2d? | start no earlier than 2009-12-03 | C1 | 16h | 16h | IMS_ConfMO | PCG-24 | Rel-9 | CP-46 | Frederic | new 24.166 |  |  |  |  |
| 577 | 225 | In Case of Emergency (ICE) Graphics | 3d? | 2010-03-17 A | 2010-03-19 A | 100% | 2010-03-17 | 2010-03-19 | 3d? | finish no earlier than 2010-03-19 | C6 | 24h | 24h | ICE_Graphics | PCG-24 | Rel-9 | CP-47 | Xavier | 31.102 CR#0433 | Sagem-Orga | heiko.kruse@sagem-orga.com |  |  |

Notes:
- 553: SP#43 umbrella BB created to host OAM WIs
- 554: SP#48 completed
- 555: SP#48 completed
- 556: SP#48 completed
- 557: SP#46 stopped (no work in Rel-9)
- 558: SP#47 completed
- 559: CP#47 completed. Rel-8 UID_380061 (Ipinterc) covers Stage 1 in SA1 22.101, 22.228
- 560: CP#47 completed
- 561: CP#46 completed
- 562: CP#46 completed
- 563: CP#46 completed
- 564: CP#46 completed
- 565: CP#46 completed
- 566: CP#48 completed. Stage 1 in 22.182
- 567: CP#48 completed
- 568: CP#47 completed. Continuation of Rel-8 Feature UID_400012 IMS Restoration Procedures
- 569: CP#47 completed
- 570: CP#47 completed
- 571: CP#47 completed
- 572: CP#47 completed
- 573: CP#48 completed
- 574: CP#47 completed [Stage 3 for Rel-7 Emergency Calls (EMC1)]. Related to Rel-9 UID_400038 LCS Control Plane Solution for EPS. Stage 2 in Rel-9 UID_400038 (23.271), UID_410037 (23.167)
- 575: CP#46 completed
- 576: CP#46 completed. Linked to Rel-6 UID_11051 (IMS Management objects) under the Feature UID_32021 (IMS Phase 2). MO compatible with OMA DM v1.2 & upwards and defined using OMA DM Device Description Framework (OMA-ERELD _DM-V1_2)
- 577: CP#47 approved WID and completed. Added capability to store ICE graphical information (picture). Linked to CT6 Rel-8 ICE Feature UID_380059 In Case of Emergency numbers storage and easy access on UICC

| ID | WBS | Task | Duration | Start | Finish | Complete | Remaining | Baseline start | Baseline finish | Baseline duration | Total slack | Constraint | Resources | Work | Actual work | Text1 | Text2 | Text6 | Text7 | Text8 | Text4 | Text5 | Text11 |
| --- | --- | --- | --- | --- | --- | --- | --- | --- | --- | --- | --- | --- | --- | --- | --- | --- | --- | --- | --- | --- | --- | --- | --- |
| 578 | 226 | **Rel-9 Improvements of the Radio Interface** | 397d? | 2008-09-12 A | 2010-03-19 A | 100% |  | 2008-09-12 | 2010-03-19 | 397d? |  |  | RP,GP | 19147.6h | 19147.6h | RInImp9 | PCG-21 | Rel-9 | RP-41 | Issam |  |  |  |
| 579 | 226.1 | LCR TDD UE OTA Performance Requirements | 186d? | 2008-09-12 A | 2009-05-29 A | 100% |  | 2008-09-12 | 2009-05-29 | 186d? |  | finish no earlier than 2009-05-29 | R4 | 1488h | 1488h | RInImp9-RFLCROTA | PCG-21 | Rel-9 | RP-41 | Issam | RITT | Wu Xiang (wuxiang@chinattl.com) | RP-090389 |
| 580 | 226.2 | **RF requirements for Multicarrier and Multi-RAT BS** | 347d? | 2008-11-21 A | 2010-03-19 A | 100% |  | 2008-11-21 | 2010-03-19 | 347d? |  |  | R4,G1 | 7403.6h | 7403.6h | RInImp9-RFmulti | PCG-21 | Rel-9 | RP-41 | Issam | Ericsson | Johan.skold@ericsson.com |  |
| 581 | 226.2.1 | RAN4 part of RF requirements for Multicarrier and Multi RAT BS | 337d? | 2008-12-05 A | 2010-03-19 A | 100% |  | 2008-12-05 | 2010-03-19 | 337d? |  | finish no earlier than 2010-03-19 | R4 | 2696h | 2696h | RInImp9-Rfmulti | PCG-22 | Rel-9 | RP-42 | Issam | Ericsson | Johan.skold@ericsson.com | RP-100027 |
| 582 | 226.2.2 | GERAN part of RF requirements for Multicarrier and Multi RAT BS | 261d? | 2008-11-21 A | 2009-11-20 A | 100% |  | 2008-11-21 | 2009-11-20 | 261d? |  | finish no earlier than 2009-11-20 | G1 | 2088h | 2088h | RInImp9-RFmulti-GERAN | PCG-22 | Rel-9 | GP-40 | Paolo | Ericsson | mats.y.samuelsson@ericsson.com |  |
| 583 | 226.3 | Extended UMTS/LTE 800 MHz | 207d? | 2008-12-05 A | 2009-09-18 A | 100% |  | 2008-12-05 | 2009-09-18 | 207d? |  |  | R4,R2,R3 | 1648h | 1648h | RInImp9-UMTSLTE800 | PCG-22 | Rel-9 | RP-42 | Issam | NTT DoCoMo | Shingo Suwa (suwas@nttdocomo.co.jp) | RP-090687 |
| 584 | 226.4 | UMTS/LTE 800 MHz for Europe | 272d? | 2009-03-06 A | 2010-03-19 A | 100% |  | 2009-03-06 | 2010-03-19 | 272d? |  | finish no earlier than 2010-03-19 | R4,R2,R3 | 2176h | 2176h | RInImp9-UMTSLTE800EU | PCG-22 | Rel-9 | RP-43 | Issam | Ericsson | olav.queseth@ericsson.com | RP-100028 |
| 585 | 226.5 | Performance requirement for LCR TDD with UE speeds up to 350 km/h | 196d? | 2009-03-06 A | 2009-12-04 A | 100% |  | 2009-03-06 | 2009-12-04 | 196d? |  | finish no earlier than 2009-12-04 | R4 | 1568h | 1568h | RInImp9-LCRTDD350 | PCG-22 | Rel-9 | RP-43 | Issam | CATT | Yuexia Song (songyuexia@datangmobile.cn) | RP-091035 |
| 586 | 226.6 | Extended UMTS/LTE 1500 MHz | 211d? | 2009-05-30 A | 2010-03-19 A | 100% |  | 2009-05-30 | 2010-03-19 | 211d? |  | finish no earlier than 2010-03-19 | R4,R2,R3 | 1688h | 1688h | UMTSLTE1500 | PCG-23 | Rel-9 | RP-44 | Issam | NTT DoCoMo | Shingo Suwa (suwas@nttdocomo.co.jp) | RP-100029 |
| 587 | 227 | **Rel-9 Improvements of the Radio Interface - UE Conformance Testing** | 350d? | 2009-05-19 A | 2010-09-17 A | 100% |  | 2009-05-19 | 2010-09-17 | 350d? |  |  | R5 | 8184h | 8184h | RInImp-UEConTest | PCG-23 | Rel-9 | RP-44 | Ingbert |  |  |  |
| 588 | 227.1 | Conformance Test Aspects – UMTS/LTE in 800 MHz for Europe | 350d? | 2009-05-19 A | 2010-09-17 A | 100% |  | 2009-05-19 | 2010-09-17 | 350d? |  | finish no earlier than 2010-09-17 | R5 | 2800h | 2800h | RInImp-UEConTest-UMTSLTE800EU | PCG-23 | Rel-9 | RP-44 | Ingbert | Ericsson | fredrik.sundstrom@ericsson.com | RP-100736 |
| 589 | 227.2 | Conformance Test Aspects – Extended UMTS/LTE 1500 MHz | 186d? | 2009-09-18 A | 2010-06-04 A | 100% |  | 2009-09-18 | 2010-06-04 | 186d? |  | finish no earlier than 2010-06-04 | R5 | 1488h | 1488h | UMTSLTE1500_UEConTest | PCG-23 | Rel-9 | RP-45 | Ingbert | NTT DoCoMo | Nguyen Dung Dao (dao@nttdocomo.co.jp) | RP-100487 |
| 590 | 227.3 | TDD UE Over The Air (Antenna) conformance testing methodology | 81d? | 2009-05-30 A | 2009-09-18 A | 100% |  | 2009-05-30 | 2009-09-18 | 81d? |  | finish no earlier than 2009-09-18 | R5 | 648h | 648h | UEAnt_TDDTest | PCG-23 | Rel-9 | RP-44 | Ingbert | CATR | Qu Yan (quyan@emcite.com) | RP-090727 |
| 591 | 227.4 | Conformance Test Aspects – Performance requirement for LCR TDD with UE speeds up to 350 km/h | 56d? | 2010-03-19 A | 2010-06-04 A | 100% |  | 2010-03-19 | 2010-06-04 | 56d? |  | finish no earlier than 2010-06-04 | R5 | 448h | 448h | RInImp9-LCRTDD350_UEConTest | PCG-24 | Rel-9 | RP-47 | Ingbert | CATT | Xiaozhong Chen (chexiaozhong@datangmobile.cn) | RP-100496 |
| 592 | 228 | Conformance Test Aspects – SMS over IMS in E-UTRAN | 131d? | 2009-09-18 A | 2010-03-19 A | 100% |  | 2009-09-18 | 2010-03-19 | 131d? |  | finish no earlier than 2010-06-18 | R5 | 1048h | 1048h | SMSoverIMS_UEConTest | PCG-23 | Rel-9 | RP-45 | Ingbert | Alcatel-Lucent | Nidal Khrais (khrais@alcatel-lucent.com) | RP-100072 |
| 593 | 229 | **Rel-9 RAN improvements** | 272d? | 2009-03-06 A | 2010-03-19 A | 100% |  | 2009-03-06 | 2010-03-19 | 272d? |  |  | RP | 9536h | 9536h | RANimp | PCG-22 | Rel-9 | RP-43 | Issam |  |  |  |
| 594 | 229.1 | Dual-Cell HSUPA | 272d? | 2009-03-06 A | 2010-03-19 A | 100% |  | 2009-03-06 | 2010-03-19 | 272d? |  | finish no earlier than 2010-03-19 | R1,R2,R3,R4 | 1568h | 1568h | RANimp-DC_HSUPA | PCG-22 | Rel-9 | RP-43 | Patrick | Nokia Siemens Networks | Karri Ranta-aho (karri.ranta-aho@nsn.com) | RP-100030 |
| 595 | 229.2 | Support for different bands for Dual-Cell HSDPA | 197d? | 2009-03-06 A | 2009-12-04 A | 100% |  | 2009-03-06 | 2009-12-04 | 197d? |  |  | R4,R2,R3 | 1568h | 1568h | RANimp-MultiBand_DC_HSDPA | PCG-22 | Rel-9 | RP-43 | Issam | Nokia Siemens Networks | Tuomo Säynäjäkangas (tuomo.saynajakangas@nsn.com) | RP-091038 |
| 596 | 229.3 | Combination of DC-HSDPA with MIMO | 197d? | 2009-03-06 A | 2009-12-04 A | 100% |  | 2009-03-06 | 2009-12-04 | 197d? |  |  | R1,R2,R3,R4 | 1568h | 1568h | RANimp-DC_MIMO | PCG-22 | Rel-9 | RP-43 | Patrick | Ericsson | johan.bergman@ericsson.com | RP-091039 |
| 597 | 229.4 | Transmit Antenna Array (TxAA) extension for non-MIMO UEs | 197d? | 2009-03-06 A | 2009-12-04 A | 100% |  | 2009-03-06 | 2009-12-04 | 197d? |  |  | R1,R2,R3,R4 | 1568h | 1568h | RANimp-TxAA_nonMIMO | PCG-22 | Rel-9 | RP-43 | Patrick | Nokia | Arto Lehti (arto.lehti@nokia.com) | RP-091040 |
| 598 | 229.5 | Cell Portion for 1.28 Mcps TDD | 136d? | 2009-05-30 A | 2009-12-04 A | 100% |  | 2009-05-30 | 2009-12-04 | 136d? |  |  | R3,R1,R4 | 1088h | 1088h | CP_LCRTDD | PCG-23 | Rel-9 | RP-44 | Juha | CATT | Ying Zhang (zhangying2@datangmobile.cn) | RP-091041 |
| 599 | 230 | **Rel-9 RAN improvements - UE Conformance Testing** | 196d? | 2010-09-17 A | 2011-06-17 | 25% | 147d? | 2010-09-17 | 2011-06-17 | 196d? | 390d |  | R5 | 3136h | 784h |  | PCG-25 | Rel-9 | RP-49 | Ingbert |  |  |  |
| 600 | 230.1 | Conformance Test Aspects – Combination of DC-HSDPA with MIMO | 196d? | 2010-09-17 A | 2011-06-17 | 25% | 147d? | 2010-09-17 | 2011-06-17 | 196d? | 390d | finish no earlier than 2011-06-17 | R5 | 1568h | 392h | RANimp-DC_MIMO_UEConTest | PCG-25 | Rel-9 | RP-49 | Ingbert | Ericsson | leif.mattisson@ericsson.com | RP-101076 |
| 601 | 231 | **LTE improvements** | 532d? | 2009-03-06 A | 2011-03-18 | 79% | 110.53d? | 2009-03-06 | 2011-03-18 | 532d? | 455d |  | RP | 9048h | 7005.54h | LTEimp | PCG-22 | Rel-9 | RP-42 | Patrick |  |  |  |
| 602 | 231.1 | LTE Pico NodeB RF Requirements | 196d? | 2009-03-06 A | 2009-12-04 A | 100% |  | 2009-03-06 | 2009-12-04 | 196d? |  | finish no earlier than 2010-03-05 | R4 | 1568h | 1568h | LTEimp-Pico_eNB-RF | PCG-22 | Rel-9 | RP-43 | Issam | Huawei | Liyan Yin (yinliyan@huawei.com) | RP-091045 |
| 603 | 231.2 | Enhanced Dual-Layer transmission for LTE | 272d? | 2009-03-06 A | 2010-03-19 A | 100% |  | 2009-03-06 | 2010-03-19 | 272d? |  | finish no earlier than 2010-03-18 | R1,R2,R4 | 2176h | 2176h | LTEimp-eDL | PCG-22 | Rel-9 | RP-43 | Patrick | China Mobile | Xu Xiaodong (xuxiaodong@chinamobile.com) | RP-100034 |
| 604 | 231.3 | UE Conformance Test Aspects – Enhanced Dual-layer transmission for LTE TDD | 131d? | 2010-09-17 A | 2011-03-18 | 5% | 124.45d? | 2010-09-17 | 2011-03-18 | 131d? | 455d | finish no earlier than 2011-03-18 | R5 | 1048h | 52.4h | LTEimp-eDL_UEConTest | PCG-25 | Rel-9 | RP-49 | Ingbert | China Mobile | Shanpeng Xiao (xiaoshanpeng@chinamobile.com) | RP-101075 |
| 605 | 232 | Self-Organizing Networks (SON) | 272d? | 2009-03-06 A | 2010-03-19 A | 100% |  | 2009-03-06 | 2010-03-19 | 272d? |  | finish no earlier than 2010-03-19 | R3,R2 | 2176h | 2176h | SON | PCG-22 | Rel-9 | SP-42 | Juha | Nokia Siemens Networks | krzysztof.kordybach@nsn.com | RP-100038 |

Notes:
- 578: RP#41 umbrella Feature created to host Rel-9 WIs / Text3: GERA, UTRA, LTE
- 579: RP#44 completed technical work (RAN4 internal TR abandoned) / Text3: UTRA (no TR 25.8xy produced)
- 580: RP#47 completed. RF requirements specification applicable to Multi-Standard Radio (MSR) Base Station with multiple carriers and/or multiple 3GPP Radio Access Technologies (RAT) / Text3: GERA, UTRA, LTE
- 581: RP#48 completed / Text3: UTRA, LTE 25.104, 25.105, 36.104, new 37.104, 37.113, 37.141, 37.900
- 582: GP#44 Core spec completed (ongoing BS conformance spec). GP#40 WID approved / Text3: GERA 45.005, 51.021
- 583: RP#45 completed / Text3: UTRA, LTE 25.101, 25.104, 25.113, 25.133, 34.124, 36.101, 36.104, 36.113, 36.124, 36.133, 36.141, 25.306, 25.307, 25.331, 36.331, 25.461, 25.466, new 36.800
- 584: RP#47 completed / Text3: UTRA, LTE 25.101, 25.104, 25.113, 25.133, 25.141, 34.124, 36.101, 36.104, 36.113, 36.124, 36.133, 36.141, new 36.810, 25.306, 25.307, 25.331, 36.331, 25.461, 25.466
- 585: RP#46 completed / Text3: UTRA 25.102, 25.105, 25.142
- 586: RP#47 completed. For potential deployment in Japan / Text3: UTRA, LTE 25.101, 25.104, 25.113, 25.133, 25.141, 25.306, 25.307, 25.331, 25.461, 25.466, 34.124, 36.101, 36.104, 36.113, 36.124, 36.133, 36.141, 36.331, new (36.821, 36.307)
- 587: - / Text3: UTRA, LTE
- 588: RP#49 completed. Testing for UID_430009 UMTS/LTE 800 MHz for Europe / Text3: UTRA, LTE 34.108, 34.121-1, 34.121-2, 36.508, 36.521-1, 36.521-2, 36.521-3
- 589: RP#48 completed / Text3: UTRA, LTE 34.108, 34.121-1, 34.121-2, 34.123-1, 34.123-2, 36.508, 36.521-1, 36.521-2, 36.521-3, 36.523-1, 36.523-2, 36.523-3
- 590: RP#45 completed. Finalized TDD UE test methodology based on R4 TR 25.914 (UE and MS antenna performance evaluation method) and TS 25.144 Over the Air (Antenna) minimum performance requirements for the speech mode (terminal close to head) / Text3: UTRA 34.114
- 591: RP#48 completed. Testing for UID_430010 Performance requirement for LCR TDD with UE speeds up to 350 km/h / Text3: UTRA 34.122
- 592: RP#47 completed / Text3: LTE 34.229-1, 34.229-2, 34.229-3
- 593: RP#47 completed / Text3: UTRA
- 594: RP#47 completed / Text3: 25.101, 25.104, 25.133, 25.211, 25.212, 25.213, 25.214, 25.215, 25.319, 25.306, 25.321, 25.331, 25.423, 25.433
- 595: RP#46 completed / Text3: 25.101, 25.104, 25.133, 25.306, 25.308, 25.331, 25.423, 25.433, new 25.317 (Requirements on Ues supporting a release-independent frequency band combination)
- 596: RP#46 completed / Text3: 25.101, 25.104, 25.133, 25.211, 25.212, 25.213, 25.214, 25.215, 25.308, 25.321, 25.331, 26.306, 25.423, 25.433
- 597: RP#46 completed / Text3: 25.101, 25.104, 25.211, 25.212, 25.213, 25.214, 25.215, 25.308, 25.306, 25.321, 25.331, 25.423, 25.433
- 598: RP#46 completed / Text3: 25.102, 25.105, 25.123, 25.225, 25.423, 25.433
- 599: -
- 600: UTRA. Testing for Rel-9 UID_430016 Combination of DC-HSDPA with MIMO / Text3: UTRA 34.108, 34.121-1, 34.121-2, 34.123-1, 34.123-2, 34.123-3
- 601: - / Text3: LTE
- 602: RP#46 completed / Text3: 36.104, 36.141, new 36.931
- 603: RP#47 completed / Text3: 36.101, 36.211, 36.212, 36.213, 36.331
- 604: Testing for UID_430029 (Enhanced Dual-Layer transmission for LTE) / Text3: 36.508, 36.521-1, 36.521-2
- 605: RP#47 completed / Text3: LTE 25.413, 36.300, 36.413, 36.423, 48.018, new 36.902

| ID | WBS | Task | Type | Duration | Start | Finish | Complete | Remaining | Baseline start | Baseline finish | Baseline duration | Total slack | Constraint | Resources | Work | Actual work | Text1 | Text4 | Text5 | Text6 | Text8 | Text2 | Text7 | Text9 | Text12 |
| --- | --- | --- | --- | --- | --- | --- | --- | --- | --- | --- | --- | --- | --- | --- | --- | --- | --- | --- | --- | --- | --- | --- | --- | --- | --- |
| 606 | 233 | **A-GNSS Performances and Testing Procedures** |  | 732d? | 2008-05-16 A | 2011-03-04 | 88% | 89.01d? | 2008-05-16 | 2011-03-04 | 732d? | 465d |  | GP | 15488h | 8778.4h | AGNSSPTP | Thales | Michel.monnerat@thalesaleniaspace.com | Rel-9 | Paolo |  |  |  |  |
| 607 | 233.1 | A-GNSS Minimum Performances |  | 472d? | 2008-05-16 A | 2010-03-05 A | 100% |  | 2008-05-16 | 2010-03-05 | 472d? |  | finish no earlier than 2010-03-05 | G1 | 3776h | 3776h | AGNSSPTP- Perfreq | Thales | Michel.monnerat@thalesaleniaspace.com | Rel-9 | Paolo |  |  |  |  |
| 608 | 233.2 | A-GNSS Testing Procedures |  | 732d? | 2008-05-16 A | 2011-03-04 | 80% | 146.4d? | 2008-05-16 | 2011-03-04 | 732d? | 465d | finish no earlier than 2011-03-04 | G3new | 5856h | 4684.8h | AGNSSPTP-MStest | Thales | Michel.monnerat@thalesaleniaspace.com | Rel-9 | Ingbert |  |  |  |  |
| 609 | 234 | **Voice services over Adaptive Multi-user channels on One Slot** |  | 857d? | 2008-11-21 A | 2012-03-02 | 76% | 202.69d? | 2008-11-21 | 2012-03-02 | 857d? | 205d |  | GP,G1,G2,G3new | 23224h | 15632.8h | VAMOS | Nokia Siemens Networks, China Mobile | juergen.hofmann@nsn.com, liuxiaoyu@chinamobile.com | Rel-9 | Paolo | PCG-22 | SP-42 |  |  |
| 610 | 234.1 | Stage 2 for Voice services over Adaptive Multi-user channels on One Slot |  | 392d? | 2008-11-21 A | 2010-05-21 A | 100% |  | 2008-11-21 | 2010-05-21 | 392d? |  | finish no earlier than 2010-05-21 | GP,G1,G2 | 3136h | 3136h | VAMOS | Nokia Siemens Networks, China Mobile | juergen.hofmann@nsn.com, liuxiaoyu@chinamobile.com | Rel-9 | Paolo | PCG-22 | GP-40 |  |  |
| 611 | 234.2 | Stage 3 for Voice services over Adaptive Multi-user channels on One Slot |  | 596d? | 2008-11-24 A | 2011-03-04 | 95% | 29.8d? | 2008-11-24 | 2011-03-04 | 596d? | 465d | finish no earlier than 2011-03-04 | GP,G1,G2 | 4768h | 4529.6h | VAMOS | Nokia Siemens Networks, China Mobile | juergen.hofmann@nsn.com, liuxiaoyu@chinamobile.com | Rel-9 | Paolo | PCG-22 | GP-40 |  |  |
| 612 | 234.3 | VAMOS Radio Performance Requirements |  | 596d? | 2008-11-24 A | 2011-03-04 | 90% | 59.6d? | 2008-11-24 | 2011-03-04 | 596d? | 465d | finish no earlier than 2011-03-04 | GP,G1,G2 | 4768h | 4291.2h | VAMOS | Nokia Siemens Networks, China Mobile | juergen.hofmann@nsn.com, liuxiaoyu@chinamobile.com | Rel-9 | Paolo | PCG-22 | GP-40 |  |  |
| 613 | 234.4 | VAMOS - MS conformance testing |  | 391d? | 2010-09-03 A | 2012-03-02 | 10% | 351.9d? | 2010-09-03 | 2012-03-02 | 391d? | 205d | finish no earlier than 2012-03-02 | G3new | 3128h | 312.8h | VAMOS_MStest | Research In Motion | Raveendra Seetharam (rseetharam@rim.com) | Rel-9 | Ingbert | PCG-25 | GP-47 |  |  |
| 614 | 234.5 | VAMOS - BTS conformance testing |  | 71d? | 2010-11-26 A | 2011-03-04 | 40% | 42.6d? | 2010-11-26 | 2011-03-04 | 71d? | 465d | finish no earlier than 2011-03-04 | G1 | 568h | 227.2h | VAMOS_BTStest | Nokia Siemens Networks | eddie.riddington@nsn.com | Rel-9 | Paolo | PCG-26 | GP-48 |  |  |
| 615 | 235 | **Cell Broadcast protocol Base Station Controller – Cell Broadcast Centre (BSC-CBC)** |  | 222d? | 2009-05-15 A | 2010-03-19 A | 100% |  | 2009-05-15 | 2010-03-19 | 222d? |  |  | GP,C1 | 5248h | 5248h | CEBRO | Ericsson | Claes-Göran Persson | Rel-9 | Paolo | PCG-23 | GP-42 |  |  |
| 616 | 235.1 | GERAN part of Cell Broadcast protocol Base Station Controller – Cell Broadcast Centre |  | 212d? | 2009-05-15 A | 2010-03-05 A | 100% |  | 2009-05-15 | 2010-03-05 | 212d? |  | finish no earlier than 2010-03-05 | GP | 1696h | 1696h | CEBRO | Ericsson | Claes-Göran Persson | Rel-9 | Paolo | PCG-23 | GP-42 |  |  |
| 617 | 235.2 | CT1 part of Cell Broadcast protocol Base Station Controller – Cell Broadcast Centre |  | 222d? | 2009-05-15 A | 2010-03-19 A | 100% |  | 2009-05-15 | 2010-03-19 | 222d? |  | finish no earlier than 2010-03-19 | C1 | 1776h | 1776h | CEBRO | Ericsson | Claes-Göran Persson | Rel-9 | Frederic | PCG-23 | GP-42 |  |  |
| 618 | 236 | Hybrid Location |  | 136d? | 2009-05-18 A | 2009-11-20 A | 100% |  | 2009-05-18 | 2009-11-20 | 136d? |  | finish no earlier than 2009-11-20 | GP | 1088h | 1088h | HILT | TruePosition | Matt Ward (mward@trueposition.com) | Rel-9 | Paolo | PCG-23 | GP-42 |  |  |
| 619 | 237 | (Small) Technical Enhancements and Improvements for Rel-9 |  | 325d? | 2008-09-15 A | 2009-12-10 A | 100% |  | 2008-09-15 | 2009-12-10 | 325d? |  | finish no earlier than 2009-12-10 | All | 2600h | 2600h | TEI9 |  |  | Rel-9 | A | PCG-22 | SP-42 |  |  |
| 620 | 238 | Test - (Small) Technical Enhancements and Improvements for Rel-9 |  | 286d? | 2009-11-20 A | 2010-12-24 A | 100% |  | 2009-11-20 | 2010-12-24 | 286d? |  | finish no earlier than 2010-12-24 | R5,G3new | 2288h | 2288h | TEI9_Test |  |  | Rel-9 | Ingbert | PCG-24 | GP-44 |  |  |
| 621 | 239 | **Deleted - Services Alignment and Migration** |  | 467d? | 2006-12-06 A | 2008-09-18 A | 100% |  | 2006-12-06 | 2008-09-18 | 467d? |  |  | S1 | 7472h | 7472h | ServAl | Telefónica O2 Europe | chris.friel@o2.com | Rel-9 | Alain |  | SP-33 |  |  |
| 622 | 239.1 | Deleted - Stage 1 for ServAl |  | 467d? | 2006-12-06 A | 2008-09-18 A | 100% |  | 2006-12-06 | 2008-09-18 | 467d? |  | finish no earlier than 2008-12-11 | S1 | 3736h | 3736h | ServAl | Telefónica O2 Europe | chris.friel@o2.com | Rel-9 | Alain | PCG-21 | SP-33 |  |  |
| 623 | 240 | Deleted - Harmonization of Gq'/Rx for Common IMS |  | 304d? | 2008-01-14 A | 2009-03-12 A | 100% |  | 2008-01-14 | 2009-03-12 | 304d? |  | finish no earlier than 2009-03-12 | S2 | 2432h | 2432h | IMS_Comm_GqRx_Harm | Alcatel-Lucent | geoffrey.cristallo@alcatel-lucent.be | Rel-9 | Maurice | PCG-21 | SP-38 | PCG-22 | SP-43 |
| 624 | 241 | Deleted - Support of WiMAX - LTE Mobility |  | 407d? | 2008-06-06 A | 2009-12-25 A | 100% |  | 2008-06-06 | 2009-12-25 | 407d? |  | start no earlier than 2008-06-06 | R2 | 3248h | 3248h | WiMAX_LTE_Mobility | Samsung |  | Rel-9 | Joern | PCG-21 | RP-38 | PCG-21 | SP-39 |
| 625 | 242 | Deleted - Support of WiMAX - UMTS Mobility |  | 407d? | 2008-06-06 A | 2009-12-25 A | 100% |  | 2008-06-06 | 2009-12-25 | 407d? |  | start no earlier than 2008-06-06 | R2 | 3248h | 3248h | WiMAX_UMTS_Mobility | Intel |  | Rel-9 | Joern | PCG-21 | RP-38 | PCG-21 | SP-39 |
| 626 | 243 | Deleted - Definition of 3GPP UICC services over the new high-speed interface | milestone | 0d? | 2010-03-19 A | 2010-03-19 A | 100% |  | 2010-03-19 | 2010-03-19 | 0d? |  |  | C6 |  |  | UICCHS | Gemalto | Denis L'Heriteau | Rel-9 | Xavier | PCG-21 | CP-38 | PCG-24 | CP-47 |
| 627 | 244 | **Deleted - SAES Enhancements (non RAN aspects)** |  | 381d? | 2007-06-25 A | 2008-12-08 A | 100% |  | 2007-06-25 | 2008-12-08 | 381d? |  |  | S2 | 11664h | 11664h | SAES_Ph2 | Nokia Siemens Networks |  | Rel-9 | Maurice | PCG-21 | SP-39 | PCG-21 | SP-39 |
| 628 | 244.1 | Deleted - Functions and procedures for SAE to support LTE MBMS |  | 381d? | 2007-06-25 A | 2008-12-08 A | 100% |  | 2007-06-25 | 2008-12-08 | 381d? |  | finish no earlier than 2008-12-08 | S2 | 3048h | 3048h | SAES_Ph2 |  |  | Rel-9 | Maurice |  | SP-35 | PCG-21 | SP-39 |
| 629 | 244.2 | Deleted - CS over EPS |  | 194d? | 2008-03-12 A | 2008-12-08 A | 100% |  | 2008-03-12 | 2008-12-08 | 194d? |  | finish no earlier than 2008-12-08 | S2 | 1552h | 1552h | SAES_Ph2 |  |  | Rel-9 | Maurice | PCG-21 | SP-39 | PCG-21 | SP-39 |

Notes:
- 606: GP#46 still ongoing MS testing. Linked to Rel-10 RAN4 UID_450027 (A-GNSS Minimum Performance for UTRAN)
- 607: GP#45 completed (open performance requirements alignment GPS/Galileo) / Text3: 45.005
- 608: GP#48 completion 11/10=>03/11 / Text3: 51.010-1, new 51.010-7
- 609: GP#46 completion 05/10=>09/10. GP#44 exception to 05/10 in GP-092470. GP#40 WID approved. Triggered by UID_50590 (MUROS) Study on Multi-User Reusing-One-Slot
- 610: GP#46 completed / Text3: 45.001
- 611: GP#48 completion 11/10=>03/11 / Text3: 24.008, 44.018, 45.002, 45.003, 45.004, 45.008, 48.008, 48.058
- 612: GP#48 completion 11/10=>03/11 / Text3: 45.005
- 613: GP#47 WID approved. / Text3: 51.010-1, 51.010-2
- 614: GP#48 WID approved. / Text3: 51.021
- 615: CP#47 completed. GP#45 completed. GP#42 WID approved
- 616: GP#45 completed. GP#42 WID approved / Text3: new 48.049
- 617: CP#47 completed / Text3: 23.041
- 618: GP#44 completed. GP#42 WID approved (Hybrid Integrated Location Technology=HILT) / Text3: 43.059, 48.071
- 619: SP#46 completed
- 620: GP#44 created
- 621: SP#41 closed (no tangible result of this work; no CR against TR 22.983). Triggered by Study UID_370086 (FSServAl)
- 622: SP#41 closed (no tangible result of this work; no CR against TR 22.983) / Text3: 22.983
- 623: SP#43 stopped. LS_out to TISPAN informs about stopping this activity / Text3: 23.822, 23.203
- 624: RP#39: No agreed WID / Text3: 36.306, 36.331, 36.413, 36.300, 36.214, 36.133, 36.304
- 625: RP#39: No agreed WID / Text3: 25.306, 25.331, 25.413
- 626: CP#47 work stopped/abandoned / Text3: 31.xyz
- 627: SP#39 created to host Rel-9 Wis. BUT no agreed WID
- 628: SP#39 SAE functionality moved to Rel-9. WID returned to SA2 for re-consideration & remove MBMS for EPS from Rel 8
- 629: SP#39 SAE functionality moved to Rel-9. BUT no agreed WID

| ID | WBS | Task | Duration | Start | Finish | Complete | Remaining | Baseline start | Baseline finish | Baseline duration | Total slack | Constraint | Resources | Work | Actual work | Text1 | Text2 | Text6 | Text7 | Text8 | Text9 | Text12 | Text4 | Text5 | Text11 |
| --- | --- | --- | --- | --- | --- | --- | --- | --- | --- | --- | --- | --- | --- | --- | --- | --- | --- | --- | --- | --- | --- | --- | --- | --- | --- |
| 630 | 244.3 | **Deleted - SAE for generic support for non-3GPP accesses** | 251d? | 2007-06-25 A | 2008-06-09 A | 100% |  | 2007-06-25 | 2008-06-09 | 251d? |  |  | S2 | 4016h | 4016h | SAES_Ph2 | PCG-21 | Rel-9 | SP-39 | Maurice | PCG-21 | SP-39 |  |  |  |
| 631 | 244.3.1 | Deleted - Single Radio Aspects of SAE for Optimized Handover with WiMAX | 251d? | 2007-06-25 A | 2008-06-09 A | 100% |  | 2007-06-25 | 2008-06-09 | 251d? |  | finish no earlier than 2008-06-09 | S2 | 2008h | 2008h | SAES_Ph2 | PCG-21 | Rel-9 | SP-39 | Maurice | PCG-21 | SP-39 |  |  |  |
| 632 | 245 | Deleted - Lawful Interception in the 3GPP Rel-9 | 211d? | 2009-06-04 A | 2010-03-25 A | 100% |  | 2009-06-04 | 2010-03-25 | 211d? |  | finish no earlier than 2010-03-25 | S3 | 1688h | 1688h | LI9 | PCG-23 | Rel-9 | SP-44 | Dionisio | PCG-24 | SP-47 | PIDS, Nortel | Koen Jaspers, Ronald Ryan |  |
| 633 | 246 | Release 9 Studies | 468d? | 2008-06-05 A | 2010-03-19 A | 100% |  | 2008-06-05 | 2010-03-19 | 468d? |  |  | CP,RP,SP | 3744h | 3744h |  |  | Rel-9 |  |  |  |  |  |  |  |
| 634 | 247 | Study on Service Specific Access Control in EPS | 136d? | 2008-06-05 A | 2008-12-11 A | 100% |  | 2008-06-05 | 2008-12-11 | 136d? |  | start no earlier than 2008-06-05 | S1 | 1088h | 1088h | FS_SSAC | PCG-21 | Rel-9 | SP-40 | Alain |  |  | NTT DoCoMo | Shin-ichi Isobe (isobes@nttdocomo.co.jp) |  |
| 635 | 248 | Study on CS Domain Services over EPS access | 492d? | 2007-04-25 A | 2009-03-12 A | 100% |  | 2007-04-25 | 2009-03-12 | 492d? |  | finish no earlier than 2009-03-12 | S2 | 3936h | 3936h | FS_CSoPS |  | Rel-9 | SP-35 | Maurice |  |  | T-Mobile | Karl-Heinz.Nenner@T-Mobile.net |  |
| 636 | 249 | Study on Extended Support of IMS Emergency Calls | 319d? | 2007-09-24 A | 2008-12-11 A | 100% |  | 2007-09-24 | 2008-12-11 | 319d? |  | finish no earlier than 2009-06-18 | S2 | 2552h | 2552h | FS_IMS-eCall |  | Rel-9 | SP-37 | Maurice |  |  | Qualcomm | Stephen Edge |  |
| 637 | 250 | Study on Service Continuity for Emergency Voice Calls | 721d? | 2006-06-08 A | 2009-03-12 A | 100% |  | 2006-06-08 | 2009-03-12 | 721d? |  | finish no earlier than 2009-03-12 | S2 | 5768h | 5768h | FS_VCCEm |  | Rel-9 | SP-32 | Maurice |  |  | Nortel | Ricky Kaura (rkaura@nortel.com) |  |
| 638 | 251 | Study on Security Aspects of Remote Provisioning and Change of Subscription for M2M Equipment | 582d? | 2004-04-06 A | 2009-12-10 A | 100% |  | 2004-04-06 | 2009-12-10 | 582d? |  | finish no earlier than 2009-12-10 | S3,C6 | 4656h | 4656h | FS_UM2M |  | Rel-9 | SP-37 | Dionisio |  |  | Ericsson | vesa.lehtovirta@ericsson.com |  |
| 639 | 252 | Study on System Maintenance over Itf-N | 602d? | 2007-06-07 A | 2009-09-24 A | 100% |  | 2007-06-07 | 2009-09-24 | 602d? |  | finish no earlier than 2009-09-24 | S5 | 4808h | 4808h | FS_OAM-Maint-Itf-N |  | Rel-9 | SP-36 | Dionisio |  |  | ZTE | Shuqiang Huang (huangsq@zte.com.cn) |  |
| 640 | 253 | Study on Self-Organizing Networks (SON) related OAM interfaces for Home NodeB | 522d? | 2007-06-07 A | 2009-06-04 A | 100% |  | 2007-06-07 | 2009-06-04 | 522d? |  | finish no earlier than 2009-12-10 | S5 | 4168h | 4168h | FS_OAM-SON-HNB |  | Rel-9 | SP-36 | Dionisio |  |  | Huawei | Zou Lan (zlan@huawei.com) |  |
| 641 | 254 | Study on Self-healing of Self-Organizing Networks (SON) | 416d? | 2008-02-22 A | 2009-09-24 A | 100% |  | 2008-02-22 | 2009-09-24 | 416d? |  | finish no earlier than 2009-09-24 | S5 | 3320.15h | 3320.15h | FS_OAM-SON-SH | PCG-21 | Rel-9 | SP-39 | Dionisio |  |  | ZTE | zhu.weihong@zte.com.cn |  |
| 642 | 255 | Study on Service Oriented Architecture (SOA) for IRP | 262d? | 2008-06-05 A | 2009-06-04 A | 100% |  | 2008-06-05 | 2009-06-04 | 262d? |  | finish no earlier than 2009-05-20 | S5 | 2088h | 2088h | FS_OAM_SOA_IRP | PCG-21 | Rel-9 | SP-40 | Dionisio |  |  | Ericsson | edwin.tse@ericsson.com |  |
| 643 | 256 | Study on Evaluation of the inclusion of Path Loss Based Technology in the UTRAN | 516d? | 2007-12-17 A | 2009-12-04 A | 100% |  | 2007-12-17 | 2009-12-04 | 516d? |  | finish no earlier than 2009-09-18 | R4 | 4120h | 4120h | FS_RAN-Pathloss | PCG-21 | Rel-9 | RP-38 | Issam |  |  | Polaris Wireless | Norman Shaw (nshaw@polariswireless.com) | RP-091080 |
| 644 | 257 | Study on LTE-Advanced | 461d? | 2007-03-23 A | 2010-03-19 A | 100% |  | 2007-03-23 | 2010-03-19 | 461d? |  | finish no earlier than 2010-03-19 | R1,R2,R3,R4 | 3688h | 3688h | FS_RAN_LTEA | PCG-21 | Rel-9 | RP-39 | Patrick |  |  | NTT DoCoMo | Tetsushi Abe | RP-100080 |
| 645 | 258 | Study on 1.28 Mcps TDD Home NodeB | 387d? | 2008-02-20 A | 2009-12-04 A | 100% |  | 2008-02-20 | 2009-12-04 | 387d? |  | finish no earlier than 2009-12-04 | R4 | 3096h | 3096h | FS_RAN-HNBLCRTDD | PCG-21 | Rel-9 | RP-41 | Issam |  |  | TD Tech | Li Rong (lirong@td-tech.com) | RP-091081 |
| 646 | 259 | Study on E-UTRAN Mobility Evaluation and Enhancement | 126d? | 2008-12-05 A | 2009-05-29 A | 100% |  | 2008-12-05 | 2009-05-29 | 126d? |  | finish no earlier than 2009-05-29 | R1 | 1008h | 1008h | FS_EUTRAN_mob | PCG-22 | Rel-9 | RP-42 | Patrick |  |  | Qualcomm | Rajat Prakash (rprakash@qualcomm.com) | RP-090426 |
| 647 | 260 | Study on Minimization of drive-tests in Next Generation Networks | 196d? | 2009-03-06 A | 2009-12-04 A | 100% |  | 2009-03-06 | 2009-12-04 | 196d? |  | finish no earlier than 2009-12-04 | R2 | 1568h | 1568h | FS_NGN_min_drive-tests | PCG-22 | Rel-9 | RP-43 | Joern |  |  | Qualcomm | Masato Kitazoe (mkitazoe@qualcomm.com) | RP-091084 |
| 648 | 261 | Study on Enhanced Interference Management for HNBs | 61d? | 2009-03-06 A | 2009-05-29 A | 100% |  | 2009-03-06 | 2009-05-29 | 61d? |  | start no earlier than 2009-03-06 | R4 | 488h | 488h | FS_eInterfMgmt_HNB | PCG-22 | Rel-9 | RP-43 | Issam |  |  | Qualcomm | Farhad Meshkati (fmeshkat@qualcomm.com) | RP-090429 |
| 649 | 262 | Study on Enhanced Interference Management Mechanisms for HNBs | 81d? | 2009-05-30 A | 2009-09-18 A | 100% |  | 2009-05-30 | 2009-09-18 | 81d? |  | finish no earlier than 2009-09-18 | R3 | 648h | 648h | FS_eInterfMgmtMchsm_HNB | PCG-23 | Rel-9 | RP-44 | Juha |  |  | Qualcomm | Farhad Meshkati (fmeshkat@qualcomm.com) | RP-090733 |
| 650 | 263 | Deleted - Study on Protection against SMS and MMS spam | 862d? | 2006-06-08 A | 2009-09-24 A | 100% |  | 2006-06-08 | 2009-09-24 | 862d? |  | finish no earlier than 2009-09-24 | S3 | 6896h | 6896h | FS_CPSMal |  | Rel-9 | SP-32 | Dionisio | PCG-23 | SP-45 | Orange | eric.gauthier@orange.ch |  |
| 651 | 264 | Release 8 Features | 914.3d? | 2006-09-19 A | 2010-03-19 A | 100% |  | 2006-09-19 | 2010-03-19 | 914.3d? |  | start no earlier than 2000-01-03 | CP,GP,RP,SP | 7314.4h | 7314.4h |  |  | Rel-8 |  |  |  |  |  |  |  |
| 652 | 265 | **3GPP System Architecture Evolution Specification - Evolved Packet System (non RAN aspects)** | 1354d? | 2006-04-12 A | 2011-06-17 | 99% | 8.85d? | 2006-04-12 | 2011-06-17 | 1354d? | 390d |  | SP,CP | 268388h | 263400h | SAES |  | Rel-8 |  | Alain |  |  | T-Mobile | michael.kurz@t-mobile.at |  |
| 653 | 265.1 | Requirements for evolution of the 3GPP system architecture | 395d? | 2006-06-08 A | 2007-12-12 A | 100% |  | 2006-06-08 | 2007-12-12 | 395d? |  | finish no earlier than 2007-11-30 | S1 | 3160h | 3160h | AIPN-SAE |  | Rel-8 |  | Alain |  |  | T-Mobile | michael.kurz@t-mobile.at |  |

Notes:
- 630: SP#39 SAE functionality moved to Rel-9. BUT no agreed WID
- 631: SP#39 SAE functionality moved to Rel-9. BUT no agreed WID
- 632: SP#47 stopped. WI + new topics moved to Rel-10 / Text3: 33.106, 33.107, 33.108
- 633: -
- 634: SP#42 completed. Spin-off Feature UID_420020 (SSAC) / Text3: 22.986
- 635: SP#43 completed. Linked to Combinational Services UID_31064, Services Alignment and Migration (ServAl) UID_330017 and 3GPP System Architecture Evolution (SAES) UID_3208 / Text3: 23.879
- 636: SP#42 completed / Text3: 23.868
- 637: SP#43 completed / Text3: 23.826
- 638: SP#46 completed. Triggered by the SA1 Rel-8 Study on Facilitating Machine to Machine Communication in GSM and UMTS (FS_M2M) UID_7027 in TR 22.868. / Text3: 33.812
- 639: SP#45 completed / Text3: 32.822
- 640: SP#44 completed. Linked to SA5 TR 32.816 Study of Management for LTE and SAE (UID_340036) / Text3: 32.821
- 641: SP#45 completed. Linked to SA5 TR 32.816 Study of Management for LTE and SAE (UID_340036) / Text3: 32.823
- 642: SP#44 completed. Spin-off implementation WI UID_440064 Service Oriented Architecture (SOA) for IRP / Text3: 32.824
- 643: RP#46 completed / Text3: 25.907
- 644: RP#47 completed / Text3: 36.913 , new 36.814, 36.912, R2 36.806 (Relay architectures for E-UTRA), R4 36.815 (LTE-Advanced feasibility studies in RAN4)
- 645: RP#46 completed / Text3: 25.866
- 646: RP#44 closed (RP-090452 R1 LS to RAN on Conclusions for LTE Mobility Study Item - no further Rel-9 action / no TR needed) / Text3: none
- 647: RP#46 completed / Text3: 36.805
- 648: RP#44 completed. Linked to UID_420008 LTE FDD Home eNodeB RF Requirements. Spin-off RAN3 UID_440015 Study on Enhanced Interference Management Mechanisms for HNBs / Text3: 25.967
- 649: RP#45 completed. Triggered by RAN4 UID_430027 Study on Enhanced Interference Management for HNBs / Text3: 25.967
- 650: SP#45 work stopped/abandoned / Text3: 33.9xx
- 651: -
- 652: SP#39 WID updated SP-070933=>SP-080132. Role model for SAE/LTE system wide project management by SA2 in SP-060166
- 653: SP#38 completed / Text3: 22.011, 22.246, new 22.278

| ID | WBS | Task | Duration | Start | Finish | Complete | Baseline start | Baseline finish | Baseline duration | Constraint | Resources | Work | Actual work | Text1 | Text4 | Text5 | Text6 | Text7 | Text8 | Text2 |
| --- | --- | --- | --- | --- | --- | --- | --- | --- | --- | --- | --- | --- | --- | --- | --- | --- | --- | --- | --- | --- |
| 654 | 265.2 | **High level and common (for all accesses) functions** | 629d? | 2007-01-02 A | 2009-05-29 A | 100% | 2007-01-02 | 2009-05-29 | 629d? |  | SP,CP | 42536h | 42536h | EPS-ComF | Nokia Siemens Networks | balazs.bertenyi@nsn.com | Rel-8 | SP-37 | Maurice |  |
| 655 | 265.2.1 | Stage 2 for High level functions | 370d? | 2007-01-02 A | 2008-06-02 A | 100% | 2007-01-02 | 2008-06-02 | 370d? | finish no earlier than 2008-06-02 | S2 | 2960h | 2960h | SAES-SA-HLF | Motorola | Irfan.Ali@motorola.com | Rel-8 |  | Maurice |  |
| 656 | 265.2.2 | Stage 2 Security Architecture | 197d? | 2008-03-12 A | 2008-12-11 A | 100% | 2008-03-12 | 2008-12-11 | 197d? | finish no earlier than 2008-12-11 | S3 | 1576h | 1576h | SAES | Nokia Siemens Networks | marc.blommaert.ext@nsn.com | Rel-8 | SP-39 | Dionisio | PCG-21 |
| 657 | 265.2.3 | Stage 3 (CT1) for SAE impact on services, network functions and capabilities | 545d? | 2007-02-05 A | 2009-03-06 A | 100% | 2007-02-05 | 2009-03-06 | 545d? | finish no earlier than 2009-03-06 | C1 | 4360h | 4360h | SAES | Nokia Siemens Networks | robert.zaus@nsn.com | Rel-8 |  | Frederic |  |
| 658 | 265.2.4 | Stage 3 SAE impact on existing capabilities | 480d? | 2007-02-05 A | 2008-12-05 A | 100% | 2007-02-05 | 2008-12-05 | 480d? | finish no earlier than 2008-12-12 | C3 | 3840h | 3840h | SAES | Huawei | Wei Weihua (weiwh@huawei.com) | Rel-8 |  | Gwiho |  |
| 659 | 265.2.5 | Stage 3 (CT4) of SAE impact on existing capabilities | 545d? | 2007-02-05 A | 2009-03-06 A | 100% | 2007-02-05 | 2009-03-06 | 545d? | finish no earlier than 2009-03-06 | C4 | 4360h | 4360h | SAES | Huawei | shahab.lavasani@huawei.com | Rel-8 |  | Kimmo |  |
| 660 | 265.2.6 | Stage 2/3 for Network selection procedures | 480d? | 2007-02-05 A | 2008-12-05 A | 100% | 2007-02-05 | 2008-12-05 | 480d? | finish no earlier than 2009-03-06 | C1 | 3840h | 3840h | SAES | Nokia Siemens Networks | robert.zaus@nsn.com | Rel-8 |  | Frederic |  |
| 661 | 265.2.7 | Stage 3 EPC interworking with external PDNs (SGi) | 605d? | 2007-02-05 A | 2009-05-29 A | 100% | 2007-02-05 | 2009-05-29 | 605d? | finish no earlier than 2009-05-29 | C3 | 4840h | 4840h | SAES-St3-intwk | Huawei | Wei Weihua (weiwh@huawei.com) | Rel-8 |  | Gwiho |  |
| 662 | 265.2.8 | Stage 3 PCC within SAE | 605d? | 2007-02-05 A | 2009-05-29 A | 100% | 2007-02-05 | 2009-05-29 | 605d? | finish no earlier than 2009-05-29 | C3 | 4840h | 4840h | SAES-St3-PCC | Ericsson | j.javier.pastor@ericsson.com | Rel-8 |  | Gwiho |  |
| 663 | 265.2.9 | Stage 3 for SAE / LTE identities | 545d? | 2007-02-05 A | 2009-03-06 A | 100% | 2007-02-05 | 2009-03-06 | 545d? | finish no earlier than 2009-03-06 | C4 | 4360h | 4360h | SAES | Huawei | shahab.lavasani@huawei.com | Rel-8 |  | Kimmo |  |
| 664 | 265.2.10 | Unified guidelines for Diameter usage within 3GPP | 316d? | 2007-09-21 A | 2008-12-05 A | 100% | 2007-09-21 | 2008-12-05 | 316d? | finish no earlier than 2008-12-05 | C3 | 2528h | 2528h | SAES-DIAM | Huawei | Javier Gonzalez Gallego | Rel-8 | CP-37 | Gwiho |  |
| 665 | 265.3 | **SAE for LTE access** | 569d? | 2007-01-02 A | 2009-03-06 A | 100% | 2007-01-02 | 2009-03-06 | 569d? |  | S2,C1,C3,C4 | 57824h | 57824h | SAES-LTE | Motorola | Irfan.Ali@motorola.com | Rel-8 |  | Maurice |  |
| 666 | 265.3.1 | CT4 Stage 3 for protocol between EPCs | 545d? | 2007-02-05 A | 2009-03-06 A | 100% | 2007-02-05 | 2009-03-06 | 545d? | finish no earlier than 2009-03-06 | C4 | 4360h | 4360h | SAES | Huawei | shahab.lavasani@huawei.com | Rel-8 |  | Kimmo |  |
| 667 | 7.2.2.1 | **SAES-SA-FP_LTE with GTP variant** | 569d? | 2007-01-02 A | 2009-03-06 A | 100% | 2007-01-02 | 2009-03-06 | 569d? |  | S2,C4 | 11896h | 11896h | SAES-SA-FP_LTE-GTP | Nokia Siemens Networks | balazs.bertenyi@nsn.com | Rel-8 |  | Maurice |  |
| 668 | 265.3.2.1 | Stage 2 for SAES-SA-FP_LTE with GTP variant | 373d? | 2007-01-02 A | 2008-06-05 A | 100% | 2007-01-02 | 2008-06-05 | 373d? | finish no earlier than 2008-06-02 | S2 | 2984h | 2984h | SAES-SA-FP_LTE-GTP-St2 | Nokia Siemens Networks | balazs.bertenyi@nsn.com | Rel-8 |  | Maurice |  |
| 669 | 265.3.2.2 | CT4 Stage 3 for GTP v2 protocol | 545d? | 2007-02-05 A | 2009-03-06 A | 100% | 2007-02-05 | 2009-03-06 | 545d? | finish no earlier than 2009-03-06 | C4 | 4360h | 4360h | SAES | Huawei | shahab.lavasani@huawei.com | Rel-8 |  | Kimmo |  |
| 670 | 7.2.2.2 | **SAES-SA-FP_LTE with PMIP variant** | 569d? | 2007-01-02 A | 2009-03-06 A | 100% | 2007-01-02 | 2009-03-06 | 569d? |  | S2,C4 | 15736h | 15736h | SAES-SA-FP_LTE-IETF | Nokia Siemens Networks | balazs.bertenyi@nsn.com | Rel-8 |  | Maurice |  |
| 671 | 265.3.3.1 | Stage 2 for SAES-SA-FP_LTE with PMIP variant | 373d? | 2007-01-02 A | 2008-06-05 A | 100% | 2007-01-02 | 2008-06-05 | 373d? | finish no earlier than 2008-06-02 | S2 | 2984h | 2984h | SAES-SA-FP_LTE-IETF-St2 | Nokia Siemens Networks | balazs.bertenyi@nsn.com | Rel-8 |  | Maurice |  |
| 672 | 265.3.3.2 | CT4 Stage 3 for PMIP protocol within EPC | 545d? | 2007-02-05 A | 2009-03-06 A | 100% | 2007-02-05 | 2009-03-06 | 545d? | finish no earlier than 2009-03-06 | C4 | 4360h | 4360h | SAES | Huawei | shahab.lavasani@huawei.com | Rel-8 | CP-37 | Kimmo |  |
| 673 | 265.3.3.3 | Mobile IPv4 (MIPv4) based Mobility protocols | 480d? | 2007-02-05 A | 2008-12-05 A | 100% | 2007-02-05 | 2008-12-05 | 480d? | finish no earlier than 2008-12-05 | C4 | 3840h | 3840h | SAES | Motorola | Lewis Milton | Rel-8 | CP-41 | Kimmo |  |
| 674 | 265.3.4 | Stage 3 for UE NAS mobility procedures in idle and active mode | 545d? | 2007-02-05 A | 2009-03-06 A | 100% | 2007-02-05 | 2009-03-06 | 545d? | finish no earlier than 2009-03-06 | C1 | 4360h | 4360h | SAES | Nokia Siemens Networks | robert.zaus@nsn.com | Rel-8 |  | Frederic |  |
| 675 | 265.3.5 | Stage 3 for Session management, bearer control and QoS aspects | 545d? | 2007-02-05 A | 2009-03-06 A | 100% | 2007-02-05 | 2009-03-06 | 545d? | finish no earlier than 2009-03-06 | C1 | 4360h | 4360h | SAES | Nokia Siemens Networks | robert.zaus@nsn.com | Rel-8 |  | Frederic |  |
| 676 | 265.3.6 | Stage 3 for security aspects of LTE Access | 545d? | 2007-02-05 A | 2009-03-06 A | 100% | 2007-02-05 | 2009-03-06 | 545d? | finish no earlier than 2009-03-06 | C1 | 4360h | 4360h | SAES | Nokia Siemens Networks | robert.zaus@nsn.com | Rel-8 |  | Frederic |  |
| 677 | 265.3.7 | Stage 3 for QoS mechanisms | 480d? | 2007-02-05 A | 2008-12-05 A | 100% | 2007-02-05 | 2008-12-05 | 480d? | finish no earlier than 2008-12-12 | C3 | 3840h | 3840h | SAES | Ericsson | j.javier.pastor@ericsson.com | Rel-8 |  | Gwiho |  |
| 678 | 265.3.8 | Stage 3 for EPC - HSS interface | 545d? | 2007-02-05 A | 2009-03-06 A | 100% | 2007-02-05 | 2009-03-06 | 545d? | finish no earlier than 2009-03-06 | C4 | 4360h | 4360h | SAES | Huawei | shahab.lavasani@huawei.com | Rel-8 |  | Kimmo |  |

Notes:
- 654: CP#44 completed
- 655: SP#40 completed / Text3: new 23.402
- 656: SP#42 completed / Text3: 33.210, 33.310, new 33.401
- 657: CP#43 completed / Text3: 24.229, 27.007, new 24.305
- 658: CP#42 completed / Text3: 29.061
- 659: CP#43 completed / Text3: new (29.274, 29.275)
- 660: CP#42 completed / Text3: 23.122, new 24.302
- 661: CP#44 completed / Text3: 29.061
- 662: CP#44 completed / Text3: 29.212, 29.213, 29.214, new 29.215
- 663: CP#43 completed / Text3: 23.003
- 664: CP#42 completed / Text3: new 29.909
- 665: CP#43 completed
- 666: CP#43 completed / Text3: 29.274, 29.275
- 667: CP#43 completed
- 668: SP#40 completed / Text3: 23.401, 23.060, 23.002, 23.246, 23.203, 23.107, 23.234, 23.271
- 669: CP#43 completed / Text3: 29.274
- 670: CP#43 completed
- 671: SP#40 completed
- 672: CP#43 completed / Text3: 29.275, 29.282
- 673: CP#42 completed / Text3: 29.279
- 674: CP#43 completed / Text3: 24.007, 24.301
- 675: CP#43 completed / Text3: 24.007, 24.301
- 676: CP#43 completed / Text3: 24.008, 24.301
- 677: CP#42 completed / Text3: 29.213
- 678: CP#43 completed / Text3: 29.272

| ID | WBS | Task | Type | Duration | Start | Finish | Complete | Baseline start | Baseline finish | Baseline duration | Constraint | Resources | Work | Actual work | Text1 | Text4 | Text5 | Text6 | Text8 | Text3 | Text7 | Text2 | Text12 |
| --- | --- | --- | --- | --- | --- | --- | --- | --- | --- | --- | --- | --- | --- | --- | --- | --- | --- | --- | --- | --- | --- | --- | --- |
| 679 | 265.4 | **SAE for Interoperation between LTE and legacy cellular PS accesses** |  | 545d? | 2007-02-05 A | 2009-03-06 A | 100% | 2007-02-05 | 2009-03-06 | 545d? |  | S2,C1,C4 | 40152h | 40152h | SAES-SA-FP_3GPP | Motorola | Irfan.Ali@motorola.com | Rel-8 | Maurice |  |  |  |  |
| 680 | 265.4.1 | Stage 2 for Interoperation between LTE and 2G/3G |  | 424d? | 2007-02-05 A | 2008-09-18 A | 100% | 2007-02-05 | 2008-09-18 | 424d? | finish no earlier than 2008-09-11 | S2 | 3392h | 3392h | EPSto2_3G | Motorola | Irfan.Ali@motorola.com | Rel-8 | Maurice | 23.401, 23.402 | SP-37 |  |  |
| 681 | 265.4.2 | Stage 3 for Inter-system mobility between E-UTRAN and 2G/3G |  | 545d? | 2007-02-05 A | 2009-03-06 A | 100% | 2007-02-05 | 2009-03-06 | 545d? | finish no earlier than 2009-03-06 | C1 | 4360h | 4360h | SAES | Nokia Siemens Networks | robert.zaus@nsn.com | Rel-8 | Frederic | 24.008, 24.301 | CP-38 | PCG-21 |  |
| 682 | 265.4.3 | Stage 2 GPRS enhancements for LTE access |  | 272d? | 2007-09-04 A | 2008-09-18 A | 100% | 2007-09-04 | 2008-09-18 | 272d? | start no earlier than 2007-09-04 | S2 | 2176h | 2176h | SAES-GPRS_LTE | Vodafone | chris.pudney@vodafone.com | Rel-8 | Maurice | 23.401 |  |  |  |
| 683 | 265.4.4 | Stage 2 GPRS for EPC (23.060, etc.) |  | 179d? | 2008-01-14 A | 2008-09-18 A | 100% | 2008-01-14 | 2008-09-18 | 179d? | finish no earlier than 2008-09-18 | S2 | 1432h | 1432h | SAES | Nokia Siemens Networks | balazs.bertenyi@nsn.com | Rel-8 | Maurice | 23.060 | SP-39 | PCG-21 |  |
| 684 | 265.4.5 | Stage 3 for EPC - GPRS |  | 545d? | 2007-02-05 A | 2009-03-06 A | 100% | 2007-02-05 | 2009-03-06 | 545d? | finish no earlier than 2009-03-06 | C4 | 4360h | 4360h | SAES | Huawei | shahab.lavasani@huawei.com | Rel-8 | Kimmo | 29.274, 29.275, 29.281 |  |  |  |
| 685 | 265.4.6 | Stage 3 for EPC to UTRAN |  | 545d? | 2007-02-05 A | 2009-03-06 A | 100% | 2007-02-05 | 2009-03-06 | 545d? | finish no earlier than 2009-03-06 | C4 | 4360h | 4360h | SAES | Huawei | shahab.lavasani@huawei.com | Rel-8 | Kimmo | 29.274, 29.275, 29.281 | CP-38 | PCG-21 |  |
| 686 | 265.4.7 | Stage 3 for EPC to 3GPP2 |  | 545d? | 2007-02-05 A | 2009-03-06 A | 100% | 2007-02-05 | 2009-03-06 | 545d? | finish no earlier than 2009-03-06 | C4 | 4360h | 4360h | SAES | Huawei | shahab.lavasani@huawei.com | Rel-8 | Kimmo | 29.277, 29.276 | CP-38 | PCG-21 |  |
| 687 | 265.4.8 | Stage 2 for Interoperation between LTE and CDMA2000 |  | 329d? | 2007-06-18 A | 2008-09-18 A | 100% | 2007-06-18 | 2008-09-18 | 329d? | finish no earlier than 2008-04-25 | S2 | 2632h | 2632h | EPStoC2k | Motorola, Vodafone | Irfan.Ali@motorola.com, chris.pudney@vodafone.com | Rel-8 | Maurice | 23.401, 23.402 | CP-37 |  |  |
| 688 | 265.4.9 | Stage 3 for Inter-system mobility between E-UTRAN and CDMA2000 |  | 545d? | 2007-02-05 A | 2009-03-06 A | 100% | 2007-02-05 | 2009-03-06 | 545d? | finish no earlier than 2009-03-06 | C1 | 4360h | 4360h | SAES | Nokia Siemens Networks | robert.zaus@nsn.com | Rel-8 | Frederic | 24.301, 24.302 |  |  |  |
| 689 | 265.4.10 | Stage 3 for MME - SGSN signalling free protocol |  | 545d? | 2007-02-05 A | 2009-03-06 A | 100% | 2007-02-05 | 2009-03-06 | 545d? | finish no earlier than 2009-03-06 | C4 | 4360h | 4360h | SAES | Huawei | shahab.lavasani@huawei.com | Rel-8 | Kimmo | 29.272, 29.274 |  |  |  |
| 690 | 265.5 | **SAE for support for non-3GPP accesses** |  | 569d? | 2007-01-02 A | 2009-03-06 A | 100% | 2007-01-02 | 2009-03-06 | 569d? |  | S2,S3,C1,C4 | 53872h | 53872h | SAES-SA-FP_n3GPP | Motorola | Irfan.Ali@motorola.com | Rel-8 | Maurice |  |  |  |  |
| 691 | 7.2.4.1 | Stage 2 for Host-based Mobility aspects |  | 373d? | 2007-01-02 A | 2008-06-05 A | 100% | 2007-01-02 | 2008-06-05 | 373d? | finish no earlier than 2008-04-11 | S2 | 2984h | 2984h | SAES-SA-FP_n3GPP-HBMob | Motorola | Irfan.Ali@motorola.com | Rel-8 | Maurice | 23.402 |  |  |  |
| 692 | 7.2.4.2 | Stage 2 for Network-based Mobility aspects |  | 448d? | 2007-01-02 A | 2008-09-18 A | 100% | 2007-01-02 | 2008-09-18 | 448d? | finish no earlier than 2008-09-18 | S2 | 3584h | 3584h | SAES-SA-FP_n3GPP-NBMob | Motorola | Irfan.Ali@motorola.com | Rel-8 | Maurice | 23.402 |  |  |  |
| 693 | 265.5.3 | Stage 3 for Mobility management based on DSMIPv6 |  | 480d? | 2007-02-05 A | 2008-12-05 A | 100% | 2007-02-05 | 2008-12-05 | 480d? | finish no earlier than 2008-12-05 | C1 | 3840h | 3840h | SAES | Nokia Siemens Networks | robert.zaus@nsn.com | Rel-8 | Frederic | 24.303 |  |  |  |
| 694 | 265.5.4 | Stage 3 for Mobility management based on MIP v4 |  | 480d? | 2007-02-05 A | 2008-12-05 A | 100% | 2007-02-05 | 2008-12-05 | 480d? | start no earlier than 2007-02-05 | C1 | 3840h | 3840h | SAES | Nokia Siemens Networks | robert.zaus@nsn.com | Rel-8 | Frederic | 24.304 | CP-39 | PCG-21 |  |
| 695 | 265.5.5 | Stage 3 for Inter-system mobility between E-UTRAN and non 3GPP accesses |  | 545d? | 2007-02-05 A | 2009-03-06 A | 100% | 2007-02-05 | 2009-03-06 | 545d? | finish no earlier than 2009-03-06 | C1 | 4360h | 4360h | SAES | Nokia Siemens Networks | robert.zaus@nsn.com | Rel-8 | Frederic | 24.008, 24.301 | CP-38 | PCG-21 |  |
| 696 | 265.5.6 | Stage 2 for Optimized Dual-Radio Handover with WiMAX |  | 249d? | 2007-06-25 A | 2008-06-05 A | 100% | 2007-06-25 | 2008-06-05 | 249d? | finish no earlier than 2008-06-09 | S2 | 1992h | 1992h | SAES-SA-FP_n3GPP-OptWIMAX | Motorola | Irfan.Ali@motorola.com | Rel-8 | Maurice | 23.402 |  |  |  |
| 697 | 265.5.7 | Stage 2 Security aspects for non-3GPP Access |  | 197d? | 2008-03-12 A | 2008-12-11 A | 100% | 2008-03-12 | 2008-12-11 | 197d? | finish no earlier than 2008-12-11 | S3 | 1576h | 1576h | SAES | Nokia Siemens Networks | marc.blommaert.ext@nsn.com | Rel-8 | Dionisio | 33.402, 33.210, 33.310 | SP-39 | PCG-21 |  |
| 698 | 265.5.8 | Stage 3 security aspects for DSMIPv6 Access |  | 480d? | 2007-02-05 A | 2008-12-05 A | 100% | 2007-02-05 | 2008-12-05 | 480d? | finish no earlier than 2008-12-05 | C1 | 3840h | 3840h | SAES | Nokia Siemens Networks | robert.zaus@nsn.com | Rel-8 | Frederic | 24.303 | CP-37 |  |  |
| 699 | 265.5.9 | Stage 3 security aspects for MIPv4 Access |  | 480d? | 2007-02-05 A | 2008-12-05 A | 100% | 2007-02-05 | 2008-12-05 | 480d? | finish no earlier than 2008-12-05 | C1 | 3840h | 3840h | SAES | Nokia Siemens Networks | robert.zaus@nsn.com | Rel-8 | Frederic | 24.304 | CP-39 | PCG-21 |  |
| 700 | 265.5.10 | Stage 3 for Access to the EPC via non-3GPP access networks |  | 545d? | 2007-02-05 A | 2009-03-06 A | 100% | 2007-02-05 | 2009-03-06 | 545d? | finish no earlier than 2009-03-06 | C1 | 4360h | 4360h | SAES | Nokia Siemens Networks | robert.zaus@nsn.com | Rel-8 | Frederic | 24.302, 24.312 |  |  |  |
| 701 | 265.5.11 | Stage 3 for interfaces within EPC |  | 383d? | 2007-09-19 A | 2009-03-06 A | 100% | 2007-09-19 | 2009-03-06 | 383d? | finish no earlier than 2009-03-06 | C4 | 3064h | 3064h | SAES | Huawei | shahab.lavasani@huawei.com | Rel-8 | Kimmo | 29.274, 29.281 | CP-37 |  |  |
| 702 | 265.5.12 | Stage 3 for Interfaces EPC - non-3GPP IP access |  | 545d? | 2007-02-05 A | 2009-03-06 A | 100% | 2007-02-05 | 2009-03-06 | 545d? | finish no earlier than 2009-03-06 | C4 | 4360h | 4360h | SAES | Huawei | shahab.lavasani@huawei.com | Rel-8 | Kimmo | 29.273, 29.275 |  |  |  |
| 703 | 265.5.13 | Stage 3 for AAA/HSS related |  | 480d? | 2007-02-05 A | 2008-12-05 A | 100% | 2007-02-05 | 2008-12-05 | 480d? | finish no earlier than 2008-12-05 | C4 | 3840h | 3840h | SAES | Huawei | shahab.lavasani@huawei.com | Rel-8 | Kimmo | 29.273 |  |  |  |
| 704 | 265.5.14 | Stage 3 for EPC - AAA interface |  | 480d? | 2007-02-05 A | 2008-12-05 A | 100% | 2007-02-05 | 2008-12-05 | 480d? | finish no earlier than 2008-12-05 | C4 | 3840h | 3840h | SAES | Huawei | shahab.lavasani@huawei.com | Rel-8 | Kimmo | 29.273 |  |  |  |
| 705 | 265.5.15 | Deleted (already covered) SAES-SA-FP_n3GPP Optimized Handover with CDMA | milestone | 0d? | 2007-06-25 A | 2007-06-25 A | 100% | 2007-06-25 | 2007-06-25 | 0d? | finish no earlier than 2007-06-25 | S2 |  |  | SAES-SA-FP_n3GPP-OptCDMA | Nokia Siemens Networks |  | Rel-8 | Maurice |  |  |  | SP-37 |

Notes:
- 679: CP#43 completed
- 680: SP#41 completed
- 681: CP#43 completed
- 682: SP#41 completed
- 683: SP#41 completed
- 684: CP#43 completed
- 685: CP#43 completed
- 686: CP#43 completed
- 687: SP#41 completed (except: Handover of multiple PDNs=>Rel-9)
- 688: CP#43 completed
- 689: CP#43 completed
- 690: CP#43 completed. SP#39 retained in Rel-8 (in addition to the essential functionality defined in SP-070699). Replaces UID_340037
- 691: SP#40 completed
- 692: SP#41 completed
- 693: CP#42 completed
- 694: CP#42 completed
- 695: CP#43 completed
- 696: SP#40 completed
- 697: SP#42 completed
- 698: CP#42 completed
- 699: CP#42 completed
- 700: CP#43 completed
- 701: CP#43 completed
- 702: CP#43 completed
- 703: CP#42 completed
- 704: CP#42 completed
- 705: SP#37 stopped

| ID | WBS | Task | Type | Duration | Start | Finish | Complete | Remaining | Baseline start | Baseline finish | Baseline duration | Total slack | Constraint | Resources | Work | Actual work | Text1 | Text4 | Text6 | Text8 | Text2 | Text7 | Text9 | Text12 | Text11 |
| --- | --- | --- | --- | --- | --- | --- | --- | --- | --- | --- | --- | --- | --- | --- | --- | --- | --- | --- | --- | --- | --- | --- | --- | --- | --- |
| 706 | 265.6 | **Single Radio Voice Call Continuity for 3GPP (SRVCC)** |  | 569d? | 2007-01-02 A | 2009-03-06 A | 100% |  | 2007-01-02 | 2009-03-06 | 569d? |  |  | S2,C1,C4 | 10752h | 10752h | SAES-SRVCC | Nokia Siemens Networks | Rel-8 | Maurice |  |  |  |  |  |
| 707 | 265.6.1 | Stage 2 for 2G/3G SRVCC |  | 448d? | 2007-01-02 A | 2008-09-18 A | 100% |  | 2007-01-02 | 2008-09-18 | 448d? |  | finish no earlier than 2008-09-15 | S2 | 3584h | 3584h | SAES-SRVCC | Nokia Siemens Networks | Rel-8 | Maurice |  |  |  |  |  |
| 708 | 265.6.2 | Stage 3 for SRVCC in EPS |  | 201d? | 2008-05-30 A | 2009-03-06 A | 100% |  | 2008-05-30 | 2009-03-06 | 201d? |  | finish no earlier than 2009-03-06 | C1 | 1608h | 1608h | SAES-SRVCC | Nokia Siemens Networks | Rel-8 | Frederic | PCG-21 | CP-41 |  |  |  |
| 709 | 265.6.3 | MME to MSC interface for SRVCC |  | 126d? | 2008-09-12 A | 2009-03-06 A | 100% |  | 2008-09-12 | 2009-03-06 | 126d? |  | finish no earlier than 2009-03-06 | C4 | 1008h | 1008h | SAES-SRVCC | Nokia Siemens Networks | Rel-8 | Kimmo | PCG-21 | CP-41 |  |  |  |
| 710 | 265.7 | Voice Call Continuity for CDMA2000 1X |  | 249d? | 2007-06-25 A | 2008-06-05 A | 100% |  | 2007-06-25 | 2008-06-05 | 249d? |  | finish no earlier than 2008-06-13 | S2 | 1992h | 1992h | SAES-VCC_1X | Nokia Siemens Networks | Rel-8 | Maurice |  |  |  |  |  |
| 711 | 265.8 | SAE impacts on IMS |  | 373d? | 2007-01-02 A | 2008-06-05 A | 100% |  | 2007-01-02 | 2008-06-05 | 373d? |  | finish no earlier than 2008-06-13 | S2 | 2984h | 2984h | SAES-SA_IMS | Nokia Siemens Networks | Rel-8 | Maurice |  |  |  |  |  |
| 712 | 265.9 | **CS Fallback in EPS** |  | 258d? | 2008-03-12 A | 2009-03-06 A | 100% |  | 2008-03-12 | 2009-03-06 | 258d? |  |  | S2,C1,C4 | 4800h | 4800h | SAES-CSFB | T-Mobile, Vodafone | Rel-8 | Maurice | PCG-21 | SP-39 |  |  |  |
| 713 | 265.9.1 | Stage 2 for CS Fallback in EPS |  | 62d? | 2008-03-12 A | 2008-06-05 A | 100% |  | 2008-03-12 | 2008-06-05 | 62d? |  | finish no earlier than 2008-12-05 | S2 | 496h | 496h | SAES-CSFB | T-Mobile, Vodafone | Rel-8 | Maurice | PCG-21 | SP-40 |  |  |  |
| 714 | 265.9.2 | Stage 3 for CS Fallback in EPS |  | 201d? | 2008-05-30 A | 2009-03-06 A | 100% |  | 2008-05-30 | 2009-03-06 | 201d? |  | finish no earlier than 2009-03-06 | C1 | 1608h | 1608h | SAES-CSFB | NEC | Rel-8 | Frederic | PCG-21 | CP-40 |  |  |  |
| 715 | 265.9.3 | Stage 3 for CS Fallback in EPS |  | 136d? | 2008-05-30 A | 2008-12-05 A | 100% |  | 2008-05-30 | 2008-12-05 | 136d? |  | finish no earlier than 2008-12-05 | C4 | 1088h | 1088h | SAES-CSFB | NEC | Rel-8 | Kimmo | PCG-21 | CP-40 |  |  |  |
| 716 | 265.10 | System enhancements for the use of IMS services in local breakout |  | 62d? | 2008-03-12 A | 2008-06-05 A | 100% |  | 2008-03-12 | 2008-06-05 | 62d? |  | finish no earlier than 2008-06-05 | S2 | 496h | 496h | SAES-IMS_LBO | Telecom Italia | Rel-8 | Maurice | PCG-21 | SP-39 |  |  |  |
| 717 | 265.11 | **EPC Data Definitions** |  | 309d? | 2008-01-07 A | 2009-03-12 A | 100% |  | 2008-01-07 | 2009-03-12 | 309d? |  |  | S5 | 7144h | 7144h | EPC-OAM |  | Rel-8 | Dionisio | PCG-21 | SP-39 |  |  |  |
| 718 | 265.11.1 | EPC Network Resource Model (NRM) Integration Reference Point (IRP) |  | 309d? | 2008-01-07 A | 2009-03-12 A | 100% |  | 2008-01-07 | 2009-03-12 | 309d? |  | finish no earlier than 2009-03-12 | S5 | 2472h | 2472h | EPC-OAM | Huawei | Rel-8 | Dionisio | PCG-21 | SP-38 |  |  |  |
| 719 | 265.11.2 | Performance measurements for EPC |  | 275d? | 2008-02-22 A | 2009-03-12 A | 100% |  | 2008-02-22 | 2009-03-12 | 275d? |  | finish no earlier than 2009-03-12 | S5 | 2200h | 2200h | EPC-OAM | China Mobile | Rel-8 | Dionisio | PCG-21 | SP-39 |  |  |  |
| 720 | 265.12 | EPC Charging |  | 309d? | 2008-01-07 A | 2009-03-12 A | 100% |  | 2008-01-07 | 2009-03-12 | 309d? |  | finish no earlier than 2009-03-12 | S5 | 2472h | 2472h | EPC-CH | Nokia Siemens Networks | Rel-8 | Dionisio | PCG-21 | SP-38 |  |  |  |
| 721 | 265.13 | Domain Name System Procedures for Evolved Packet System (DEPS) |  | 179.75d? | 2008-05-30 A | 2009-03-06 A | 100% |  | 2008-05-30 | 2009-03-06 | 179.75d? |  | finish no earlier than 2009-03-06 | C4 | 1438h | 1438h | SAES-DEPS | TeliaSonera | Rel-8 | Kimmo | PCG-21 | CP-40 |  |  |  |
| 722 | 265.14 | InterWorking Function (IWF) between MAP based and Diameter based interfaces |  | 126d? | 2008-09-12 A | 2009-03-06 A | 100% |  | 2008-09-12 | 2009-03-06 | 126d? |  | finish no earlier than 2009-03-06 | C4 | 1008h | 1008h | SAES-MAP2Diam | Huawei | Rel-8 | Kimmo | PCG-21 | CP-41 |  |  |  |
| 723 | 265.15 | **CT6 aspects of SAE** |  | 857d? | 2008-03-07 A | 2011-06-17 | 83% | 144.94d? | 2008-03-07 | 2011-06-17 | 857d? | 390d |  | C6 | 13640h | 11333.1h | SAES | Nokia | Rel-8 | Xavier | PCG-21 | SP-39 |  |  |  |
| 724 | 265.15.1 | CT6 aspects of SAE |  | 321d? | 2008-03-07 A | 2009-05-29 A | 100% |  | 2008-03-07 | 2009-05-29 | 321d? |  | finish no earlier than 2009-05-29 | C6 | 2568h | 2568h | SAES | Nokia | Rel-8 | Xavier | PCG-21 | CP-39 |  |  |  |
| 725 | 265.15.2 | Test interworking of LTE Terminals with the USIM |  | 526d? | 2008-12-05 A | 2010-12-10 A | 100% |  | 2008-12-05 | 2010-12-10 | 526d? |  | finish no earlier than 2010-12-10 | C6 | 4208h | 4208h | SAES-USIM_LTE-Test | Comprion | Rel-8 | Xavier | PCG-22 | CP-42 |  |  |  |
| 726 | 265.15.3 | Test interworking of IP Multimedia Services Identity Module (ISIM) terminals with IP Multimedia Subsystem (IMS) |  | 196d? | 2010-09-17 A | 2011-06-17 | 10% | 176.4d? | 2010-09-17 | 2011-06-17 | 196d? | 390d | start no earlier than 2010-09-17 | C6 | 1568h | 156.8h | SAES-ISIM_IMS_Test | Comprion | Rel-8 | Xavier | PCG-25 | CP-49 |  |  |  |
| 727 | 265.16 | Issues for CT1 TR 24.801 |  | 420d? | 2007-01-04 A | 2008-12-05 A | 100% |  | 2007-01-04 | 2008-12-05 | 420d? |  | finish no earlier than 2008-12-05 | C1 | 3360h | 3360h | SAES | Nokia Siemens Networks | Rel-8 | Frederic | PCG-21 | CP-39 |  |  |  |
| 728 | 265.17 | Issues for CT3 TR 29.804 |  | 420d? | 2007-02-05 A | 2008-09-12 A | 100% |  | 2007-02-05 | 2008-09-12 | 420d? |  | finish no earlier than 2008-12-12 | C3 | 3360h | 3360h | SAES | Ericsson | Rel-8 | Gwiho | PCG-21 | CP-39 |  |  |  |
| 729 | 265.18 | Deleted - Issues for CT4 TR 29.803 |  | 420d? | 2007-01-04 A | 2008-09-12 A | 100% |  | 2007-01-04 | 2008-09-12 | 420d? |  | finish no earlier than 2008-12-11 | C4 | 3360h | 3360h | SAES | Huawei | Rel-8 | Kimmo | PCG-21 | CP-39 | PCG-21 | CP-41 |  |
| 730 | 265.19 | Deleted (covered by 380068): Functions and procedures for SAE to support LCS | milestone | 0d? | 2008-03-03 A | 2008-03-03 A | 100% |  | 2008-03-03 | 2008-03-03 | 0d? |  | finish no earlier than 2008-03-03 | S2 |  |  | SAES-SA-FP_LCS | Nokia Siemens Networks | Rel-8 | Maurice |  |  |  | SP-37 |  |
| 731 | 265.20 | Deleted (covered by 380064): SAE aspects of Emergency Calls | milestone | 0d? | 2008-03-03 A | 2008-03-03 A | 100% |  | 2008-03-03 | 2008-03-03 | 0d? |  | start no earlier than 2008-03-03 | S2 |  |  | SAES-SA-EmCall | Nokia Siemens Networks | Rel-8 | Maurice |  |  |  | SP-37 |  |
| 732 | 265.21 | Deleted - CT1 aspects of SAES |  | 16.7d? | 2007-09-04 A | 2007-09-27 A | 100% |  | 2007-09-04 | 2007-09-27 | 16.7d? |  | start no earlier than 2007-09-04 | CP,C1 | 133.62h | 133.62h | SAES-St3 |  | Rel-8 | Frederic |  |  |  | SP-37 |  |
| 733 | 265.22 | Deleted - CT1 aspects of SAES | milestone | 0d? | 2007-09-04 A | 2007-09-04 A | 100% |  | 2007-09-04 | 2007-09-04 | 0d? |  | start no earlier than 2007-09-04 | C1 |  |  | SAES-St3 |  | Rel-8 | Frederic |  |  |  | SP-37 |  |
| 734 | 265.23 | Deleted - Interoperability | milestone | 0d? | 2008-03-14 A | 2008-03-14 A | 100% |  | 2008-03-14 | 2008-03-14 | 0d? |  | start no earlier than 2008-03-14 | C1 |  |  | SAES-St3-interop |  | Rel-8 | Frederic |  |  |  | SP-37 |  |
| 735 | 265.24 | Deleted - CT3 aspects of SAES | milestone | 0d? | 2007-09-04 A | 2007-09-04 A | 100% |  | 2007-09-04 | 2007-09-04 | 0d? |  | start no earlier than 2007-09-04 | C3 |  |  | SAES-St3 |  | Rel-8 | Gwiho |  |  |  | SP-37 |  |
| 736 | 265.25 | Deleted - CT4 aspects of SAES | milestone | 0d? | 2007-09-04 A | 2007-09-04 A | 100% |  | 2007-09-04 | 2007-09-04 | 0d? |  | start no earlier than 2007-09-04 | C4 |  |  | SAES-St3 |  | Rel-8 | Kimmo |  |  |  | SP-37 |  |
| 737 | 265.26 | Deleted - UE to EPC NAS signalling (incl. MBMS and QoS aspects) | milestone | 0d? | 2008-03-14 A | 2008-03-14 A | 100% |  | 2008-03-14 | 2008-03-14 | 0d? |  | start no earlier than 2008-03-14 | C1 |  |  | SAES-St3-sig |  | Rel-8 | Frederic |  |  |  | SP-37 |  |
| 738 | 265.27 | Deleted - User and Control plane protocols | milestone | 0d? | 2007-09-21 A | 2007-09-21 A | 100% |  | 2007-09-21 | 2007-09-21 | 0d? |  | start no earlier than 2007-09-21 | C4 |  |  | SAES-St3-prot |  | Rel-8 | Kimmo |  |  |  | SP-37 |  |
| 739 | 265.28 | Deleted - Architecture enhancements for non-3GPP accesses | milestone | 0d? | 2007-09-04 A | 2007-09-04 A | 100% |  | 2007-09-04 | 2007-09-04 | 0d? |  | start no earlier than 2007-09-04 | S2 |  |  | SAES-non_3GPP | Motorola | Rel-8 | Maurice |  |  |  | SP-34 |  |
| 740 | 265.29 | Deleted - Stage 2 of architecture for the 3GPP System Architecture Evolution | milestone | 0d? | 2007-10-02 A | 2007-10-02 A | 100% |  | 2007-10-02 | 2007-10-02 | 0d? |  | start no earlier than 2007-10-02 | S2 |  |  | SAES-St2 | Vodafone | Rel-8 | Maurice |  |  |  | SP-34 |  |
| 741 | 265.30 | Deleted - SA aspects of System Architecture Evolution |  | 384d? | 2006-04-12 A | 2007-10-01 A | 100% |  | 2006-04-12 | 2007-10-01 | 384d? |  | finish no earlier than 2007-10-02 | S2 | 3072h | 3072h | SAES-SA |  | Rel-8 | Maurice |  |  |  | SP-34 |  |
| 742 | 266 | Conformance Test Aspects – Mobility management based on DSMIPv6 (Dual-Stack Mobile IPv6) |  | 261d? | 2009-09-18 A | 2010-09-17 A | 100% |  | 2009-09-18 | 2010-09-17 | 261d? |  | finish no earlier than 2010-09-17 | R5 | 2088h | 2088h | DSMIPv6_UEConTest | Qualcomm | Rel-8 | Ingbert | PCG-23 | RP-45 |  |  | RP-100738 |

Notes:
- 706: CP#43 completed. SP#38 WID approved (extract from SAE WID SP-070817). / Text5: curt.c.wong@nokia.com
- 707: SP#41 completed. SP#38 WID approved / Text3: new 23.216 / Text5: curt.c.wong@nokia.com
- 708: CP#43 completed / Text3: 23.009, 24.008, new 24.301 / Text5: robert.zaus@nsn.com
- 709: CP#43 completed / Text3: 23.003, 23.008, new (29.274, 29.277, 29.280) / Text5: Giorgi Gulbani
- 710: SP#40 completed / Text5: balazs.bertenyi@nsn.com
- 711: SP#40 completed / Text5: balazs.bertenyi@nsn.com
- 712: CP#43 completed / Text5: sabine.demel@t-mobile.at, chris.pudney@vodafone.com
- 713: SP#40 completed / Text3: new (23.272, 23.401) / Text5: sabine.demel@t-mobile.at, chris.pudney@vodafone.com
- 714: CP#43 completed / Text3: 24.007, 24.008, 24.011, 29.018, new (24.301, 24.801, 29.118) / Text5: yannick.lair@nectech.fr
- 715: CP#42 completed / Text3: 23.007, 23.008, 29.274, new 29.277 / Text5: yannick.lair@nectech.fr
- 716: SP#40 completed / Text3: 23.228, 23.221, 23.203 / Text5: mario.madella@telecomitalia.it
- 717: SP#43 completed
- 718: SP#43 completed / Text3: new (32.751, 32.752, 32.753, 32.755) / Text5: WANG, Xuelong
- 719: SP#43 completed / Text3: new 32.426 / Text5: Li Jian (lijian@chinamobile.com), Liang Shuangchun (liangshuangchun@cmdi.chinamobile.com)
- 720: SP#43 completed / Text3: 32.240, 32.296, 32.251, 32.252, 32.298, 32.299 / Text5: Gerald.Goermer@nsn.com
- 721: CP#43 completed / Text3: 23.003, new 29.303 / Text5: jouni.korhonen@teliasonera.com
- 722: CP#43 completed. Triggered by UID_380023 (FS_MAP2Diam) / Text3: new 29.305 / Text5: liming49985@huawei.com
- 723: CP#44 completed core specification / Text5: Rune Lindholm
- 724: CP#44 completed (specified Network Measurement Results collection via USAT) / Text3: 31.102, 31.111 / Text5: Rune Lindholm
- 725: CP#50 completed. Steering of Roaming test cases have been introduced. Remaining issues CSG display testing (Provide Local Information, Call Control for EPS/PDN, Event Download (Access Technology Change - Multiple Access Technologies) / Text3: 31.121, 31.124 / Text5: Udo Willenbrink (uwillenbrink@comprion.com )
- 726: Linked to Rel-5 UID_1273 Provisioning of IP-based multimedia services (24.229, 31.103), Rel-8 UID_390021 CT6 aspects of SAE, UID_420018 Test interworking of LTE Terminals with the USIM, Rel-9 UID_450018 Testing SMS over IMS in E-UTRAN (34.229). / Text3: 31.121, 31.124, new TS 31.134 / Text5: Udo Willenbrink (uwillenbrink@comprion.com )
- 727: CP#43 completed / Text3: 24.801 / Text5: robert.zaus@nsn.com
- 728: CP#41 completed / Text3: 29.804 / Text5: j.javier.pastor@ericsson.com
- 729: CP#41 Work stopped and continued in Normative specifications / Text3: 29.803
- 730: SP#37 stopped
- 731: SP#37 stopped
- 732: SP#37 stopped
- 733: SP#37 stopped
- 734: SP#37 stopped
- 735: SP#37 stopped
- 736: SP#37 stopped / Text3: 29.803
- 737: SP#37 stopped
- 738: SP#37 stopped
- 739: SP#34 stopped. Replaced by UID_350027 and its children / Text3: 23.402 / Text5: Irfan.Ali@motorola.com
- 740: SP#34 stopped. Replaced by UIDs 340018 and 340037. (SP#34 report discussion of SP-060917.) / Text3: 23.002, 23.060, 23.107, 23.203, 23.228, 23.234, 23.246, 23.271, 23.279 / Text5: chris.pudney@vodafone.com
- 741: SP#34 stopped
- 742: RP#49 completed. Testing for CT1's UID_360022 (24.303) under Rel-8 Feature SAES / Text3: 36.508, 36.523-1, 36.523-2, 36.523-3 / Text5: Lena Chaponniere (lchaponn@qualcomm.com)

| ID | WBS | Task | Duration | Start | Finish | Complete | Baseline start | Baseline finish | Baseline duration | Constraint | Resources | Work | Actual work | Text1 | Text4 | Text5 | Text6 | Text7 | Text8 | Text2 | Text9 | Text12 |
| --- | --- | --- | --- | --- | --- | --- | --- | --- | --- | --- | --- | --- | --- | --- | --- | --- | --- | --- | --- | --- | --- | --- |
| 743 | 267 | **IMS Centralized Service Control (ICSRA)** | 395d? | 2007-09-03 A | 2009-03-06 A | 100% | 2007-09-03 | 2009-03-06 | 395d? |  | S1,S2,C1,C3,C4 | 10680h | 10680h | ICSRA | AT&T | Randolph Wohlert (rwohlert@tri.sbc.com) | Rel-8 | SP-37 | Alain |  |  |  |
| 744 | 267.1 | Stage 1 for ICSRA | 138d? | 2007-09-03 A | 2008-03-12 A | 100% | 2007-09-03 | 2008-03-12 | 138d? | finish no earlier than 2007-12-14 | S1 | 1104h | 1104h | ICSRA | AT&T | Randolph Wohlert (rwohlert@tri.sbc.com) | Rel-8 | SP-38 | Alain | PCG-21 |  |  |
| 745 | 267.2 | Stage 2 for ICSRA | 125d? | 2007-12-14 A | 2008-06-05 A | 100% | 2007-12-14 | 2008-06-05 | 125d? | start no earlier than 2007-12-14 | S2 | 1000h | 1000h | ICSRA-St2 | Alcatel-Lucent |  | Rel-8 | SP-38 | Maurice | PCG-21 |  |  |
| 746 | 267.3 | **Stage 3 for ICSRA – Protocol, Addressing, Subscriber Data** | 201d? | 2008-05-30 A | 2009-03-06 A | 100% | 2008-05-30 | 2009-03-06 | 201d? |  | C1,C3,C4 | 6520h | 6520h | ICSRA | Ericsson | Sean Schneyer | Rel-8 |  | Frederic |  |  |  |
| 747 | 267.3.1 | CT1 aspects - Stage 3 for ICSRA | 201d? | 2008-05-30 A | 2009-03-06 A | 100% | 2008-05-30 | 2009-03-06 | 201d? | finish no earlier than 2009-03-06 | C1 | 1608h | 1608h | ICSRA | Ericsson | Sean Schneyer | Rel-8 | CP-40 | Frederic | PCG-21 |  |  |
| 748 | 267.3.2 | CT3 aspects - Stage 3 for ICSRA | 201d? | 2008-05-30 A | 2009-03-06 A | 100% | 2008-05-30 | 2009-03-06 | 201d? | finish no earlier than 2009-03-06 | C3 | 1608h | 1608h | ICSRA | Mavenir | Brett Wallis | Rel-8 | CP-40 | Gwiho | PCG-21 |  |  |
| 749 | 267.3.3 | CT4 aspects - Stage 3 for ICSRA | 136d? | 2008-05-30 A | 2008-12-05 A | 100% | 2008-05-30 | 2008-12-05 | 136d? | start no earlier than 2008-05-30 | C4 | 1088h | 1088h | ICSRA | Ericsson | Sean Schneyer | Rel-8 | CP-40 | Kimmo | PCG-21 |  |  |
| 750 | 267.3.4 | Deleted - Stage 3 for ICSRA – I1 interface | 76d? | 2008-05-30 A | 2008-09-12 A | 100% | 2008-05-30 | 2008-09-12 | 76d? | finish no earlier than 2008-09-12 | C1 | 608h | 608h | ICSRA | Huawei | xupeili@huawei.com | Rel-8 | CP-40 | Frederic | PCG-21 | PCG-21 | CP-41 |
| 751 | 268 | **IMS Multimedia Telephony and Supplementary Services** | 487d? | 2007-05-02 A | 2009-03-12 A | 100% | 2007-05-02 | 2009-03-12 | 487d? |  | S1,S5,C1,C3,C4 | 46006.4h | 46006.4h | IMSTSS |  |  | Rel-8 | SP-37 | Alain |  |  |  |
| 752 | 268.1 | **General aspects of IMS Sup Services** | 395d? | 2007-09-03 A | 2009-03-06 A | 100% | 2007-09-03 | 2009-03-06 | 395d? |  | S1,C1,C3,C4 | 9752h | 9752h | IMSSS-Gal | Ericsson | Susana Sabater | Rel-8 | SP-37 | Alain |  |  |  |
| 753 | 268.1.1 | Service and Capability for Core IMS - inclusion of TISPAN requirements | 75d? | 2007-09-03 A | 2007-12-14 A | 100% | 2007-09-03 | 2007-12-14 | 75d? | finish no earlier than 2007-12-14 | S1 | 600h | 600h | TISCAPR8 | Ericsson | Susana Sabater | Rel-8 | SP-37 | Alain |  |  |  |
| 754 | 268.1.2 | Documentation of TISPAN R1 and R2 in CT1 | 208d? | 2007-11-28 A | 2008-09-12 A | 100% | 2007-11-28 | 2008-09-12 | 208d? | finish no earlier than 2008-09-12 | C1 | 1664h | 1664h | REDOC_TIS-C1 | Nokia Siemens Networks | peter.leis@nsn.com | Rel-8 | CP-38 | Frederic | PCG-21 |  |  |
| 755 | 268.1.3 | Documentation of TISPAN R1 and R2 in CT3 | 333d? | 2007-11-28 A | 2009-03-06 A | 100% | 2007-11-28 | 2009-03-06 | 333d? | finish no earlier than 2009-03-06 | C3 | 2664h | 2664h | REDOC_TIS-C3 | Nokia Siemens Networks | peter.leis@nsn.com | Rel-8 | CP-38 | Gwiho | PCG-21 |  |  |
| 756 | 268.1.4 | Documentation of TISPAN R1 and R2 in CT4 | 208d? | 2007-11-28 A | 2008-09-12 A | 100% | 2007-11-28 | 2008-09-12 | 208d? | finish no earlier than 2008-09-12 | C4 | 1664h | 1664h | REDOC_TIS-C4 | Nokia Siemens Networks | peter.leis@nsn.com | Rel-8 | CP-38 | Kimmo | PCG-21 |  |  |
| 757 | 268.2 | **IMS Multimedia Telephony Service** | 394d? | 2007-09-10 A | 2009-03-12 A | 100% | 2007-09-10 | 2009-03-12 | 394d? |  | S1,S5 | 5096h | 5096h | IMS-MMTel |  |  | Rel-8 | SP-37 | Alain |  |  |  |
| 758 | 268.2.1 | Merging TISPAN MMTel [requirements] for Common IMS | 65d? | 2007-09-10 A | 2007-12-07 A | 100% | 2007-09-10 | 2007-12-07 | 65d? | finish no earlier than 2007-12-07 | S1 | 520h | 520h | TMMTEL | Nokia Siemens Networks |  | Rel-8 | SP-37 | Alain |  |  |  |
| 759 | 268.2.2 | Multimedia Telephony Service and Supplementary Services (MMTel) offline Charging | 309d? | 2008-01-07 A | 2009-03-12 A | 100% | 2008-01-07 | 2009-03-12 | 309d? | finish no earlier than 2009-03-12 | S5 | 2472h | 2472h | MMTel-CH | Alcatel-Lucent | GARDELLA, Maryse | Rel-8 | SP-38 | Dionisio | PCG-21 |  |  |
| 760 | 268.3 | **Call Completion on Busy Subscriber (CCBS)/Call Completion on Non-Reachable (CCNR) on IMS** | 483d? | 2007-05-02 A | 2009-03-06 A | 100% | 2007-05-02 | 2009-03-06 | 483d? |  | C1,C3 | 11072h | 11072h | CCBS_CCNR | Deutsche Telekom | martin.huelsemann@telekom.de | Rel-8 | SP-38 | Frederic | PCG-21 |  |  |
| 761 | 268.3.1 | Stage 3 CCBS_CCNR | 483d? | 2007-05-02 A | 2009-03-06 A | 100% | 2007-05-02 | 2009-03-06 | 483d? | finish no earlier than 2009-03-06 | C1 | 3864h | 3864h | CCBS_CCNR | Deutsche Telekom | martin.huelsemann@telekom.de | Rel-8 | CP-38 | Frederic | PCG-21 |  |  |
| 762 | 268.3.2 | Stage 3 CCBS_CCNR | 418d? | 2007-05-02 A | 2008-12-05 A | 100% | 2007-05-02 | 2008-12-05 | 418d? | finish no earlier than 2008-12-05 | C3 | 3344h | 3344h | CCBS_CCNR | Deutsche Telekom | martin.huelsemann@telekom.de | Rel-8 | CP-38 | Gwiho | PCG-21 |  |  |
| 763 | 268.4 | **Flexible Alerting** | 288d? | 2008-01-30 A | 2009-03-06 A | 100% | 2008-01-30 | 2009-03-06 | 288d? |  | S1,C1 | 5278.4h | 5278.4h | FA | Nortel | milanpa@nortel.com | Rel-8 | SP-39 | Alain | PCG-21 |  |  |
| 764 | 268.4.1 | Stage 1 FA | 92d? | 2008-01-30 A | 2008-06-05 A | 100% | 2008-01-30 | 2008-06-05 | 92d? |  | S1 | 670.4h | 670.4h | FA | Telecom Italia |  | Rel-8 | SP-39 | Alain | PCG-21 |  |  |
| 765 | 268.4.2 | Stage 3 FA | 288d? | 2008-01-30 A | 2009-03-06 A | 100% | 2008-01-30 | 2009-03-06 | 288d? | finish no earlier than 2009-03-06 | C1 | 2304h | 2304h | FA | Nortel | milanpa@nortel.com | Rel-8 | CP-39 | Frederic | PCG-21 |  |  |
| 766 | 268.5 | **Communication Wait on IMS** | 331d? | 2007-11-30 A | 2009-03-06 A | 100% | 2007-11-30 | 2009-03-06 | 331d? |  | C1,C3 | 7416h | 7416h | CW_IMS | Deutsche Telekom | martin.huelsemann@telekom.de | Rel-8 | SP-38 | Frederic | PCG-21 |  |  |
| 767 | 268.5.1 | Stage 3 CW-IMS | 331d? | 2007-11-30 A | 2009-03-06 A | 100% | 2007-11-30 | 2009-03-06 | 331d? | finish no earlier than 2009-03-06 | C1 | 2648h | 2648h | CW_IMS | Deutsche Telekom | martin.huelsemann@telekom.de | Rel-8 | CP-38 | Frederic | PCG-21 |  |  |
| 768 | 268.5.2 | Stage 3 CW-IMS | 265d? | 2007-11-30 A | 2008-12-04 A | 100% | 2007-11-30 | 2008-12-04 | 265d? | finish no earlier than 2008-12-05 | C3 | 2120h | 2120h | CW_IMS | Deutsche Telekom | martin.huelsemann@telekom.de | Rel-8 | CP-38 | Gwiho | PCG-21 |  |  |
| 769 | 268.6 | Advice of Charge (AoC) support in IMS Charging | 309d? | 2008-01-07 A | 2009-03-12 A | 100% | 2008-01-07 | 2009-03-12 | 309d? | finish no earlier than 2009-03-12 | S5 | 2472h | 2472h | IMSTSS | Nokia Siemens Networks | Gerald.Goermer@nsn.com | Rel-8 | SP-38 | Dionisio | PCG-21 |  |  |
| 770 | 268.7 | Add Interconnection Border Control Function (IBCF) to IMS Charging | 128d? | 2007-09-17 A | 2008-03-12 A | 100% | 2007-09-17 | 2008-03-12 | 128d? | finish no earlier than 2008-03-12 | S5 | 1024h | 1024h | IMSTSS | Alcatel-Lucent | GARDELLA, Maryse | Rel-8 | SP-37 | Dionisio |  |  |  |

Notes:
- 743: CP#46 completed
- 744: SP#39 completed / Text3: 22.101
- 745: SP#40 completed / Text3: 23.292, 23.206
- 746: CP#46 completed
- 747: CP#46 completed / Text3: 24.229, new (24.292, 24.286)
- 748: CP#43 completed / Text3: new 29.292
- 749: CP#42 completed / Text3: 23.003, 29.232, 23.018, 29.002
- 750: CP#41 work stopped / Text3: 24.293
- 751: SP#43 completed
- 752: CP#43 completed
- 753: SP#39 completed / Text3: 22.228, 22.115, 22.101
- 754: CP#41 completed / Text3: 24.141, 24.147, 24.173, 24.229, 24.247, 24.341, 24.604, 24.605, 24.606, 24.607, 24.608, 24.610, 24.611, 24.616, 24.623, 24.628, 24.629, 24.647, 24.654
- 755: CP#43 completed / Text3: 29.162, 29.163, 29.658
- 756: CP#41 completed / Text3: 29.228, 29.229
- 757: SP#43 completed
- 758: SP#38 completed / Text3: 22.173
- 759: CP#43 completed / Text3: 32.275, 32.298/299
- 760: CP#43 completed
- 761: CP#43 completed / Text3: 24.642, 24.229, 24.173
- 762: CP#42 completed / Text3: 29.163
- 763: CP#43 completed
- 764: SP#40 completed / Text3: 22.173
- 765: CP#43 completed / Text3: 24.239, 24.173
- 766: CP#43 completed
- 767: CP#43 completed / Text3: 24.615, 24.229, 24.173
- 768: CP#42 completed / Text3: 29.163
- 769: SP#43 completed / Text3: 32.240, 32.260, 32.296, 32.298, 32.299, new 32.280
- 770: SP#39 completed / Text3: 32.260, 32.298

| ID | WBS | Task | Duration | Start | Finish | Complete | Baseline start | Baseline finish | Baseline duration | Constraint | Resources | Work | Actual work | Text1 | Text2 | Text4 | Text5 | Text6 | Text7 | Text8 |
| --- | --- | --- | --- | --- | --- | --- | --- | --- | --- | --- | --- | --- | --- | --- | --- | --- | --- | --- | --- | --- |
| 771 | 269 | **3GPP2 Input to Common IMS** | 200d? | 2008-03-07 A | 2008-12-11 A | 100% | 2008-03-07 | 2008-12-11 | 200d? |  | S1,S2,S3,C1,C3,C4 | 8653.2h | 8653.2h | CIMS_3GPP2 | PCG-21 | Nortel | Amar Deol (deola@nortelnetworks.com) | Rel-8 | SP-39 | Alain |
| 772 | 269.1 | Stage 1 CIMS_3GPP2 (SA1) | 30.65d? | 2008-03-12 A | 2008-06-05 A | 100% | 2008-03-12 | 2008-06-05 | 30.65d? | finish no earlier than 2008-06-12 | S1 | 245.2h | 245.2h | CIMS_3GPP2 | PCG-21 | Nortel | Amar Deol (deola@nortelnetworks.com) | Rel-8 | SP-39 | Alain |
| 773 | 269.2 | Stage 2 CIMS_3GPP2 (SA2) | 62d? | 2008-03-12 A | 2008-06-05 A | 100% | 2008-03-12 | 2008-06-05 | 62d? | finish no earlier than 2008-09-11 | S2 | 496h | 496h | IMS_Common | PCG-21 | Nortel | Amar Deol (deola@nortelnetworks.com) | Rel-8 | SP-39 | Maurice |
| 774 | 269.3 | Security CIMS_3GPP2 (SA3) | 197d? | 2008-03-12 A | 2008-12-11 A | 100% | 2008-03-12 | 2008-12-11 | 197d? | finish no earlier than 2008-12-11 | S3 | 1576h | 1576h | IMS_Common | PCG-21 | Nortel | Amar Deol (deola@nortelnetworks.com) | Rel-8 | SP-39 | Dionisio |
| 775 | 269.4 | Stage 3 CIMS_3GPP2 (CT1) | 196d? | 2008-03-07 A | 2008-12-05 A | 100% | 2008-03-07 | 2008-12-05 | 196d? | finish no earlier than 2008-12-11 | C1 | 1568h | 1568h | REDOC_3GPP2 | PCG-21 | Alcatel-Lucent | orsic@alcatel-lucent.com | Rel-8 | CP-39 | Frederic |
| 776 | 269.5 | Stage 3 CIMS_3GPP2 (CT3) | 196d? | 2008-03-07 A | 2008-12-05 A | 100% | 2008-03-07 | 2008-12-05 | 196d? | finish no earlier than 2008-12-05 | C3 | 1568h | 1568h | REDOC_3GPP2 | PCG-21 | Alcatel-Lucent | orsic@alcatel-lucent.com | Rel-8 | CP-39 | Gwiho |
| 777 | 269.6 | Stage 3 CIMS_3GPP2 (CT4) | 200d? | 2008-03-07 A | 2008-12-11 A | 100% | 2008-03-07 | 2008-12-11 | 200d? | finish no earlier than 2008-12-11 | C4 | 1600h | 1600h | REDOC_3GPP2 | PCG-21 | Alcatel-Lucent | orsic@alcatel-lucent.com | Rel-8 | CP-39 | Kimmo |
| 778 | 270 | **IMS Enhancements for support of Packet Cable access** | 388d? | 2006-12-06 A | 2008-05-30 A | 100% | 2006-12-06 | 2008-05-30 | 388d? |  | S2,S3,C1,C3,C4 | 27448h | 27448h | PktCbl |  | Cablelabs | Bernie McKibben | Rel-8 |  | Maurice |
| 779 | 270.1 | **IMS Enhancements for Cable Client Types and Deployment Models** | 345d? | 2007-02-05 A | 2008-05-30 A | 100% | 2007-02-05 | 2008-05-30 | 345d? |  | S2,C1 | 6992h | 6992h | PktCbl-Deploy |  | Cablelabs | Bernie McKibben | Rel-8 |  | Maurice |
| 780 | 270.1.1 | Architecture aspects of PktCbl-Deploy | 219d? | 2007-02-05 A | 2007-12-06 A | 100% | 2007-02-05 | 2007-12-06 | 219d? | finish no earlier than 2007-12-03 | S2 | 1752h | 1752h | PktCbl-Deploy |  | Cablelabs | Bernie McKibben | Rel-8 |  | Maurice |
| 781 | 270.1.2 | CT1 aspects of PktCbl-Deploy | 310d? | 2007-03-26 A | 2008-05-30 A | 100% | 2007-03-26 | 2008-05-30 | 310d? | finish no earlier than 2008-06-15 | C1 | 2480h | 2480h | PktCbl-Deploy |  | Cablelabs | D.Hancock@ CableLabs.com | Rel-8 |  | Frederic |
| 782 | 270.2 | **IMS Inter-working aspects in Support of Cable Regulatory requirements** | 290d? | 2007-02-05 A | 2008-03-14 A | 100% | 2007-02-05 | 2008-03-14 | 290d? |  | S2,C1,C3 | 5640h | 5640h | PktCbl-Intw |  | Cablelabs | B.McKibben@CableLabs.com | Rel-8 |  | Maurice |
| 783 | 270.2.1 | Architecture aspects of PktCbl-Interwork | 160d? | 2007-02-05 A | 2007-09-14 A | 100% | 2007-02-05 | 2007-09-14 | 160d? | start no earlier than 2007-02-05 | S2 | 1280h | 1280h | PktCbl-Intw |  | Cablelabs | B.McKibben@CableLabs.com | Rel-8 |  | Maurice |
| 784 | 270.2.2 | CT1,CT3 aspects of PktCbl-Interwork | 255d? | 2007-03-26 A | 2008-03-14 A | 100% | 2007-03-26 | 2008-03-14 | 255d? | finish no earlier than 2008-03-15 | C1,C3 | 2040h | 2040h | PktCbl-Intw |  | Cablelabs | D.Hancock@ CableLabs.com | Rel-8 |  | Frederic |
| 785 | 270.3 | **IMS Enhancements for Security Requirements in Support of Cable Deployments** | 388d? | 2006-12-06 A | 2008-05-30 A | 100% | 2006-12-06 | 2008-05-30 | 388d? |  | S3,C1,C3,C4 | 11712h | 11712h | PktCbl-Sec |  | Cablelabs | s.dotson@cablelabs.com | Rel-8 |  | Dionisio |
| 786 | 270.3.1 | SA3 aspects of PktCbl-Sec | 331d? | 2006-12-06 A | 2008-03-12 A | 100% | 2006-12-06 | 2008-03-12 | 331d? | finish no earlier than 2007-12-20 | S3 | 2648h | 2648h | PktCbl-Sec |  | Cablelabs | s.dotson@cablelabs.com | Rel-8 |  | Dionisio |
| 787 | 270.3.2 | CT1 aspects of PktCbl-Sec | 310d? | 2007-03-26 A | 2008-05-30 A | 100% | 2007-03-26 | 2008-05-30 | 310d? | finish no earlier than 2008-06-06 | C1 | 2480h | 2480h | PktCbl-Sec |  | Cablelabs | D.Hancock@ CableLabs.com | Rel-8 |  | Frederic |
| 788 | 270.3.3 | CT3 aspects of PktCbl-Sec | 180d? | 2007-03-26 A | 2007-11-30 A | 100% | 2007-03-26 | 2007-11-30 | 180d? | finish no earlier than 2008-03-15 | C3 | 1440h | 1440h | PktCbl-Intw | PCG-21 | Cablelabs | D.Hancock@ CableLabs.com | Rel-8 | CP-38 | Gwiho |
| 789 | 270.3.4 | CT4 aspects of PktCbl-Sec | 255d? | 2007-03-26 A | 2008-03-14 A | 100% | 2007-03-26 | 2008-03-14 | 255d? | finish no earlier than 2008-03-14 | C4 | 2040h | 2040h | PktCbl-Sec |  | Cablelabs | D.Hancock@ CableLabs.com | Rel-8 |  | Kimmo |
| 790 | 271 | **IMS System enhancements for corporate network access** | 717d? | 2007-06-22 A | 2010-03-19 A | 100% | 2007-06-22 | 2010-03-19 | 717d? |  | S2,S1,C1,C4 | 14336.9h | 14336.9h | IMS_Corp |  | Orange | Delphin Barankanira | Rel-8 |  | Maurice |
| 791 | 271.1 | SA1 aspects of IMS_Corp | 23.6d? | 2008-03-12 A | 2008-06-05 A | 100% | 2008-03-12 | 2008-06-05 | 23.6d? | finish no earlier than 2008-06-05 | S1 | 188.8h | 188.8h | IMS_Corp | PCG-21 | Telecom Italia |  | Rel-8 | SP-39 | Alain |
| 792 | 271.2 | SA2 aspects of IMS_Corp | 325d? | 2007-06-22 A | 2008-09-18 A | 100% | 2007-06-22 | 2008-09-18 | 325d? | finish no earlier than 2008-12-25 | S2 | 2600h | 2600h | IMS_Corp |  | Orange | Delphin Barankanira | Rel-8 |  | Maurice |
| 793 | 271.3 | CT1 aspects of IMS_Corp | 532d? | 2008-03-07 A | 2010-03-19 A | 100% | 2008-03-07 | 2010-03-19 | 532d? | finish no earlier than 2010-03-19 | C1 | 4244.09h | 4244.09h | IMS_Corp | PCG-21 | Alcatel-Lucent | Keith Drage (drage@alcatel-lucent.com) | Rel-8 | CP-39 | Frederic |
| 794 | 271.4 | CT4 aspects of IMS_Corp | 196d? | 2008-02-26 A | 2008-12-05 A | 100% | 2008-02-26 | 2008-12-05 | 196d? | finish no earlier than 2008-12-11 | C4 | 1568h | 1568h | IMS_Corp | PCG-21 | Alcatel-Lucent | Keith Drage (drage@alcatel-lucent.com) | Rel-8 | CP-39 | Kimmo |

Notes:
- 771: TSG#42 completed
- 772: SP#40 completed / Text3: 22.228, 22.173, 22.101, 22.153
- 773: SP#40 completed / Text3: 23.002, 23.141, 23.203, 23.167, 23.228
- 774: SP#42 completed [issues addressed under UID_370078 (IMS-Sec)] / Text3: 33.141, 33.203, 33.210
- 775: CP#42 completed / Text3: 23.218, 24.141, 24.147, 24.173, 24.229, 24.238, 24.247, 24.604, 24.605, 24.606, 24.607, 24.608, 24.610, 24.611, 24.629, 24.930
- 776: CP#42 completed / Text3: 29.163, 29.212, 29.213, 29.214
- 777: CP#42 completed / Text3: 29.228, 29.229, 29.328, 29.329
- 778: CP#40 completed
- 779: CP#40 completed
- 780: SP#38 completed / Text3: 23.228
- 781: CP#40 completed
- 782: CP#39 completed
- 783: SP#37 completed / Text3: 23.228
- 784: CP#39 completed / Text3: 24.229
- 785: CP#40 completed
- 786: SP#39 completed / Text3: 33.203, 33.210, 33.220
- 787: CP#40 completed / Text3: 24.229
- 788: CP#38 completed / Text3: 29.163
- 789: CP#39 completed / Text3: 29.228, 29.229, 23.008
- 790: CP#47 completed
- 791: SP#40 completed
- 792: no Stage 2 impacts / Text3: 23.228
- 793: CP#47 completed / Text3: 24.229, 24.503
- 794: CP#42 completed / Text3: 29.228, 29.229, 23.003, 23.008, 29.433

| ID | WBS | Task | Duration | Start | Finish | Complete | Baseline start | Baseline finish | Baseline duration | Constraint | Resources | Work | Actual work | Text1 | Text2 | Text6 | Text7 | Text8 | Text4 | Text5 |
| --- | --- | --- | --- | --- | --- | --- | --- | --- | --- | --- | --- | --- | --- | --- | --- | --- | --- | --- | --- | --- |
| 795 | 272 | **Maintenance of TISPAN documentation** | 244d? | 2007-07-02 A | 2008-06-05 A | 100% | 2007-07-02 | 2008-06-05 | 244d? |  | S2,C1,C3,C4 | 5984h | 5984h | MAINTISP | PCG-21 | Rel-8 | SP-38 | Maurice |  |  |
| 796 | 272.1 | Maintenance of TISPAN R1 | 86d? | 2007-11-09 A | 2008-03-07 A | 100% | 2007-11-09 | 2008-03-07 | 86d? | start no earlier than 2007-11-09 | C1,C3,C4 | 688h | 688h | MAINT_R1 | PCG-21 | Rel-7 | CP-38 | Frederic | Alcatel-Lucent | Keith Drage (drage@alcatel-lucent.com) |
| 797 | 272.2 | Maintenance of TISPAN R2 | 86d? | 2007-11-09 A | 2008-03-07 A | 100% | 2007-11-09 | 2008-03-07 | 86d? | start no earlier than 2007-11-09 | C1,C3,C4 | 688h | 688h | MAINT_R2 | PCG-21 | Rel-8 | CP-38 | Frederic | Alcatel-Lucent | Keith Drage (drage@alcatel-lucent.com) |
| 798 | 272.3 | Documentation of TISPAN NGN R1 and R2 in 3GPP SA2 | 104d? | 2008-01-14 A | 2008-06-05 A | 100% | 2008-01-14 | 2008-06-05 | 104d? | finish no earlier than 2008-06-20 | S2 | 832h | 832h | IMS_Comm_Doc | PCG-21 | Rel-8 | SP-38 | Maurice | Nokia Siemens Networks | jozsef.varga@nsn.com |
| 799 | 272.4 | Maintenance of TISPAN release 1 common IMS | 114d? | 2007-07-02 A | 2007-12-06 A | 100% | 2007-07-02 | 2007-12-06 | 114d? | finish no earlier than 2007-12-06 | S2,S1 | 912h | 912h | IMS_Comm_Mtce7 | PCG-21 | Rel-7 | SP-38 | Maurice | BT, Ericsson | Dick Knight, Raymond Forbes |
| 800 | 272.5 | Maintenance of TISPAN release 2 common IMS | 114d? | 2007-07-02 A | 2007-12-06 A | 100% | 2007-07-02 | 2007-12-06 | 114d? | finish no earlier than 2007-12-06 | S2 | 912h | 912h | IMS_Comm_Mtce8 | PCG-21 | Rel-8 | SP-38 | Maurice | Telecom Italia | antonio.ascolese@telecomitalia.it |
| 801 | 273 | **IMS Service Continuity** | 318d? | 2008-03-12 A | 2009-05-29 A | 100% | 2008-03-12 | 2009-05-29 | 318d? |  | S2,S1,C1 | 5624h | 5624h | IMS-Cont | PCG-21 | Rel-8 | SP-39 | Maurice | LG Electronics | JaeSeung SONG (anthonys@lge.com) |
| 802 | 273.1 | Stage 1 IMS Service Continuity | 62d? | 2008-03-12 A | 2008-06-05 A | 100% | 2008-03-12 | 2008-06-05 | 62d? | start no earlier than 2008-03-12 | S1 | 496h | 496h | IMS-Cont | PCG-21 | Rel-8 | SP-39 | Alain | LG Electronics | JaeSeung SONG (anthonys@lge.com) |
| 803 | 273.2 | Stage 2 IMS Service Continuity | 62d? | 2008-03-12 A | 2008-06-05 A | 100% | 2008-03-12 | 2008-06-05 | 62d? | finish no earlier than 2008-06-05 | S2 | 496h | 496h | IMS-Cont | PCG-21 | Rel-8 | SP-39 | Maurice | LG Electronics | JaeSeung SONG (anthonys@lge.com) |
| 804 | 273.3 | Stage 3 IMS Service Continuity | 261d? | 2008-05-30 A | 2009-05-29 A | 100% | 2008-05-30 | 2009-05-29 | 261d? | finish no earlier than 2009-05-29 | C1 | 2088h | 2088h | IMS-Cont | PCG-21 | Rel-8 | CP-40 | Frederic | Huawei | Lili Yang (kadyyang@huawei.com) |
| 805 | 274 | **Security Enhancements for IMS** | 643.3d? | 2006-09-19 A | 2009-03-06 A | 100% | 2006-09-19 | 2009-03-06 | 643.3d? |  | S3,C1,C4 | 18624h | 18624h | IMS-Sec |  | Rel-8 | SP-37 | Dionisio | Ericsson | Bengt.Sahlin@ericsson.com |
| 806 | 274.1 | Stage 2 for IMS-Sec | 466d? | 2007-03-01 A | 2008-12-11 A | 100% | 2007-03-01 | 2008-12-11 | 466d? | finish no earlier than 2008-12-11 | S3 | 3728h | 3728h | IMS-Sec |  | Rel-8 |  | Dionisio | Ericsson | Bengt.Sahlin@ericsson.com |
| 807 | 274.2 | CT1 part of Stage 3 for IMS-Sec | 392d? | 2006-09-19 A | 2008-12-05 A | 100% | 2006-09-19 | 2008-12-05 | 392d? | finish no earlier than 2008-12-05 | C1 | 3136h | 3136h | IMS-Sec | PCG-21 | Rel-8 | CP-39 | Frederic | Ericsson |  |
| 808 | 274.3 | CT4 part of Stage 3 for IMS-Sec | 457d? | 2007-06-07 A | 2009-03-06 A | 100% | 2007-06-07 | 2009-03-06 | 457d? | finish no earlier than 2009-03-06 | C4 | 3656h | 3656h | IMS-Sec | PCG-21 | Rel-8 | CP-39 | Kimmo | Ericsson |  |
| 809 | 274.4 | CT1 part of NASS Bundled Authentication | 343d? | 2007-11-14 A | 2009-03-06 A | 100% | 2007-11-14 | 2009-03-06 | 343d? | finish no earlier than 2009-03-06 | C1 | 2744h | 2744h | NBA | PCG-21 | Rel-8 | CP-39 | Frederic | Alcatel-Lucent | Keith Drage (drage@alcatel-lucent.com) |
| 810 | 274.5 | CT4 part of NASS Bundled Authentication | 143d? | 2007-11-14 A | 2008-05-30 A | 100% | 2007-11-14 | 2008-05-30 | 143d? | start no earlier than 2007-11-14 | C4 | 1144h | 1144h | NBA-CT4 | PCG-21 | Rel-8 | CP-39 | Kimmo | Alcatel-Lucent |  |
| 811 | 275 | IMS initiated and controlled PSS and MBMS User Service | 262d? | 2008-03-12 A | 2009-03-12 A | 100% | 2008-03-12 | 2009-03-12 | 262d? | finish no earlier than 2009-03-12 | S2,C3,C4 |  |  | IMS_PSS_MBMS_US |  | Rel-8 |  | Paolo | FT, Ericsson | olle.franceschi@ericsson.com |
| 812 | 276 | **Multimedia interworking between IMS and CS networks** | 836d? | 2005-09-23 A | 2008-12-05 A | 100% | 2005-09-23 | 2008-12-05 | 836d? |  | C3,C4 | 16112h | 16112h | MIW-IMS |  | Rel-8 |  | Gwiho | Vodafone | nico.gabriele@vodafone.com |
| 813 | 276.1 | Note: Stages 1 and 2 defined in earlier Release | 49d? | 2005-09-23 A | 2005-11-30 A | 100% | 2005-09-23 | 2005-11-30 | 49d? | start no earlier than 2005-09-23 | S2 | 392h | 392h | MIW-IMS |  | Rel-8 |  | Maurice | Vodafone | nico.gabriele@vodafone.com |
| 814 | 276.2 | Stage 3 of MW-IMS | 571d? | 2005-09-23 A | 2007-11-30 A | 100% | 2005-09-23 | 2007-11-30 | 571d? | finish no earlier than 2007-09-14 | C3 | 4568h | 4568h | MIW-IMS-St3 |  | Rel-8 |  | Gwiho | Vodafone | nico.gabriele@vodafone.com |
| 815 | 276.3 | Stage 3 for MW-IMS, MONA extension | 285d? | 2007-11-05 A | 2008-12-05 A | 100% | 2007-11-05 | 2008-12-05 | 285d? | finish no earlier than 2008-12-05 | C3 | 2280h | 2280h | MIW-IMS | PCG-21 | Rel-8 | CP-38 | Gwiho | Vodafone | Christer.Holmberg@ericsson.com |
| 816 | 276.4 | Mn interface (MGCF – IM MGW) | 273d? | 2007-11-21 A | 2008-12-05 A | 100% | 2007-11-21 | 2008-12-05 | 273d? | finish no earlier than 2008-12-19 | C4 | 2184h | 2184h | MIW-IMS | PCG-21 | Rel-8 | CP-38 | Kimmo | Vodafone | Christer.Holmberg@ericsson.com |
| 817 | 277 | IMS Stage 3 IETF Protocol Alignment | 446d? | 2007-06-22 A | 2009-03-06 A | 100% | 2007-06-22 | 2009-03-06 | 446d? | finish no earlier than 2009-03-06 | C1 | 3568h | 3568h | IMSProtoc2 |  | Rel-8 |  | Frederic | Alcatel-Lucent | Keith Drage (drage@alcatel-lucent.com) |
| 818 | 278 | **Interworking between User-to-User Signalling (UUS) and SIP** | 335d? | 2007-11-30 A | 2009-03-12 A | 100% | 2007-11-30 | 2009-03-12 | 335d? |  | C1,C3 | 7488h | 7488h | UUSIW | PCG-21 | Rel-8 | CP-38 | Kimmo | Huawei | Lili Yang (kadyyang@huawei.com) |
| 819 | 278.1 | Stage 3 MGCF UUSIW | 266d? | 2007-11-30 A | 2008-12-05 A | 100% | 2007-11-30 | 2008-12-05 | 266d? | finish no earlier than 2008-12-05 | C1 | 2128h | 2128h | UUSIW | PCG-21 | Rel-8 | CP-38 | Frederic | Huawei | Lili Yang (kadyyang@huawei.com) |
| 820 | 278.2 | Stage 3 MGCF UUSIW | 335d? | 2007-11-30 A | 2009-03-12 A | 100% | 2007-11-30 | 2009-03-12 | 335d? | finish no earlier than 2009-03-12 | C3 | 2680h | 2680h | UUSIW | PCG-21 | Rel-8 | CP-38 | Gwiho | Huawei | Lili Yang (kadyyang@huawei.com) |

Notes:
- 795: SP#40 completed
- 796: CP#39 completed / Text3: 24.404, 24.405, 24.406, 24.407, 24.408, 24.410, 24.411, 24.416, 29.421, 24.423, 24.428, 24.429, 29.433, 24.441, 24.403, 29.427, 24.430, 29.412
- 797: CP#39 completed / Text3: 24.406, 24.407, 24.410, 24.411, 24.423, 24.430, 24.447, 24.451, 24.454, 24.503, 24.505, 24.508, 24.516, 24.528, 24.529, 29.412, 29.421, 29.433, 29.458, 29.527, 29.624
- 798: SP#40 completed / Text3: 23.228, 23.204, 23.167
- 799: SP#38 completed / Text3: 22.273, 22.401, 23.406, 23.417, 23.508, 23.509, 23.511, 22.401, 22.173
- 800: SP#38 completed / Text3: 23.506, 23.507,23.517, 23.521
- 801: CP#44 completed
- 802: SP#40 completed
- 803: SP#40 completed / Text3: 23.237, 23.292
- 804: CP#44 completed / Text3: 24.237, 24.229, 24.216
- 805: CP#43 completed
- 806: SP#42 completed. SP#46 withdrawn draft 33.178-100 and 33.978 from Rel-8 onwards / Text3: 33.203, 33.141, 33.803
- 807: CP#42 completed
- 808: CP#43 completed
- 809: CP#43 completed / Text3: 24.229
- 810: CP#40 completed / Text3: 29.229, 29.228, 23.008
- 811: SP#43 completed. SP#39 WID approved / Text3: 26.237, 26.234, 26.346, 33.246
- 812: CP#42 completed
- 813: SP#31 Moved from FS section Feb 2006
- 814: Moved from Rel-7. Feature extended in Rel-8 by including Stage 3 covering MONA UID_380021 / Text3: 29.863, 29.163
- 815: CP#42 completed / Text3: 29.863, 29.163
- 816: CP#42 completed / Text3: 29.332
- 817: CP#43 completed / Text3: 23.218, 24.229, 24.930
- 818: CP#43 completed
- 819: CP#42 completed / Text3: 24.279, 24.229
- 820: CP#43 completed / Text3: 29.163

| ID | WBS | Task | Type | Duration | Start | Finish | Complete | Baseline start | Baseline finish | Baseline duration | Constraint | Resources | Work | Actual work | Text1 | Text2 | Text4 | Text5 | Text6 | Text7 | Text8 | Text3 | Text11 |
| --- | --- | --- | --- | --- | --- | --- | --- | --- | --- | --- | --- | --- | --- | --- | --- | --- | --- | --- | --- | --- | --- | --- | --- |
| 821 | 279 | **Support of Overlap signalling** |  | 331d? | 2007-11-30 A | 2009-03-06 A | 100% | 2007-11-30 | 2009-03-06 | 331d? |  | C3,C1,C4 | 10008.2h | 10008.2h | Overlap | PCG-21 | Deutsche Telekom | r.jesske@telekom.de | Rel-8 | CP-38 | Gwiho |  |  |
| 822 | 279.1 | Stage 3 Overlap (CT1) |  | 331d? | 2007-11-30 A | 2009-03-06 A | 100% | 2007-11-30 | 2009-03-06 | 331d? | finish no earlier than 2009-03-06 | C1 | 2648h | 2648h | Overlap | PCG-21 | Deutsche Telekom | r.jesske@telekom.de | Rel-8 | CP-38 | Frederic | 24.229 |  |
| 823 | 279.2 | Stage 3 Overlap (CT3) |  | 331d? | 2007-11-30 A | 2009-03-06 A | 100% | 2007-11-30 | 2009-03-06 | 331d? | finish no earlier than 2009-03-06 | C3 | 2648h | 2648h | Overlap | PCG-21 | Deutsche Telekom | r.jesske@telekom.de | Rel-8 | CP-38 | Gwiho | 29.163 |  |
| 824 | 279.3 | Stage 3 Overlap (CT4) |  | 258.02d? | 2007-11-30 A | 2008-12-05 A | 100% | 2007-11-30 | 2008-12-05 | 258.02d? | start no earlier than 2007-11-30 | C4 | 2064.16h | 2064.16h | Overlap | PCG-21 | Deutsche Telekom | r.jesske@telekom.de | Rel-8 | CP-38 | Kimmo | 29.228, 29.229 |  |
| 825 | 280 | AS/MRFC Stage 2 and 3 |  | 278d? | 2007-11-14 A | 2008-12-05 A | 100% | 2007-11-14 | 2008-12-05 | 278d? | finish no earlier than 2008-12-05 | C1 | 2224h | 2224h | MRFC_TS | PCG-21 | Hewlett-Packard | mark.syrett@hp.com | Rel-8 | CP-38 | Frederic | 23.218, 24.229, 24.147, 24.247 |  |
| 826 | 281 | **IMS Restoration Procedures** |  | 201d? | 2008-05-30 A | 2009-03-06 A | 100% | 2008-05-30 | 2009-03-06 | 201d? |  | C4,C1 | 4824h | 4824h | IMS_RP | PCG-21 | Ericsson | german.blanco@ericsson.com | Rel-8 | SP-40 | Kimmo |  |  |
| 827 | 281.1 | IMS Restoration Procedures (CT4) |  | 201d? | 2008-05-30 A | 2009-03-06 A | 100% | 2008-05-30 | 2009-03-06 | 201d? | finish no earlier than 2009-03-06 | C4 | 1608h | 1608h | IMS_RP | PCG-21 | Ericsson | german.blanco@ericsson.com | Rel-8 | SP-40 | Kimmo | 23.380, 29.228, 29.229, 29.230, 23.008 |  |
| 828 | 281.2 | IMS Restoration Procedures (CT1) |  | 201d? | 2008-05-30 A | 2009-03-06 A | 100% | 2008-05-30 | 2009-03-06 | 201d? | finish no earlier than 2009-03-06 | C1 | 1608h | 1608h | IMS_RP | PCG-21 | Ericsson | german.blanco@ericsson.com | Rel-8 | SP-40 | Frederic | 24.229 |  |
| 829 | 282 | IMS Application Server Service Data Descriptions for AS interoperability |  | 125d? | 2008-09-12 A | 2009-03-06 A | 100% | 2008-09-12 | 2009-03-06 | 125d? | finish no earlier than 2009-03-06 | C4 | 1000h | 1000h | IMS_ASIO | PCG-21 | Alcatel-Lucent | nhberry@alcatel-lucent.com | Rel-8 | CP-41 | Kimmo | 29.328, 29.329, 29.364 |  |
| 830 | 283 | **I-WLAN Network Selection Principle (NSP)** |  | 451d? | 2007-06-14 A | 2009-03-06 A | 100% | 2007-06-14 | 2009-03-06 | 451d? |  | S1,C1,C6 | 6643.2h | 6643.2h | IWLANNSP |  | Telefonica O2 | chris.friel@o2.com | Rel-8 |  | Alain |  |  |
| 831 | 283.1 | Stage 1 for I-WLAN NSP | milestone | 0d? | 2007-06-14 A | 2007-06-14 A | 100% | 2007-06-14 | 2007-06-14 | 0d? |  | S1 |  |  | IWLANNSP | PCG-21 | Telefonica O2 | chris.friel@o2.com | Rel-8 | SP-39 | Alain | 22.234 |  |
| 832 | 283.2 | Stage 3 for I-WLAN NSP |  | 261d? | 2008-03-07 A | 2009-03-06 A | 100% | 2008-03-07 | 2009-03-06 | 261d? | finish no earlier than 2008-12-05 | C1 | 2088h | 2088h | IWLANNSP | PCG-21 | RIM | Adrian Buckley (abuckley@rim.com) | Rel-8 | CP-39 | Frederic | 24.234 |  |
| 833 | 283.3 | Stage 3 for I-WLAN NSP |  | 118.4d? | 2008-03-07 A | 2008-12-11 A | 100% | 2008-03-07 | 2008-12-11 | 118.4d? | finish no earlier than 2008-12-11 | C6 | 947.2h | 947.2h | IWLANNSP | PCG-21 | RIM | Adrian Buckley (abuckley@rim.com) | Rel-8 | CP-39 | Xavier | 31.102, 31.111 |  |
| 834 | 284 | **Mobility between 3GPP-WLAN Interworking and 3GPP Systems** |  | 386d? | 2007-09-14 A | 2009-03-06 A | 100% | 2007-09-14 | 2009-03-06 | 386d? |  | S2,C1 | 6216h | 6216h | IWLAN_Mob |  | Orange | xiaobao.chen@orange-ftgroup.com | Rel-8 | SP-37 | Maurice |  |  |
| 835 | 284.1 | Stage 2: I-WLAN Mobility |  | 190d? | 2007-09-14 A | 2008-06-05 A | 100% | 2007-09-14 | 2008-06-05 | 190d? | finish no earlier than 2008-09-08 | S2 | 1520h | 1520h | IWLAN_Mob | PCG-21 | Orange | xiaobao.chen@orange-ftgroup.com | Rel-8 | SP-38 | Maurice | new 23.327 |  |
| 836 | 284.2 | CT1 aspects of I-WLAN Mobility |  | 201d? | 2008-05-30 A | 2009-03-06 A | 100% | 2008-05-30 | 2009-03-06 | 201d? | finish no earlier than 2009-03-06 | C1 | 1608h | 1608h | IWLAN_Mob | PCG-21 | Orange | reina.nader@orange-ftgroup.com | Rel-8 | CP-40 | Frederic | 24.303, new 24.327 |  |
| 837 | 285 | Conformance Test Aspects – Mobility between 3GPP WLAN Interworking and 3GPP Systems |  | 206d? | 2009-12-04 A | 2010-09-17 A | 100% | 2009-12-04 | 2010-09-17 | 206d? | finish no earlier than 2010-09-17 | R5 | 1648h | 1648h | IWLAN_Mob_UEConTest | PCG-24 | Qualcomm | Patrick Stupar (pstupar@qualcomm.com) | Rel-8 | RP-46 | Ingbert | 34.108, 34.123-1, 34.123-2, 34.123-3 | RP-100740 |
| 838 | 286 | **Enhancements for Voice Group Call Service (VGCS) Applications (EVA)** |  | 919d? | 2006-03-15 A | 2009-09-18 A | 100% | 2006-03-15 | 2009-09-18 | 919d? |  | S1,C1,C4,G2 | 23503.5h | 23503.5h | EVA |  | Nortel | Amar Deol (deola@nortelnetworks.com) | Rel-8 |  | Alain |  |  |
| 839 | 286.1 | SA1 aspects of EVA |  | 191d? | 2006-03-15 A | 2006-12-06 A | 100% | 2006-03-15 | 2006-12-06 | 191d? | finish no earlier than 2006-12-06 | S1 | 1528h | 1528h | EVA |  | Nortel | Amar Deol (deola@nortelnetworks.com) | Rel-8 |  | Alain | 42.068 |  |
| 840 | 286.2 | VGCS/VBS and GPRS Interactions |  | 145d? | 2007-09-03 A | 2008-03-21 A | 100% | 2007-09-03 | 2008-03-21 | 145d? | finish no earlier than 2008-03-21 | S1 | 1160h | 1160h | EVA |  | Huawei | Ling Liu | Rel-8 | SP-37 | Alain | 42.068, 42.069 |  |
| 841 | 286.3 | CT1 aspects of EVA |  | 862d? | 2006-06-02 A | 2009-09-18 A | 100% | 2006-06-02 | 2009-09-18 | 862d? | finish no earlier than 2009-12-04 | C1 | 6887.53h | 6887.53h | EVA |  | Nortel | milanpa@nortel.com | Rel-8 |  | Frederic | 43.068, 44.068 |  |
| 842 | 286.4 | CT4 aspects of EVA |  | 391d? | 2006-06-02 A | 2007-11-30 A | 100% | 2006-06-02 | 2007-11-30 | 391d? | finish no earlier than 2007-06-01 | C4 | 3128h | 3128h | EVA |  | Nortel |  | Rel-8 |  | Kimmo | 29.002 |  |
| 843 | 286.5 | GERAN2 aspects of EVA |  | 431d? | 2006-06-30 A | 2008-02-22 A | 100% | 2006-06-30 | 2008-02-22 | 431d? | finish no earlier than 2008-02-22 | G2 | 3448h | 3448h | EVA |  | Nortel | frank.billenkamp@nortel.com | Rel-8 |  | Gert | 44.018, 48.008 |  |
| 844 | 287 | **Personal Network Management** |  | 955d? | 2005-07-11 A | 2009-03-06 A | 100% | 2005-07-11 | 2009-03-06 | 955d? |  | S1,C1,S3 | 27008h | 27008h | PNM |  | Vodafone | armin.toepfer@vodafone.com | Rel-8 |  | Alain |  |  |
| 845 | 287.1 | Stage 1 for PNM |  | 276d? | 2005-07-11 A | 2006-07-31 A | 100% | 2005-07-11 | 2006-07-31 | 276d? | start no earlier than 2005-07-11 | S1 | 2208h | 2208h | PNM |  | Vodafone | armin.toepfer@vodafone.com | Rel-8 |  | Alain | 22.259 |  |
| 846 | 287.2 | Stage 2 for PNM |  | 445d? | 2007-03-26 A | 2008-12-05 A | 100% | 2007-03-26 | 2008-12-05 | 445d? | finish no earlier than 2008-12-05 | C1 | 3560h | 3560h | PNM |  | Vodafone | yang.lu@vodafone.com | Rel-8 |  | Frederic | 23.259 |  |

Notes:
- 821: CP#43 completed
- 822: CP#43 completed
- 823: CP#43 completed
- 824: CP#42 completed
- 825: CP#42 completed. Triggered by Study UID_7048 (MRFC)
- 826: CP#43 completed. Triggered by Study TR 23.820 (FS_IMS_RP) UID_350018
- 827: CP#43 completed
- 828: CP#43 completed
- 829: CP#43 completed. Triggered by UID_360030 (FS_IMS_ASIO)
- 830: CP#43 completed
- 831: SP#36 completed
- 832: CP#43 completed
- 833: CP#42 completed
- 834: CP#43 completed
- 835: SP#40 completed
- 836: CP#43 completed
- 837: RP#49 completed. Testing for Rel-8 UID_400013 CT1 aspects of mobility between 3GPP WLAN Interworking and 3GPP Systems (24.327)
- 838: CP#45 completed
- 839: SP#38 completed
- 840: SP#39 completed
- 841: CP#45 completed
- 842: CP#38 completed
- 843: GP#37 completed
- 844: CP#43 completed
- 845: SP#31 completed
- 846: CP#42 completed

| ID | WBS | Task | Type | Duration | Start | Finish | Complete | Baseline start | Baseline finish | Baseline duration | Constraint | Resources | Work | Actual work | Text1 | Text4 | Text5 | Text6 | Text8 | Text3 | Text12 | Text7 | Text2 | Text11 |
| --- | --- | --- | --- | --- | --- | --- | --- | --- | --- | --- | --- | --- | --- | --- | --- | --- | --- | --- | --- | --- | --- | --- | --- | --- |
| 847 | 287.3 | **Stage 3 for PNM** |  | 510d? | 2007-03-26 A | 2009-03-06 A | 100% | 2007-03-26 | 2009-03-06 | 510d? |  | C1,C4 | 11720h | 11720h | PNM | Vodafone | yang.lu@vodafone.com | Rel-8 | Frederic |  |  |  |  |  |
| 848 | 287.3.1 | CT1 aspects of Stage 3 PNM |  | 510d? | 2007-03-26 A | 2009-03-06 A | 100% | 2007-03-26 | 2009-03-06 | 510d? | finish no earlier than 2008-12-05 | C1 | 4080h | 4080h | PNM | Vodafone | yang.lu@vodafone.com | Rel-8 | Frederic | 24.259, 24.229 |  |  |  |  |
| 849 | 287.3.2 | Deleted - CT4 aspects of Stage 3 PNM |  | 445d? | 2007-03-26 A | 2008-12-05 A | 100% | 2007-03-26 | 2008-12-05 | 445d? | finish no earlier than 2008-12-11 | C4 | 3560h | 3560h | PNM | Vodafone | yang.lu@vodafone.com | Rel-8 | Kimmo |  | CP-42 |  |  |  |
| 850 | 287.4 | Key establishment between a UICC hosting device and a remote device |  | 235d? | 2006-12-06 A | 2007-10-30 A | 100% | 2006-12-06 | 2007-10-30 | 235d? | finish no earlier than 2007-10-30 | S3 | 1880h | 1880h | PNM | Ericsson | Vesa.Lehtovirta@ericsson.com | Rel-8 | Dionisio | 33.259 |  |  |  |  |
| 851 | 287.5 | Deleted - Actual Requirements of PNM | milestone | 0d? | 2007-03-26 A | 2007-03-26 A | 100% | 2007-03-26 | 2007-03-26 | 0d? | finish no earlier than 2007-03-26 | C1 |  |  | PNM | Ericsson |  | Rel-8 | Frederic |  | SP-37 |  |  |  |
| 852 | 288 | **eCall Data Transfer** |  | 637d? | 2006-09-28 A | 2009-03-06 A | 100% | 2006-09-28 | 2009-03-06 | 637d? |  | S1,C1 | 9744h | 9744h | EData | Airbiquity | rrobinson@airbiquity.com | Rel-8 | Alain |  |  |  |  |  |
| 853 | 288.1 | eData Requirements |  | 380d? | 2006-09-28 A | 2008-03-12 A | 100% | 2006-09-28 | 2008-03-12 | 380d? | finish no earlier than 2006-12-07 | S1 | 3040h | 3040h | EData | Airbiquity | rrobinson@airbiquity.com | Rel-8 | Alain | 22.101, 22.105 |  | SP-37 |  |  |
| 854 | 288.2 | Transfer of data during an emergency call |  | 201d? | 2008-05-30 A | 2009-03-06 A | 100% | 2008-05-30 | 2009-03-06 | 201d? | finish no earlier than 2009-03-06 | C1 | 1608h | 1608h | EData | T-Mobile | Dieter Jacobsohn | Rel-8 | Frederic | 24.008 |  | SP-40 | PCG-21 |  |
| 855 | 289 | eCall data transfer Phase 2: Comparison of alternative in-band modem solutions and standardization of one in-band modem solution |  | 472d? | 2007-12-06 A | 2009-09-24 A | 100% | 2007-12-06 | 2009-09-24 | 472d? | finish no earlier than 2009-09-24 | S4 | 3768.09h | 3768.09h | eCall_Phase2 | Airbiquity | lhong@airbiquity.com & rrobinson@airbiquity.com | Rel-8 | Paolo | 26.267, 26.268, 26.269, 26.967, 26.969 |  |  |  |  |
| 856 | 290 | eCall Conformance Testing |  | 261d? | 2009-09-04 A | 2010-09-03 A | 100% | 2009-09-04 | 2010-09-03 | 261d? | finish no earlier than 2010-09-03 | G3new | 2088h | 2088h | eCall_MSTest | Ericsson, Qualcomm | Vikrant Jain (vikrantj@qualcomm.com) | Rel-8 | Ingbert | 51.010-1, 51.010-2 |  | GP-45 | PCG-23 |  |
| 857 | 291 | Conformance Test Aspects – non-modem procedures of eCall sessions in UTRA |  | 186d? | 2009-09-18 A | 2010-06-04 A | 100% | 2009-09-18 | 2010-06-04 | 186d? | finish no earlier than 2010-06-04 | R5 | 1488h | 1488h | UMTS_eCall_UEConTest | Ericsson, Qualcomm | Shubhang Vora (svora@qualcomm.com) | Rel-8 | Ingbert | 34.108, 34.123-1, 34.123-2, 34.123-3 |  | RP-45 | PCG-23 | RP-100489 |
| 858 | 292 | **IP Interconnection of Services** |  | 668d? | 2006-08-16 A | 2009-03-06 A | 100% | 2006-08-16 | 2009-03-06 | 668d? |  | S1,S2,S5,C3 | 17520h | 17520h | IPinterc | Telefonica O2 | chris.friel@O2.com | Rel-8 | Alain |  |  | SP-38 | PCG-21 |  |
| 859 | 292.1 | Stage 1 for IPinterc |  | 70d? | 2007-12-06 A | 2008-03-12 A | 100% | 2007-12-06 | 2008-03-12 | 70d? | start no earlier than 2007-12-06 | S1 | 560h | 560h | IPinterc | Telefonica O2 | chris.friel@O2.com | Rel-8 | Alain | 22.101, 22.228 |  | SP-38 | PCG-21 |  |
| 860 | 292.2 | **System enhancements for interconnection interfaces between two IMSs** |  | 668d? | 2006-08-16 A | 2009-03-06 A | 100% | 2006-08-16 | 2009-03-06 | 668d? |  | S2,S5,C3 | 11616h | 11616h | IMS_NNI | Telecom Italia | Mario Madella (mario.madella@telecomitalia.it) | Rel-8 | Maurice |  |  |  |  |  |
| 861 | 292.2.1 | Stage 2 for IMS_NNI |  | 120d? | 2007-06-22 A | 2007-12-06 A | 100% | 2007-06-22 | 2007-12-06 | 120d? | finish no earlier than 2007-12-21 | S2 | 960h | 960h | IMS_NNI | Telecom Italia | Mario Madella (mario.madella@telecomitalia.it) | Rel-8 | Maurice | 23.002, 23.228 |  |  |  |  |
| 862 | 292.2.2 | IMS inter-operator service interconnection interface |  | 461d? | 2007-06-01 A | 2009-03-06 A | 100% | 2007-06-01 | 2009-03-06 | 461d? | finish no earlier than 2009-03-06 | C3 | 3688h | 3688h | FBI2-IOPSI | Telecom Italia | antonio.ascolese@telecomitalia.it | Rel-8 | Gwiho | 29.865, 29.165 |  |  |  |  |
| 863 | 292.2.3 | Charging harmonization for NGN between 3GPP and ATIS-TMOC |  | 51d? | 2006-09-28 A | 2006-12-07 A | 100% | 2006-09-28 | 2006-12-07 | 51d? | finish no earlier than 2006-12-07 | S5 | 408h | 408h | FBI2-TISP2-CH | Amdocs | yishai.brown@amdocs.com | Rel-8 | Dionisio | 32.297 |  |  |  |  |
| 864 | 292.2.4 | Deleted - Protocol impact of FBI for TISPAN R2 |  | 152d? | 2006-08-16 A | 2007-03-15 A | 100% | 2006-08-16 | 2007-03-15 | 152d? | finish no earlier than 2007-03-15 | C1 | 1216h | 1216h | FBI2-TISP2-c1 | Ericsson |  | Rel-8 | Frederic |  | SP-38 |  |  |  |
| 865 | 292.2.5 | Deleted (never approved) - Stage 2 of FBI for TISPAN R2 - Rel 8 | milestone | 0d? | 2007-11-30 A | 2007-11-30 A | 100% | 2007-11-30 | 2007-11-30 | 0d? | finish no earlier than 2007-11-30 | S2 |  |  | FBI2-TISP2-s2 | Nokia Siemens Networks |  | Rel-8 | Maurice |  | SP-36 |  |  |  |
| 866 | 293 | **Support of (G)MSC-S – (G)MSC-S Nc Interface based on the SIP-I protocol** |  | 386d? | 2007-09-14 A | 2009-03-06 A | 100% | 2007-09-14 | 2009-03-06 | 386d? |  | C4,C3 | 11872h | 11872h | SIP_Nc | Vodafone | David.Hutton@vodafone.com | Rel-8 | Kimmo |  |  |  |  |  |
| 867 | 293.1 | Stage 1 for SIP_Nc (covered by Feature IPinterc) |  | 70d? | 2007-12-06 A | 2008-03-12 A | 100% | 2007-12-06 | 2008-03-12 | 70d? | start no earlier than 2007-12-06 | S1 | 560h | 560h | IPinterc | Telefonica O2 | chris.friel@O2.com | Rel-8 | Alain | 22.101, 22.228 |  | CP-41 | PCG-21 |  |
| 868 | 293.2 | SIP-I based circuit-switched core network; Stage 2 |  | 321d? | 2007-09-14 A | 2008-12-05 A | 100% | 2007-09-14 | 2008-12-05 | 321d? | finish no earlier than 2008-12-11 | C4 | 2568h | 2568h | SIP_Nc-St2 | Vodafone | David.Hutton@vodafone.com | Rel-8 | Kimmo | 23.231, 23.153, 23.205 |  |  |  |  |
| 869 | 293.3 | Application of SIP-I Protocols to Circuit Switched (CS) core network architecture; Stage 3 |  | 321d? | 2007-09-14 A | 2008-12-05 A | 100% | 2007-09-14 | 2008-12-05 | 321d? | finish no earlier than 2008-12-11 | C4 | 2568h | 2568h | SIP_Nc-St3 | Vodafone | David.Hutton@vodafone.com | Rel-8 | Kimmo | 29.231, 29.232, 29.332 |  |  |  |  |
| 870 | 293.4 | Interworking between the 3GPP CS domain with SIP-I as signalling protocol and other networks |  | 386d? | 2007-09-14 A | 2009-03-06 A | 100% | 2007-09-14 | 2009-03-06 | 386d? | finish no earlier than 2009-03-06 | C3 | 3088h | 3088h | SIP_Nc | Nokia Siemens Networks | Thomas.Belling@nsn.com | Rel-8 | Gwiho | 29.235, 23.172, 23.202, 29.007, 29.163, 29.414 |  |  |  |  |

Notes:
- 847: CP#43 completed
- 848: CP#43 completed
- 849: CP#42 no impact on CT4 specs
- 850: SP#37 completed
- 851: SP#37 stopped
- 852: SP#39 completed. Linked to SA4 Feature UID_34042 (eCall_Phase2)
- 853: SP#39 completed
- 854: CP#43 completed
- 855: SP#45 completed. Triggered by Study UID_360015 (eCALLIBMS). Linked to SA1 Feature UID_330005 (EData)
- 856: GP#47 completed. GP#43 WID approved. Testing for Rel-8 eCall_Phase2 (UID_34042) and EData (UID_330005)
- 857: RP#48 completed. Testing for Rel-8 eCall_Phase2 (UID_34042) and Edata (UID_330005)
- 858: SP#43 completed
- 859: SP#39 completed.
- 860: CP#43 completed
- 861: SP#38 completed
- 862: CP#43 completed
- 863: SP#34 completed
- 864: SP#38 stopped
- 865: SP#36 stopped
- 866: CP#43 completed. Stage 1 in Feature UID_380060 (IPinterc). CP#40 updated WID CP-070517=>CP-080282
- 867: 22/07/08 Created. Stage 1 for SIP_Nc (covered by SA1 Feature UID_380060 Ipinterc)
- 868: CP#42 completed
- 869: CP#42 completed
- 870: CP#43 completed. CP#42 target 12/08=>03/09

| ID | WBS | Task | Type | Duration | Start | Finish | Complete | Baseline start | Baseline finish | Baseline duration | Constraint | Resources | Work | Actual work | Text1 | Text4 | Text5 | Text6 | Text7 | Text8 | Text3 | Text2 | Text11 | Text9 | Text12 |
| --- | --- | --- | --- | --- | --- | --- | --- | --- | --- | --- | --- | --- | --- | --- | --- | --- | --- | --- | --- | --- | --- | --- | --- | --- | --- |
| 871 | 294 | **Earthquake and Tsunami Warning System** |  | 440d? | 2007-09-10 A | 2009-05-15 A | 100% | 2007-09-10 | 2009-05-15 | 440d? |  | S1,S2,C1,C4,G2 | 7200h | 7200h | ETWS | NTT DoCoMo | kitaharar@nttdocomo.co.jp | Rel-8 | SP-37 | Alain |  |  |  |  |  |
| 872 | 294.1 | Stage 1 for ETWS |  | 133d? | 2007-09-10 A | 2008-03-12 A | 100% | 2007-09-10 | 2008-03-12 | 133d? | finish no earlier than 2008-03-12 | S1 | 1064h | 1064h | ETWS | NTT DoCoMo | kitaharar@nttdocomo.co.jp | Rel-8 | SP-37 | Alain | 22.168 |  |  |  |  |
| 873 | 294.2 | SA2 aspects of ETWS |  | 179d? | 2008-01-14 A | 2008-09-18 A | 100% | 2008-01-14 | 2008-09-18 | 179d? | finish no earlier than 2008-09-08 | S2 | 1432h | 1432h | ETWS | NTT DoCoMo | tanakai@nttdocomo.co.jp | Rel-8 | SP-38 | Maurice | 23.828, 23.401 | PCG-21 |  |  |  |
| 874 | 294.3 | CT1 aspects of ETWS |  | 50.5d? | 2008-05-30 A | 2008-12-05 A | 100% | 2008-05-30 | 2008-12-05 | 50.5d? | finish no earlier than 2008-12-05 | C1 | 404h | 404h | ETWS | NTT DoCoMo | yamashitahi@s1.nttdocomo.co.jp | Rel-8 | CP-40 | Frederic | 23.041 | PCG-21 |  |  |  |
| 875 | 294.4 | CT4 aspects of ETWS |  | 50.5d? | 2008-09-26 A | 2008-12-05 A | 100% | 2008-09-26 | 2008-12-05 | 50.5d? | finish no earlier than 2008-12-05 | C4 | 404h | 404h | ETWS | NTT DoCoMo | yamashitahi@s1.nttdocomo.co.jp | Rel-8 | CP-40 | Kimmo | 29.168 | PCG-21 |  |  |  |
| 876 | 294.5 | ETWS primary notification message definition in GERAN |  | 47d? | 2009-03-12 A | 2009-05-15 A | 100% | 2009-03-12 | 2009-05-15 | 47d? | finish no earlier than 2009-05-15 | G2 | 376h | 376h | ETWS | Ericsson | claes-goran.persson@ericsson.com | Rel-8 | SP-43 | Gert | 44.018, 44.060 | PCG-22 |  |  |  |
| 877 | 295 | Conformance Test Aspects – UMTS Earthquake and Tsunami Warning System (ETWS) FDD |  | 207d? | 2009-05-29 A | 2010-03-12 A | 100% | 2009-05-29 | 2010-03-12 | 207d? | finish no earlier than 2010-03-12 | R5 | 1656h | 1656h | ETWS_UMTS_UEConTestFDD | NTT DoCoMo | Makoto Ito (itohm@nttdocomo.co.jp) | Rel-8 | RP-44 | Ingbert | 34.108, 34.123-1, 34.123-2 | PCG-23 | RP-100068 |  |  |
| 878 | 296 | **In Case of Emergency numbers storage and easy access on UICC** |  | 519d? | 2007-03-13 A | 2009-03-06 A | 100% | 2007-03-13 | 2009-03-06 | 519d? |  | S1,C6 | 8864h | 8864h | ICE | Vodafone | armin.toepfer@vodafone.com | Rel-8 | SP-38 | Alain |  | PCG-21 |  |  |  |
| 879 | 296.1 | Stage 1 for ICE |  | 262d? | 2007-03-13 A | 2008-03-12 A | 100% | 2007-03-13 | 2008-03-12 | 262d? | finish no earlier than 2008-03-12 | S1 | 2096h | 2096h | ICE | Vodafone | armin.toepfer@vodafone.com | Rel-8 | SP-38 | Alain | 22.030, 22.101 | PCG-21 |  |  |  |
| 880 | 296.2 | CT6 aspects of ICE |  | 519d? | 2007-03-13 A | 2009-03-06 A | 100% | 2007-03-13 | 2009-03-06 | 519d? | finish no earlier than 2009-03-06 | C6 | 4152h | 4152h | ICE | Vodafone | armin.toepfer@vodafone.com | Rel-8 | SP-38 | Xavier | 31.102 | PCG-21 |  |  |  |
| 881 | 297 | Local Charging Zone Requirements |  | 380d? | 2006-09-28 A | 2008-03-12 A | 100% | 2006-09-28 | 2008-03-12 | 380d? | finish no earlier than 2006-12-07 | S1 | 3040h | 3040h | LCZR | China Mobile | liuhongyfw@chinamobile.com | Rel-8 |  | Alain | 22.115 |  |  |  |  |
| 882 | 298 | **Customized Alerting Tone (CAT) Service** |  | 729d? | 2006-12-06 A | 2009-09-18 A | 100% | 2006-12-06 | 2009-09-18 | 729d? |  | S1,C1,C3,C4 | 12302h | 12302h | CAT | China Mobile | fenglingjuan@chinamobile.com | Rel-8 |  | Alain |  |  |  |  |  |
| 883 | 298.1 | Stage 1 for CAT |  | 207d? | 2006-12-06 A | 2007-09-20 A | 100% | 2006-12-06 | 2007-09-20 | 207d? | start no earlier than 2006-12-06 | S1 | 1656h | 1656h | CAT | China Mobile | fenglingjuan@chinamobile.com | Rel-8 | SP-37 | Alain | 22.182 |  |  |  |  |
| 884 | 298.2 | TISPAN requirements for customized multimedia information services |  | 71d? | 2007-09-03 A | 2007-12-10 A | 100% | 2007-09-03 | 2007-12-10 | 71d? | finish no earlier than 2007-12-10 | S1 | 568h | 568h | TISCMI | China Mobile | fenglingjuan@chinamobile.com | Rel-8 | SP-37 | Alain | 22.182 |  |  |  |  |
| 885 | 298.3 | IMS CAT Supplementary Service |  | 164d? | 2008-04-21 A | 2008-12-04 A | 100% | 2008-04-21 | 2008-12-04 | 164d? | finish no earlier than 2008-12-05 | C1 | 1312h | 1312h | CAT-SS | Nortel | milanpa@nortel.com | Rel-8 | CP-39 | Frederic | 24.182 | PCG-21 |  |  |  |
| 886 | 298.4 | CAT solution for voice and video call in CS domain |  | 389.8d? | 2008-03-12 A | 2009-09-18 A | 100% | 2008-03-12 | 2009-09-18 | 389.8d? | finish no earlier than 2009-09-11 | C3 | 3118.4h | 3118.4h | CAT-SS | Nortel | milanpa@nortel.com | Rel-8 | CP-39 | Gwiho | 29.163 | PCG-21 |  |  |  |
| 887 | 298.5 | CAT Service in 3GPP CS domain |  | 126d? | 2008-09-12 A | 2009-03-06 A | 100% | 2008-09-12 | 2009-03-06 | 126d? | finish no earlier than 2009-03-06 | C4 | 1008h | 1008h | CAT-3G_CS | China Mobile | zhaoyuyi@chinamobile.com | Rel-8 | CP-41 | Kimmo | 23.205, 23.231, 29.002 | PCG-21 |  |  |  |
| 888 | 298.6 | CAT Service in 3GPP CS domain |  | 57.95d? | 2008-09-12 A | 2008-12-05 A | 100% | 2008-09-12 | 2008-12-05 | 57.95d? | start no earlier than 2008-09-12 | C1 | 463.6h | 463.6h | CAT-3G_CS | China Mobile | zhaoyuyi@chinamobile.com | Rel-8 | CP-41 | Frederic | 24.008, 23.014 | PCG-21 |  |  |  |
| 889 | 299 | **Service-Level Interworking for Messaging Services** |  | 509d? | 2007-03-26 A | 2009-03-06 A | 100% | 2007-03-26 | 2009-03-06 | 509d? |  | S1,S2,C3,C1 | 8584h | 8584h | MESSIW | Huawei | ling.liu@huawei.com; duanxiaoqin@huawei.com | Rel-8 |  | Alain |  |  |  |  |  |
| 890 | 299.1 | Stage 1 for MESSIW | milestone | 0d? | 2007-03-26 A | 2007-03-26 A | 100% | 2007-03-26 | 2007-03-26 | 0d? | finish no earlier than 2007-12-01 | S1 |  |  | MESSIW | Huawei | ling.liu@huawei.com | Rel-8 |  | Alain | 22.105, 22.340 |  |  |  |  |
| 891 | 299.2 | Stage 2 for MESSIW |  | 227d? | 2007-04-26 A | 2008-03-07 A | 100% | 2007-04-26 | 2008-03-07 | 227d? | finish no earlier than 2008-03-07 | S2 | 1816h | 1816h | MESSIW | Huawei | patrice.hede@huawei.com | Rel-8 |  | Maurice | 23.811, 23.204 |  |  |  |  |
| 892 | 299.3 | Stage 3 for MESSIW |  | 201d? | 2008-05-30 A | 2009-03-06 A | 100% | 2008-05-30 | 2009-03-06 | 201d? | finish no earlier than 2008-12-05 | C3 | 1608h | 1608h | MESSIW | Huawei | xupeili@huawei.com | Rel-8 | CP-40 | Gwiho | 29.311 | PCG-21 |  |  |  |
| 893 | 299.4 | Stage 3 for MESSIW |  | 136d? | 2008-05-30 A | 2008-12-05 A | 100% | 2008-05-30 | 2008-12-05 | 136d? | finish no earlier than 2008-12-12 | C1 | 1088h | 1088h | MESSIW | Huawei | xupeili@huawei.com | Rel-8 | CP-40 | Frederic | 24.229 | PCG-21 |  |  |  |
| 894 | 300 | **Multimedia Priority Service** |  | 858d? | 2006-06-08 A | 2009-09-18 A | 100% | 2006-06-08 | 2009-09-18 | 858d? |  | S1,C1,C3,C4 | 22424h | 22424h | PRIOR | Telcordia | jgarraha@telcordia.com | Rel-8 | SP-34 | Alain |  |  |  |  |  |
| 895 | 300.1 | Service Requirements for PRIOR |  | 391d? | 2006-06-08 A | 2007-12-06 A | 100% | 2006-06-08 | 2007-12-06 | 391d? | finish no earlier than 2007-11-30 | S1 | 3128h | 3128h | PRIOR-EMR | Telcordia | jgarraha@telcordia.com | Rel-8 | SP-32 | Alain | 22.153 |  |  |  |  |
| 896 | 300.2 | Stage 3 for PRIOR |  | 732d? | 2006-12-01 A | 2009-09-18 A | 100% | 2006-12-01 | 2009-09-18 | 732d? | finish no earlier than 2009-09-18 | C1 | 5856h | 5856h | PRIOR | Alcatel-Lucent | Keith Drage (drage@alcatel-lucent.com) | Rel-8 | CP-34 | Frederic | 24.229 |  |  |  |  |
| 897 | 300.3 | Stage 3 for PRIOR |  | 381d? | 2007-09-21 A | 2009-03-06 A | 100% | 2007-09-21 | 2009-03-06 | 381d? | finish no earlier than 2009-03-06 | C4 | 3048h | 3048h | PRIOR | Alcatel-Lucent | Keith Drage (drage@alcatel-lucent.com) | Rel-8 | CP-37 | Kimmo | 23.008, 29.228, 29.229 |  |  |  |  |
| 898 | 300.4 | Deleted - Stage 3 for PRIOR |  | 441d? | 2007-09-21 A | 2009-05-29 A | 100% | 2007-09-21 | 2009-05-29 | 441d? | finish no earlier than 2009-05-29 | C3 | 3528h | 3528h | PRIOR | Alcatel-Lucent | Keith Drage (drage@alcatel-lucent.com) | Rel-8 | CP-37 | Gwiho | 29.212, 29.213, 29.214, 29.163 |  |  | PCG-23 | CP-44 |

Notes:
- 871: SP#43 Larger scope Feature UID_380057 (PWS) moved to Rel-9
- 872: SP#39 completed
- 873: SP#41 completed
- 874: CP#42 completed
- 875: CP#42 completed
- 876: SP#44 completed with CT1 help (GERAN2 LS_in SP-090154)
- 877: RP#47 completed. Testing for Rel-8 ETWS UID_370051
- 878: CP#43 completed (ICE Graphics not included in Rel-8)
- 879: SP#39 Stage 1 completed
- 880: CP#43 completed (ICE Graphics not in Rel-8 / not explicitly in SA1 WID either)
- 881: SP#39 Stage 1 completed
- 882: CP#45 completed
- 883: -
- 884: SP#38 completed
- 885: CP#42 completed
- 886: CP#45 completed. Triggered by Study UID_360031 (TR 29.882)
- 887: CP#43 completed. Triggered by Study UID_360031 (TR 29.882)
- 888: CP#42 completed. Triggered by Study UID_360031 (TR 29.882)
- 889: CP#43 completed
- 890: SP#35 completed
- 891: SP#39 completed
- 892: CP#43 completed
- 893: CP#42 completed
- 894: CP#45 completed
- 895: SP#38 completed
- 896: CP#45 completed
- 897: CP#43 completed
- 898: CP#44 stopped (Reason: No Rel-8 solution expected (LS sent to SA2, but not prioritized in SA2)

| ID | WBS | Task | Duration | Start | Finish | Complete | Baseline start | Baseline finish | Baseline duration | Constraint | Resources | Work | Actual work | Text1 | Text4 | Text5 | Text6 | Text8 | Text3 | Text7 | Text2 | Text9 | Text12 | Text11 |
| --- | --- | --- | --- | --- | --- | --- | --- | --- | --- | --- | --- | --- | --- | --- | --- | --- | --- | --- | --- | --- | --- | --- | --- | --- |
| 899 | 301 | **OSA Rel-8** | 202d? | 2007-08-23 A | 2008-05-30 A | 100% | 2007-08-23 | 2008-05-30 | 202d? |  | S1,C5 | 23552h | 23552h | OSA8 | Orange | Song Dong | Rel-8 | Alain |  |  |  |  |  |  |
| 900 | 301.1 | OSA Stage 1 - Service Requirements | 145d? | 2007-08-23 A | 2008-03-12 A | 100% | 2007-08-23 | 2008-03-12 | 145d? | finish no earlier than 2007-12-04 | S1 | 1160h | 1160h | OSA8 | Orange, AePONA | Song Dong | Rel-8 | Alain | 22.127 |  |  |  |  |  |
| 901 | 301.2 | OSA Stage 1 - NGN Service Requirement | 140d? | 2007-09-03 A | 2008-03-14 A | 100% | 2007-09-03 | 2008-03-14 | 140d? | finish no earlier than 2008-03-14 | S1 | 1120h | 1120h | OSA8-IMS | Orange | Song Dong | Rel-8 | Alain | 22.127 | SP-37 |  |  |  |  |
| 902 | 301.3 | **OSA Stage 2/3 enhancements** | 157d? | 2007-10-25 A | 2008-05-30 A | 100% | 2007-10-25 | 2008-05-30 | 157d? |  | C5 | 20016h | 20016h | OSA8 | Alcatel-Lucent | unmehopa@alcatel-lucent.com | Rel-8 | Kimmo | 23.198, 29.198, 29.199 |  |  |  |  |  |
| 903 | 301.3.1 | Deleted - Ensure Parlay-X composable with identity management frameworks, in particular Liberty Alliance | 157d? | 2007-10-25 A | 2008-05-30 A | 100% | 2007-10-25 | 2008-05-30 | 157d? | finish no earlier than 2008-12-25 | C5 | 1256h | 1256h | OSA8 | Ericsson, FT/Orange, Sprint, Telecom Italia | catherine.mulligan@ericsson.com | Rel-8 | Kimmo | existing 29.199-xy | CP-37 | PCG-21 | PCG-21 | CP-40 |  |
| 904 | 301.3.2 | Parlay-X Content Management web service (store/manage meta-data) | 157d? | 2007-10-25 A | 2008-05-30 A | 100% | 2007-10-25 | 2008-05-30 | 157d? | finish no earlier than 2008-12-04 | C5 | 1256h | 1256h | OSA8 | Alcatel-Lucent | unmehopa@alcatel-lucent.com | Rel-8 | Kimmo | 29.199-21 | CP-37 |  |  |  |  |
| 905 | 301.3.3 | Parlay-X Policy web service | 157d? | 2007-10-25 A | 2008-05-30 A | 100% | 2007-10-25 | 2008-05-30 | 157d? | finish no earlier than 2008-12-04 | C5 | 1256h | 1256h | OSA8 | Alcatel-Lucent | unmehopa@alcatel-lucent.com | Rel-8 | Kimmo | 29.199-22 | CP-37 |  |  |  |  |
| 906 | 301.3.4 | Parlay-X Terminal status web service | 157d? | 2007-10-25 A | 2008-05-30 A | 100% | 2007-10-25 | 2008-05-30 | 157d? | finish no earlier than 2008-05-30 | C5 | 1256h | 1256h | OSA8 | Alcatel-Lucent | unmehopa@alcatel-lucent.com | Rel-8 | Kimmo | 29.199-08 | CP-37 |  |  |  |  |
| 907 | 301.3.5 | Deleted - Identify communication format used by a particular application | 157d? | 2007-10-25 A | 2008-05-30 A | 100% | 2007-10-25 | 2008-05-30 | 157d? | finish no earlier than 2008-05-30 | C5 | 1256h | 1256h | OSA8 | Ericsson | catherine.mulligan@ericsson.com | Rel-8 | Kimmo | existing 29.199-xy | CP-37 | PCG-21 | PCG-21 | CP-40 |  |
| 908 | 301.3.6 | Deleted - Security on User Profile Management - reuse GUP API (22.127 CR 0084 S1-071794) | 128d? | 2007-12-05 A | 2008-05-30 A | 100% | 2007-12-05 | 2008-05-30 | 128d? | finish no earlier than 2008-12-25 | C5 | 1024h | 1024h | OSA8 | Telecom Italia | vincenzo.amorino@telecomitalia.it | Rel-8 | Kimmo | PXWS Framework | CP-38 | PCG-21 | PCG-21 | CP-40 |  |
| 909 | 301.3.7 | Deleted - Privacy on Subscriber Identity (Liberty Alliance, OASIS) (22.127 CR 0085 S1-071835) | 128d? | 2007-12-05 A | 2008-05-30 A | 100% | 2007-12-05 | 2008-05-30 | 128d? | finish no earlier than 2008-12-25 | C5 | 1024h | 1024h | OSA8 | Telecom Italia | vincenzo.amorino@telecomitalia.it | Rel-8 | Kimmo | PXWS Framework | CP-38 | PCG-21 | PCG-21 | CP-40 |  |
| 910 | 301.3.8 | Deleted - Topology Hiding (22.127 CR 0086 S1-071838) | 128d? | 2007-12-05 A | 2008-05-30 A | 100% | 2007-12-05 | 2008-05-30 | 128d? | finish no earlier than 2008-12-25 | C5 | 1024h | 1024h | OSA8 | Telecom Italia | vincenzo.amorino@telecomitalia.it | Rel-8 | Kimmo | PXWS Framework | CP-38 | PCG-21 | PCG-21 | CP-40 |  |
| 911 | 301.3.9 | Deleted - Subscriber event notification (22.127 CR 0087 S1-071836) | 128d? | 2007-12-05 A | 2008-05-30 A | 100% | 2007-12-05 | 2008-05-30 | 128d? | finish no earlier than 2008-12-25 | C5 | 1024h | 1024h | OSA8 | Telecom Italia | vincenzo.amorino@telecomitalia.it | Rel-8 | Kimmo | PXWS Framework | CP-38 | PCG-21 | PCG-21 | CP-40 |  |
| 912 | 301.3.10 | Deleted - Event notification (22.127 CR 0088 S1-071762) | 128d? | 2007-12-05 A | 2008-05-30 A | 100% | 2007-12-05 | 2008-05-30 | 128d? | finish no earlier than 2008-12-25 | C5 | 1024h | 1024h | OSA8 | Telecom Italia | vincenzo.amorino@telecomitalia.it | Rel-8 | Kimmo | PXWS Framework | CP-38 | PCG-21 | PCG-21 | CP-40 |  |
| 913 | 301.3.11 | Deleted - Access policy (22.127 CR 0089 S1-071763) | 128d? | 2007-12-05 A | 2008-05-30 A | 100% | 2007-12-05 | 2008-05-30 | 128d? | finish no earlier than 2008-12-25 | C5 | 1024h | 1024h | OSA8 | Telecom Italia | vincenzo.amorino@telecomitalia.it | Rel-8 | Kimmo | PXWS Framework | CP-38 | PCG-21 | PCG-21 | CP-40 |  |
| 914 | 301.3.12 | Deleted - API usage accounting (22.127 CR 0090 S1-071792) | 128d? | 2007-12-05 A | 2008-05-30 A | 100% | 2007-12-05 | 2008-05-30 | 128d? | finish no earlier than 2008-12-25 | C5 | 1024h | 1024h | OSA8 | Telecom Italia | vincenzo.amorino@telecomitalia.it | Rel-8 | Kimmo | PXWS Framework | CP-38 | PCG-21 | PCG-21 | CP-40 |  |
| 915 | 301.3.13 | Presence alignment with OMA and IETF (22.127 CR 0092 S1-071764) | 128d? | 2007-12-05 A | 2008-05-30 A | 100% | 2007-12-05 | 2008-05-30 | 128d? | finish no earlier than 2008-05-30 | C5 | 1024h | 1024h | OSA8 | Alcatel-Lucent | unmehopa@alcatel-lucent.com | Rel-8 | Kimmo | 29.199-14/13 | CP-38 | PCG-21 |  |  |  |
| 916 | 301.3.14 | Deleted - Service identification (22.127 CR 0095 S1-071837) | 128d? | 2007-12-05 A | 2008-05-30 A | 100% | 2007-12-05 | 2008-05-30 | 128d? | finish no earlier than 2008-05-30 | C5 | 1024h | 1024h | OSA8 | Ericsson | catherine.mulligan@ericsson.com | Rel-8 | Kimmo | existing 29.199-xy | CP-38 | PCG-21 | PCG-21 | CP-40 |  |
| 917 | 301.3.15 | Framework Enterprise Operator (Service Subscription function) | 102d? | 2008-01-10 A | 2008-05-30 A | 100% | 2008-01-10 | 2008-05-30 | 102d? | finish no earlier than 2008-05-30 | C5 | 816h | 816h | OSA8 | Alcatel-Lucent | unmehopa@alcatel-lucent.com | Rel-8 | Kimmo | 29.198-03 | CP-39 | PCG-21 |  |  |  |
| 918 | 301.3.16 | Mobility Emergency Location | 102d? | 2008-01-10 A | 2008-05-30 A | 100% | 2008-01-10 | 2008-05-30 | 102d? | finish no earlier than 2008-05-30 | C5 | 816h | 816h | OSA8 | Alcatel-Lucent | unmehopa@alcatel-lucent.com | Rel-8 | Kimmo | 29.198-06 | CP-39 | PCG-21 |  |  |  |
| 919 | 301.3.17 | Connectivity Manager SCF | 102d? | 2008-01-10 A | 2008-05-30 A | 100% | 2008-01-10 | 2008-05-30 | 102d? |  | C5 | 816h | 816h | OSA8 | Alcatel-Lucent | unmehopa@alcatel-lucent.com | Rel-8 | Kimmo | 29.198-10 | CP-39 | PCG-21 |  |  |  |
| 920 | 301.3.18 | PAM Presence Agent | 102d? | 2008-01-10 A | 2008-05-30 A | 100% | 2008-01-10 | 2008-05-30 | 102d? | finish no earlier than 2008-05-30 | C5 | 816h | 816h | OSA8 | Alcatel-Lucent | unmehopa@alcatel-lucent.com | Rel-8 | Kimmo | 29.198-14 | CP-39 | PCG-21 |  |  |  |
| 921 | 302 | **Paging Permission with Access Control (PPACR)** | 389d? | 2007-06-12 A | 2008-12-05 A | 100% | 2007-06-12 | 2008-12-05 | 389d? |  | S1,C1 | 5888h | 5888h | PPACR | NTT DoCoMo | Morita Takashi | Rel-8 | Alain |  |  |  |  |  |  |
| 922 | 302.1 | Stage 1 for PPACR | 69d? | 2007-06-12 A | 2007-09-14 A | 100% | 2007-06-12 | 2007-09-14 | 69d? | finish no earlier than 2007-09-14 | S1 | 552h | 552h | PPACR-S1 | NTT DoCoMo | Morita Takashi | Rel-8 | Alain | 22.011 | SP-37 |  |  |  |  |
| 923 | 302.2 | Stage 3 for PPACR (CT1) | 278d? | 2007-11-14 A | 2008-12-05 A | 100% | 2007-11-14 | 2008-12-05 | 278d? | finish no earlier than 2008-12-05 | C1 | 2224h | 2224h | PPACR-CT1 | NTT DoCoMo |  | Rel-8 | Frederic | 24.008, 23.122, 24.301 | CP-38 | PCG-21 |  |  |  |
| 924 | 303 | Conformance Test Aspects – Paging Permission with Access Control (PPAC) | 61d? | 2010-09-17 A | 2010-12-10 A | 100% | 2010-09-17 | 2010-12-10 | 61d? | finish no earlier than 2010-12-10 | R5 | 488h | 488h | PPAC_UEConTest | NTT DoCoMo | Takao.Shimizu.rp@nttdocomo.com | Rel-8 | Ingbert | UTRA 34.108, 34.123-1, 34.123-2, 34.123-3 | RP-49 | PCG-25 |  |  | RP-101074 |

Notes:
- 899: SP#40 maintenance & new OSA work moved to OMA. Rel-9 onwards 3GPP references to 22.127 changed to OMA Parlay Service Access Requirements (OMA-RD-Parlay_Service_Access-V1_0-20100427-A).
- 900: SP#40 maintenance & new OSA work moved to OMA. Rel-9 onwards 3GPP references to 22.127 changed to OMA Parlay Service Access Requirements (OMA-RD-Parlay_Service_Access-V1_0-20100427-A).
- 901: SP#40 maintenance & new OSA work moved to OMA
- 902: SP#40 maintenance & new OSA work moved to OMA
- 903: CP#40: Work moved to OMA
- 904: CP#40 completed
- 905: CP#40 completed
- 906: CP#40 completed
- 907: CP#40: Work moved to OMA
- 908: SP#38 SP-070853 R8 CRs 22.127 OSA Stage 1. CP#40: Work moved to OMA
- 909: SP#38 SP-070853 R8 CRs 22.127 OSA Stage 1. CP#40: Work moved to OMA
- 910: SP#38 SP-070853 R8 CRs 22.127 OSA Stage 1. CP#40: Work moved to OMA
- 911: SP#38 SP-070853 R8 CRs 22.127 OSA Stage 1. CP#40: Work moved to OMA
- 912: SP#38 SP-070853 R8 CRs 22.127 OSA Stage 1. CP#40: Work moved to OMA
- 913: SP#38 SP-070853 R8 CRs 22.127 OSA Stage 1. CP#40: Work moved to OMA
- 914: SP#38 SP-070853 R8 CRs 22.127 OSA Stage 1. CP#40: Work moved to OMA
- 915: CP#40 completed
- 916: SP#38 SP-070853 R8 CRs 22.127 OSA Stage 1. CP#40: Work moved to OMA
- 917: CP#40 completed
- 918: CP#40 completed
- 919: CP#40 completed
- 920: CP#40 completed
- 921: CP#42 completed. Triggered by Study UID_330016 (PPAC).
- 922: SP#37 completed
- 923: CP#42 completed
- 924: RP#50 completed

| ID | WBS | Task | Duration | Start | Finish | Complete | Baseline start | Baseline finish | Baseline duration | Constraint | Resources | Work | Actual work | Text1 | Text2 | Text4 | Text6 | Text7 | Text8 | Text11 | Text12 |
| --- | --- | --- | --- | --- | --- | --- | --- | --- | --- | --- | --- | --- | --- | --- | --- | --- | --- | --- | --- | --- | --- |
| 925 | 304 | **Charging for multi-phases services** | 70d? | 2007-12-06 A | 2008-03-12 A | 100% | 2007-12-06 | 2008-03-12 | 70d? |  | S1 | 560h | 560h | CHRGMPH | PCG-21 | Telecom Italia | Rel-8 | SP-38 | Alain |  |  |
| 926 | 304.1 | Stage 1 for CHRGMPH | 70d? | 2007-12-06 A | 2008-03-12 A | 100% | 2007-12-06 | 2008-03-12 | 70d? | start no earlier than 2007-12-06 | S1 | 560h | 560h | CHRGMPH-s1 | PCG-21 | Telecom Italia | Rel-8 | SP-38 | Alain |  |  |
| 927 | 305 | **Home NodeB / eNodeB** | 327d? | 2007-12-06 A | 2009-03-06 A | 100% | 2007-12-06 | 2009-03-06 | 327d? |  | S1,C1,C4 | 5720h | 5720h | HomeNB | PCG-21 | Vodafone | Rel-8 | SP-38 | Alain |  |  |
| 928 | 305.1 | Stage 1 for Home NodeB / eNodeB | 70d? | 2007-12-06 A | 2008-03-12 A | 100% | 2007-12-06 | 2008-03-12 | 70d? | start no earlier than 2007-12-06 | S1 | 560h | 560h | HomeNB-S1 | PCG-21 | Vodafone | Rel-8 | SP-38 | Alain |  |  |
| 929 | 305.2 | Support of Closed Subscriber Group (CSG) | 66d? | 2008-12-05 A | 2009-03-06 A | 100% | 2008-12-05 | 2009-03-06 | 66d? | finish no earlier than 2009-03-06 | C4 | 528h | 528h | HomeNB | PCG-22 | CT#42 | Rel-8 | CP-42 | Kimmo |  |  |
| 930 | 305.3 | CSG and Idle Mode Mobility for LTE Home eNodeB | 126d? | 2008-09-12 A | 2009-03-06 A | 100% | 2008-09-12 | 2009-03-06 | 126d? | finish no earlier than 2009-03-06 | C1 | 1008h | 1008h | HomeNB-LTE | PCG-21 | Huawei | Rel-8 | CP-41 | Frederic |  |  |
| 931 | 305.4 | CSG and Idle Mode Mobility for 3G Home NodeB | 126d? | 2008-09-12 A | 2009-03-06 A | 100% | 2008-09-12 | 2009-03-06 | 126d? | finish no earlier than 2009-03-06 | C1 | 1008h | 1008h | HomeNB-3G | PCG-21 | Qualcomm | Rel-8 | CP-41 | Frederic |  |  |
| 932 | 306 | **UTRA HNB** | 326d? | 2008-03-07 A | 2009-06-04 A | 100% | 2008-03-07 | 2009-06-04 | 326d? |  | RP,S5 | 6832h | 6832h | HNB | PCG-21 |  | Rel-8 | SP-39 | Issam |  |  |
| 933 | 306.1 | Support of UTRA HNB | 201d? | 2008-05-30 A | 2009-03-06 A | 100% | 2008-05-30 | 2009-03-06 | 201d? | finish no earlier than 2009-03-06 | R2 | 1608h | 1608h | HNB-supp | PCG-21 | Huawei | Rel-8 | SP-40 | Joern | RP-090040 |  |
| 934 | 306.2 | UTRAN Architecture for 3G HNB | 136d? | 2008-05-30 A | 2008-12-05 A | 100% | 2008-05-30 | 2008-12-05 | 136d? | finish no earlier than 2008-12-05 | R3 | 1088h | 1088h | HNB-arch | PCG-21 | Alcatel-Lucent | Rel-8 | SP-40 | Juha | RP-090042 |  |
| 935 | 306.3 | FDD Home NodeB RF requirements | 261d? | 2008-03-07 A | 2009-03-06 A | 100% | 2008-03-07 | 2009-03-06 | 261d? | finish no earlier than 2009-03-06 | R4 | 2088h | 2088h | HNB-RF | PCG-21 | Motorola | Rel-8 | SP-39 | Issam | RP-090041 |  |
| 936 | 306.4 | 3G Home NodeB OAM&P Type 1 Management Interface | 127d? | 2008-12-11 A | 2009-06-04 A | 100% | 2008-12-11 | 2009-06-04 | 127d? | finish no earlier than 2009-06-04 | S5 | 1008h | 1008h | HNB-3G_OAM | PCG-22 | Huawei | Rel-8 | SP-42 | Dionisio |  |  |
| 937 | 307 | **UTRA HNB – UE Conformance Testing** | 327d? | 2009-03-06 A | 2010-06-04 A | 100% | 2009-03-06 | 2010-06-04 | 327d? |  | R5 | 5224h | 5224h | HNB-UEConTest | PCG-22 |  | Rel-8 | RP-43 | Ingbert |  |  |
| 938 | 307.1 | Conformance Test Aspects – UTRA HNB (FDD) | 326d? | 2009-03-06 A | 2010-06-04 A | 100% | 2009-03-06 | 2010-06-04 | 326d? | finish no earlier than 2010-06-04 | R5 | 2608h | 2608h | HNB-UEConTestFDD | PCG-22 | Huawei | Rel-8 | RP-43 | Ingbert | RP-100482 |  |
| 939 | 308 | Lawful Interception in the 3GPP Rel-8 | 524d? | 2007-03-12 A | 2009-03-12 A | 100% | 2007-03-12 | 2009-03-12 | 524d? | finish no earlier than 2009-03-12 | S3 | 4192h | 4192h | LI8 |  | BMWI, Verizon | Rel-8 |  | Dionisio |  |  |
| 940 | 309 | **Generic Bootstrapping Architecture Push Function** | 258d? | 2008-03-12 A | 2009-03-06 A | 100% | 2008-03-12 | 2009-03-06 | 258d? |  | S3,C1,C4 | 6468.8h | 6468.8h | GBAPush | PCG-21 | Ericsson | Rel-8 | SP-39 | Dionisio |  |  |
| 941 | 309.1 | SA3 part of GBAPush (33.223) | 193d? | 2008-03-12 A | 2008-12-05 A | 100% | 2008-03-12 | 2008-12-05 | 193d? | finish no earlier than 2008-12-05 | S3 | 1544h | 1544h | GBAPush | PCG-21 | Ericsson | Rel-8 | SP-39 | Dionisio |  |  |
| 942 | 309.2 | CT1 part of GBAPush | 178.8d? | 2008-03-12 A | 2009-03-06 A | 100% | 2008-03-12 | 2009-03-06 | 178.8d? | finish no earlier than 2009-03-06 | C1 | 1430.4h | 1430.4h | GBAPush | PCG-21 | Ericsson | Rel-8 | SP-39 | Frederic |  |  |
| 943 | 309.3 | CT4 part of GBAPush | 178.8d? | 2008-03-12 A | 2009-03-06 A | 100% | 2008-03-12 | 2009-03-06 | 178.8d? | finish no earlier than 2009-03-06 | C4 | 1430.4h | 1430.4h | GBAPush | PCG-21 | Ericsson | Rel-8 | SP-39 | Kimmo |  |  |
| 944 | 310 | Requirements and Test methods for Wideband Terminals | 197d? | 2008-03-12 A | 2008-12-11 A | 100% | 2008-03-12 | 2008-12-11 | 197d? | start no earlier than 2008-03-12 | S4 | 1576h | 1576h | RETEM_WB_T |  | FT, Ericsson | Rel-8 |  | Paolo |  |  |
| 945 | 311 | Extending PSS and MBMS User Services for optimized Mobile TV | 266d? | 2007-12-06 A | 2008-12-11 A | 100% | 2007-12-06 | 2008-12-11 | 266d? | finish no earlier than 2008-12-11 | S4 | 2128h | 2128h | PSS_MBMS_OMTV |  | Ericsson | Rel-8 |  | Paolo |  |  |
| 946 | 312 | **Encoding formats, transport formats and media description signalling for interworking, QoE, and other enhancements to MTSI-MHI** | 331d? | 2007-12-06 A | 2009-03-12 A | 100% | 2007-12-06 | 2009-03-12 | 331d? |  | S4,C3,C4 | 9640h | 9640h | MTSI_eMHI | PCG-21 | Ericsson, Qualcomm | Rel-8 | SP-40 | Paolo |  |  |
| 947 | 312.1 | MTSI Video - Dynamic Rate Adaptation/Signalling of Image Size | 331d? | 2007-12-06 A | 2009-03-12 A | 100% | 2007-12-06 | 2009-03-12 | 331d? | finish no earlier than 2009-03-12 | S4 | 2648h | 2648h | MTSI_eMHI-DRASIS |  | Qualcomm, Samsung | Rel-8 |  | Paolo |  |  |
| 948 | 312.2 | CT3 part of Enhancement of interworking between MTSI and CS networks | 201d? | 2008-05-30 A | 2009-03-06 A | 100% | 2008-05-30 | 2009-03-06 | 201d? | finish no earlier than 2009-03-06 | C3 | 1608h | 1608h | MTSI_eMHI | PCG-21 | Huawei | Rel-8 | CP-40 | Gwiho |  |  |
| 949 | 312.3 | CT4 part of Enhancement of interworking between MTSI and CS networks | 201d? | 2008-05-30 A | 2009-03-06 A | 100% | 2008-05-30 | 2009-03-06 | 201d? | finish no earlier than 2009-03-06 | C4 | 1608h | 1608h | MTSI_eMHI | PCG-21 | Huawei | Rel-8 | CP-40 | Kimmo |  |  |
| 950 | 312.4 | Deleted - CT1 part of Enhancement of interworking between MTSI and CS networks | 141d? | 2008-05-30 A | 2008-12-12 A | 100% | 2008-05-30 | 2008-12-12 | 141d? | start no earlier than 2008-05-30 | C1 | 1128h | 1128h | MTSI_eMHI | PCG-21 | Huawei | Rel-8 | CP-40 | Frederic |  | CP-42 |

Notes:
- 925: SP#39 Stage 1 completed / Text3: 22.115 / Text5: Marco.DeLuca1@telecomitalia.it
- 926: SP#39 completed / Text3: 22.115 / Text5: Marco.DeLuca1@telecomitalia.it
- 927: CP#43 completed / Text5: John Watson
- 928: SP#39 completed / Text3: 22.011, 22.115 / Text5: John Watson
- 929: CP#43 completed. SP#42 SP-080874 22.011CR0141 confirmed Requirement to support roaming subscribers with CSG home network subscription but did NOT confirmed requirement for home network independent support of roamers in CSG / Text3: 29.002, 29.272, 23.008, 23.003 / Text5: Hannu Hietalahti
- 930: CP#43 completed / Text3: 23.122, new (24.285, 24.301, 24.801) / Text5: zhang.peng@huawei.com
- 931: CP#43 completed / Text3: 23.122, 24.008, new 24.285 / Text5: Osok Song
- 932: SP#44 completed
- 933: RP#43 completed / Text3: 25.304, 25.306, 25.331, new 25.367 / Text5: Yang Xudong (yangxudong@huawei.com)
- 934: RP#42 completed / Text3: 25.401, 25.410, 25.412, 25.413, 25.414, 25.415, new (25.467, 25.468, 25.469) / Text5: Martin Warner (mw15@alcatel-lucent.com)
- 935: RP#43 completed / Text3: 25.104, 25.141, new 25.967 / Text5: Ying Cai (yingcai@motorola.com)
- 936: SP#44 completed. Complements work in BroadBand Forum / Text3: new (32.581, 32.582, 32.583, 32.584) / Text5: Zou Lan (zlan@huawei.com)
- 937: RP#48 FDD completed. Testing for Feature UID_390033 UTRA HNB
- 938: RP#48 completed / Text3: 34.108, 34.123-1, 34.123-2, 34.123-3 / Text5: Trica Li (trica_li@huawei.com)
- 939: SP#43 completed / Text3: 33.106, 33.107, 33.108 / Text5: berthold.wilhelm@bnetza.de, ron_ryan@verizon.net
- 940: CP#43 completed / Text5: Rolf Blom
- 941: SP#42 completed 33.223 as Rel-8. TS 33.224 moved to Rel-9 under new UID_420039 / Text3: 33.223 / Text5: Rolf Blom
- 942: CP#43 completed / Text3: 24.109 / Text5: Rolf Blom
- 943: CP#43 completed / Text3: 29.109 / Text5: Rolf Blom
- 944: SP#42 completed. SP#39 WID approved. / Text3: 26.131, 26.132 / Text5: stephane.ragot@orange-ftgroup.com, wanqing.shi@sonyericsson.com
- 945: SP#42 completed. SP#38 WID approved. / Text3: 26.234, 26.346, 26.946 / Text5: thorsten.lohmar@ericsson.com
- 946: TSG#43 completed / Text5: olle.franceschi@ericsson.com, nleung@qualcomm.com
- 947: SP#43 completed / Text3: 26.114 / Text5: nleung@qualcomm.com & kyunghun.jung@samsung.com
- 948: CP#43 completed / Text3: 29.163 / Text5: Tingfang Tang (tagna_online@huawei.com)
- 949: CP#43 completed / Text3: 29.332 / Text5: Tingfang Tang (tagna_online@huawei.com)
- 950: CP#42 stopped (No CT1-impact). WID updated CP-080422=>CP-080774 / Text5: Tingfang Tang (tagna_online@huawei.com)

| ID | WBS | Task | Duration | Start | Finish | Complete | Baseline start | Baseline finish | Baseline duration | Constraint | Resources | Work | Actual work | Text1 | Text6 | Text8 | Text4 | Text2 | Text7 | Text9 | Text12 |
| --- | --- | --- | --- | --- | --- | --- | --- | --- | --- | --- | --- | --- | --- | --- | --- | --- | --- | --- | --- | --- | --- |
| 951 | 313 | **OAM&P 8** | 653d? | 2007-06-07 A | 2009-12-04 A | 100% | 2007-06-07 | 2009-12-04 | 653d? |  | S5,C1,C4 | 44177.6h | 44177.6h | OAM8 | Rel-8 | Dionisio |  |  |  |  |  |
| 952 | 313.1 | **Network Infrastructure Management** | 653d? | 2007-06-07 A | 2009-12-04 A | 100% | 2007-06-07 | 2009-12-04 | 653d? |  | S5 | 19464h | 19464h | OAM8-NIM | Rel-8 | Dionisio |  |  |  |  |  |
| 953 | 313.1.1 | Telecom Management Methodology | 461d? | 2007-06-07 A | 2009-03-12 A | 100% | 2007-06-07 | 2009-03-12 | 461d? | finish no earlier than 2009-03-12 | S5 | 3688h | 3688h | OAM8 | Rel-8 | Dionisio | Ericsson |  |  |  |  |
| 954 | 313.1.2 | Advanced Alarming on Itf-N | 266d? | 2007-06-07 A | 2008-06-12 A | 100% | 2007-06-07 | 2008-06-12 | 266d? | finish no earlier than 2008-12-11 | S5 | 2128h | 2128h | OAM8 | Rel-8 | Dionisio | Nokia Siemens Networks |  |  |  |  |
| 955 | 313.1.3 | CN CS Bearer Transport Network (BTN) relative NRM | 266d? | 2007-06-07 A | 2008-06-12 A | 100% | 2007-06-07 | 2008-06-12 | 266d? | finish no earlier than 2008-12-11 | S5 | 2128h | 2128h | OAM8 | Rel-8 | Dionisio | China Mobile |  |  |  |  |
| 956 | 313.1.4 | Alignment with eTOM and M.3060 architectural concepts | 210d? | 2008-02-22 A | 2008-12-11 A | 100% | 2008-02-22 | 2008-12-11 | 210d? | start no earlier than 2008-02-22 | S5 | 1680h | 1680h | OAM8 | Rel-8 | Dionisio | TeliaSonera | PCG-21 | SP-39 |  |  |
| 957 | 313.1.5 | IRP SOAP Solution Sets | 201d? | 2008-06-05 A | 2009-03-12 A | 100% | 2008-06-05 | 2009-03-12 | 201d? | finish no earlier than 2009-03-12 | S5 | 1608h | 1608h | OAM8 | Rel-8 | Dionisio | Ericsson | PCG-21 | SP-40 |  |  |
| 958 | 313.1.6 | Create missing specifications for IRP XML definitions | 52d? | 2009-09-24 A | 2009-12-04 A | 100% | 2009-09-24 | 2009-12-04 | 52d? | finish no earlier than 2010-03-12 | S5 | 416h | 416h | OAM8 | Rel-8 | Dionisio | ZTE | PCG-23 | SP-45 |  |  |
| 959 | 313.1.7 | Deleted - End point modelling for reference point | 324d? | 2007-09-17 A | 2008-12-11 A | 100% | 2007-09-17 | 2008-12-11 | 324d? | finish no earlier than 2008-12-11 | S5 | 2592h | 2592h | OAM8 | Rel-8 | Dionisio | Motorola |  | SP-37 | PCG-21 | SP-41 |
| 960 | 313.2 | **Performance Management** | 461d? | 2007-06-07 A | 2009-03-12 A | 100% | 2007-06-07 | 2009-03-12 | 461d? |  | S5 | 13712h | 13712h | OAM8-PM | Rel-8 | Dionisio |  |  |  |  |  |
| 961 | 313.2.1 | IP bearer network Performance measurement definitions | 396d? | 2007-06-07 A | 2008-12-11 A | 100% | 2007-06-07 | 2008-12-11 | 396d? | finish no earlier than 2008-12-11 | S5 | 3168h | 3168h | OAM8 | Rel-8 | Dionisio | China Mobile |  |  |  |  |
| 962 | 313.2.2 | HSUPA performance measurements | 396d? | 2007-06-07 A | 2008-12-11 A | 100% | 2007-06-07 | 2008-12-11 | 396d? | finish no earlier than 2008-12-11 | S5 | 3168h | 3168h | OAM8 | Rel-8 | Dionisio | China Mobile |  |  |  |  |
| 963 | 313.2.3 | Key Performance Indicators (KPIs) for UMTS and GSM | 461d? | 2007-06-07 A | 2009-03-12 A | 100% | 2007-06-07 | 2009-03-12 | 461d? | finish no earlier than 2009-03-12 | S5 | 3688h | 3688h | OAM8 | Rel-8 | Dionisio | China Mobile |  |  |  |  |
| 964 | 313.3 | **Trace Management** | 196d? | 2008-03-07 A | 2008-12-05 A | 100% | 2008-03-07 | 2008-12-05 | 196d? |  | S5,C1,C3,C4 | 5777.6h | 5777.6h | OAM8-Trace | Rel-8 | Dionisio |  |  |  |  |  |
| 965 | 313.3.1 | Service Level Tracing in IMS | 196d? | 2008-03-07 A | 2008-12-05 A | 100% | 2008-03-07 | 2008-12-05 | 196d? | finish no earlier than 2008-12-05 | C1 | 1568h | 1568h | OAM8-Trace | Rel-8 | Frederic | Vodafone |  |  |  |  |
| 966 | 313.3.2 | Service Level Tracing in IMS | 175.4d? | 2008-03-07 A | 2008-12-05 A | 100% | 2008-03-07 | 2008-12-05 | 175.4d? | finish no earlier than 2008-12-05 | C4 | 1403.2h | 1403.2h | OAM8-Trace | Rel-8 | Frederic | Vodafone | PCG-21 | CP-40 |  |  |
| 967 | 313.3.3 | Deleted - Service Level Tracing in IMS | 175.4d? | 2008-03-07 A | 2008-12-05 A | 100% | 2008-03-07 | 2008-12-05 | 175.4d? | finish no earlier than 2008-12-05 | C3 | 1403.2h | 1403.2h | OAM8-Trace | Rel-8 | Gwiho | Vodafone | PCG-21 | CP-40 |  | CP-42 |
| 968 | 314 | **Charging Management small Enhancements** | 716d? | 2006-03-16 A | 2008-12-11 A | 100% | 2006-03-16 | 2008-12-11 | 716d? |  | S5 | 12544h | 12544h | CH8 | Rel-8 | Dionisio |  |  |  |  |  |
| 969 | 314.1 | Online charging correlation | 457d? | 2006-03-16 A | 2007-12-14 A | 100% | 2006-03-16 | 2007-12-14 | 457d? | start no earlier than 2006-03-16 | S5 | 3656h | 3656h | CH8 | Rel-8 | Dionisio | Orange |  |  |  |  |
| 970 | 314.2 | SMS online charging | 137d? | 2007-06-07 A | 2007-12-14 A | 100% | 2007-06-07 | 2007-12-14 | 137d? | finish no earlier than 2007-12-14 | S5 | 1096h | 1096h | CH8 | Rel-8 | Dionisio | Vodafone |  |  |  |  |
| 971 | 314.3 | Introduce Online Charging from SMS-SC into the SMS Charging Specifications | 61d? | 2008-09-18 A | 2008-12-11 A | 100% | 2008-09-18 | 2008-12-11 | 61d? | finish no earlier than 2008-12-11 | S5 | 488h | 488h | CH8 | Rel-8 | Dionisio | Acision | PCG-21 | SP-41 |  |  |
| 972 | 314.4 | Deleted - WLAN Offline Charging | 244d? | 2008-01-07 A | 2008-12-11 A | 100% | 2008-01-07 | 2008-12-11 | 244d? | finish no earlier than 2008-12-11 | S5 | 1952h | 1952h | CH8 | Rel-8 | Dionisio | Alcatel-Lucent | PCG-21 | SP-38 | PCG-22 | SP-42 |
| 973 | 315 | **Conferencing enhancements for Mp interface** | 266d? | 2007-11-30 A | 2008-12-05 A | 100% | 2007-11-30 | 2008-12-05 | 266d? |  | C4 | 6384h | 6384h | eMp | Rel-8 | Kimmo | Huawei | PCG-21 |  |  |  |
| 974 | 315.1 | Stage 2 for eMp | 266d? | 2007-11-30 A | 2008-12-05 A | 100% | 2007-11-30 | 2008-12-05 | 266d? | finish no earlier than 2008-12-11 | C4 | 2128h | 2128h | eMp | Rel-8 | Kimmo | Huawei | PCG-21 | CP-38 |  |  |
| 975 | 315.2 | Stage 3 for eMp | 266d? | 2007-11-30 A | 2008-12-05 A | 100% | 2007-11-30 | 2008-12-05 | 266d? | finish no earlier than 2008-12-05 | C4 | 2128h | 2128h | eMp | Rel-8 | Kimmo | Huawei | PCG-21 | CP-38 |  |  |

Notes:
- 951: - / Text3: TR 30.818
- 952: -
- 953: SP#43 completed / Text3: 32.155, 32.153 / Text5: thomas.tovinger@ericsson.com
- 954: SP#40 completed / Text3: 32.121, 32.122, 32.123 / Text5: SUERBAUM, Clemens
- 955: SP#40 completed / Text3: 32.632, 32.633, 32.635 / Text5: Li Jian (lijian@chinamobile.com)
- 956: SP#42 completed / Text3: 32.101/2, 32-series / Text5: tommy.berggren@teliasonera.com
- 957: SP#43 completed / Text3: 32.111-7, 32.617, 32.417, 32.367, 32.347, 32.111-1, 32.111-2, 32.111-3, 32.111-5, 32.307, 32.317, 32.341, 32.342, 32.343, 32.345, 32.361, 32.362, 32.363, 32.365, 32.411, 32.412, 32.413, 32.415, 32.611, 32.612, 32.613, 32.615, 32.625 / Text5: edwin.tse@ericsson.com
- 958: SP#46 completed. Create missing XML definitions specs for IRPs (Advanced Alarm Management, Communication Surveillance, Self-Configuration of Network Elements, Software Management) needed for implementation of Rel-8 Notification Log IRP (TS 32.33x) / Text3: new (32.125, 32.355, 32.505, 32.535), 32.150, 32.153, 32.335 / Text5: Shuqiang Huang (huangsq@zte.com.cn)
- 959: SP#41 Work stopped. Contributions related to E-UTRAN/EPC to be submitted to UID_380036 E-UTRAN NRM IRP/ UID_380037 EPC NRM IRP / Text3: 32.152, 32.62/3/4x, 32.73x / Text5: Yizhi Yao (yzyao@motorola.com)
- 960: - / Text5: Li Jian (lijian@chinamobile.com)
- 961: SP#42 completed / Text3: 32.321, 32.322, 32.323, 32.325 / Text5: lilianyuan@chinamobile.com
- 962: SP#42 completed / Text3: 32.405 / Text5: Li Jian (lijian@chinamobile.com)
- 963: SP#43 completed / Text3: 32.410 / Text5: Li Jian (lijian@chinamobile.com), Liang Shuangchun (liangshuangchun@cmdi.chinamobile.com)
- 964: -
- 965: CP#42 completed / Text3: 24.323, 24.229 / Text5: peter.dawes@vodafone.com
- 966: CP#42 completed / Text3: 29.228, 29.229 / Text5: peter.dawes@vodafone.com
- 967: CP#42 stopped (No CT3-impact) / Text5: peter.dawes@vodafone.com
- 968: SP#42 completed / Text3: TR 30.818
- 969: SP#38 completed / Text3: 32.296 / Text5: Chahine, Rony
- 970: SP#38 completed / Text3: 32.240, 32.299, new 32.274 / Text5: WONG, Gavin
- 971: SP#42 completed. Linked to SA2 UID 32081 (Support of SMS over IP networks) and CT4 UID 340016 (Routeing of MT-SMS via the HPLMN). / Text3: 32.274, 32.299 / Text5: Gebler, Erik - Acision [erik.gebler (at) acision.com]
- 972: SP#42 stopped / Text3: 32.252, 32.298, 32.299 / Text5: GARDELLA, Maryse
- 973: CP#42 completed / Text5: Chencheng@huawei.com
- 974: CP#42 completed / Text3: 23.333 / Text5: Chencheng@huawei.com
- 975: CP#42 completed / Text3: 29.333 / Text5: Chencheng@huawei.com

| ID | WBS | Task | Type | Duration | Start | Finish | Complete | Baseline start | Baseline finish | Baseline duration | Constraint | Resources | Work | Actual work | Text1 | Text4 | Text5 | Text6 | Text8 | Text7 | Text12 | Text11 | Text2 |
| --- | --- | --- | --- | --- | --- | --- | --- | --- | --- | --- | --- | --- | --- | --- | --- | --- | --- | --- | --- | --- | --- | --- | --- |
| 976 | 316 | **Contact Manager for 3GPP UICC applications** |  | 642d? | 2006-06-22 A | 2008-12-05 A | 100% | 2006-06-22 | 2008-12-05 | 642d? |  | C6 | 13352h | 13352h | eUPHBOOK | Gemalto | Jacques.seif@gemalto.com | Rel-8 | Xavier |  |  |  |  |
| 977 | 316.1 | Requirements for Contact Manager |  | 392d? | 2006-06-22 A | 2007-12-21 A | 100% | 2006-06-22 | 2007-12-21 | 392d? | finish no earlier than 2007-12-21 | C6 | 3136h | 3136h | eUPHBOOK-St1 | Gemalto | Jacques.seif@gemalto.com | Rel-8 | Xavier |  |  |  |  |
| 978 | 316.2 | External interface for eUPHBOOK |  | 220d? | 2007-05-07 A | 2008-03-07 A | 100% | 2007-05-07 | 2008-03-07 | 220d? | finish no earlier than 2008-03-07 | C6 | 1760h | 1760h | eUPHBOOK-Ext_Spec | Gemalto | Jacques.seif@gemalto.com | Rel-8 | Xavier |  |  |  |  |
| 979 | 316.3 | Internal interface for eUPHBOOK |  | 415d? | 2007-05-07 A | 2008-12-05 A | 100% | 2007-05-07 | 2008-12-05 | 415d? | finish no earlier than 2008-12-05 | C6 | 3320h | 3320h | eUPHBOOK-Int_Spec | Gemalto | Jacques.seif@gemalto.com | Rel-8 | Xavier | CP-37 |  |  |  |
| 980 | 316.4 | Deleted - Implementation of eUPHBOOK | milestone | 0d? | 2007-06-21 A | 2007-06-21 A | 100% | 2007-06-21 | 2007-06-21 | 0d? | start no earlier than 2007-06-21 | C6 |  |  | eUPHBOOK-St23 | Giesecke & Devrient | Claus Dietze | Rel-8 | Xavier |  | SP-33 |  |  |
| 981 | 317 | **Rel-8 LTE – 3G Long Term Evolution - Evolved Packet System RAN part** |  | 644d? | 2006-09-25 A | 2009-03-12 A | 100% | 2006-09-25 | 2009-03-12 | 644d? |  | RP,S5 | 44896h | 44896h | LTE | NTT DoCoMo | Takehiro Nakamura (nakamurata@nttdocomo.co.jp) | Rel-8 |  |  |  | RP-080741 |  |
| 982 | 317.1 | LTE – Physical Layer |  | 380d? | 2006-09-25 A | 2008-03-07 A | 100% | 2006-09-25 | 2008-03-07 | 380d? | finish no earlier than 2007-09-14 | R1 | 3040h | 3040h | LTE-Phys | NTT DoCoMo | Sadayuki Abeta | Rel-8 | Patrick |  |  | RP-080741 |  |
| 983 | 317.2 | LTE – Radio Interface Layer 2 and 3 Protocol Aspect |  | 575d? | 2006-09-25 A | 2008-12-05 A | 100% | 2006-09-25 | 2008-12-05 | 575d? | finish no earlier than 2008-12-11 | R2 | 4600h | 4600h | LTE-L23 | Nokia Siemens Networks | benoist.sebire@nokia.com | Rel-8 | Joern |  |  | RP-080741 |  |
| 984 | 317.3 | LTE – eUTRAN Interfaces |  | 575d? | 2006-09-25 A | 2008-12-05 A | 100% | 2006-09-25 | 2008-12-05 | 575d? | finish no earlier than 2008-12-11 | R3 | 4600h | 4600h | LTE-interfaces | Ericsson | Martin Israelsson | Rel-8 | Juha |  |  | RP-080741 |  |
| 985 | 317.4 | LTE – Evolved UTRA and UTRAN RF Radio Transmission/Reception, System Performance Requirements and Conformance Testing |  | 575d? | 2006-09-25 A | 2008-12-05 A | 100% | 2006-09-25 | 2008-12-05 | 575d? | finish no earlier than 2008-12-11 | R4 | 4600h | 4600h | LTE-RF | Nokia Siemens Networks | Tuomo Saynajakangas | Rel-8 | Issam |  |  | RP-080741 |  |
| 986 | 317.5 | LTE – FDD repeaters |  | 386d? | 2007-09-14 A | 2009-03-06 A | 100% | 2007-09-14 | 2009-03-06 | 386d? | finish no earlier than 2009-03-06 | R4 | 3088h | 3088h | LTE-Repeaters | Powerwave Technologies, Andrew Wireless | ralf.michanikl@andrew.com, Alf.Ahlstrom@pwav.com | Rel-8 | Issam | RP-37 |  | RP-090037 |  |
| 987 | 317.6 | **E-UTRAN Data Definitions** |  | 389d? | 2007-09-17 A | 2009-03-12 A | 100% | 2007-09-17 | 2009-03-12 | 389d? |  | S5 | 13096h | 13096h | E-UTRAN-OAM |  |  | Rel-8 | Dionisio | SP-39 |  |  | PCG-21 |
| 988 | 317.6.1 | Subscriber and Equipment Trace for E-UTRAN and EPC |  | 389d? | 2007-09-17 A | 2009-03-12 A | 100% | 2007-09-17 | 2009-03-12 | 389d? | finish no earlier than 2009-03-12 | S5 | 3112h | 3112h | E-UTRAN-OAM | Ericsson | robert.petersen@ericsson.com | Rel-8 | Dionisio | SP-37 |  |  |  |
| 989 | 317.6.2 | E-UTRAN Network Resource Model (NRM) Integration Reference Point (IRP) |  | 309d? | 2008-01-07 A | 2009-03-12 A | 100% | 2008-01-07 | 2009-03-12 | 309d? | finish no earlier than 2009-03-12 | S5 | 2472h | 2472h | E-UTRAN-OAM | Ericsson | ELMDAHL, Per | Rel-8 | Dionisio | SP-38 |  |  | PCG-21 |
| 990 | 317.6.3 | Performance measurements for E-UTRAN |  | 275d? | 2008-02-22 A | 2009-03-12 A | 100% | 2008-02-22 | 2009-03-12 | 275d? | finish no earlier than 2009-03-12 | S5 | 2200h | 2200h | E-UTRAN-OAM | Motorola, Huawei | Yizhi Yao (yzyao@motorola.com) | Rel-8 | Dionisio | SP-39 |  |  | PCG-21 |
| 991 | 317.6.4 | Key Performance Indicators (KPIs) for E-UTRAN |  | 275d? | 2008-02-22 A | 2009-03-12 A | 100% | 2008-02-22 | 2009-03-12 | 275d? | finish no earlier than 2009-03-12 | S5 | 2200h | 2200h | E-UTRAN-OAM | Ericsson | ulf.hubinette@ericsson.com | Rel-8 | Dionisio | SP-39 |  |  | PCG-21 |
| 992 | 317.7 | **Self-Organizing Networks (SON)** |  | 210d? | 2008-02-22 A | 2008-12-11 A | 100% | 2008-02-22 | 2008-12-11 | 210d? |  | S5 | 6720h | 6720h | LTE_SON-OAM | Vodafone | GOMPAKIS, Panagiotis | Rel-8 | Dionisio | SP-39 |  |  | PCG-21 |
| 993 | 317.7.1 | SON Concepts and requirements |  | 210d? | 2008-02-22 A | 2008-12-11 A | 100% | 2008-02-22 | 2008-12-11 | 210d? |  | S5 | 1680h | 1680h | LTE_SON-OAM | Vodafone | GOMPAKIS, Panagiotis | Rel-8 | Dionisio | SP-39 |  |  | PCG-21 |
| 994 | 317.7.2 | Self-Establishment of eNBs, including automated Software Management |  | 210d? | 2008-02-22 A | 2008-12-11 A | 100% | 2008-02-22 | 2008-12-11 | 210d? | start no earlier than 2008-02-22 | S5 | 1680h | 1680h | LTE_SON-OAM | Nokia Siemens Networks | SUERBAUM, Clemens | Rel-8 | Dionisio | SP-39 |  |  | PCG-21 |
| 995 | 317.7.3 | SON Automatic Neighbour Relations (ANR) List Management |  | 210d? | 2008-02-22 A | 2008-12-11 A | 100% | 2008-02-22 | 2008-12-11 | 210d? | finish no earlier than 2008-12-11 | S5 | 1680h | 1680h | LTE_SON-OAM | Ericsson | edwin.tse@ericsson.com | Rel-8 | Dionisio | SP-39 |  |  | PCG-21 |
| 996 | 318 | **Rel-8 LTE – Terminal Conformance Test Specification** |  | 657d? | 2007-06-01 A | 2009-12-04 A | 100% | 2007-06-01 | 2009-12-04 | 657d? |  | R5 | 17544h | 17544h | LTE-UEConTest |  |  | Rel-8 | Ingbert |  |  |  |  |
| 997 | 318.1 | 3G LTE – Terminal Protocol Conformance Test Specifications |  | 657d? | 2007-06-01 A | 2009-12-04 A | 100% | 2007-06-01 | 2009-12-04 | 657d? | finish no earlier than 2009-12-04 | R5 | 5256h | 5256h | LTE-UEConTest_SIG | NEC, Motorola | david.lecompte@nectech.fr, Jacob.John@motorola.com | Rel-8 | Ingbert |  |  | RP-091060 |  |
| 998 | 318.2 | LTE – Terminal Radio Transmission and Reception Conformance Test Specifications |  | 657d? | 2007-06-01 A | 2009-12-04 A | 100% | 2007-06-01 | 2009-12-04 | 657d? |  | R5 | 5256h | 5256h | LTE-UEConTest_RF | Agilent | andrea_leonardi@agilent.com | Rel-8 | Ingbert |  |  | RP-091059 |  |
| 999 | 318.3 | Deleted - LTE – Terminal Radio Transmission and Reception Conformance Test Specifications |  | 401d? | 2007-06-01 A | 2008-12-12 A | 100% | 2007-06-01 | 2008-12-12 | 401d? |  | R5 | 3208h | 3208h | LTE-UEConTest_RF | Agilent | andrea_leonardi@agilent.com | Rel-8 | Ingbert |  | RP-41 | RP-091059 |  |

Notes:
- 976: CP#42 completed. CP#40: WID updated CP-070622=>CP-080382. aka Enhanced USIM phonebook
- 977: CP#38 completed / Text3: 21.111
- 978: CP#39 completed / Text3: new 31.220
- 979: CP#42 completed / Text3: new 31.221
- 980: SP#33 stopped / Text3: 31.102
- 981: RP#43 completed. Role model for SAE/LTE system wide project management by SA2 in SP-060166 / Text3: 36.300, 36.938
- 982: RP#39 completed / Text3: 36.201, 36.211, 36.212, 36.213, 36.214, 25.215, 25.225
- 983: RP#42 completed / Text3: 36.302, 36.304, 36.306, 36.314, 36.321, 36.322, 36.323, 36.331, 25.302, 25.304, 25.331
- 984: RP#42 completed / Text3: 36.401, 36.410, 36.411, 36.412, 36.413, 36.414, 36.420, 36.421, 36.422, 36.423, 36.424, 25.413
- 985: RP#42 completed. RP#47 abandoned draft 36.801, 36.803, 36.804 / Text3: 36.101, 36.104, 36.113, 36.124, 36.133, 36.141, 36.942, 25.123, 25.133
- 986: RP#43 completed. RP#47 create Rel-9 TR 36.956 (see R4-100386, RP-100320_RAN4 Report) / Text3: 36.106, 36.143, 25.113
- 987: SP#43 completed
- 988: SP#43 completed / Text3: 32.421, 2.422, 32.423, 2.441, 32.442, 32.443, 32.445
- 989: SP#43 completed / Text3: new (32.761, 32.762, 32.763, 32.765)
- 990: SP#43 completed / Text3: new 32.425
- 991: SP#43 completed / Text3: new (32.450, 32.451)
- 992: SP#42 completed (WT UID_390007 moved to Rel-9)
- 993: SP#42 completed / Text3: new 32.500
- 994: SP#42 completed / Text3: new (32.501, 32.502, 32.503, 32.531, 32.532, 32.533)
- 995: SP#42 completed / Text3: 32.761, 32.762, 32.763, 32.765, new 32.511
- 996: Testing for Feature UID_20068 (LTE)
- 997: RP#46 completed / Text3: 36.521-1, 36.521-2, 36.508, 36.509, 36.523-1, 36.523-2, 36.523-3
- 998: RP#46 completed. RP#50 TR 36.903 v100 for Approval / Text3: 36.521-1, 36.521-2, 36.521-3, new TR 36.903
- 999: RP#41 stopped / Text3: 36.521-1, 36.521-2, 36.521-3

| ID | WBS | Task | Duration | Start | Finish | Complete | Baseline start | Baseline finish | Baseline duration | Constraint | Resources | Work | Actual work | Text1 | Text6 | Text8 | Text4 | Text5 | Text11 | Text2 | Text7 | Text9 | Text12 |
| --- | --- | --- | --- | --- | --- | --- | --- | --- | --- | --- | --- | --- | --- | --- | --- | --- | --- | --- | --- | --- | --- | --- | --- |
| 1000 | 319 | **Rel-8 Improvements of the Radio Interface** | 525d? | 2007-03-05 A | 2009-03-06 A | 100% | 2007-03-05 | 2009-03-06 | 525d? |  | RP | 18152h | 18152h | RInImp8 | Rel-8 | Issam |  |  |  |  |  |  |  |
| 1001 | 319.1 | UMTS 1500 MHz | 140d? | 2007-03-05 A | 2007-09-14 A | 100% | 2007-03-05 | 2007-09-14 | 140d? | finish no earlier than 2007-09-14 | R4 | 1120h | 1120h | RInImp8-UMTS1500 | Rel-8 | Issam | NTT DoCoMo | Takehiro Nakamura (nakamurata@nttdocomo.co.jp) | RP-070526 |  |  |  |  |
| 1002 | 319.2 | UMTS 700 MHz FDD | 325d? | 2007-03-05 A | 2008-05-30 A | 100% | 2007-03-05 | 2008-05-30 | 325d? | finish no earlier than 2008-06-12 | R4 | 2600h | 2600h | RInImp8-UMTS700 | Rel-8 | Issam | Nokia | Tuomo Saynajakangas | RP-080260 |  |  |  |  |
| 1003 | 319.3 | UMTS 1880 MHz TDD | 126d? | 2008-09-12 A | 2009-03-06 A | 100% | 2008-09-12 | 2009-03-06 | 126d? | finish no earlier than 2009-03-09 | R4 | 1008h | 1008h | RInImp9-UMTS1880TDD | Rel-8 | Issam | CATT | Yuexia Song (songyuexia@datangmobile.cn) | RP-090044 | PCG-21 | RP-41 |  |  |
| 1004 | 319.4 | UMTS 2300 MHz TDD LCR | 195d? | 2007-12-17 A | 2008-09-12 A | 100% | 2007-12-17 | 2008-09-12 | 195d? | finish no earlier than 2008-09-12 | R4 | 1560h | 1560h | RInImp8-UMTS2300TDD | Rel-8 | Issam | CATT | songyuexia@datangmobile.cn | RP-080517 | PCG-21 | RP-38 |  |  |
| 1005 | 319.5 | Further Improved Minimum Performance Requirements for HSDPA UE (FDD) - Two-Branch Interference Cancellation | 265d? | 2007-03-05 A | 2008-03-07 A | 100% | 2007-03-05 | 2008-03-07 | 265d? | finish no earlier than 2008-03-12 | R4 | 2120h | 2120h | RInImp8-2BIC | Rel-8 | Issam | AT&T | Marc Grant | RP-080041 |  |  |  |  |
| 1006 | 319.6 | CS Voice Service over HSPA | 167d? | 2007-07-19 A | 2008-03-07 A | 100% | 2007-07-19 | 2008-03-07 | 167d? |  | R2 | 1336h | 1336h | RInImp8-CsHspa | Rel-8 | Joern | Nokia Siemens Networks | woonhee.hwang@nsn.com | RP-080042 |  | RP-37 |  |  |
| 1007 | 319.7 | Performance requirements for 15 code reception with 16QAM/QPSK (FDD) | 126d? | 2007-06-11 A | 2008-03-07 A | 100% | 2007-06-11 | 2008-03-07 | 126d? | finish no earlier than 2008-06-12 | R4 | 1008h | 1008h | RInImp8-Hsdpa15codes | Rel-8 | Issam | Vodafone | tim.frost@vodafone.com | RP-080043 |  | RP-37 |  |  |
| 1008 | 319.8 | Deleted - UMTS 2300 MHz FDD/TDD | 400d? | 2007-03-05 A | 2008-09-12 A | 100% | 2007-03-05 | 2008-09-12 | 400d? | finish no earlier than 2008-12-11 | R4 | 3200h | 3200h | RInImp8-UMTS2300 | Rel-8 | Issam | AT&T | Marc Grant | RP-080515 |  |  | PCG-21 | RP-41 |
| 1009 | 320 | **Rel-8 Improvements of the Radio Interface - UE Conformance Testing** | 396d? | 2007-06-01 A | 2008-12-05 A | 100% | 2007-06-01 | 2008-12-05 | 396d? |  | R5 | 6256h | 6256h | RInImp-UEConTest | Rel-8 | Ingbert |  |  |  |  |  |  |  |
| 1010 | 320.1 | Conformance Test Aspects – CS Voice Service over HSPA | 336d? | 2007-06-01 A | 2008-09-12 A | 100% | 2007-06-01 | 2008-09-12 | 336d? | finish no earlier than 2008-09-12 | R5 | 2688h | 2688h | RInImp8-CsHspa_UEConTest | Rel-8 | Ingbert | Huawei | baoyi@huawei.com | RP-080542 |  |  |  |  |
| 1011 | 320.2 | Conformance Test Aspects – Performance requirements for 15 code reception with 16QAM/QPSK (FDD) | 195d? | 2008-03-07 A | 2008-12-05 A | 100% | 2008-03-07 | 2008-12-05 | 195d? | finish no earlier than 2008-12-05 | R5 | 1560h | 1560h | RInImp8-UEConTest_ Hsdpa15codes | Rel-8 | Ingbert | Ericsson | Mikael.Ziren@Ericsson.com | RP-080818 | PCG-21 | RP-40 |  |  |
| 1012 | 321 | **Rel-8 RAN improvements** | 520d? | 2007-06-04 A | 2009-05-29 A | 100% | 2007-06-04 | 2009-05-29 | 520d? |  | RP | 29776h | 29776h | RANimp | Rel-8 |  |  |  |  |  |  |  |  |
| 1013 | 321.1 | Combination of 64QAM and MIMO for HSDPA (FDD) | 205d? | 2007-06-04 A | 2008-09-12 A | 100% | 2007-06-04 | 2008-09-12 | 205d? | finish no earlier than 2008-09-12 | R1 | 1640h | 1640h | RANimp-64QamMimoHsdpa | Rel-8 | Patrick | Ericsson | Johan.Bergman@ericsson.com | RP-080518 |  |  |  |  |
| 1014 | 321.2 | Improved L2 for uplink | 186d? | 2007-09-14 A | 2008-05-30 A | 100% | 2007-09-14 | 2008-05-30 | 186d? | finish no earlier than 2008-05-30 | R2 | 1488h | 1488h | RANimp-UplinkL2dataRates | Rel-8 | Joern | Ericsson | Janne.Peisa@ericsson.com | RP-080265 |  | RP-37 |  |  |
| 1015 | 321.3 | Enhanced Uplink for CELL_FACH State in FDD | 321d? | 2007-09-14 A | 2008-12-05 A | 100% | 2007-09-14 | 2008-12-05 | 321d? | finish no earlier than 2008-12-12 | R2 | 2568h | 2568h | RANimp-UplinkEnhState | Rel-8 | Joern | Nokia Siemens Networks | markus.wimmer@nsn.com | RP-080804 |  | RP-37 |  |  |
| 1016 | 321.4 | Enhanced UE Discontinuous Reception (DRX) for FDD | 261d? | 2007-09-14 A | 2008-09-12 A | 100% | 2007-09-14 | 2008-09-12 | 261d? | finish no earlier than 2008-09-12 | R2 | 2088h | 2088h | RANimp-DRX | Rel-8 | Joern | Nokia | luis.barreto@nokia.com | RP-080520 |  | RP-37 |  |  |
| 1017 | 321.5 | Enhancements for Serving Radio Network Subsystem (SRNS) Relocation Procedure | 261d? | 2007-09-14 A | 2008-09-12 A | 100% | 2007-09-14 | 2008-09-12 | 261d? | finish no earlier than 2008-09-12 | R3 | 2088h | 2088h | RANimp-SrnsReloc | Rel-8 | Juha | Nokia Siemens Networks | masatoshi.nakamata@nsn.com | RP-080521 |  | RP-37 |  |  |
| 1018 | 321.6 | Enhancements for FDD HSPA Evolution | 321d? | 2007-09-14 A | 2008-12-05 A | 100% | 2007-09-14 | 2008-12-05 | 321d? | finish no earlier than 2008-12-05 | R3,R2 | 2568h | 2568h | RANimp-HSPAEvo | Rel-8 | Juha | Nokia Siemens Networks | masatoshi.nakamata@nsn.com | RP-080805 |  | RP-37 |  |  |
| 1019 | 321.7 | 64QAM for 1.28 Mcps TDD HSDPA | 264d? | 2007-12-04 A | 2008-12-05 A | 100% | 2007-12-04 | 2008-12-05 | 264d? | finish no earlier than 2008-12-05 | R1 | 2112h | 2112h | RANimp-64Qam1.28TDD | Rel-8 | Patrick | ZTE | zfmail@zte.com.cn | RP-080806 | PCG-21 | RP-38 |  |  |
| 1020 | 321.8 | Enhanced CELL_FACH state in 1.28 Mcps TDD | 264d? | 2007-12-04 A | 2008-12-05 A | 100% | 2007-12-04 | 2008-12-05 | 264d? | finish no earlier than 2008-12-12 | R2 | 2112h | 2112h | RANimp-EnhState1.28TDD | Rel-8 | Joern | ZTE | zhang.yincheng@zte.com.cn | RP-080807 | PCG-21 | RP-38 |  |  |
| 1021 | 321.9 | Continuous Connectivity for packet data users for 1.28 Mcps TDD | 321d? | 2008-03-07 A | 2009-05-29 A | 100% | 2008-03-07 | 2009-05-29 | 321d? | finish no earlier than 2009-05-29 | R1 | 2568h | 2568h | RANimp-LCRCPC | Rel-8 | Patrick | TD Tech | chenying@td-tech.com | RP-090394 | PCG-21 | RP-39 |  |  |
| 1022 | 321.10 | HSPA VoIP to WCDMA/GSM CS continuity | 261d? | 2008-03-07 A | 2009-03-06 A | 100% | 2008-03-07 | 2009-03-06 | 261d? | finish no earlier than 2009-03-06 | R2 | 2088h | 2088h | RANimp-HSPAVoIP | Rel-8 | Joern | Nokia | Simone.Provvedi@nokia.com | RP-090050 | PCG-21 | RP-39 |  |  |
| 1023 | 321.11 | HS-DSCH Serving Cell Change Enhancements | 196d? | 2008-03-07 A | 2008-12-05 A | 100% | 2008-03-07 | 2008-12-05 | 196d? | finish no earlier than 2008-12-12 | R2 | 1568h | 1568h | RANimp-HSDSCH | Rel-8 | Joern | Ericsson | henrik.enbuske@ericsson.com | RP-080811 | PCG-21 | RP-39 |  |  |
| 1024 | 321.12 | MIMO for 1.28 Mcps TDD. Linked to Rel-8 Study on Scope of future HSPA Evolution for 1.28 Mcps TDD (UID_370041) TR 25.824 | 201d? | 2007-11-01 A | 2009-03-06 A | 100% | 2007-11-01 | 2009-03-06 | 201d? | finish no earlier than 2009-05-29 | R1,R4 | 1608h | 1608h | RANimp-MIMOLCR | Rel-8 | Patrick | CATT | wangke@datangmobile.cn | RP-090313 | PCG-21 | RP-40 |  |  |
| 1025 | 321.13 | Dual-Cell HSDPA operation on adjacent carriers | 140d? | 2008-05-30 A | 2008-12-11 A | 100% | 2008-05-30 | 2008-12-11 | 140d? | finish no earlier than 2009-05-29 | R1,R4 | 1120h | 1120h | RANimp-DCHSDPA | Rel-8 | Patrick | Ericsson | johan.bergman@ericsson.com | RP-080814 | PCG-21 | RP-40 |  |  |

Notes:
- 1000: -
- 1001: RP#37 completed / Text3: 25.101, 25.104, 25.133, 25.141, 25.331, 25.942, 25.306, 25.307, 34.121
- 1002: RP#40 completed / Text3: 25.101, 25.104, 25.133, 25.141, 25.331, 25.942, 25.306, 25.307, 34.121
- 1003: RP#43 completed / Text3: 25.102, 25.105, 25.113, 25.123, 25.142, 34.124, 25.307
- 1004: RP#41 completed. RP#47 abandoned draft 25.828 / Text3: 25.102, 25.105, 25.113, 25.123, 25.142, 34.124, 25.306, 25.331, 34.122
- 1005: RP#39 completed / Text3: 25.101
- 1006: RP#39 completed / Text3: 25.323, 25.331, 25.322
- 1007: RP#39 completed / Text3: 25.101
- 1008: RP#41 stopped / Text3: 25.101, 25.104, 25.133, 25.141, 25.331, 25.942, 25.306, 25.307, 34.121
- 1009: 05/08: Linked to Feature UID_20028 (RInImp)
- 1010: RP#41 completed / Text3: 34.108, 34.123-1, 34.123-2, 34.123-3
- 1011: RP#42 completed / Text3: 34.121-1, 34.121-2
- 1012: -
- 1013: RP#41 completed / Text3: 25.308, 25.211, 25.212, 25.213, 25.306, 25.331, 25.433, 25.435, 25.423, 25.425, 25.101, 25.104, 25.141
- 1014: RP#40 completed. Linked to UID_370037 Enhanced Uplink for CELL_FACH State in FDD / Text3: 25.319, 25.301, 25.306, 25.321, 25.331, 25.433, 25.435, 25.423, 25.425, 25.427
- 1015: RP#42 completed. Linked to UID_370036 Improved L2 for uplink / Text3: 25.309, 25.211, 25.214, 25.321, 25.331, 25.423, 25.433
- 1016: RP#41 completed. Continuation of Rel-7 work item "Continuous connectivity for packet data users" UID_20046. / Text3: 25.306, 25.308, 25.321, 25.331, 25.423
- 1017: RP#41 completed. Linked to UID_370040 Enhancements for FDD HSPA Evolution / Text3: 25.306, 25.308, 25.321, 25.331, 25.423, 25.433, 25.214, 25.133
- 1018: RP#42 completed. Triggered by Rel-7 Study on Scope of future FDD HSPA Evolution (UID_20065) TR 25.999 / Text3: 25.401, 25.413, 25.420, 25.423, 25.427, 25.433, 25.446, 25.301, 25.346
- 1019: RP#42 completed. Linked to Rel-8 Study on Scope of future HSPA Evolution for 1.28 Mcps TDD (UID_370041) TR 25.824 / Text3: 25.102, 25.105, 25.123, 25.142, 25.201, 25.221, 25.222, 25.223, 25.224, 25.306, 25.308, 25.321, 25.331, 25.423, 25.433
- 1020: RP#42 completed. Linked to Rel-8 Study on Scope of future HSPA Evolution for 1.28 Mcps TDD (UID_370041) TR 25.824 / Text3: 25.123, 25.221, 25.222, 25.224, 25.301, 25.302, 25.304, 25.306, 25.308, 25.319, 25.321, 25.331, 25.401, 25.423, 25.425, 25.433, 25.435
- 1021: RP#44 completed. Linked to Rel-8 Study on Scope of future HSPA Evolution for 1.28 Mcps TDD (UID_370041) TR 25.824 / Text3: 25.929, 25.308, 25.319
- 1022: RP#43 completed / Text3: 25.331, 25.413
- 1023: RP#42 completed / Text3: 25.101, 25.104, 25.133, 25.212, 25.214, 25.308, 25.321, 25.331, 25.423, 25.433
- 1024: RP#43 completed / Text3: 25.201, 25.221, 25.222, 25.223, 25.224, 25.306, 25.308, 25.321, 25.331, 25.423, 25.433, 25.102, 25.105, 25.142
- 1025: RP#42 completed. Triggered by UID_390032 Study on Dual-Cell HSDPA (withdrawn TR 25.825 v100). / Text3: 25.101, 25.104, 25.133, 25.141, 25.211, 25.212, 25.213, 25.214, 25.215, 25.306, 25.308, 25.321, 25.331, 25.423, 25.433

| ID | WBS | Task | Duration | Start | Finish | Complete | Remaining | Baseline start | Baseline finish | Baseline duration | Total slack | Constraint | Resources | Work | Actual work | Text1 | Text6 | Text8 | Text2 | Text4 | Text7 | Text11 |
| --- | --- | --- | --- | --- | --- | --- | --- | --- | --- | --- | --- | --- | --- | --- | --- | --- | --- | --- | --- | --- | --- | --- |
| 1026 | 322 | **Rel-8 RAN improvements - UE Conformance Testing** | 602d? | 2008-05-30 A | 2010-09-17 A | 100% |  | 2008-05-30 | 2010-09-17 | 602d? |  |  | R5 | 29391.2h | 29391.2h | RANimp-UEConTest | Rel-8 | Ingbert |  |  |  |  |
| 1027 | 322.1 | Conformance Test Aspects – Combination of 64QAM and MIMO for HSDPA (FDD) | 322d? | 2008-09-12 A | 2009-12-04 A | 100% |  | 2008-09-12 | 2009-12-04 | 322d? |  | finish no earlier than 2009-12-04 | R5 | 2576h | 2576h | RANimp-UEConTest_64QamMimoHsdpa | Rel-8 | Ingbert | PCG-21 | Ericsson | RP-41 | RP-091058 |
| 1028 | 322.2 | Conformance Test Aspects – Improved L2 for uplink | 341d? | 2008-05-30 A | 2009-09-18 A | 100% |  | 2008-05-30 | 2009-09-18 | 341d? |  | finish no earlier than 2009-09-18 | R5 | 2728h | 2728h | RANimp-UEConTest_UplinkL2dataRates | Rel-8 | Ingbert | PCG-21 | Ericsson | RP-40 | RP-090712 |
| 1029 | 322.3 | Conformance Test Aspects – 1.28 Mcps TDD Improved L2 support for high data rates | 342d? | 2009-05-29 A | 2010-09-17 A | 100% |  | 2009-05-29 | 2010-09-17 | 342d? |  | finish no earlier than 2010-09-17 | R5 | 2736h | 2736h | RANimp-UEConTest_ImprovedL2LCRTDD | Rel-8 | Ingbert | PCG-23 | CATT | RP-44 | RP-100737 |
| 1030 | 322.4 | Conformance Test Aspects – 64QAM for 1.28 Mcps TDD HSDPA | 261d? | 2008-05-30 A | 2009-05-29 A | 100% |  | 2008-05-30 | 2009-05-29 | 261d? |  | finish no earlier than 2009-05-29 | R5 | 2088h | 2088h | RANimp-UEConTest_64Qam1.28TDD | Rel-8 | Ingbert | PCG-21 | ZTE | RP-40 | RP-090415 |
| 1031 | 322.5 | Conformance Test Aspects – Dual-Cell HSDPA operation on adjacent carriers | 391d? | 2008-12-05 A | 2010-06-04 A | 100% |  | 2008-12-05 | 2010-06-04 | 391d? |  | finish no earlier than 2010-06-04 | R5 | 3128h | 3128h | RANimp-UEConTest_DCHSDPA | Rel-8 | Ingbert | PCG-22 | Qualcomm | RP-42 | RP-100479 |
| 1032 | 322.6 | Conformance Test Aspects – Enhanced Uplink for CELL_FACH State in FDD | 326d? | 2009-03-06 A | 2010-06-04 A | 100% |  | 2009-03-06 | 2010-06-04 | 326d? |  | finish no earlier than 2010-06-04 | R5 | 2608h | 2608h | RANimp-UEConTest_EnhancedRACHCellFACHState | Rel-8 | Ingbert | PCG-22 | Nokia | RP-43 | RP-100483 |
| 1033 | 322.7 | Conformance Test Aspects – Receiver Type3i | 196d? | 2009-03-06 A | 2009-12-04 A | 100% |  | 2009-03-06 | 2009-12-04 | 196d? |  | finish no earlier than 2009-12-04 | R5 | 1568h | 1568h | RANimp-UEConTest_ReceiverType3i | Rel-8 | Ingbert | PCG-22 | Qualcomm | RP-43 | RP-091066 |
| 1034 | 322.8 | Conformance Test Aspects – Enhanced CELL_FACH State in LCR TDD | 341d? | 2009-05-30 A | 2010-09-17 A | 100% |  | 2009-05-30 | 2010-09-17 | 341d? |  | finish no earlier than 2010-09-17 | R5 | 2728h | 2728h | RANimp-UEConTest_EnhancedCellFACHStateLCRTDD | Rel-8 | Ingbert | PCG-23 | CATT | RP-44 | RP-100735 |
| 1035 | 322.9 | Conformance Test Aspects – Continuous Connectivity for packet data users for 1.28 Mcps TDD | 261d? | 2009-09-18 A | 2010-09-17 A | 100% |  | 2009-09-18 | 2010-09-17 | 261d? |  | finish no earlier than 2010-09-17 | R5 | 2088h | 2088h | RANimp-UEConTest_CPCLCRTDD | Rel-8 | Ingbert | PCG-23 | ZTE | RP-45 | RP-100739 |
| 1036 | 322.10 | Conformance Test Aspects – MIMO for 1.28 Mcps TDD | 186d? | 2009-09-18 A | 2010-06-04 A | 100% |  | 2009-09-18 | 2010-06-04 | 186d? |  | finish no earlier than 2010-06-04 | R5 | 1488h | 1488h | RANimp-UEConTest_MIMOLCRTDD | Rel-8 | Ingbert | PCG-23 | ZTE | RP-45 | RP-100660 |
| 1037 | 322.11 | Conformance Test Aspects – HS-DSCH Serving Cell Change Enhancements | 131d? | 2009-09-18 A | 2010-03-19 A | 100% |  | 2009-09-18 | 2010-03-19 | 131d? |  | finish no earlier than 2010-03-12 | R5 | 1048h | 1048h | HSDSCH_UEConTest | Rel-8 | Ingbert | PCG-23 | Qualcomm | RP-45 | RP-100077 |
| 1038 | 323 | 3.84 Mcps TDD MBSFN Integrated Mobile Broadcast | 395d? | 2007-06-04 A | 2008-12-05 A | 100% |  | 2007-06-04 | 2008-12-05 | 395d? |  |  | R1 | 3160h | 3160h | MBSFN-DOB | Rel-8 | Patrick |  | Ericsson |  | RP-080218 |
| 1039 | 324 | Conformance Test Aspects – 3.84 Mcps TDD MBSFN Integrated Mobile Broadcast | 211d? | 2009-05-30 A | 2010-03-19 A | 100% |  | 2009-05-30 | 2010-03-19 | 211d? |  | finish no earlier than 2010-03-19 | R5 | 1688h | 1688h | MBSFN_IMB_UEConTest | Rel-8 | Ingbert | PCG-23 | IPwireless | RP-44 | RP-100070 |
| 1040 | 325 | **GERAN support for GERAN - 3G Long Term Evolution interworking** | 1172d? | 2006-09-08 A | 2011-03-04 | 85% | 177.52d? | 2006-09-08 | 2011-03-04 | 1172d? | 465d |  | GP,G1,C1 | 34136h | 28965.4h | GELTE | Rel-8 | Paolo |  | Nokia, Nokia Siemens Networks |  |  |
| 1041 | 325.1 | G1 part of GERAN support for GERAN - 3G Long Term Evolution interworking | 641d? | 2006-09-08 A | 2009-02-20 A | 100% |  | 2006-09-08 | 2009-02-20 | 641d? |  | finish no earlier than 2009-02-20 | G1 | 5128h | 5128h | GELTE | Rel-8 | Paolo |  | Nokia, Nokia Siemens Networks |  |  |
| 1042 | 325.2 | G2 part of GERAN support for GERAN - 3G Long Term Evolution interworking | 641d? | 2006-09-08 A | 2009-02-20 A | 100% |  | 2006-09-08 | 2009-02-20 | 641d? |  | finish no earlier than 2009-02-20 | G2 | 5128h | 5128h | GELTE | Rel-8 | Paolo |  | Nokia, Nokia Siemens Networks |  |  |
| 1043 | 325.3 | CT1 part of GERAN support for GERAN - 3G Long Term Evolution interworking | 641d? | 2006-09-08 A | 2009-02-20 A | 100% |  | 2006-09-08 | 2009-02-20 | 641d? |  | finish no earlier than 2009-02-20 | C1 | 5128h | 5128h | GELTE | Rel-8 | Paolo |  | Nokia, Nokia Siemens Networks |  |  |
| 1044 | 325.4 | Testing for GERAN support for GERAN - 3G Long Term Evolution interworking | 1172d? | 2006-09-08 A | 2011-03-04 | 60% | 468.8d? | 2006-09-08 | 2011-03-04 | 1172d? | 465d | finish no earlier than 2011-03-04 | G3new | 9376h | 5625.6h | GELTE | Rel-8 | Ingbert |  | Nokia, Nokia Siemens Networks |  |  |
| 1045 | 326 | U-TDOA Enhancement | 131d? | 2007-05-18 A | 2007-11-16 A | 100% |  | 2007-05-18 | 2007-11-16 | 131d? |  | finish no earlier than 2007-05-18 | GP | 1048h | 1048h | GUTEN | Rel-8 | Paolo |  | TruePosition |  |  |
| 1046 | 327 | **GAN Enhancements** | 604.2d? | 2007-05-15 A | 2009-09-04 A | 100% |  | 2007-05-15 | 2009-09-04 | 604.2d? |  |  | GP | 9432h | 9432h | GANENH | Rel-8 | Paolo |  | T-Mobile |  |  |
| 1047 | 327.1 | Update to GAN specifications | 126d? | 2007-08-31 A | 2008-02-22 A | 100% |  | 2007-08-31 | 2008-02-22 | 126d? |  | finish no earlier than 2008-02-22 | GP | 1008h | 1008h | GANENH-SPEC | Rel-8 | Paolo |  | T-Mobile |  |  |
| 1048 | 327.2 | Update TS 51.010 Mobile Station (MS) Conformance Specification for GAN Enhancements | 526d? | 2007-05-15 A | 2009-09-04 A | 100% |  | 2007-05-15 | 2009-09-04 | 526d? |  | finish no earlier than 2009-09-04 | G3new | 4208h | 4208h | GANENH-MStest | Rel-8 | Ingbert |  | T-Mobile |  |  |
| 1049 | 328 | **AoIP (A-interface over IP)** | 2335d? | 2000-01-03 A | 2008-12-11 A | 100% |  | 2000-01-03 | 2008-12-11 | 2335d? |  |  | GP,S4,C4,C1,C3 | 41412.1h | 41412.1h | AoIP | Rel-8 | Paolo | PCG-21 | China Mobile, Ericsson |  |  |
| 1050 | 328.1 | GERAN aspects of AoIP | 2321d? | 2000-01-03 A | 2008-11-21 A | 100% |  | 2000-01-03 | 2008-11-21 | 2321d? |  | finish no earlier than 2008-11-21 | GP | 18560h | 18560h | AoIP | Rel-8 | Paolo | PCG-21 | China Mobile, Ericsson | SP-40 |  |
| 1051 | 328.2 | Media Requirements for CS over IP based User Plane | 267d? | 2007-12-05 A | 2008-12-11 A | 100% |  | 2007-12-05 | 2008-12-11 | 267d? |  | finish no earlier than 2008-12-11 | S4 | 1996.09h | 1996.09h | AoIP-CSoIP | Rel-8 | Paolo | PCG-21 | China Mobile, Ericsson | SP-40 |  |
| 1052 | 328.3 | Core Network Impacts for A-Interface User Plane over IP | 136d? | 2008-05-30 A | 2008-12-05 A | 100% |  | 2008-05-30 | 2008-12-05 | 136d? |  | start no earlier than 2008-05-30 | C4 | 1088h | 1088h | AoIP-CN | Rel-8 | Kimmo | PCG-21 | Ericsson | CP-40 |  |
| 1053 | 328.4 | Core Network Impacts for A-Interface User Plane over IP | 68d? | 2008-05-30 A | 2008-12-05 A | 100% |  | 2008-05-30 | 2008-12-05 | 68d? |  | finish no earlier than 2008-12-05 | C1 | 544h | 544h | AoIP-CN | Rel-8 | Frederic | PCG-21 | Ericsson | CP-40 |  |
| 1054 | 328.5 | Core Network Impacts for A-Interface User Plane over IP | 68d? | 2008-05-30 A | 2008-12-05 A | 100% |  | 2008-05-30 | 2008-12-05 | 68d? |  | finish no earlier than 2008-12-05 | C3 | 544h | 544h | AoIP-CN | Rel-8 | Gwiho | PCG-21 | Ericsson | CP-40 |  |
| 1055 | 329 | New multicarrier BTS class | 261d? | 2007-08-31 A | 2008-08-29 A | 100% |  | 2007-08-31 | 2008-08-29 | 261d? |  | finish no earlier than 2008-08-29 | G1 | 2088h | 2088h | MCBTS | Rel-8 | Paolo |  | Alcatel-Lucent |  |  |

Notes:
- 1026: Linked to Feature UID_20029 (RANimp)
- 1027: RP#46 completed. Testing for UID_360013 / Text3: 34.108, 34.121-1, 34.121-2, 34.123-1, 34.123-2 / Text5: leif.mattisson@ericsson.com
- 1028: RP#45 completed. Testing for UID_370036 / Text3: 34.108, 34.123-1, 34.123-2, 34.123-3 / Text5: leif.mattisson@ericsson.com
- 1029: RP#49 completed. Testing for Rel-7 UID_340039 Improved L2 support for high data rates and Rel-8 UID_370036 Improved L2 for uplink / Text3: 34.108, 34.123-1, 34.123-2, 34.123-3 / Text5: Xiaozhong Chen (chenxiaozhong@datangmobile.cn)
- 1030: RP#44 completed. Testing for UID_380075 / Text3: 34.108, 34.122, 34.123-1, 34.123-2, 34.123-3 / Text5: ma.zijiang@zte.com.cn
- 1031: RP#48 completed. Testing for UID_400052 / Text3: 34.108, 34.121-1, 34.121-2, 34.123-1, 34.123-2, 34.123-3 / Text5: Shubhang Vora (svora@qualcomm.com)
- 1032: RP#48 completed. Testing for UID_370037 / Text3: 34.108, 34.121-1, 34.121-2, 34.123-1, 34.123-2, 34.123-3 / Text5: jarkko.hellsten@nokia.com
- 1033: RP#46 completed. Testing for Receiver Type3i in 25.101 UE radio Tx and Rx FDD / Text3: 34.108, 34.121-1, 34.121-2 / Text5: Ashok Kumar Narayanaswamy (anarayan@qualcomm.com)
- 1034: RP#49 completed. Testing for UID_380076 / Text3: 34.108, 34.123-1, 34.123-2, 34.123-3 / Text5: Xiaozhong Chen (chenxiaozhong@datangmobile.cn)
- 1035: RP#49 completed. Testing for UID_390028 / Text3: 34.108, 34.123-1, 34.123-2, 34.123-3 / Text5: huang.he4@zte.com.cn
- 1036: PR#48 completed. Testing for UID_400050 / Text3: 34.108, 34.122, 34.123-1, 34.123-2, 34.123-3 / Text5: huang.chun2@zte.com.cn
- 1037: RP#47 completed. Testing for UID_390030 / Text3: 34.108, 34.121-1, 34.121-2, 34.123-1, 34.123-2, 34.123-3 / Text5: Shubhang Vora (svora@qualcomm.com)
- 1038: RP#42 completed. WID updated RP-070493=>RP-081124 (changed WI title "MBSFN Downlink Optimized Broadcast (DOB) 3.84 Mcps TDD" => "3.84Mcps TDD MBSFN Integrated Mobile Broadcast"). / Text3: 25.102, 25.105, 25.123, 25.201, 25.221, 25.222, 25.223, 25.224, 25.304, 25.306, 25.331, 25.346, 25.402, 25.433 / Text5: Lars.Lindbom@ericsson.com
- 1039: RP#47 completed. Testing for Rel-8 MBSFN-DOB UID_360008 / Text3: 34.108, 34.122, 34.123-1, 34.123-2, 34.123-3 / Text5: Phil Young (pyoung@ipwireless.com)
- 1040: GP#41 completed (MS conformance testing open) / Text3: 44.018, 44.060, 45.002, 45.008, 45.010, 48.008, 48.018, 51.010 / Text5: sergio.parolari@nsn.com, vlora.rexhepi@nokia.com
- 1041: GP#41 completed / Text3: 43.055, 43.129, 43.246, 45.002, 45.008, 45.010 / Text5: sergio.parolari@nsn.com, vlora.rexhepi@nokia.com
- 1042: GP#41 completed / Text3: 44.018, 44.060, 48.008, 48.018 / Text5: sergio.parolari@nsn.com, vlora.rexhepi@nokia.com
- 1043: - / Text3: 24.008 / Text5: sergio.parolari@nsn.com, vlora.rexhepi@nokia.com
- 1044: GP#48 completion 11/10=>03/11 / Text3: 51.010 / Text5: sergio.parolari@nsn.com, vlora.rexhepi@nokia.com
- 1045: GP#36 completed U-TDOA (Uplink Time Difference of Arrival) / Text3: 43.059, 45.008, 48.071 / Text5: Terry Brooks (terri.brooks@trueposition.com)
- 1046: GP#37 completed. GP#43 completed Testing / Text5: mohammed.versi@t-mobile.com
- 1047: GP#37 completed / Text3: 43.318, 44.318 / Text5: mohammed.versi@t-mobile.com
- 1048: GP#43 completed / Text3: 51.010 / Text5: mohammed.versi@t-mobile.com
- 1049: GP#40/TSG#42 completed . Triggered by TR 43.903 Study on A-interface over IP (AINTIP) UID_50589. / Text5: wangshuaiyu@chinamobile.com, paul.schliwa-bertling@ericsson.com
- 1050: GP#40 completed. GP#39 updated WID GP-080901=>GP-081362. / Text3: 48.001, 48.002, 48.008, 48.020, 49.008, 48.103 / Text5: wangshuaiyu@chinamobile.com, paul.schliwa-bertling@ericsson.com
- 1051: SP#42 completed / Text3: 26.102, 26.103, 26.202 / Text5: Karl.Hellwig@Ericsson.com
- 1052: CP#42 completed. Updated WID CP-080278=>CP-080722 / Text3: 23.205, 23.153, 23.231, 29.232 / Text5: philip.hodges@ericsson.com
- 1053: CP#42 completed. Updated WID CP-080278=>CP-080722 / Text3: 23.009 / Text5: philip.hodges@ericsson.com
- 1054: CP#42 completed. Updated WID CP-080278=>CP-080722 / Text3: 29.007 / Text5: philip.hodges@ericsson.com
- 1055: GP#39 completed / Text3: 45.005, 45.050, 51.021 / Text5: thomas.bitzer@alcatel-lucent.de

| ID | WBS | Task | Type | Duration | Start | Finish | Complete | Baseline start | Baseline finish | Baseline duration | Constraint | Resources | Work | Actual work | Text1 | Text4 | Text6 | Text8 | Text2 | Text3 | Text7 | Text11 | Text12 | Text9 |
| --- | --- | --- | --- | --- | --- | --- | --- | --- | --- | --- | --- | --- | --- | --- | --- | --- | --- | --- | --- | --- | --- | --- | --- | --- |
| 1056 | 330 | **Support for Additional Navigation Satellite Systems (ANSS) for LCS** |  | 150d? | 2008-05-16 A | 2008-12-11 A | 100% | 2008-05-16 | 2008-12-11 | 150d? |  | S1,G2 | 3384h | 3384h | ANSS | Qualcomm | Rel-8 | Paolo |  |  |  |  |  |  |
| 1057 | 330.1 | Stage 1 for ANSS for LCS |  | 1d? | 2008-12-11 A | 2008-12-11 A | 100% | 2008-12-11 | 2008-12-11 | 1d? | start no earlier than 2008-12-11 | S1 | 8h | 8h | ANSS |  | Rel-8 | Alain | PCG-22 | 22.071 | SP-42 |  |  |  |
| 1058 | 330.2 | Support for Additional Navigation Satellite Systems (ANSS) for LCS |  | 136d? | 2008-05-16 A | 2008-11-21 A | 100% | 2008-05-16 | 2008-11-21 | 136d? | start no earlier than 2008-05-16 | G2 | 1088h | 1088h | ANSS | Qualcomm | Rel-8 | Paolo |  | 43.059, 44.031, 49.031, 44.071, 48.031, 51.010 |  |  |  |  |
| 1059 | 330.3 | Support for Additional Navigation Satellite Systems (ANSS) for LCS |  | 136d? | 2008-05-30 A | 2008-12-05 A | 100% | 2008-05-30 | 2008-12-05 | 136d? | finish no earlier than 2008-12-08 | R2 | 1088h | 1088h | RANimp-ANSS | Qualcomm | Rel-8 | Joern | PCG-21 | 25.305, 25.306, 25.331, 25.413, 25.423, 25.433, 25.453 | RP-40 | RP-080813 |  |  |
| 1060 | 331 | **Conformance testing for the Latency Reductions feature** |  | 532d? | 2008-02-22 A | 2010-03-05 A | 100% | 2008-02-22 | 2010-03-05 | 532d? |  | G1, G3new | 10592h | 10592h | CTLATRED | Ericsson | Rel-8 | Paolo | PCG-21 |  |  |  |  |  |
| 1061 | 331.1 | MS conformance testing for the Latency Reductions feature |  | 532d? | 2008-02-22 A | 2010-03-05 A | 100% | 2008-02-22 | 2010-03-05 | 532d? | finish no earlier than 2010-03-05 | G3new | 4248h | 4248h | CTLATRED-MStest | Ericsson | Rel-8 | Ingbert | PCG-21 | 51.010 |  |  |  |  |
| 1062 | 331.2 | BTS conformance testing for the Latency Reductions feature |  | 261d? | 2008-02-22 A | 2009-02-20 A | 100% | 2008-02-22 | 2009-02-20 | 261d? | finish no earlier than 2009-02-20 | G1 | 2088h | 2088h | CTLATRED-BTStest | Ericsson | Rel-8 | Paolo | PCG-21 | 51.021 |  |  |  |  |
| 1063 | 332 | MS conformance testing of changes introduced by WI "Support of Packet-switched Handover for GERAN A/Gb mode" |  | 196d? | 2008-02-22 A | 2008-11-21 A | 100% | 2008-02-22 | 2008-11-21 | 196d? | finish no earlier than 2008-11-21 | G3new | 1568h | 1568h | PSHCT-MStest | Rohde & Schwarz | Rel-8 | Ingbert | PCG-21 | 51.010 |  |  |  |  |
| 1064 | 333 | (Small) Technical Enhancements and Improvements for Rel-8 |  | 509d? | 2007-01-01 A | 2008-12-11 A | 100% | 2007-01-01 | 2008-12-11 | 509d? | finish no earlier than 2008-12-11 | All | 4072h | 4072h | TEI8 |  | Rel-8 | All |  |  |  |  |  |  |
| 1065 | 334 | Test - (Small) Technical Enhancements and Improvements for Rel-8 |  | 672d? | 2007-03-07 A | 2010-12-24 A | 100% | 2007-03-07 | 2010-12-24 | 672d? | finish no earlier than 2010-12-24 | R5,G3new | 5376h | 5376h | TEI8_Test |  | Rel-8 | Ingbert | PCG-21 |  | RP-40 |  |  |  |
| 1066 | 335 | **Deleted - All-IP Network** |  | 448d? | 2004-06-28 A | 2006-03-15 A | 100% | 2004-06-28 | 2006-03-15 | 448d? |  | S1 | 7168h | 7168h | AIPN | NTT DoCoMo | Rel-8 | Alain |  |  |  |  | SP-38 |  |
| 1067 | 335.1 | Deleted - Stage 1 |  | 448d? | 2004-06-28 A | 2006-03-15 A | 100% | 2004-06-28 | 2006-03-15 | 448d? | finish no earlier than 2006-03-15 | S1 | 3584h | 3584h | AIPN | NTT DoCoMo | Rel-8 | Alain |  | 22.258 |  |  | SP-38 |  |
| 1068 | 336 | Deleted - was Rel7 - LCS for 3GPP Interworking WLAN | milestone | 0d? | 2007-09-28 A | 2007-09-28 A | 100% | 2007-09-28 | 2007-09-28 | 0d? | start no earlier than 2007-09-28 | S2 |  |  | LCS4_IWLAN | LG Electronics | Rel-8 | Maurice |  | 23.234, 23.271, 23.167 |  |  | SP-35 |  |
| 1069 | 337 | Deleted - never approved- FBI Phase 2 | milestone | 0d | 2007-09-28 A | 2007-09-28 A | 100% | 2007-09-28 | 2007-09-28 | 0d | start no earlier than 2007-09-28 | S2 |  |  | FBI2 | Nokia Siemens Networks | Rel-8 | Maurice |  |  |  |  | SP-38 |  |
| 1070 | 338 | Deleted -Enhancements to BS30 Bearer service for Videotelephony | milestone | 0d? | 2007-03-15 A | 2007-03-15 A | 100% | 2007-03-15 | 2007-03-15 | 0d? | finish no earlier than 2007-03-15 | S1 |  |  | BS30 |  | Rel-8 | Alain |  | 22.002, 22.004, 22.101, 22.105, 24.008 |  |  | SP-38 |  |
| 1071 | 339 | Deleted - IMS Enhancements Rel-8 |  | 75d? | 2007-09-03 A | 2007-12-14 A | 100% | 2007-09-03 | 2007-12-14 | 75d? |  | S1 | 600h | 600h | IMS8 | Telecom Italia | Rel-8 | Alain |  |  | SP-37 |  | SP-38 |  |
| 1072 | 340 | **Deleted - Contact Manager Conformance Test specifications** |  | 471d? | 2008-06-02 A | 2010-03-19 A | 100% | 2008-06-02 | 2010-03-19 | 471d? |  | C6 | 11304h | 11304h | eUPHBOOK-Test | Comprion, Gemalto | Rel-8 | Xavier | PCG-21 |  | CP-40 |  | CP-47 | PCG-24 |
| 1073 | 340.1 | Deleted - Contact Manager for 3GPP UICC applications test specifications |  | 471d? | 2008-06-02 A | 2010-03-19 A | 100% | 2008-06-02 | 2010-03-19 | 471d? | finish no earlier than 2010-03-19 | C6 | 3768h | 3768h | eUPHBOOK-Test | Comprion | Rel-8 | Xavier | PCG-21 | 31.320 (external interface for communication with the ME) | CP-40 |  | CP-47 | PCG-24 |
| 1074 | 340.2 | Deleted - Contact Manager API for Java™ Card test specification |  | 471d? | 2008-06-02 A | 2010-03-19 A | 100% | 2008-06-02 | 2010-03-19 | 471d? | finish no earlier than 2010-03-19 | C6 | 3768h | 3768h | eUPHBOOK-Test | Gemalto | Rel-8 | Xavier | PCG-21 | 31.321 (internal interface (API)) | CP-40 |  | CP-47 | PCG-24 |
| 1075 | 341 | Deleted - MS conformance testing of Support of Conversational Services in A/Gb mode via the PS domain |  | 401d? | 2008-02-25 A | 2009-09-04 A | 100% | 2008-02-25 | 2009-09-04 | 401d? | finish no earlier than 2009-09-04 | G3new | 3208h | 3208h | SCSAGBCT-MStest | Nokia | Rel-8 | Ingbert | PCG-21 | 51.010 |  |  | GP-43 | PCG-23 |
| 1076 | 342 | Release 8 Studies |  | 1332d? | 2005-10-07 A | 2010-11-12 A | 100% | 2005-10-07 | 2010-11-12 | 1332d? | start no earlier than 2000-01-03 | CP,GP,RP,SP | 10656h | 10656h |  |  | Rel-8 | All |  |  |  |  |  |  |
| 1077 | 343 | Study on Customised Alerting Tone (CAT) Requirements |  | 245d? | 2005-10-07 A | 2006-09-14 A | 100% | 2005-10-07 | 2006-09-14 | 245d? | start no earlier than 2005-10-07 | S1 | 1960h | 1960h | FS_CAT | China Mobile | Rel-8 | Alain |  | 22.982 |  |  |  |  |
| 1078 | 344 | Study on Facilitating Machine to Machine Communication in GSM and UMTS (M2M) |  | 350d? | 2005-11-04 A | 2007-03-08 A | 100% | 2005-11-04 | 2007-03-08 | 350d? | finish no earlier than 2006-06-16 | S1 | 2800h | 2800h | FS_M2M | Siemens | Rel-8 | Alain |  | 22.868 |  |  |  |  |
| 1079 | 345 | Study on Network Composition |  | 526d? | 2005-12-07 A | 2007-12-12 A | 100% | 2005-12-07 | 2007-12-12 | 526d? | finish no earlier than 2006-09-27 | S1 | 4208h | 4208h | FS_NetComp | Nokia Siemens Networks | Rel-8 | Alain |  | 22.980 |  |  |  |  |
| 1080 | 346 | Study on Requirements of IMS Multimedia Conferencing |  | 330d? | 2006-06-08 A | 2007-09-12 A | 100% | 2006-06-08 | 2007-09-12 | 330d? | finish no earlier than 2007-03-21 | S1 | 2640h | 2640h | FS_IMSconf | China Mobile | Rel-8 | Alain |  | 22.948 |  |  |  |  |
| 1081 | 347 | Study on support of a Public Warning System |  | 140d? | 2007-09-03 A | 2008-03-14 A | 100% | 2007-09-03 | 2008-03-14 | 140d? |  | S1 | 1120h | 1120h | FS_PWS | T-Mobile | Rel-8 | Alain |  | 22.968 |  |  |  |  |
| 1082 | 348 | Study on Paging Permission with Access Control |  | 256d? | 2006-09-28 A | 2007-09-20 A | 100% | 2006-09-28 | 2007-09-20 | 256d? | finish no earlier than 2007-09-20 | S1 | 2048h | 2048h | FS_PPAC | NTT DoCoMo | Rel-8 | Alain |  | 22.908 |  |  |  |  |
| 1083 | 349 | Study on Non-3GPP access Network Selection Principles (NSP) |  | 392d? | 2006-12-06 A | 2008-06-05 A | 100% | 2006-12-06 | 2008-06-05 | 392d? | finish no earlier than 2007-11-19 | S1 | 3136h | 3136h | FS_N3GtoNSP | Telefonica O2 | Rel-8 | Alain |  | 22.912 |  |  |  |  |
| 1084 | 350 | Study on Value Added Services for Short Message Service |  | 263d? | 2006-12-06 A | 2007-12-07 A | 100% | 2006-12-06 | 2007-12-07 | 263d? | finish no earlier than 2007-12-07 | S1 | 2104h | 2104h | FS_VAS4SMS | China Mobile | Rel-8 | Alain |  | 22.942 |  |  |  |  |
| 1085 | 351 | Study on Service continuity between mobile and WLAN networks |  | 262d? | 2006-12-06 A | 2007-12-06 A | 100% | 2006-12-06 | 2007-12-06 | 262d? | finish no earlier than 2008-12-25 | S1 | 2096h | 2096h | FS_SMLSWLAN | NEC | Rel-8 | Alain |  | 22.937 |  |  |  |  |
| 1086 | 352 | Study on Services Alignment and Migration |  | 331d? | 2006-12-06 A | 2008-03-12 A | 100% | 2006-12-06 | 2008-03-12 | 331d? | finish no earlier than 2007-09-20 | S1 | 2648h | 2648h | FS_ServAl | Telefónica O2 Europe | Rel-8 | Alain |  | 22.983 | SP-37 |  |  |  |

Notes:
- 1056: GP#40 completed. Align with RANimp-ANSS ongoing work item. GP#40 WID updated GP-080776=>GP-081784 (Conformance testing moved to A-GNSS WID) / Text5: Mungal Dhanda
- 1057: SP#42 completed by 22.071 CR0077
- 1058: GP#40 completed. Align with RANimp-ANSS ongoing work item. GP#40 WID updated GP-080776=>GP-081784 (Conformance testing moved to A-GNSS WID) / Text5: Mungal Dhanda
- 1059: SR in RP-080813. RP#42 WI closed at 95%. GERAN leading the work / considers performance requirements for Rel-9 / Text5: Etienne Chaponniere (echaponn@qualcomm.com)
- 1060: GP#45 completed / Text5: mats.y.samuelsson@ericsson.com, hakan.e.grunditz@ericsson.com
- 1061: GP#45 completed / Text5: hakan.e.grunditz@ericsson.com
- 1062: GP#41 completed / Text5: mats.y.samuelsson@ericsson.com
- 1063: GP#40 completed / Text5: Franz.Segerer@ROHDE-SCHWARZ.COM
- 1064: SP#42 completed
- 1065: -
- 1066: SP#38 stopped. 25/07/08 Moved UID_31059 Study on All-IP Network (FS_AIPN/was AIPFS ) to Rel-7 out of the stopped Rel-8 Feature UID_31067 Deleted - All-IP Network (AIPN) / Text5: c.masyu@nttdocomo.co.jp
- 1067: 22.258 withdrawn, superseded by 22.278 (UID 320022). SP#38 stopped / Text5: c.masyu@nttdocomo.co.jp
- 1068: SP-35 stopped / Text5: dhshim@lge.com
- 1069: SP#38 stopped
- 1070: SP#38 stopped (no support) / Text5: andre.jarvis@three.co.uk
- 1071: SP#38 stopped
- 1072: CP#47 work stopped/abandoned / Text5: Udo Willenbrink, Jacques Seif
- 1073: CP#47 work stopped/abandoned / Text5: Udo Willenbrink (uwillenbrink@comprion.com )
- 1074: CP#47 work stopped/abandoned / Text5: jacques.seif@gemalto.com
- 1075: GP#43 work stopped/abandoned (completion 0%) / Text5: arsi.heino@nokia.com
- 1076: -
- 1077: Spin-off Rel-8 Feature Customized Alerting Tone (CAT) Service UID_340029 / Text5: Qing Huang (huangqing@chinamobile.com)
- 1078: SP#35 completed. Spin-off SA3 Study on Security Aspects of Remote Provisioning and Change of Subscription for M2M (UID_370053). SP#40 Spin-off new Feature UID_410030 (NIMTC) / Text5: Juergen Merkel
- 1079: SP#38 completed / Text5: Joerg Swetina (joerg.swetina@nw.neclab.eu)
- 1080: SP#37 completed. Spin-off New Feature UID_370026 Value-Added Services for Short Message Service (VAS4SMS) / Text5: Qing Huang (huangqing@chinamobile.com)
- 1081: SP#39 completed. Spin-off Rel-9 Feature UID_380057 (PWS) / Text5: mark.younge@t-mobile.com
- 1082: SP#37 completed. Spin-off new Feature UID_370084 (PPACR) / Text5: Katsuhiro NOGUCHI (noguchi@nttdocomo.co.jp)
- 1083: SP#38 completed. Spin-off New Feature UID_380062 (N3GTONSP). SP#40 WID updated SP-060930=>SP-080318. TR re-approved with new # 22.812=>22.912 / Text5: chris.friel@o2.com
- 1084: SP#38 completed. Spin-off New Feature UID_370026 (VAS4SM) / Text5: Qing Huang (huangqing@chinamobile.com)
- 1085: SP#38 completed / Text5: joerg.swetina@neclab.eu
- 1086: SP#39 completed. Spin-off Rel-9 Feature UID_330017 Services Alignment and Migration (ServAl) / Text5: chris.friel@o2.com

| ID | WBS | Task | Duration | Start | Finish | Complete | Baseline start | Baseline finish | Baseline duration | Constraint | Resources | Work | Actual work | Text1 | Text4 | Text5 | Text6 | Text8 | Text3 | Text2 | Text7 | Text11 | Text9 | Text12 |
| --- | --- | --- | --- | --- | --- | --- | --- | --- | --- | --- | --- | --- | --- | --- | --- | --- | --- | --- | --- | --- | --- | --- | --- | --- |
| 1087 | 353 | **Study on 3GPP System Architecture Evolution** | 1115d? | 2004-12-03 A | 2009-03-12 A | 100% | 2004-12-03 | 2009-03-12 | 1115d? |  | S2,S3 | 23456h | 23456h | FS_SAE | Vodafone | Chris Pudney | Rel-8 | Maurice |  |  |  |  |  |  |
| 1088 | 353.1 | Stage 2 Interim conclusion for RAN Work to start | 990d? | 2004-12-03 A | 2008-09-18 A | 100% | 2004-12-03 | 2008-09-18 | 990d? | finish no earlier than 2005-09-23 | S2 | 7920h | 7920h | FS_SAE | Vodafone | Chris Pudney | Rel-8 | Maurice | 23.882 |  |  |  |  |  |
| 1089 | 353.2 | Stage 2 study on 3GPP architectural development | 704d? | 2006-01-09 A | 2008-09-18 A | 100% | 2006-01-09 | 2008-09-18 | 704d? | finish no earlier than 2007-09-28 | S2 | 5632h | 5632h | FS_SAE | Vodafone | Chris Pudney | Rel-8 | Maurice | 23.882 |  |  |  |  |  |
| 1090 | 353.3 | Security study for Inter-access mobility between non-3GPP and 3GPP system | 334d? | 2007-09-03 A | 2009-03-12 A | 100% | 2007-09-03 | 2009-03-12 | 334d? | finish no earlier than 2009-03-12 | S3 | 2672h | 2672h | FS_SAE | Nokia | dajiang.zhang@nokia.com | Rel-8 | Dionisio | 33.821, 33.822 |  |  |  |  |  |
| 1091 | 354 | Study on Stage 2 aspects of IMS Service Brokering | 589d? | 2006-06-19 A | 2008-09-18 A | 100% | 2006-06-19 | 2008-09-18 | 589d? | finish no earlier than 2008-09-18 | S2 | 4712h | 4712h | FS_ISB_ST2 | Telcordia | raquel@research.telcordia.com | Rel-8 | Maurice | 23.810 |  |  |  |  |  |
| 1092 | 355 | Study on IMS utilizing multicast bearer services | 447d? | 2006-03-22 A | 2007-12-06 A | 100% | 2006-03-22 | 2007-12-06 | 447d? | finish no earlier than 2007-12-03 | S2 | 3576h | 3576h | FS_MLTICAST-IMS | Nokia Siemens Networks |  | Rel-8 | Maurice | 23.847 |  |  |  |  |  |
| 1093 | 356 | Study on Multimedia Session Continuity | 291d? | 2007-04-26 A | 2008-06-05 A | 100% | 2007-04-26 | 2008-06-05 | 291d? | finish no earlier than 2008-06-05 | S2 | 2328h | 2328h | FS_MMSC | LG Electronics |  | Rel-8 | Maurice | 23.893 |  |  |  |  |  |
| 1094 | 357 | **Study on centralized IMS service control** | 363d? | 2006-10-23 A | 2008-03-12 A | 100% | 2006-10-23 | 2008-03-12 | 363d? |  | S2,S1 | 7952h | 7952h | FS_ICS | Ericsson | peter.bleckert@ericsson.com | Rel-8 | Alain |  | PCG-21 | SP-38 |  |  |  |
| 1095 | 357.1 | Study on centralized IMS services requirements | 268d? | 2007-03-05 A | 2008-03-12 A | 100% | 2007-03-05 | 2008-03-12 | 268d? | start no earlier than 2007-03-05 | S1 | 2144h | 2144h | FS_ICS-S1 | NEC | joerg.swetina@neclab.eu | Rel-8 | Alain | 22.892 |  | SP-37 |  |  |  |
| 1096 | 357.2 | Study on centralized IMS services control | 363d? | 2006-10-23 A | 2008-03-12 A | 100% | 2006-10-23 | 2008-03-12 | 363d? | finish no earlier than 2008-02-21 | S2 | 2904h | 2904h | FS_IMS_CSC | Alcatel-Lucent | Andy Bennett (andybennett@alcatel-lucent.com) | Rel-8 | Maurice | 23.892 |  |  |  |  |  |
| 1097 | 358 | Study on Architecture of IMS based Customized Alerting Tone (CAT) | 208d? | 2007-12-04 A | 2008-09-18 A | 100% | 2007-12-04 | 2008-09-18 | 208d? | finish no earlier than 2008-09-08 | S2 | 1664h | 1664h | FS_CAT-St2 | China Mobile | WANG, Jing (wangjing@chinamobilecom) | Rel-8 | Maurice | 23.872 | PCG-21 | SP-38 |  |  |  |
| 1098 | 359 | Study on Home (e)NodeB Security | 321d? | 2007-12-20 A | 2009-03-12 A | 100% | 2007-12-20 | 2009-03-12 | 321d? | finish no earlier than 2009-03-10 | S3 | 2568h | 2568h | FS_HNB_Sec | Huawei | yangyanmei@huawei.com | Rel-8 | Dionisio | 33.820 | PCG-21 | SP-38 |  |  |  |
| 1099 | 360 | Study on Transferring of emergency call data – in-band modem solution | 265d? | 2006-12-07 A | 2007-12-12 A | 100% | 2006-12-07 | 2007-12-12 | 265d? | finish no earlier than 2008-09-18 | S4 | 2120h | 2120h | eCALLIBMS | Airbiquity | lhong@airbiquity.com | Rel-8 | Paolo | 26.967 |  |  |  |  |  |
| 1100 | 361 | Study on Element Operations Systems Function (EOSF) definition | 266d? | 2007-06-07 A | 2008-06-12 A | 100% | 2007-06-07 | 2008-06-12 | 266d? | finish no earlier than 2008-12-11 | S5 | 2128h | 2128h | OAM7-NIM- EOSF | China Mobile | Li Jian (lijian@chinamobile.com) | Rel-8 | Dionisio | 32.819 |  |  |  |  |  |
| 1101 | 362 | Study on SA5 MTOSI XML Harmonization | 351d? | 2006-05-10 A | 2007-09-12 A | 100% | 2006-05-10 | 2007-09-12 | 351d? | finish no earlier than 2007-12-14 | S5 | 2808h | 2808h | OAM8-NIM-XML | Nortel | jduguay@nortel.com | Rel-8 | Dionisio | 32.818 |  |  |  |  |  |
| 1102 | 363 | Study on Common Profile Storage (CPS) Framework of User Data for network services and management | 244d? | 2006-07-03 A | 2007-06-07 A | 100% | 2006-07-03 | 2007-06-07 | 244d? | finish no earlier than 2007-06-07 | S5 | 1952h | 1952h | OAM7-CPS | T-Mobile | istvan.aba@t-mobile.at | Rel-8 | Dionisio | 32.808 |  |  |  |  |  |
| 1103 | 364 | Study on Management for LTE and SAE | 526d? | 2006-12-07 A | 2008-12-11 A | 100% | 2006-12-07 | 2008-12-11 | 526d? | finish no earlier than 2008-12-11 | S5 | 4208h | 4208h | FS_OAM_LTE_SAE | Ericsson | robert.petersen@ericsson.com | Rel-8 | Dionisio | 32.816 |  |  |  |  |  |
| 1104 | 365 | Study on Charging Aspects of 3GPP System Evolution | 179d? | 2007-04-02 A | 2007-12-06 A | 100% | 2007-04-02 | 2007-12-06 | 179d? | finish no earlier than 2007-12-06 | S5 | 1432h | 1432h | FS_SAEcharg | Nokia Siemens Networks | Gerald.Goermer@nsn.com | Rel-8 | Dionisio | 32.820 |  |  |  |  |  |
| 1105 | 366 | Study on AS-MRFC media server control protocol | 583d? | 2006-03-22 A | 2008-06-13 A | 100% | 2006-03-22 | 2008-06-13 | 583d? | finish no earlier than 2008-06-13 | C1 | 4664h | 4664h | MRFC | Hewlett-Packard | mark.syrett@hp.com | Rel-8 | Frederic | 24.880 |  |  |  |  |  |
| 1106 | 367 | Study on IMS Restoration Procedures | 310d? | 2007-03-26 A | 2008-05-30 A | 100% | 2007-03-26 | 2008-05-30 | 310d? | finish no earlier than 2008-05-30 | C4 | 2480h | 2480h | FS_IMS_RP | Ericsson | german.blanco@ericsson.com | Rel-8 | Kimmo | 23.820 |  |  |  |  |  |
| 1107 | 368 | Study on IMS Application Server Service Data Descriptions for AS interoperability | 261d? | 2007-09-14 A | 2008-09-12 A | 100% | 2007-09-14 | 2008-09-12 | 261d? | finish no earlier than 2008-09-12 | C4 | 2088h | 2088h | FS_IMS_ASIO | Alcatel-Lucent | Jean-Jacques Trottin | Rel-8 | Kimmo | 29.864 |  |  |  |  |  |
| 1108 | 369 | Study on Customized Alerting Tone (CAT) solution for voice and video call in CS domain | 261d? | 2007-09-14 A | 2008-09-12 A | 100% | 2007-09-14 | 2008-09-12 | 261d? |  | C4 | 626.4h | 626.4h | FS_CAT_VVC_CS | China Mobile | zhanghao@chinamobile.com | Rel-8 | Kimmo | 29.882 |  |  |  |  |  |
| 1109 | 370 | Study on InterWorking Function between MAP based and Diameter based interfaces | 266d? | 2007-11-30 A | 2008-12-05 A | 100% | 2007-11-30 | 2008-12-05 | 266d? | finish no earlier than 2008-12-05 | C4 | 2128h | 2128h | FS_MAP2Diam | Huawei | liming49985@huawei.com | Rel-8 | Kimmo | 29.805 | PCG-21 | CP-38 |  |  |  |
| 1110 | 371 | Study on Scope of future HSPA Evolution for 1.28 Mcps TDD | 186d? | 2007-09-14 A | 2008-05-30 A | 100% | 2007-09-14 | 2008-05-30 | 186d? | finish no earlier than 2008-05-30 | R1 | 1488h | 1488h | FS_RAN-LCRTDDHSPAEvo | RITT | Xu Fei | Rel-8 | Patrick | 25.824 |  | RP-37 | RP-080290 |  |  |
| 1111 | 372 | Study on Synchronized E-DCH for UTRA FDD | 126d? | 2007-09-14 A | 2008-03-07 A | 100% | 2007-09-14 | 2008-03-07 | 126d? | finish no earlier than 2008-03-14 | R1 | 1008h | 1008h | FS_RAN-UplinkSync | Nokia Siemens Networks | Karri.Ranta-aho@nsn.com | Rel-8 | Patrick | 25.823 |  | RP-37 | RP-080068 |  |  |
| 1112 | 373 | Study on Improved network controlled mobility between LTE and 3GPP2/mobile WiMAX radio technologies | 131d? | 2007-06-04 A | 2007-12-03 A | 100% | 2007-06-04 | 2007-12-03 | 131d? | finish no earlier than 2007-12-03 | R4 | 1048h | 1048h | FS_RAN-LTEmob | Motorola | hao.bi@Motorola.com | Rel-8 | Issam | 36.938 |  |  | RP-070827 |  |  |
| 1113 | 374 | Study on 3G Home NodeB/eNodeB | 325d? | 2007-03-05 A | 2008-05-30 A | 100% | 2007-03-05 | 2008-05-30 | 325d? | finish no earlier than 2008-05-30 | R4 | 2600h | 2600h | FS_RAN-HNBeNB | Motorola | howard.thomas@motorola.com | Rel-8 | Issam | 25.820 |  |  | RP-080289 |  |  |
| 1114 | 375 | Study on A-interface over IP | 126d? | 2007-08-31 A | 2008-02-22 A | 100% | 2007-08-31 | 2008-02-22 | 126d? | finish no earlier than 2008-02-22 | GP | 1008h | 1008h | AINTIP | China Mobile, Ericsson | paul.schliwa-bertling@ericsson.com | Rel-8 | Paolo | 43.903 |  |  |  |  |  |
| 1115 | 376 | Study on Multi-User Reusing-One-Slot | 782d? | 2007-11-16 A | 2010-11-12 A | 100% | 2007-11-16 | 2010-11-12 | 782d? | finish no earlier than 2010-11-12 | GP | 6248h | 6248h | MUROS | Nokia Siemens Networks | juergen.hofmann@nsn.com | Rel-8 | Paolo | 45.914 |  |  |  |  |  |
| 1116 | 377 | Study on Optimized Transmit Pulse Shape for Downlink EGPRS2-B | 657d? | 2007-11-16 A | 2010-05-21 A | 100% | 2007-11-16 | 2010-05-21 | 657d? | finish no earlier than 2010-05-27 | G1 | 5248.44h | 5248.44h | WIDER | RIM, Nokia Siemens Networks | jdwyer@RIM.COM and eddie.riddington@nsn.com | Rel-8 | Paolo | 45.913 |  |  |  |  |  |
| 1117 | 378 | Deleted - Study on Mobility between 3GPP-WLAN Interworking and 3GPP Systems | 393d? | 2007-03-20 A | 2008-09-18 A | 100% | 2007-03-20 | 2008-09-18 | 393d? | finish no earlier than 2008-09-18 | S2 | 3144h | 3144h | FS_SM3GWLAN | Orange |  | Rel-8 | Maurice | withdrawn 23.827 |  |  |  | PCG-21 | SP-41 |
| 1118 | 379 | Deleted - equals 340035 -FS on Service continuity between mobile and WLAN networks | 75d? | 2007-09-03 A | 2007-12-14 A | 100% | 2007-09-03 | 2007-12-14 | 75d? | finish no earlier than 2007-12-14 | S1 | 600h | 600h | FSSCMobToW | BT | mike.meyerstein@bt.com | Rel-8 | Alain | 22.937 |  | SP-37 |  | PCG-21 | SP-39 |
| 1119 | 380 | Deleted - Study on Evaluation of LCS Control Plane Solution for EPS | 100d? | 2008-01-14 A | 2008-05-30 A | 100% | 2008-01-14 | 2008-05-30 | 100d? | finish no earlier than 2009-03-20 | S2 | 800h | 800h | FS_LCS_EPS | SiRF |  | Rel-8 | Maurice | 23.891 |  | SP-38 |  | PCG-21 | SP-40 |
| 1120 | 381 | Deleted - Study on HS-PDSCH serving cell change enhancements | 60d? | 2007-12-17 A | 2008-03-07 A | 100% | 2007-12-17 | 2008-03-07 | 60d? | finish no earlier than 2008-06-12 | R4 | 480h | 480h | FS_RAN-HSPDSCH | Qualcomm |  | Rel-8 | Issam | none | PCG-21 | RP-38 | RP-080070 | PCG-21 | RP-39 |
| 1121 | 382 | Deleted - Study on Dual-Cell HSDPA operation | 261d? | 2007-08-15 A | 2009-03-06 A | 100% | 2007-08-15 | 2009-03-06 | 261d? | finish no earlier than 2009-03-06 | R1 | 2088h | 2088h | FS_RAN-DCHS | Qualcomm | Josef Blanz | Rel-8 | Patrick | withdrawn 25.825 v100 | PCG-21 | RP-39 | RP-090066 | PCG-22 | RP-43 |
| 1122 | 383 | Release 7 Features | 679d? | 2005-05-02 A | 2007-12-06 A | 100% | 2005-05-02 | 2007-12-06 | 679d? | start no earlier than 2000-01-01 | CP,GP,RP,SP | 5432h | 5432h |  |  |  | Rel-7 | All |  |  |  |  |  |  |

Notes:
- 1087: SP#43 completed
- 1088: SP#41 completed
- 1089: SP#41 completed
- 1090: SP#43 completed
- 1091: SP#41 completed. No spin-off activity proposed. [Note: IMS Service Brokering enhancements UID_31088 moved back from R8 to R7 to give a home to 22228CR0036_(Rel-7)_S1-051232. Hence, Rel-7 ISB has Stage 1 only (and is misaligned with Rel-7 Stages 2/3.]
- 1092: SP#38 completed
- 1093: SP#40 completed
- 1094: SP#39 completed
- 1095: SP#39 completed
- 1096: SP#39 completed
- 1097: SP#41 completed as Rel-8
- 1098: SP#43 completed. Linked to RAN4 Study on 3G Home NodeB/eNodeB (UID_350039) and to SA5 Study on Self-Organizing Networks (SON) related OAM interfaces for Home NodeB (UID_360007)
- 1099: SP#38 completed. Spin-off WID UID_34042 (eCall_Phase2)
- 1100: SP#40 completed. SID updated SP-050608=>SP-070307
- 1101: SP#37 completed. SID updated SP-050295=>SP-070305
- 1102: SP#36 completed. Spin-off New Feature UID_400034 User Data Convergence (UDC)
- 1103: SP#42 completed
- 1104: SP#38 completed
- 1105: CP#40 completed. Spin-off New Feature UID_380035 (MRFC_TS)
- 1106: CP#40 completed. Spin-off WID UID_400012 (IMS_RP)
- 1107: CP#41 completed. Linked to SA5 Study on Common Profile Storage framework UID_320006. Spin-off WID UID_410003 (IMS_ASIO)
- 1108: CP#41 completed. Spin-off WID under Feature CAT UID_340029
- 1109: CP#42 completed. Spin-off implementation Building Block UID_410007 (MAP2Diam) under the SAES Feature UID_320005
- 1110: RP#40 completed
- 1111: RP#39 completed
- 1112: RP#38 completed
- 1113: RP#40 completed
- 1114: GP#37 completed. Spin-off implementation Feature AoIP (A-interface over IP) UID_50591
- 1115: GP#48 completed as Rel-8. Spin-off implementation WI UID_420002 VAMOS (Voice services over Adaptive Multi-user channels on One Slot)
- 1116: GP#46 completed
- 1117: SP#41 stopped. Draft TR 23.827 content implemented in TS 23.327.
- 1118: SP#39 stopped
- 1119: SP#40 spin-off Feature UID_400038 (LCS_CPS_EPS). SP#40 FS stopped
- 1120: RP#39 stopped (no TR produced). Spin-off HS-DSCH Serving Cell Change Enhancements (UID_39003)
- 1121: RP#43 stopped (draft TR 25.825 v100 withdrawn). Conclusions in RP-090318 (RAN1 findings of the UTRA Multi-Carrier Evolution study). RP#42 New WI approved on Dual-Cell HSDPA operation on adjacent carriers (UID_400052)
- 1122: -

| ID | WBS | Task | Type | Duration | Start | Finish | Complete | Baseline start | Baseline finish | Baseline duration | Constraint | Resources | Work | Actual work | Text1 | Text4 | Text5 | Text6 | Text8 | Text12 | Text11 | Text7 | Text2 |
| --- | --- | --- | --- | --- | --- | --- | --- | --- | --- | --- | --- | --- | --- | --- | --- | --- | --- | --- | --- | --- | --- | --- | --- |
| 1123 | 384 | **Identification of Communication Services in IMS** |  | 620d? | 2005-05-02 A | 2007-09-14 A | 100% | 2005-05-02 | 2007-09-14 | 620d? |  | S2,S1,C1,S5 | 13016h | 13016h | ServID | Ericsson | stephen.terrill@ericsson.com | Rel-7 | Maurice |  |  |  |  |
| 1124 | 384.1 | TR on ServID |  | 232d? | 2005-05-02 A | 2006-03-21 A | 100% | 2005-05-02 | 2006-03-21 | 232d? | finish no earlier than 2006-03-20 | S2 | 1856h | 1856h | ServID | Ericsson | stephen.terrill@ericsson.com | Rel-7 | Maurice |  |  |  |  |
| 1125 | 384.2 | Stage 1,2 of ServID |  | 144d? | 2005-11-11 A | 2006-05-31 A | 100% | 2005-11-11 | 2006-05-31 | 144d? | start no earlier than 2005-11-11 | S1,S2 | 1152h | 1152h | ServID | Ericsson | stephen.terrill@ericsson.com | Rel-7 | Maurice |  |  |  |  |
| 1126 | 384.3 | Stage 3 of ServID |  | 250d? | 2006-03-31 A | 2007-03-15 A | 100% | 2006-03-31 | 2007-03-15 | 250d? | finish no earlier than 2007-03-15 | C1 | 2000h | 2000h | ServID | Ericsson | christer.holmberg@ericsson.com | Rel-7 | Frederic |  |  |  |  |
| 1127 | 384.4 | Charging of ServID |  | 381d? | 2006-03-31 A | 2007-09-14 A | 100% | 2006-03-31 | 2007-09-14 | 381d? | finish no earlier than 2007-09-14 | S5 | 3048h | 3048h | ServID | Orange | alain.bibas@orange-ft.com | Rel-7 | Dionisio |  |  |  |  |
| 1128 | 385 | **Supporting Globally Routable User Agent URIs in IMS** |  | 415d? | 2005-11-14 A | 2007-06-15 A | 100% | 2005-11-14 | 2007-06-15 | 415d? |  | S2,S1,C1 | 7760h | 7760h | GRUU | RIM | Adrian Buckley (abuckley@rim.com) | Rel-7 | Maurice |  |  |  |  |
| 1129 | 385.1 | Deleted - TR on GRUU |  | 219d? | 2005-11-14 A | 2006-09-14 A | 100% | 2005-11-14 | 2006-09-14 | 219d? | finish no earlier than 2006-09-14 | S2 | 1752h | 1752h | GRUU | RIM | Adrian Buckley (abuckley@rim.com) | Rel-7 | Maurice | SP-32 |  |  |  |
| 1130 | 385.2 | Stage 1,2 of GRUU |  | 65d? | 2006-07-03 A | 2006-09-29 A | 100% | 2006-07-03 | 2006-09-29 | 65d? | start no earlier than 2006-07-03 | S1,S2 | 520h | 520h | GRUU | RIM | Adrian Buckley (abuckley@rim.com) | Rel-7 | Maurice |  |  |  |  |
| 1131 | 385.3 | Stage 3 of GRUU |  | 271d? | 2006-06-02 A | 2007-06-15 A | 100% | 2006-06-02 | 2007-06-15 | 271d? | finish no earlier than 2007-06-15 | C1 | 2168h | 2168h | GRUU | CableLabs | Bernie McKibben | Rel-7 | Frederic |  |  |  |  |
| 1132 | 386 | **Multimedia Telephony Service for IMS** |  | 357d? | 2006-02-01 A | 2007-06-15 A | 100% | 2006-02-01 | 2007-06-15 | 357d? |  | S1,C1,S4 | 8976h | 8976h | MTSI | Ericsson | peter.bleckert@ericsson.com | Rel-7 | Alain |  |  |  |  |
| 1133 | 386.1 | Stage 1 of MTSI |  | 173d? | 2006-02-01 A | 2006-09-29 A | 100% | 2006-02-01 | 2006-09-29 | 173d? | start no earlier than 2006-02-01 | S1 | 1384h | 1384h | MTSI-REQ | Ericsson | peter.bleckert@ericsson.com | Rel-7 | Alain |  |  |  |  |
| 1134 | 386.2 | Stage 3 of MTSI |  | 330d? | 2006-03-10 A | 2007-06-14 A | 100% | 2006-03-10 | 2007-06-14 | 330d? | finish no earlier than 2007-06-15 | C1 | 2640h | 2640h | MTSI | Ericsson | christer.holmberg@ericsson.com | Rel-7 | Frederic |  |  |  |  |
| 1135 | 386.3 | Media handling and interaction in MTSI |  | 262d? | 2006-03-15 A | 2007-03-15 A | 100% | 2006-03-15 | 2007-03-15 | 262d? | finish no earlier than 2007-03-15 | S4 | 2096h | 2096h | MTSI-MHI | Ericsson | olle.franceschi@ericsson.com | Rel-7 | Paolo |  |  |  |  |
| 1136 | 386.4 | Deleted - duplicates UID7039 - IMS Multimedia Telephony Service | milestone | 0d? | 2007-06-15 A | 2007-06-15 A | 100% | 2007-06-15 | 2007-06-15 | 0d? | start no earlier than 2007-06-15 | S1 |  |  | MMTEL | Ericsson | peter.bleckert@ericsson.com | Rel-7 | Alain | SP-32 |  |  |  |
| 1137 | 387 | Multimedia Telephony Service for IMS (MTSI) - UE Conformance Testing |  | 387d | 2007-09-19 A | 2009-03-12 A | 100% | 2007-09-19 | 2009-03-12 | 387d | finish no earlier than 2009-03-13 | R5 | 1664h | 1664h | MTSI-UEConTest | Ericsson, Motorola | Leif.Mattisson@ericsson.com, Jacob.John@motorola.com | Rel-7 | Ingbert |  | RP-090056 |  |  |
| 1138 | 388 | TISPAN requirements for Multimedia Telephony with PSTN/ISDN simulation services |  | 58d? | 2007-09-18 A | 2007-12-06 A | 100% | 2007-09-18 | 2007-12-06 | 58d? | start no earlier than 2007-09-18 | S1 | 464h | 464h | TMMTEL7 |  |  | Rel-7 | Alain |  |  | SP-37 |  |
| 1139 | 389 | **Maintenance of TISPAN release 1 common IMS** |  | 58d? | 2007-09-18 A | 2007-12-06 A | 100% | 2007-09-18 | 2007-12-06 | 58d? |  | S2 | 1392h | 1392h | MCIMSTR1 | Ericsson | Raymond Forbes | Rel-7 | Maurice |  |  | SP-38 | PCG-21 |
| 1140 | 389.1 | SA1 aspects of MCIMSTR1 |  | 58d? | 2007-09-18 A | 2007-12-06 A | 100% | 2007-09-18 | 2007-12-06 | 58d? | finish no earlier than 2007-12-06 | S1 | 464h | 464h | MCIMSTR1-S1 | Telecom Italia | Marco.DeLuca1@telecomitalia.it | Rel-7 | Alain |  |  | SP-38 | PCG-21 |
| 1141 | 389.2 | SA2 aspects of MCIMSTR1 |  | 58d? | 2007-09-18 A | 2007-12-06 A | 100% | 2007-09-18 | 2007-12-06 | 58d? | finish no earlier than 2007-12-06 | S2 | 464h | 464h | MCIMSTR1-S2 | Ericsson | Raymond Forbes | Rel-7 | Maurice |  |  | SP-38 | PCG-21 |
| 1142 | 390 | **PS domain and IMS impacts for supporting IMS Emergency calls** |  | 1760d? | 2000-09-18 A | 2007-06-15 A | 100% | 2000-09-18 | 2007-06-15 | 1760d? |  | S2,S1 | 44157h | 44157h | EMC1 | Siemens | Rainer Liebhart | Rel-7 | Maurice |  |  |  |  |
| 1143 | 10.1.1 | Service Requirements for IP-based emergency calls |  | 985d | 2000-09-18 A | 2004-06-25 A | 100% | 2000-09-18 | 2004-06-25 | 985d | finish no earlier than 2004-06-25 | S1 | 7880h | 7880h | EMC1 | Siemens | Rainer Liebhart | Rel-7 | Alain |  |  |  |  |
| 1144 | 390.2 | Study on Stage 2 for IMS-level solution |  | 668d? | 2003-02-26 A | 2005-09-16 A | 100% | 2003-02-26 | 2005-09-16 | 668d? | finish no earlier than 2005-09-16 | S2 | 5344h | 5344h | EMC1 | Siemens | Rainer Liebhart | Rel-7 | Maurice |  |  |  |  |
| 1145 | 390.3 | Study on Stage 2 for GPRS-level solution |  | 301d? | 2004-10-14 A | 2005-12-08 A | 100% | 2004-10-14 | 2005-12-08 | 301d? | finish no earlier than 2005-12-08 | S2 | 2408h | 2408h | EMC1 | Siemens | Rainer Liebhart | Rel-7 | Maurice |  |  |  |  |
| 1146 | 390.4 | Stage 2 Specification Phase - IMS-level |  | 200d? | 2005-09-05 A | 2006-06-09 A | 100% | 2005-09-05 | 2006-06-09 | 200d? | finish no earlier than 2006-06-09 | S2 | 1600h | 1600h | EMC1 | Siemens | Rainer Liebhart | Rel-7 | Maurice |  |  |  |  |
| 1147 | 390.5 | Deleted - Stage 2 Specification Phase - GPRS-level | milestone | 0d? | 2007-03-02 A | 2007-03-02 A | 100% | 2007-03-02 | 2007-03-02 | 0d? | start no earlier than 2007-03-02 | S2 |  |  | EMC1 | Siemens | Rainer Liebhart | Rel-7 | Maurice | SP-32 |  |  |  |

Notes:
- 1123: WID approved SP#28. WID updated SP#32
- 1124: - / Text3: 23.816
- 1125: - / Text3: 22.228, 23.228, 23.203
- 1126: CP#32 approved WID / Text3: 23.218, 24.229
- 1127: - / Text3: 32.260, 32.298, 32.299
- 1128: SP#29 approved WID
- 1129: Abandoned
- 1130: SP#29 approved WID / Text3: 22.228, 23.228, 23.218, 24.229
- 1131: CP#32 approved WID / Text3: 24.229
- 1132: -
- 1133: - / Text3: 22.173
- 1134: - / Text3: 24.173
- 1135: - / Text3: 26.114
- 1136: - / Text3: 22.173
- 1137: RP#43 completed. Linked UID_7038 (MTSI) / Text3: 34.123-1, 34.123-2, 34.123-3, 34.229-1, 34.229-2
- 1138: - / Text3: 22.273 (EI 181 002 maintenance)
- 1139: - / Text3: http://www.3gpp.org/specs/TISPAN-IMS-ansfer.htm
- 1140: - / Text3: 22.173, 22.273
- 1141: - / Text3: 23.406, 23.417, 23.508,23.509, 23.511
- 1142: -
- 1143: - / Text3: 22.976 (DB shows 04/2003 withdrawn Study on PS domain services and capabilities (az: belongs this really here ?!)
- 1144: - / Text3: 23.867
- 1145: - / Text3: 23.867
- 1146: - / Text3: 23.167, 23.228, 23.060, 23.002, 23.271
- 1147: -

| ID | WBS | Task | Type | Duration | Start | Finish | Complete | Baseline start | Baseline finish | Baseline duration | Constraint | Resources | Work | Actual work | Text1 | Text4 | Text5 | Text6 | Text8 | Text3 | Text12 | Text10 | Text11 |
| --- | --- | --- | --- | --- | --- | --- | --- | --- | --- | --- | --- | --- | --- | --- | --- | --- | --- | --- | --- | --- | --- | --- | --- |
| 1148 | 10.1 | **Emergency Call Enhancements for IP& PS Based Calls – stage 3** |  | 375d | 2006-01-09 A | 2007-06-15 A | 100% | 2006-01-09 | 2007-06-15 | 375d |  | C1 | 12845h | 12845h | EMC1 | Ericsson | alf.heidermark@ericsson.com | Rel-7 | Frederic |  |  |  |  |
| 1149 | 10.1.2 | CT1 IMS aspects to support IMS Emergency sessions |  | 350.82d | 2006-01-09 A | 2007-06-15 A | 100% | 2006-01-09 | 2007-06-15 | 350.82d | finish no earlier than 2007-06-15 | C1 | 2806.57h | 2806.57h | EMC1 | Ericsson | alf.heidermark@ericsson.com | Rel-7 | Frederic | 24.229 |  |  |  |
| 1150 | 10.1.2 | Deleted - CT3 IMS aspects to support IMS Emergency sessions |  | 95d | 2006-05-08 A | 2006-09-15 A | 100% | 2006-05-08 | 2006-09-15 | 95d | finish no earlier than 2006-09-15 | C3 | 760h | 760h | EMC1 | Ericsson | alf.heidermark@ericsson.com | Rel-7 | Gwiho | 29.163 | CP-33 |  |  |
| 1151 | 10.1.5 | Deleted - CT3 PS domain aspects to support IMS Emergency sessions |  | 95d | 2006-05-08 A | 2006-09-15 A | 100% | 2006-05-08 | 2006-09-15 | 95d | start no earlier than 2006-05-08 | C3 | 760h | 760h | EMC1 | Ericsson | alf.heidermark@ericsson.com | Rel-7 | Gwiho | 29.061 | CP-33 |  |  |
| 1152 | 10.1.5 | CT1 PS domain aspects to support IMS Emergency sessions |  | 349.9d | 2006-01-09 A | 2007-06-15 A | 100% | 2006-01-09 | 2007-06-15 | 349.9d | finish no earlier than 2007-06-15 | C1 | 2799.2h | 2799.2h | EMC1 | Ericsson | alf.heidermark@ericsson.com | Rel-7 | Frederic | 24.008, 24.234 |  |  |  |
| 1153 | 10.1.5 | CT4 PS domain aspects to support IMS Emergency sessions |  | 365d | 2006-01-09 A | 2007-06-01 A | 100% | 2006-01-09 | 2007-06-01 | 365d | finish no earlier than 2007-06-01 | C4 | 2920h | 2920h | EMC1-GPRSc4 | Ericsson | alf.heidermark@ericsson.com | Rel-7 | Kimmo | 29.060 |  |  |  |
| 1154 | 391 | IMS Support of Conferencing |  | 355d? | 2005-11-04 A | 2007-03-15 A | 100% | 2005-11-04 | 2007-03-15 | 355d? | finish no earlier than 2007-03-15 | C1 | 2840h | 2840h | IMSconf | Alcatel-Lucent | Keith Drage (drage@alcatel-lucent.com) | Rel-7 | Frederic | 24.147, 24.229 |  |  |  |
| 1155 | 392 | Performance Characterization of VoIMS over HSDPA\EUL channels |  | 713d? | 2005-03-15 A | 2007-12-06 A | 100% | 2005-03-15 | 2007-12-06 | 713d? | finish no earlier than 2007-12-06 | S4 | 5704h | 5704h | VoIMS-PCVoIMS | Alcatel-Lucent | mcgowan@alcatel-lucent.com | Rel-7 | Paolo | 26.935 |  |  |  |
| 1156 | 393 | **WLAN-UMTS Interworking Phase 2** |  | 371d? | 2004-01-05 A | 2005-06-07 A | 100% | 2004-01-05 | 2005-06-07 | 371d? |  | S1 | 3888h | 3888h | WLAN2 | Telenor | frederic.paint@telenor.com | Rel-7 | Alain | 33.234 (SP-36 SA3 CRs approved) |  |  |  |
| 1157 | 393.1 | Stage 1 on Session Continuity |  | 115d? | 2004-01-05 A | 2004-06-11 A | 100% | 2004-01-05 | 2004-06-11 | 115d? | start no earlier than 2004-01-05 | S1 | 920h | 920h | WLAN-SC |  |  | Rel-7 | Alain | 22.234 |  | SP-24 |  |
| 1158 | 393.2 | Stage 2 on Session Continuity: covered by SAE | milestone | 0d? | 2005-06-07 A | 2005-06-07 A | 100% | 2005-06-07 | 2005-06-07 | 0d? | finish no earlier than 2005-06-07 | S2 |  |  | WLAN-SC |  |  | Rel-7 | Maurice |  |  |  |  |
| 1159 | 394 | **WLAN Interworking – Private Network access from WLAN 3GPP IP Access** |  | 252d? | 2005-10-10 A | 2006-09-26 A | 100% | 2005-10-10 | 2006-09-26 | 252d? |  | S2,C1,C3,C4 | 8936h | 8936h | WLANPNA | NEC | Toshiyuki Tamura (tamurato@aj.jp.nec.com) | Rel-7 | Maurice |  |  |  |  |
| 1160 | 394.1 | WLAN-PNA - Stage 2 |  | 185d? | 2005-10-10 A | 2006-06-23 A | 100% | 2005-10-10 | 2006-06-23 | 185d? | start no earlier than 2005-10-10 | S2 | 1480h | 1480h | WLANPNA-st2 | NEC | Toshiyuki Tamura (tamurato@aj.jp.nec.com) | Rel-7 | Maurice | 23.234, 33.234 |  |  |  |
| 1161 | 394.2 | **WLAN-PNA - Stage 3** |  | 170d? | 2006-02-01 A | 2006-09-26 A | 100% | 2006-02-01 | 2006-09-26 | 170d? |  | C1,C3,C4 | 5440h | 5440h | WLANPNA-st3 | NEC |  | Rel-7 | Frederic |  |  |  |  |
| 1162 | 394.2.1 | CT1 aspets for WLAN-PNA |  | 170d? | 2006-02-01 A | 2006-09-26 A | 100% | 2006-02-01 | 2006-09-26 | 170d? | start no earlier than 2006-02-01 | C1 | 1360h | 1360h | WLANPNA-st3 | NEC |  | Rel-7 | Frederic | 24.234 |  |  |  |
| 1163 | 394.2.2 | CT3 aspets for WLAN-PNA |  | 170d? | 2006-02-01 A | 2006-09-26 A | 100% | 2006-02-01 | 2006-09-26 | 170d? | start no earlier than 2006-02-01 | C3 | 1360h | 1360h | WLANPNA-st3 | NEC |  | Rel-7 | Gwiho | 29.161 |  |  |  |
| 1164 | 394.2.3 | Deleted - CT4 aspets for WLAN-PNA |  | 170d? | 2006-02-01 A | 2006-09-26 A | 100% | 2006-02-01 | 2006-09-26 | 170d? | start no earlier than 2006-02-01 | C4 | 1360h | 1360h | WLANPNA-st3 | NEC |  | Rel-7 | Kimmo | 29.234 | CP-32 |  |  |
| 1165 | 395 | **Enhancements to support QoS provisioning over 3GPP/WLAN Interworking** |  | 520d? | 2005-03-14 A | 2007-03-09 A | 100% | 2005-03-14 | 2007-03-09 | 520d? |  | S2,C4,C1 | 8360h | 8360h | WLANQOS | Samsung |  | Rel-7 | Maurice |  |  |  |  |
| 1166 | 395.1 | Deleted - TR on support of QoS on WLAN |  | 232d? | 2005-03-14 A | 2006-01-31 A | 100% | 2005-03-14 | 2006-01-31 | 232d? | start no earlier than 2005-03-14 | S2 | 1856h | 1856h | WLANQOS | Samsung |  | Rel-7 | Maurice | 23.836 | SP-32 |  |  |
| 1167 | 395.2 | Stage 2 on support of QoS over 3GPP/WLAN interworking |  | 108d? | 2006-02-01 A | 2006-06-30 A | 100% | 2006-02-01 | 2006-06-30 | 108d? | start no earlier than 2006-02-01 | S2 | 864h | 864h | WLANQOS | Samsung |  | Rel-7 | Maurice | 23.234 |  |  |  |
| 1168 | 395.3 | Stage 3 CT4 on support of QoS over 3GPP/WLAN Interworking |  | 121d? | 2006-09-22 A | 2007-03-09 A | 100% | 2006-09-22 | 2007-03-09 | 121d? | finish no earlier than 2007-03-09 | C4 | 968h | 968h | WLANQOS | Huawei | zhang.peng@huawei.com | Rel-7 | Kimmo | 29.234, 23.008 |  |  |  |
| 1169 | 395.4 | Stage 3 CT1 on support of QoS over 3GPP/WLAN Interworking |  | 64d? | 2006-09-04 A | 2006-11-30 A | 100% | 2006-09-04 | 2006-11-30 | 64d? | finish no earlier than 2006-11-30 | C1 | 512h | 512h | WLANQOS | Huawei | zhang.peng@huawei.com | Rel-7 | Frederic | 24.234 |  |  |  |
| 1170 | 396 | **Location Services enhancements** |  | 906d? | 2004-06-28 A | 2007-12-17 A | 100% | 2004-06-28 | 2007-12-17 | 906d? |  | S1,S2,GP,C4,R2 | 46933.6h | 46933.6h | LCS3 |  |  | Rel-7 | Alain |  |  |  |  |
| 1171 | 396.1 | Stage 2 for LCS3 (including IMS emergency location aspects) |  | 446d? | 2004-12-31 A | 2006-09-15 A | 100% | 2004-12-31 | 2006-09-15 | 446d? | finish no earlier than 2006-09-15 | S2 | 3568h | 3568h | LCS3 | SiRF | brodilitz@sirf.com | Rel-7 | Maurice | 23.271 |  |  |  |
| 1172 | 396.2 | LCS Enhancements related to Location-Based Services |  | 695d? | 2005-01-03 A | 2007-08-31 A | 100% | 2005-01-03 | 2007-08-31 | 695d? | finish no earlier than 2007-08-31 | GP | 5560h | 5560h | LCS3-LBS | SiRF | kjudge@sirf.com | Rel-7 | Paolo | 43.059, 44.031, 48.008, 49.031 |  |  |  |
| 1173 | 396.3 | CT4 aspects for LCS UEPos-LBS |  | 240d? | 2006-01-02 A | 2006-12-01 A | 100% | 2006-01-02 | 2006-12-01 | 240d? | finish no earlier than 2006-12-01 | C4 | 1920h | 1920h | LCS3-UEPos-LBS | SiRF | brodilitz@sirf.com | Rel-7 | Kimmo | 24.030, 24.080, 29.002 |  |  |  |
| 1174 | 396.4 | UE positioning - Velocity |  | 394d? | 2005-03-15 A | 2006-09-15 A | 100% | 2005-03-15 | 2006-09-15 | 394d? | finish no earlier than 2006-09-15 | R2 | 3152h | 3152h | LCS3-UEPos-Velocity | SiRF | BRodilitz@SiRF.com | Rel-7 | Joern | 25.305, 25.331, 25.410, 25.413, 25.453 |  |  | RP-060459 |
| 1175 | 396.5 | Inclusion of Uplink TDOA UE positioning method in the UTRAN specifications |  | 849d? | 2004-09-15 A | 2007-12-17 A | 100% | 2004-09-15 | 2007-12-17 | 849d? | finish no earlier than 2007-12-17 | R2 | 6792h | 6792h | LCS3-UEPos-UTDOA | TruePosition | Robert Gross | Rel-7 | Joern | 25.305, 25.453 |  |  | RP-070797 |

Notes:
- 1148: -
- 1149: -
- 1150: Cancelled for Rel-7 and there is now corresponding Rel-8 WI
- 1151: Cancelled for Rel-7 and there is now corresponding Rel-8 WI
- 1152: -
- 1153: -
- 1154: CP#35 revised WID
- 1155: -
- 1156: Created at TSG#27 because of WLAN items belonging to Rel-7
- 1157: -
- 1158: -
- 1159: -
- 1160: Approved at SP#29
- 1161: Approved at CP#29
- 1162: Approved at CP#29
- 1163: Approved at CP#29
- 1164: CT4#31; no impacts identified, therefore completed. CP-32 stopped
- 1165: Moved from FS section Feb 06. SP-30 updated WID
- 1166: SP-32 stopped
- 1167: SP-30 updated WID
- 1168: CP-32 approved WID
- 1169: CP-32 approved WID
- 1170: -
- 1171: SP#27 approved WID.
- 1172: -
- 1173: -
- 1174: Completed Sept 2006; SR in RP-060459
- 1175: Completed Nov 2007; SR in RP-070797

| ID | WBS | Task | Type | Duration | Start | Finish | Complete | Baseline start | Baseline finish | Baseline duration | Constraint | Resources | Work | Actual work | Text1 | Text4 | Text5 | Text6 | Text8 | Text12 | Text11 | Text2 | Text7 |
| --- | --- | --- | --- | --- | --- | --- | --- | --- | --- | --- | --- | --- | --- | --- | --- | --- | --- | --- | --- | --- | --- | --- | --- |
| 1176 | 396.6 | **LCS for 3GPP Interworking WLAN** |  | 700d? | 2004-06-28 A | 2007-03-02 A | 100% | 2004-06-28 | 2007-03-02 | 700d? |  | S1 | 11901.6h | 11901.6h | LCS3-IWLAN | Telcordia | Mike Loushine | Rel-7 | Alain |  |  |  |  |
| 1177 | 396.6.1 | FS on 3GPP system to WLAN Interworking with LCS |  | 512.7d? | 2004-06-28 A | 2006-06-30 A | 100% | 2004-06-28 | 2006-06-30 | 512.7d? | finish no earlier than 2005-09-29 | S1 | 4101.6h | 4101.6h | LCS3-IWLAN-FSs1 | Telcordia | Mike Loushine | Rel-7 | Alain |  |  |  |  |
| 1178 | 396.6.2 | Deleted - Study of work on an LCS architecture for I-WLAN. |  | 180d? | 2006-06-26 A | 2007-03-02 A | 100% | 2006-06-26 | 2007-03-02 | 180d? | finish no earlier than 2007-03-02 | S2 | 1440h | 1440h | LCS3-IWLAN-FSs2 | LG Electronics | dhshim@lge.com ; phede@lge.com | Rel-7 | Maurice | SP-35 |  |  |  |
| 1179 | 396.6.3 | Stage 2 for LCS architecture for I-WLAN |  | 95d? | 2006-10-23 A | 2007-03-02 A | 100% | 2006-10-23 | 2007-03-02 | 95d? | finish no earlier than 2007-03-02 | S2 | 760h | 760h | LCS3-IWLAN | LG Electronics | dhshim@lge.com ; phede@lge.com | Rel-7 | Maurice |  |  |  |  |
| 1180 | 396.7 | Deleted - UE positioning Rel-7 |  | 849d? | 2004-09-15 A | 2007-12-17 A | 100% | 2004-09-15 | 2007-12-17 | 849d? |  | RP | 6792h | 6792h | LCS3-UEpos |  |  | Rel-7 | Joern | RP-38 |  |  |  |
| 1181 | 396.8 | Deleted - RAN2 aspects for LBS | milestone | 0d? | 2005-06-15 A | 2005-06-15 A | 100% | 2005-06-15 | 2005-06-15 | 0d? | start no earlier than 2005-06-15 | R2 |  |  | LCS3-UEPos-LBS | SiRF | BRodilitz@SiRF.com | Rel-7 | Joern | RP-31 |  |  |  |
| 1182 | 397 | **MBMS Enhancements** |  | 625d? | 2005-07-11 A | 2007-11-30 A | 100% | 2005-07-11 | 2007-11-30 | 625d? |  | S1,R1,C3 | 10844.6h | 10844.6h | MBMSE | China Mobile | liuhongyfw@chinamobile.com | Rel-7 | Alain |  |  |  |  |
| 1183 | 397.1 | Stage 1 of MBMSE |  | 109d? | 2005-07-11 A | 2005-12-08 A | 100% | 2005-07-11 | 2005-12-08 | 109d? | finish no earlier than 2005-12-08 | S1 | 872h | 872h | MBMSE | China Mobile | liuhongyfw@chinamobile.com | Rel-7 | Alain |  |  |  |  |
| 1184 | 397.2 | MBMS FDD Physical layer Enhancements |  | 117.29d? | 2006-12-15 A | 2007-06-04 A | 100% | 2006-12-15 | 2007-06-04 | 117.29d? | finish no earlier than 2007-06-04 | R1 | 938.32h | 938.32h | MBMSE-RANPhysFDD | Ericsson | Lars.Lindbom@ericsson.com | Rel-7 | Patrick |  | RP-070290 |  |  |
| 1185 | 397.3 | MBMS TDD Physical layer Enhancements |  | 117.29d? | 2006-12-15 A | 2007-06-04 A | 100% | 2006-12-15 | 2007-06-04 | 117.29d? | finish no earlier than 2007-06-04 | R1 | 938.32h | 938.32h | MBMSE-RANPhysTDD | IPWireless | Nicholas Anderson | Rel-7 | Patrick |  | RP-070291 |  |  |
| 1186 | 397.4 | MBMS Low Chip Rate TDD Physical Layer Enhancement |  | 127d? | 2007-03-16 A | 2007-09-10 A | 100% | 2007-03-16 | 2007-09-10 | 127d? | finish no earlier than 2007-09-10 | R1 | 1016h | 1016h | MBMSE-RANPhysLCRTDD | RITT | Lin Hui | Rel-7 | Patrick |  | RP-070292 |  |  |
| 1187 | 397.5 | MBMS Mz interface |  | 260d? | 2006-12-04 A | 2007-11-30 A | 100% | 2006-12-04 | 2007-11-30 | 260d? | finish no earlier than 2007-05-11 | C3 | 2080h | 2080h | MBMSMz | Huawei | Deng Tingting (ttdeng@huawei.com) | Rel-7 | Gwiho |  |  |  |  |
| 1188 | 398 | **MBMS - UE Conformance Testing** |  | 657d? | 2007-06-01 A | 2009-12-04 A | 100% | 2007-06-01 | 2009-12-04 | 657d? |  | R5 | 13848h | 13848h | MBMSE_UEConTest |  |  | Rel-7 | Ingbert |  |  | PCG-21 | SP-40 |
| 1189 | 398.1 | Conformance Test Aspects – MBMS TDD Physical layer Enhancements – MBSFN for HCR and VHCR TDD |  | 336d? | 2007-06-01 A | 2008-09-12 A | 100% | 2007-06-01 | 2008-09-12 | 336d? | start no earlier than 2007-06-01 | R5 | 2688h | 2688h | MBMSE-RANPhysTDD_UEConTest | IPWireless | tspeight@ipwireless.com | Rel-7 | Ingbert |  | RP-080541 |  |  |
| 1190 | 398.2 | Conformance Test Aspects – MBMS LCR TDD Physical Layer Enhancement |  | 342d? | 2008-05-30 A | 2009-09-18 A | 100% | 2008-05-30 | 2009-09-18 | 342d? | finish no earlier than 2009-09-18 | R5 | 2728h | 2728h | MBMSE-RANPhysLCRTDD_UEConTest | CATT | chenxiaozhong@datangmobile.cn | Rel-7 | Ingbert |  | RP-090715 | PCG-21 | RP-40 |
| 1191 | 398.3 | Conformance Test Aspects – MBSFN for FDD |  | 397d? | 2008-05-30 A | 2009-12-04 A | 100% | 2008-05-30 | 2009-12-04 | 397d? | finish no earlier than 2009-12-04 | R5 | 3176h | 3176h | MBMSE-UEConTest_RANPhysFDD | Huawei | Xiang Li (trica_li@huawei.com) | Rel-7 | Ingbert |  | RP-091214 | PCG-21 | RP-40 |
| 1192 | 399 | MBMS User Service Extensions |  | 392d? | 2005-12-07 A | 2007-06-07 A | 100% | 2005-12-07 | 2007-06-07 | 392d? | finish no earlier than 2007-06-07 | S4 | 3136h | 3136h | MBMSUSE | Ericsson | Thorsten.Lohmar@ericsson.com | Rel-7 | Paolo |  |  |  |  |
| 1193 | 400 | **Advanced Global Navigation Satellite System (A-GNSS) concept** |  | 830d? | 2004-06-28 A | 2007-08-31 A | 100% | 2004-06-28 | 2007-08-31 | 830d? |  | S1,GP,R2 | 9553.6h | 9553.6h | LCS3-AGNSS | Alcatel | Michel.monnerat@thalesaleniaspace.com | Rel-7 | Alain |  |  |  |  |
| 1194 | 400.1 | Towards A-GNSS Concept |  | 811.2d? | 2004-06-28 A | 2007-08-31 A | 100% | 2004-06-28 | 2007-08-31 | 811.2d? | finish no earlier than 2007-08-31 | GP | 6489.6h | 6489.6h | AGNSS-GP | Alcatel | richard.couty@space.alcatel.fr | Rel-7 | Paolo |  |  |  |  |
| 1195 | 400.2 | Global Navigation Satellite System (GNSS) in UTRAN |  | 383d? | 2005-12-15 A | 2007-06-04 A | 100% | 2005-12-15 | 2007-06-04 | 383d? | finish no earlier than 2007-06-04 | R2 | 3064h | 3064h | LCS3-GNSS-UTRAN | France Telecom | alain.abinakhoul@francetelecom.com | Rel-7 | Joern |  | RP-070482 |  |  |
| 1196 | 400.3 | Deleted - Towards A-GNSS Concept | milestone | 0d? | 2007-02-16 A | 2007-02-16 A | 100% | 2007-02-16 | 2007-02-16 | 0d? | start no earlier than 2007-02-16 | S1 |  |  | GNSS | Alcatel | richard.couty@space.alcatel.fr | Rel-7 | Alain | SP-34 |  |  |  |
| 1197 | 401 | A-GPS Minimum Performance |  | 351d? | 2006-04-28 A | 2007-08-31 A | 100% | 2006-04-28 | 2007-08-31 | 351d? | finish no earlier than 2007-08-31 | GP | 2808h | 2808h | GAGR | Spirent | richard.catmur@spirentcom.com | Rel-7 | Paolo |  |  |  |  |
| 1198 | 402 | **USSD message delivery and transfer to USIM** |  | 376d? | 2004-03-05 A | 2005-08-12 A | 100% | 2004-03-05 | 2005-08-12 | 376d? |  | S1,C6 | 2762.4h | 2762.4h | USSD-USIM | Axalto | Christophe Dubois (cdubois@axalto.com) | Rel-7 | Alain |  |  |  |  |
| 1199 | 402.1 | Stage 1 |  | 152d? | 2004-03-18 A | 2004-10-15 A | 100% | 2004-03-18 | 2004-10-15 | 152d? | start no earlier than 2004-03-18 | S1 | 1216h | 1216h | USSD-USIM | Axalto | Christophe Dubois (cdubois@axalto.com) | Rel-7 | Alain |  |  |  |  |
| 1200 | 402.2 | Alignment with requirements regarding USSD usage |  | 193.3d? | 2004-03-05 A | 2005-08-12 A | 100% | 2004-03-05 | 2005-08-12 | 193.3d? | finish no earlier than 2005-08-12 | C6 | 1546.4h | 1546.4h | USSD-USIM | Axalto | Christophe Dubois (cdubois@axalto.com) | Rel-7 | Xavier |  |  |  |  |

Notes:
- 1176: -
- 1177: - / Text3: 22.935
- 1178: Updated WID at SP#32 to change "stage 2" to "study" , duplicated UID 320017 deleted. SP#33 TR for Information. Last mention SP-35 Mar 2007 (abandoned ?) / Text3: 23.837
- 1179: WID at SP#55 / Text3: 23.234, 23.271, 23.167
- 1180: -
- 1181: - / Text3: 25.305, 25.331, 25.410, 25.413, 25.453
- 1182: -
- 1183: Structure created by MCC to include RAN aspects under SA1 Feature / Text3: 22.146, 22.246, 22.228
- 1184: Completed May 2007; SR in RP-070290 / Text3: 25.211, 25.212, 25.213, 25.101, 25.104, 25.331, 25.433, 25.346, 25.306
- 1185: Completed May 2007; SR in RP-070291 / Text3: 25.346, 25.221, 25.222, 25.223, 25.224, 25.306, 25.331, 25.402, 25.433, 25.102, 25.105, 25.123
- 1186: Completed May 2007; SR in RP-070292 / Text3: 25.346, 25.221, 25.222, 25.223, 25.224, 25.306, 25.331, 25.402, 25.433, 25.102, 25.105, 25.123
- 1187: - / Text3: 29.061
- 1188: Linked to Rel-7 Feature UID_31084 (MBMSE)
- 1189: RP#41 completed / Text3: 34.108, 34.122, 34.123-1/2/3
- 1190: RP#45 completed / Text3: 34.108, 34.123-1
- 1191: RP#46 completed / Text3: 34.108, 34.109, 34.121-1, 34.121-2, 34.123-1, 34.123-2, 34.123-3
- 1192: - / Text3: 26.346, 26.946
- 1193: -
- 1194: GP#36 completed
- 1195: Completed Sept 2006; SR in RP-070482 / Text3: 25.305, 25.331, 25.306, 25.413, 25.423, 25.433, 25.453, 25.302, 25.215, 25.401, 25.402, 25.450, 25.452
- 1196: -
- 1197: - / Text3: 45.005, 51.010
- 1198: -
- 1199: - / Text3: 22.090
- 1200: -

| ID | WBS | Task | Type | Duration | Start | Finish | Complete | Baseline start | Baseline finish | Baseline duration | Constraint | Resources | Work | Actual work | Text1 | Text4 | Text5 | Text6 | Text8 | Text3 | Text12 |
| --- | --- | --- | --- | --- | --- | --- | --- | --- | --- | --- | --- | --- | --- | --- | --- | --- | --- | --- | --- | --- | --- |
| 1201 | 403 | **Combinational Services** |  | 296d? | 2005-01-17 A | 2006-03-06 A | 100% | 2005-01-17 | 2006-03-06 | 296d? |  | S1,S2,C1,S4 | 5176h | 5176h | CSICS | TeliaSonera | Robert.Frank@teliasonera.com | Rel-7 | Alain |  |  |
| 1202 | 403.1 | Stage 1 for CSICS |  | 104d? | 2005-01-17 A | 2005-06-09 A | 100% | 2005-01-17 | 2005-06-09 | 104d? | start no earlier than 2005-01-17 | S1 | 832h | 832h | CSICS | TeliaSonera | Robert.Frank@teliasonera.com | Rel-7 | Alain | 22.279 |  |
| 1203 | 403.2 | Stage 2 for CSICS |  | 130d? | 2005-01-17 A | 2005-07-15 A | 100% | 2005-01-17 | 2005-07-15 | 130d? | start no earlier than 2005-01-17 | S2 | 1040h | 1040h | CSICS | TeliaSonera | Robert.Frank@teliasonera.com | Rel-7 | Maurice | 23.279 |  |
| 1204 | 403.3 | Stage 3 for CSICS CN aspects |  | 221d? | 2005-05-02 A | 2006-03-06 A | 100% | 2005-05-02 | 2006-03-06 | 221d? | finish no earlier than 2006-03-06 | C1 | 1768h | 1768h | CSICS | Vodafone | Peter Dawes | Rel-7 | Frederic | 24.879, 24.279, 24.229, 24.008 |  |
| 1205 | 403.4 | Stage 3 for codec aspects |  | 192d? | 2005-03-15 A | 2005-12-07 A | 100% | 2005-03-15 | 2005-12-07 | 192d? | finish no earlier than 2005-12-07 | S4 | 1536h | 1536h | CSICS-Codec | Ericsson | Per.Frojdh@ericsson.com | Rel-7 | Paolo | 26.141, 26.235 |  |
| 1206 | 404 | **CAMEL Trunk Triggers** |  | 251d? | 2004-12-17 A | 2005-12-05 A | 100% | 2004-12-17 | 2005-12-05 | 251d? |  | S1,C4 | 6024h | 6024h | TTCAMEL | Nortel | Amar Deol (deola@nortelnetworks.com) | Rel-7 | Alain |  |  |
| 1207 | 404.1 | Stage 1 for CAMEL Trunk Triggers |  | 251d? | 2004-12-17 A | 2005-12-05 A | 100% | 2004-12-17 | 2005-12-05 | 251d? |  | S1 | 2008h | 2008h | TTCAMEL | Nortel | Amar Deol (deola@nortelnetworks.com) | Rel-7 | Alain | 22.078 |  |
| 1208 | 404.2 | CAMEL Trunk Originated Trigger Detection Points |  | 251d? | 2004-12-17 A | 2005-12-05 A | 100% | 2004-12-17 | 2005-12-05 | 251d? | start no earlier than 2004-12-17 | C4 | 2008h | 2008h | CamelR7 | Nortel | David Hutton (dhutton@nortel.com) | Rel-7 | Kimmo |  |  |
| 1209 | 405 | **IMS Service Brokering enhancements** |  | 69d? | 2005-12-07 A | 2006-03-13 A | 100% | 2005-12-07 | 2006-03-13 | 69d? |  | S1 | 1104h | 1104h | ISB | Telcordia | jbakker@telcordia.com | Rel-7 | Alain | 22.228 |  |
| 1210 | 405.1 | Stage 1 for ISB |  | 69d? | 2005-12-07 A | 2006-03-13 A | 100% | 2005-12-07 | 2006-03-13 | 69d? | finish no earlier than 2006-03-13 | S1 | 552h | 552h | ISB-s1 | Telcordia | jbakker@telcordia.com | Rel-7 | Alain | 22.228 |  |
| 1211 | 406 | **Enhancements of VGCS for public authority officials** |  | 731d? | 2004-08-27 A | 2007-06-15 A | 100% | 2004-08-27 | 2007-06-15 | 731d? |  | S1,C1,C4,G2 | 25920h | 25920h | EVGCS |  |  | Rel-7 | Alain | 43.068, 44.068, 24.008, 29.002 |  |
| 1212 | 406.1 | Stage 1 | milestone | 0d? | 2004-08-27 A | 2004-08-27 A | 100% | 2004-08-27 | 2004-08-27 | 0d? | finish no earlier than 2004-08-27 | S1 |  |  | EVGCS | Siemens | Joerg Swetina (joerg.swetina@nw.neclab.eu) | Rel-7 | Alain | 42.068, 43.068 |  |
| 1213 | 406.2 | **Architecture and protocol aspects** |  | 731d? | 2004-08-27 A | 2007-06-15 A | 100% | 2004-08-27 | 2007-06-15 | 731d? |  | C1,C4 | 14904h | 14904h | EVGCS | Siemens | robert.zaus@nsn.com | Rel-7 | Frederic | 43.068, 44.068 |  |
| 1214 | 406.2.1 | CT1 aspects of EVGCS |  | 731d? | 2004-08-27 A | 2007-06-15 A | 100% | 2004-08-27 | 2007-06-15 | 731d? | finish no earlier than 2006-09-15 | C1 | 5848h | 5848h | EVGCS | Siemens | robert.zaus@nsn.com | Rel-7 | Frederic | 43.068, 44.068, 24.008 |  |
| 1215 | 406.2.2 | CT4 aspects of EVGCS |  | 401d? | 2004-08-27 A | 2006-03-10 A | 100% | 2004-08-27 | 2006-03-10 | 401d? | finish no earlier than 2006-03-10 | C4 | 3208h | 3208h | EVGCS | Siemens | robert.zaus@nsn.com | Rel-7 | Kimmo | 29.002 |  |
| 1216 | 406.3 | GERAN2 aspects |  | 646d? | 2004-08-27 A | 2007-02-16 A | 100% | 2004-08-27 | 2007-02-16 | 646d? | finish no earlier than 2007-02-16 | G2 | 5168h | 5168h | EVGCS | Siemens | kenneth.isaacs@roke.co.uk | Rel-7 | Gert |  |  |
| 1217 | 407 | **Improvements of VGCS for parallel use of services** |  | 523d? | 2005-03-15 A | 2007-03-15 A | 100% | 2005-03-15 | 2007-03-15 | 523d? |  | S1 | 12230.2h | 12230.2h | IVGCS |  |  | Rel-7 | Alain |  |  |
| 1218 | 407.1 | Service Requirements for VGCS improvements |  | 62d? | 2005-03-15 A | 2005-06-08 A | 100% | 2005-03-15 | 2005-06-08 | 62d? | finish no earlier than 2005-06-08 | S1 | 496h | 496h | IVGCS | T-Mobile | kurt.bischinger@t-mobile.at | Rel-7 | Alain | 42.068 |  |
| 1219 | 407.2 | Stage 2 modifications for VGCS improvements |  | 335d? | 2005-12-01 A | 2007-03-14 A | 100% | 2005-12-01 | 2007-03-14 | 335d? | start no earlier than 2005-12-01 | C1 | 2680h | 2680h | IVGCS | T-Mobile | kurt.bischinger@t-mobile.at | Rel-7 | Frederic | 43.068 |  |
| 1220 | 407.3 | **Protocol aspects** |  | 336d? | 2005-12-01 A | 2007-03-15 A | 100% | 2005-12-01 | 2007-03-15 | 336d? |  | C1 | 5376h | 5376h | IVGCS | T-Mobile | Dieter Jacobsohn | Rel-7 | Frederic | 44.068 |  |
| 1221 | 407.3.1 | CT1 aspects of IVGCS |  | 336d? | 2005-12-01 A | 2007-03-15 A | 100% | 2005-12-01 | 2007-03-15 | 336d? | finish no earlier than 2007-03-15 | C1 | 2688h | 2688h | IVGCS | T-Mobile |  | Rel-7 | Frederic | 43.068, 44.068 |  |
| 1222 | 407.3.2 | Deleted - CT4 aspects of IVGCS | milestone | 0d? | 2007-03-09 A | 2007-03-09 A | 100% | 2007-03-09 | 2007-03-09 | 0d? | finish no earlier than 2007-03-09 | C4 |  |  | IVGCS-St3-c4 | T-mobile |  | Rel-7 | Kimmo | 29.002 | CP-35 |
| 1223 | 408 | **OSA Rel-7** |  | 584d? | 2005-03-15 A | 2007-06-08 A | 100% | 2005-03-15 | 2007-06-08 | 584d? |  | S1,C5 | 17920h | 17920h | OSA7 | AePONA | eamonn.murray@aepona.com | Rel-7 | Alain |  |  |
| 1224 | 408.1 | Service Requirements for OSA Service Broker |  | 62d? | 2005-03-15 A | 2005-06-08 A | 100% | 2005-03-15 | 2005-06-08 | 62d? | finish no earlier than 2005-06-08 | S1 | 496h | 496h | OSA7-SB | AePONA | eamonn.murray@aepona.com | Rel-7 | Alain | 22.127 |  |
| 1225 | 408.2 | Stage 2 OSA API Service Brokering |  | 156d? | 2006-04-28 A | 2006-12-01 A | 100% | 2006-04-28 | 2006-12-01 | 156d? |  | C5 | 1248h | 1248h | OSA7-SB | AePONA | damian.oneill@aepona.com | Rel-7 | Kimmo | 23.198 |  |
| 1226 | 408.3 | Stage 3 OSA API Service Brokering |  | 156d? | 2006-04-28 A | 2006-12-01 A | 100% | 2006-04-28 | 2006-12-01 | 156d? | finish no earlier than 2006-12-01 | C5 | 1248h | 1248h | OSA7-SB | AePONA | damian.oneill@aepona.com | Rel-7 | Kimmo | 29.198-16 |  |

Notes:
- 1201: -
- 1202: -
- 1203: -
- 1204: -
- 1205: -
- 1206: -
- 1207: -
- 1208: -
- 1209: No CR submitted in rel-8 (according to CR database).
- 1210: No Rel-8 changes
- 1211: Moved from Rel-6 UID_50563 Enhancements of VGCS in public networks for communication of public authority officials
- 1212: Voice Group Call Service
- 1213: -
- 1214: -
- 1215: -
- 1216: -
- 1217: Voice Group Call Service
- 1218: -
- 1219: -
- 1220: Previous name (before CT32) was Architecture and protocol aspects
- 1221: -
- 1222: CT4#33 stage 2 solution is still open. ...
- 1223: -
- 1224: az: WID URL corrected
- 1225: -
- 1226: -

| ID | WBS | Task | Type | Duration | Start | Finish | Complete | Baseline start | Baseline finish | Baseline duration | Constraint | Resources | Work | Actual work | Text1 | Text3 | Text4 | Text5 | Text6 | Text8 | Text12 | Text11 |
| --- | --- | --- | --- | --- | --- | --- | --- | --- | --- | --- | --- | --- | --- | --- | --- | --- | --- | --- | --- | --- | --- | --- |
| 1227 | 408.4 | **OSA Stage 2/3 enhancements** |  | 291d? | 2006-04-28 A | 2007-06-08 A | 100% | 2006-04-28 | 2007-06-08 | 291d? |  | C5 | 10256h | 10256h | OSA7 | 29.198/9, 23.198 | AePONA | damian.oneill@aepona.com | Rel-7 | Kimmo |  |  |
| 1228 | 408.4.1 | Parlay X Message Broadcast Web Service |  | 156d? | 2006-04-28 A | 2006-12-01 A | 100% | 2006-04-28 | 2006-12-01 | 156d? | finish no earlier than 2006-12-01 | C5 | 1248h | 1248h | OSA7 | 29.199-15, 23.198 | ETRI |  | Rel-7 | Kimmo |  |  |
| 1229 | 408.4.2 | Parlay X Geocoding Web Service |  | 156d? | 2006-04-28 A | 2006-12-01 A | 100% | 2006-04-28 | 2006-12-01 | 156d? | finish no earlier than 2006-12-01 | C5 | 1248h | 1248h | OSA7 | 29.199-16, 23.198 | ETRI |  | Rel-7 | Kimmo |  |  |
| 1230 | 408.4.3 | Parlay X Application driven QoS Web Service |  | 226d? | 2006-04-28 A | 2007-03-09 A | 100% | 2006-04-28 | 2007-03-09 | 226d? | finish no earlier than 2007-03-09 | C5 | 1808h | 1808h | OSA7 | 29.199-17, 23.198 | BT |  | Rel-7 | Kimmo |  |  |
| 1231 | 408.4.4 | Parlay-X Device Capabilities and Configuration |  | 162d? | 2006-10-26 A | 2007-06-08 A | 100% | 2006-10-26 | 2007-06-08 | 162d? | finish no earlier than 2007-06-09 | C5 | 1296h | 1296h | OSA7 | 29.199-18, 23.198 | Telenor |  | Rel-7 | Kimmo |  |  |
| 1232 | 408.4.5 | Parlay-X Multimedia Streaming Session Management Web Service |  | 97d? | 2006-10-26 A | 2007-03-09 A | 100% | 2006-10-26 | 2007-03-09 | 97d? | start no earlier than 2006-10-26 | C5 | 776h | 776h | OSA7 | 29.199-19, 23.198 | Telenor |  | Rel-7 | Kimmo |  |  |
| 1233 | 408.4.6 | Parlay-X Multimedia Multicast Control Web Service |  | 97d? | 2006-10-26 A | 2007-03-09 A | 100% | 2006-10-26 | 2007-03-09 | 97d? | start no earlier than 2006-10-26 | C5 | 776h | 776h | OSA7 | 29.199-20, 23.198 | ETRI |  | Rel-7 | Kimmo |  |  |
| 1234 | 408.4.7 | OSA API Conference Call Control SCF |  | 97d? | 2006-10-26 A | 2007-03-09 A | 100% | 2006-10-26 | 2007-03-09 | 97d? | start no earlier than 2006-10-26 | C5 | 776h | 776h | OSA7 | 29.198-04-5, 23.198 | Ericsson |  | Rel-7 | Kimmo |  |  |
| 1235 | 409 | **Selective Disabling of UE Capabilities** |  | 624.36d? | 2005-01-24 A | 2007-06-15 A | 100% | 2005-01-24 | 2007-06-15 | 624.36d? |  | S1,S2,C1 | 12351.7h | 12351.7h | SDoUE |  | Motorola |  | Rel-7 | Alain |  |  |
| 1236 | 409.1 | Stage 1 of SDoUE |  | 393.6d? | 2005-01-24 A | 2006-12-08 A | 100% | 2005-01-24 | 2006-12-08 | 393.6d? | finish no earlier than 2006-12-08 | S1 | 3148.8h | 3148.8h | SDoUE-CR | 22.011 | Motorola |  | Rel-7 | Alain |  |  |
| 1237 | 409.2 | Deleted - TR on different possible architectures |  | 195d? | 2005-03-21 A | 2005-12-16 A | 100% | 2005-03-21 | 2005-12-16 | 195d? | finish no earlier than 2005-12-16 | S2 | 1560h | 1560h | SDoUE-FS | 23.805 abandonned at SP-30; descendant C1 24.305 | Vodafone | Gavin.Wong@vodafone.com | Rel-7 | Maurice | SP-30 |  |
| 1238 | 409.3 | Stage 3 of SDoUE |  | 331d? | 2006-03-10 A | 2007-06-15 A | 100% | 2006-03-10 | 2007-06-15 | 331d? | finish no earlier than 2007-06-15 | C1 | 2648h | 2648h | SDoUE | 24.305 | Ericsson | christian.herrero@ericsson.com | Rel-7 | Frederic |  |  |
| 1239 | 410 | **Network selection enhancements (NSP)** |  | 328d? | 2006-03-15 A | 2007-06-15 A | 100% | 2006-03-15 | 2007-06-15 | 328d? |  | S1 | 6320h | 6320h | NSP-CR | 22.101, 22.011, 23.122, 24.008, 25.304, 31.102, 45.008 | O2 | chris.friel@o2.com | Rel-7 | Alain |  |  |
| 1240 | 410.1 | Stage 1 of NSP |  | 191d? | 2006-03-15 A | 2006-12-06 A | 100% | 2006-03-15 | 2006-12-06 | 191d? | start no earlier than 2006-03-15 | S1 | 1528h | 1528h | NSP-TS | 22.101, 22.011, 23.122, 24.008, 25.304, 31.102, 45.008 | O2 | chris.friel@o2.com | Rel-7 | Alain |  |  |
| 1241 | 410.2 | Procedural aspects of NSP |  | 271d? | 2006-06-02 A | 2007-06-15 A | 100% | 2006-06-02 | 2007-06-15 | 271d? | finish no earlier than 2007-06-15 | C1 | 2168h | 2168h | NSP-CR | 23.122, 24.008, 31.102 | Motorola | Andrew Howell | Rel-7 | Frederic |  |  |
| 1242 | 411 | Network selection enhancements (NSP) - UE Conformance Testing |  | 396d? | 2007-06-01 A | 2008-12-05 A | 100% | 2007-06-01 | 2008-12-05 | 396d? | finish no earlier than 2008-12-05 | R5 | 3168h | 3168h | NSP-CR_UEConTest | 34.108, 34.123-1, 34.123-2, 34.123-3 | Nokia | jarkko.hellsten@nokia.com | Rel-7 | Ingbert |  | RP-080819 |
| 1243 | 412 | **Access Class Barring and Overload Protection** |  | 650d? | 2004-03-15 A | 2006-09-08 A | 100% | 2004-03-15 | 2006-09-08 | 650d? |  | S2,C1 | 3568h | 3568h | ACBOP | 23.898 | Vodafone | Chris Pudney | Rel-7 | Maurice |  |  |
| 1244 | 412.1 | TR on Stage 2 |  | 274d? | 2004-03-15 A | 2005-03-31 A | 100% | 2004-03-15 | 2005-03-31 | 274d? | finish no earlier than 2005-03-31 | S2 | 2192h | 2192h | ACBOP | 23.898 | NTT DoCoMo | Jean-Jacques Davidian (davidian@docomo.fr) | Rel-7 | Maurice |  |  |
| 1245 | 412.2 | Stage 3 CN aspects of ACBOP |  | 172d? | 2005-06-06 A | 2006-01-31 A | 100% | 2005-06-06 | 2006-01-31 | 172d? | start no earlier than 2005-06-06 | C1 | 1376h | 1376h | ACBOP | 24.008 |  |  | Rel-7 | Frederic |  |  |
| 1246 | 412.3 | Deleted - Potential impact on Iu interface Overload functionality | milestone | 0d? | 2004-03-15 A | 2004-03-15 A | 100% | 2004-03-15 | 2004-03-15 | 0d? | finish no earlier than 2004-03-15 | RP |  |  | ACBOP | 25.413 |  |  | Rel-7 | Issam | RP-25 |  |
| 1247 | 412.4 | Deleted - Extra ACBOP information in RAN | milestone | 0d? | 2004-03-15 A | 2004-03-15 A | 100% | 2004-03-15 | 2004-03-15 | 0d? | finish no earlier than 2004-03-15 | RP |  |  | ACBOP | 25.331 |  |  | Rel-7 | Issam | RP-25 |  |
| 1248 | 412.5 | Deleted - Extra ACBOP information in GERAN | milestone | 0d? | 2006-09-08 A | 2006-09-08 A | 100% | 2006-09-08 | 2006-09-08 | 0d? | start no earlier than 2006-09-08 | GP |  |  | ACBOP | 44.018 |  |  | Rel-7 | Paolo | RP-33 |  |
| 1249 | 413 | **System enhancements for fixed broadband access to IMS** |  | 876d? | 2003-11-05 A | 2007-03-14 A | 100% | 2003-11-05 | 2007-03-14 | 876d? |  | S2,S3,S5,C1,C3,C4 | 36656h | 36656h | FBI |  |  |  | Rel-7 | Maurice |  |  |
| 1250 | 413.1 | **TISPAN Rel 1 related aspects** |  | 873d? | 2003-11-05 A | 2007-03-09 A | 100% | 2003-11-05 | 2007-03-09 | 873d? |  | S2 | 31568h | 31568h | FBI-TIS1 |  |  |  | Rel-7 | Maurice |  |  |
| 1251 | 413.1.1 | Stage 2 of FBI for TISPAN R1 |  | 365d? | 2004-10-14 A | 2006-03-08 A | 100% | 2004-10-14 | 2006-03-08 | 365d? | start no earlier than 2004-10-14 | S2 | 2920h | 2920h | FBI-TIS1 |  |  |  | Rel-7 | Maurice |  |  |

Notes:
- 1227: CP#34: WID updated. Completion 12/06 =>03/07
- 1228: -
- 1229: -
- 1230: -
- 1231: -
- 1232: -
- 1233: -
- 1234: -
- 1235: Moved from FS section Feb 06
- 1236: Moved from FS section Feb 06
- 1237: Moved from FS section Feb 06. Abandoned at SP-30
- 1238: -
- 1239: -
- 1240: -
- 1241: -
- 1242: RP#42 completed. Testing for Feature UID_7041 (NSP-CR)
- 1243: -
- 1244: -
- 1245: -
- 1246: -
- 1247: -
- 1248: -
- 1249: -
- 1250: -
- 1251: -

| ID | WBS | Task | Duration | Start | Finish | Complete | Baseline start | Baseline finish | Baseline duration | Constraint | Resources | Work | Actual work | Text1 | Text4 | Text5 | Text6 | Text8 | Text3 | Text12 |
| --- | --- | --- | --- | --- | --- | --- | --- | --- | --- | --- | --- | --- | --- | --- | --- | --- | --- | --- | --- | --- |
| 1252 | 413.1.2 | **Protocol impact of FBI for TISPAN R1** | 873d? | 2003-11-05 A | 2007-03-09 A | 100% | 2003-11-05 | 2007-03-09 | 873d? |  | C1 | 20720h | 20720h | FBI-TIS1 | Siemens | peter.leis@nsn.com | Rel-7 | Frederic |  |  |
| 1253 | 413.1.2.1 | CT1 aspects of FBI for TISPAN R1 | 802d? | 2003-11-05 A | 2006-11-30 A | 100% | 2003-11-05 | 2006-11-30 | 802d? | finish no earlier than 2006-11-30 | C1 | 6416h | 6416h | FBI-TIS1 | Siemens | peter.leis@nsn.com | Rel-7 | Frederic | 24.819, 24.229 |  |
| 1254 | 413.1.2.2 | CT3 aspects of FBI for TISPAN R1 | 808d? | 2003-11-05 A | 2006-12-08 A | 100% | 2003-11-05 | 2006-12-08 | 808d? | finish no earlier than 2006-12-08 | C3 | 6464h | 6464h | FBI-TIS1 | Siemens | peter.leis@nsn.com | Rel-7 | Gwiho | 29.163, 29.209 |  |
| 1255 | 413.1.2.3 | CT4 aspects of FBI for TISPAN R1 | 301d? | 2006-01-13 A | 2007-03-09 A | 100% | 2006-01-13 | 2007-03-09 | 301d? | finish no earlier than 2007-03-09 | C4 | 2408h | 2408h | FBI-TIS1-st3-c4 | Siemens | peter.leis@nsn.com | Rel-7 | Kimmo | 29.229 |  |
| 1256 | 413.1.3 | Security Enhancements for FBI | 118d? | 2005-06-28 A | 2005-12-08 A | 100% | 2005-06-28 | 2005-12-08 | 118d? | start no earlier than 2005-06-28 | S3 | 944h | 944h | FBI-ISE | Ericsson | Bengt.Sahlin@ericsson.com | Rel-7 | Dionisio | 33.203 |  |
| 1257 | 413.2 | **PacketCable Related aspects** | 291d? | 2006-02-01 A | 2007-03-14 A | 100% | 2006-02-01 | 2007-03-14 | 291d? |  | S2,S5,C1 | 5088h | 5088h | FBI-PCBL | CableLabs | Bernie McKibben | Rel-7 | Maurice |  |  |
| 1258 | 413.2.1 | Stage 1,2 of FBI for PacketCable | 228d? | 2006-02-01 A | 2006-12-15 A | 100% | 2006-02-01 | 2006-12-15 | 228d? | finish no earlier than 2006-12-15 | S2 | 1824h | 1824h | FBI-PCBL | CableLabs | Bernie McKibben | Rel-7 | Maurice | 22.228, 23.228 |  |
| 1259 | 413.2.2 | Protocol impact of FBI for PacketCable | 228d? | 2006-05-01 A | 2007-03-14 A | 100% | 2006-05-01 | 2007-03-14 | 228d? | finish no earlier than 2007-03-15 | C1 | 1824h | 1824h | FBI-PCBL |  |  | Rel-7 | Frederic |  |  |
| 1260 | 413.2.3 | SA5 Charging aspects of FBI for PacketCable | 180d? | 2006-03-31 A | 2006-12-07 A | 100% | 2006-03-31 | 2006-12-07 | 180d? | finish no earlier than 2006-12-07 | S5 | 1440h | 1440h | FBI-PCBL-CH | CableLabs | Bernie McKibben | Rel-7 | Dionisio | 32.240, 32.260, 32.298, 32.299 |  |
| 1261 | 414 | **Support of SMS over generic 3GPP IP access** | 696d? | 2004-10-14 A | 2007-06-14 A | 100% | 2004-10-14 | 2007-06-14 | 696d? |  | S2,C4,C1 | 12408h | 12408h | SMSIP | Huawei | zhangwenlin@huawei.com | Rel-7 | Maurice |  |  |
| 1262 | 414.1 | FS on SMSIP | 173d? | 2004-10-14 A | 2005-06-13 A | 100% | 2004-10-14 | 2005-06-13 | 173d? | start no earlier than 2004-10-14 | S2 | 1384h | 1384h | SMSIP | Huawei | zhangwenlin@huawei.com | Rel-7 | Maurice | 23.804 |  |
| 1263 | 414.2 | Stage 2 for SMSIP | 333d? | 2005-06-08 A | 2006-09-15 A | 100% | 2005-06-08 | 2006-09-15 | 333d? | finish no earlier than 2006-09-15 | S2 | 2664h | 2664h | SMSIP | Huawei | zhangwenlin@huawei.com | Rel-7 | Maurice | 23.204 |  |
| 1264 | 414.3 | **Stage 3 for SMSIP** | 527d? | 2005-06-08 A | 2007-06-14 A | 100% | 2005-06-08 | 2007-06-14 | 527d? |  | C4,C1 | 8360h | 8360h | SMSIP-St3 | Nokia | jari.jansson@nokia.com | Rel-7 | Kimmo |  |  |
| 1265 | 414.3.1 | CT1 aspects for SMSIP | 527d? | 2005-06-08 A | 2007-06-14 A | 100% | 2005-06-08 | 2007-06-14 | 527d? | finish no earlier than 2007-06-15 | C1 | 4216h | 4216h | SMSIP | Nokia | jari.jansson@nokia.com | Rel-7 | Frederic | 23.040, 24.229 |  |
| 1266 | 414.3.2 | CT4 aspects for SMSIP | 518d? | 2005-06-08 A | 2007-06-01 A | 100% | 2005-06-08 | 2007-06-01 | 518d? | finish no earlier than 2007-06-01 | C4 | 4144h | 4144h | SMSIP-St3-c4 | Nokia | jari.jansson@nokia.com | Rel-7 | Kimmo | 23.008, 29.002 |  |
| 1267 | 415 | **Evolution of Policy Control and Charging** | 817d? | 2004-10-14 A | 2007-11-30 A | 100% | 2004-10-14 | 2007-11-30 | 817d? |  | S2,S5,C3,C1 | 30336h | 30336h | PCC | Nokia | balazs.bertenyi@nsn.com | Rel-7 | Maurice |  |  |
| 1268 | 415.1 | Deleted - TR for PCC | 315d? | 2004-10-14 A | 2005-12-29 A | 100% | 2004-10-14 | 2005-12-29 | 315d? | finish no earlier than 2005-12-28 | S2 | 2520h | 2520h | PCC | Nokia | balazs.bertenyi@nsn.com | Rel-7 | Maurice | 23.803 | SP-33 |
| 1269 | 415.2 | Stage 2 for PCC | 315d? | 2005-07-04 A | 2006-09-15 A | 100% | 2005-07-04 | 2006-09-15 | 315d? | finish no earlier than 2006-09-15 | S2 | 2520h | 2520h | PCC | Nokia | balazs.bertenyi@nsn.com | Rel-7 | Maurice | 23.203 |  |
| 1270 | 415.3 | Evolution of policy control and flow based bearer level charging | 109d? | 2006-08-01 A | 2006-12-29 A | 100% | 2006-08-01 | 2006-12-29 | 109d? | start no earlier than 2006-08-01 | S2 | 872h | 872h | PCC | Nokia | balazs.bertenyi@nsn.com | Rel-7 | Maurice | 23.207, 23.002, 23.228 |  |
| 1271 | 415.4 | SA5 Charging aspects of PCC | 316d? | 2006-03-31 A | 2007-06-15 A | 100% | 2006-03-31 | 2007-06-15 | 316d? | finish no earlier than 2007-06-15 | S5 | 2528h | 2528h | PCC-CH | Orange | alain.bibas@orange-ft.com | Rel-7 | Dionisio | 32.250, 32.251, 32.298, 32.299 |  |
| 1272 | 415.5 | Gx reference point for Policy and Charging Control | 521d? | 2005-12-02 A | 2007-11-30 A | 100% | 2005-12-02 | 2007-11-30 | 521d? | finish no earlier than 2007-09-14 | C3 | 4168h | 4168h | PCC-Gx | Siemens | Thomas.Belling@nsn.com | Rel-7 | Gwiho | 29.212 (not progressed to Rel-7: 29.210, 29.207, 29.208) |  |
| 1273 | 415.6 | **Rx reference point for PCC CT3 aspects** | 521d? | 2005-12-02 A | 2007-11-30 A | 100% | 2005-12-02 | 2007-11-30 | 521d? |  | C3,C1 | 11192h | 11192h | PCC-Rx | Ericsson | j.javier.pastor@ericsson.com | Rel-7 | Gwiho |  |  |
| 1274 | 415.6.1 | PCC-Rx CT3 aspects | 521d? | 2005-12-02 A | 2007-11-30 A | 100% | 2005-12-02 | 2007-11-30 | 521d? | finish no earlier than 2007-09-14 | C3 | 4168h | 4168h | PCC-Rx-c3 | Ericsson | j.javier.pastor@ericsson.com | Rel-7 | Gwiho | 29.213, 29.214 (not progressed to Rel-7: 29.209, 29.211) |  |
| 1275 | 415.6.2 | PCC-Rx CT1 aspects | 357d? | 2005-12-02 A | 2007-06-15 A | 100% | 2005-12-02 | 2007-06-15 | 357d? | finish no earlier than 2007-06-15 | C1 | 2856h | 2856h | PCC-Rx-Gx-c1 | Ericsson | j.javier.pastor@ericsson.com | Rel-7 | Frederic | 24.229 |  |

Notes:
- 1252: -
- 1253: end date updated by CT1-chairman after CP#33
- 1254: -
- 1255: CT4#32: a set of CRs on FBI for cable labs
- 1256: Duplicated entry ("ACCSEC2", "Access Security Enhancements", SP-040865) deleted by A.Sultan
- 1257: -
- 1258: -
- 1259: -
- 1260: 03/2006 SP#31 WID approved
- 1261: SP#33 updated WID (removed MMS)
- 1262: SP#33 updated WID
- 1263: SP#33 updated WID
- 1264: CP#34 updated WID
- 1265: CP#34 updated WID
- 1266: CP#34 updated WID
- 1267: SP-29 approved WID. SP-31 updated WID adding SA5 charging. 23.125 will be discontinued from Rel-7.
- 1268: SP-30: S2 has no intention for TR completion
- 1269: SP-29 approved WID. SP-31 updated WID. 23.125 will be discontinued from Rel-7.
- 1270: SP-29 approved WID. SP-31 updated WID. 23.125 will be discontinued from Rel-7.
- 1271: SP-31 updated WID with SA5 charging.
- 1272: -
- 1273: WID approved at CP#30, Revised at CP#31, Revised at CP#33
- 1274: -
- 1275: -

| ID | WBS | Task | Type | Duration | Start | Finish | Complete | Baseline start | Baseline finish | Baseline duration | Constraint | Resources | Work | Actual work | Text1 | Text4 | Text5 | Text6 | Text8 | Text3 | Text12 |
| --- | --- | --- | --- | --- | --- | --- | --- | --- | --- | --- | --- | --- | --- | --- | --- | --- | --- | --- | --- | --- | --- |
| 1276 | 416 | **Voice call continuity between CS and IMS (incl. I-WLAN)** |  | 641d? | 2004-12-31 A | 2007-06-15 A | 100% | 2004-12-31 | 2007-06-15 | 641d? |  | S2,S1,S5,C1,C4 | 12224h | 12224h | VCC | Alcatel-Lucent | Keith Drage (drage@alcatel-lucent.com) | Rel-7 | Maurice |  |  |
| 1277 | 416.1 | TR for VCC |  | 245d? | 2004-12-31 A | 2005-12-08 A | 100% | 2004-12-31 | 2005-12-08 | 245d? | finish no earlier than 2005-12-08 | S2 | 1960h | 1960h | VCC | Alcatel-Lucent | Andy Bennett (andybennett@alcatel-lucent.com) | Rel-7 | Maurice | 23.806 |  |
| 1278 | 416.2 | Stage 1 for VCC |  | 140d? | 2005-03-17 A | 2005-09-28 A | 100% | 2005-03-17 | 2005-09-28 | 140d? | finish no earlier than 2005-09-28 | S1 | 1120h | 1120h | VCC | Alcatel-Lucent | Andy Bennett (andybennett@alcatel-lucent.com) | Rel-7 | Alain | 22.101 |  |
| 1279 | 416.3 | Stage 2 for VCC |  | 264d? | 2005-09-06 A | 2006-09-08 A | 100% | 2005-09-06 | 2006-09-08 | 264d? | finish no earlier than 2006-09-08 | S2 | 2112h | 2112h | VCC | Alcatel-Lucent | Andy Bennett (andybennett@alcatel-lucent.com) | Rel-7 | Maurice | 23.206 |  |
| 1280 | 416.4 | SA5 Charging aspects of VCC |  | 325d? | 2006-03-17 A | 2007-06-14 A | 100% | 2006-03-17 | 2007-06-14 | 325d? | finish no earlier than 2007-06-14 | S5 | 2600h | 2600h | VCC-CH | Orange | alain.bibas@orange-ft.com | Rel-7 | Dionisio | 32.250, 32.260 |  |
| 1281 | 416.5 | **Stage 3 for VCC** |  | 358d? | 2006-02-01 A | 2007-06-15 A | 100% | 2006-02-01 | 2007-06-15 | 358d? |  | C1,C4 | 4432h | 4432h | VCC | Alcatel-Lucent | Keith Drage (drage@alcatel-lucent.com) | Rel-7 | Frederic |  |  |
| 1282 | 416.5.1 | CT1 aspects of VCC |  | 358d? | 2006-02-01 A | 2007-06-15 A | 100% | 2006-02-01 | 2007-06-15 | 358d? | finish no earlier than 2007-06-15 | C1 | 2864h | 2864h | VCC | Alcatel-Lucent | Keith Drage (drage@alcatel-lucent.com) | Rel-7 | Frederic | 24.206, 24.216 |  |
| 1283 | 416.5.2 | CT4 aspects of VCC |  | 196d? | 2006-06-09 A | 2007-03-09 A | 100% | 2006-06-09 | 2007-03-09 | 196d? | start no earlier than 2006-06-09 | C4 | 1568h | 1568h | VCC-St3-c4 | Alcatel-Lucent | Keith Drage (drage@alcatel-lucent.com) | Rel-7 | Kimmo | 23.003 |  |
| 1284 | 416.5.3 | Deleted - CT3 aspects of VCC | milestone | 0d? | 2006-11-02 A | 2006-11-02 A | 100% | 2006-11-02 | 2006-11-02 | 0d? | finish no earlier than 2006-11-02 | C3 |  |  | VCC | Alcatel-Lucent | Keith Drage (drage@alcatel-lucent.com) | Rel-7 | Gwiho | 29.163 | CP-33 |
| 1285 | 417 | **One Tunnel solution for optimization of Packet Data Traffic** |  | 418d? | 2006-03-27 A | 2007-10-31 A | 100% | 2006-03-27 | 2007-10-31 | 418d? |  | S2 | 7048h | 7048h | OPTUNEL | Nokia | antti.j.pasanen@nokia.com | Rel-7 | Maurice |  |  |
| 1286 | 417.1 | Deleted - Study on Stage 2 for One Tunnel solution |  | 125d? | 2006-03-27 A | 2006-09-15 A | 100% | 2006-03-27 | 2006-09-15 | 125d? | finish no earlier than 2005-09-12 | S2 | 1000h | 1000h | OPTUNEL-Study | Nokia | antti.j.pasanen@nokia.com | Rel-7 | Maurice | 23.809 | SP-34 |
| 1287 | 417.2 | One Tunnel Deployment Guideline |  | 268d? | 2006-10-23 A | 2007-10-31 A | 100% | 2006-10-23 | 2007-10-31 | 268d? | finish no earlier than 2007-10-31 | S2 | 2144h | 2144h | OPTUNEL-Guide | Huawei | lan.liu@huawei.com | Rel-7 | Maurice | 23.919 |  |
| 1288 | 417.3 | Stage 2 specification for One Tunnel solution |  | 70d? | 2006-09-11 A | 2006-12-15 A | 100% | 2006-09-11 | 2006-12-15 | 70d? | finish no earlier than 2006-12-15 | S2 | 560h | 560h | OPTUNEL-Stage2 | Nokia | antti.j.pasanen@nokia.com | Rel-7 | Maurice | 23.060 |  |
| 1289 | 418 | **CSI Terminating Session handling** |  | 267d? | 2006-06-08 A | 2007-06-15 A | 100% | 2006-06-08 | 2007-06-15 | 267d? |  | S2,C1 | 4728h | 4728h | CSItermS | Samsung | Osok Song | Rel-7 | Maurice |  |  |
| 1290 | 418.1 | Stage 2 of CStermS |  | 192d? | 2006-06-08 A | 2007-03-02 A | 100% | 2006-06-08 | 2007-03-02 | 192d? | start no earlier than 2006-06-08 | S2 | 1536h | 1536h | CSItermS | Samsung | Osok Song | Rel-7 | Maurice | 23.279 |  |
| 1291 | 418.2 | Stage 3 of CStermS |  | 132d? | 2006-12-14 A | 2007-06-15 A | 100% | 2006-12-14 | 2007-06-15 | 132d? | finish no earlier than 2007-06-15 | C1 | 1056h | 1056h | CSItermS | Samsung | chenho.chin@samsung.com | Rel-7 | Frederic | 24.229, 24.279 |  |
| 1292 | 418.3 | Deleted - duplicated with UID 340015 -Stage 3 CSI Terminating Session handling | milestone | 0d? | 2007-03-09 A | 2007-03-09 A | 100% | 2007-03-09 | 2007-03-09 | 0d? | start no earlier than 2007-03-09 | C1 |  |  | CSItermS | Samsung | chenho.chin@samsung.com | Rel-7 | Frederic | 24.229, 24.179, 24.279 | CP-34 |
| 1293 | 419 | Liberty Alliance and 3GPP Security Interworking |  | 451d? | 2005-03-10 A | 2006-11-30 A | 100% | 2005-03-10 | 2006-11-30 | 451d? | finish no earlier than 2006-11-30 | S3 | 3608h | 3608h | LibSec | Nokia | Silke.Holtmanns@nokia.com | Rel-7 | Dionisio | 33.980 |  |
| 1294 | 420 | Trust Requirements for Open Platforms in 3GPP |  | 499d? | 2005-01-03 A | 2006-11-30 A | 100% | 2005-01-03 | 2006-11-30 | 499d? | finish no earlier than 2006-11-30 | S3 | 3992h | 3992h | TrustOP | Nokia | Silke.Holtmanns@nokia.com | Rel-7 | Dionisio | 33.905 |  |
| 1295 | 421 | Development of UEA2 and UIA2 |  | 268d? | 2004-12-01 A | 2005-12-09 A | 100% | 2004-12-01 | 2005-12-09 | 268d? | finish no earlier than 2005-12-09 | S3 | 2144h | 2144h | AlgUEA2 | TeliaSonera | per.christoffersson@teliasonera.com | Rel-7 | Dionisio | 35.919, 35.215, 35.216, 35.217, 35.218 |  |
| 1296 | 422 | Lawful Interception in the 3GPP Rel-7 architecture |  | 118d? | 2005-06-28 A | 2005-12-08 A | 100% | 2005-06-28 | 2005-12-08 | 118d? | start no earlier than 2005-06-28 | S3 | 944h | 944h | LI-7A | BMWI | berthold.wilhelm@regtp.de | Rel-7 | Dionisio | 33.106, 33.107, 33.108 |  |
| 1297 | 423 | Key establishment between a UICC and a terminal |  | 201.45d? | 2005-12-07 A | 2006-09-28 A | 100% | 2005-12-07 | 2006-09-28 | 201.45d? | finish no earlier than 2006-09-28 | S3 | 1611.6h | 1611.6h | KeyEstUTerm | Gemalto | mireille.pauliac@gemplus.com | Rel-7 | Dionisio | 33.110 |  |
| 1298 | 424 | NDS Authentication Framework Extension for Transport Layer Security |  | 50d? | 2006-09-28 A | 2006-12-06 A | 100% | 2006-09-28 | 2006-12-06 | 50d? | finish no earlier than 2006-09-28 | S3 | 400h | 400h | NDSAFTLS | Nokia | tiina.s.koskinen@nokia.com | Rel-7 | Dionisio | 33.310 |  |
| 1299 | 425 | **Security enhancements** |  | 319d? | 2005-09-12 A | 2006-11-30 A | 100% | 2005-09-12 | 2006-11-30 | 319d? |  | S3,C1,C4 | 4856h | 4856h | SEC7 |  |  | Rel-7 | Dionisio |  |  |
| 1300 | 425.1 | HTTPS connection between a UICC and a NAF |  | 1d? | 2005-09-12 A | 2005-09-12 A | 100% | 2005-09-12 | 2005-09-12 | 1d? | start no earlier than 2005-09-12 | S3,C1 | 8h | 8h | SEC7-HSUN | Gemalto | JSeif@axalto.com, mireille.pauliac@gemplus.com | Rel-7 | Dionisio | 33.918, 33.222, 24.109 |  |
| 1301 | 425.2 | 2G GBA: 2G SIM usage in 3GPP GAA framework |  | 61d? | 2005-09-12 A | 2005-12-05 A | 100% | 2005-09-12 | 2005-12-05 | 61d? | finish no earlier than 2005-12-05 | S3 | 488h | 488h | SEC7-2GGBA | Nokia | Silke.Holtmanns@nokia.com | Rel-7 | Dionisio | 33.920, 33.220 |  |
| 1302 | 425.3 | Generic Authentication Architecture usage extensions and optimizations |  | 319d? | 2005-09-12 A | 2006-11-30 A | 100% | 2005-09-12 | 2006-11-30 | 319d? | finish no earlier than 2006-11-30 | S3 | 2552h | 2552h | SEC7-GAA2 | Nokia | Silke.Holtmanns@nokia.com | Rel-7 | Dionisio | 33.220, 29.109, 24.109, (33.223 goes to R8) |  |

Notes:
- 1276: WID approved SP#27; updated SP#28; updated SP#32
- 1277: -
- 1278: -
- 1279: -
- 1280: 03/2006 SP#31 WID approved
- 1281: -
- 1282: -
- 1283: -
- 1284: -
- 1285: -
- 1286: S2#52 CREATED. TR for Info SP-33. SP-34: S2 Report intention to discontinue TR
- 1287: -
- 1288: S2#52 CREATED
- 1289: Triggered by the abandoned Study UID_32117
- 1290: -
- 1291: CP-34 approved WID. CP-35 updated WID
- 1292: CP-34 approved WID
- 1293: WID approved SP#27.
- 1294: WID approved SP#26.
- 1295: WID approved SP#26, Dependant on Funding Availability.
- 1296: -
- 1297: -
- 1298: TLS profile is moved to Rel-8
- 1299: -
- 1300: -
- 1301: -
- 1302: 33.223 goes to R8

| ID | WBS | Task | Duration | Start | Finish | Complete | Baseline start | Baseline finish | Baseline duration | Constraint | Resources | Work | Actual work | Text1 | Text4 | Text5 | Text6 | Text8 | Text3 | Text12 | Text2 | Text7 |
| --- | --- | --- | --- | --- | --- | --- | --- | --- | --- | --- | --- | --- | --- | --- | --- | --- | --- | --- | --- | --- | --- | --- |
| 1303 | 425.4 | **SS7 TCAP security Gateway** | 241d? | 2005-09-12 A | 2006-08-14 A | 100% | 2005-09-12 | 2006-08-14 | 241d? |  | S3,C4 | 1808h | 1808h | SEC7-NDS-TCAPsec | Siemens | marc.blommaert.ext@nsn.com | Rel-7 | Dionisio |  |  |  |  |
| 1304 | 425.4.1 | SA3 aspects of SEC7-NDS-TCAPsec | 130d? | 2005-09-12 A | 2006-03-10 A | 100% | 2005-09-12 | 2006-03-10 | 130d? | finish no earlier than 2006-03-10 | S3 | 1040h | 1040h | SEC7-NDS-TCAPsec-SA3 | Siemens | marc.blommaert.ext@nsn.com | Rel-7 | Dionisio | 33.204 |  |  |  |
| 1305 | 425.4.2 | TCAPsec Gateway | 96d? | 2006-04-03 A | 2006-08-14 A | 100% | 2006-04-03 | 2006-08-14 | 96d? | start no earlier than 2006-04-01 | C4 | 768h | 768h | SEC7-TCAP | Siemens | Ulrich.wiehe@gksag.de | Rel-7 | Kimmo | 29.204, 29.002 |  |  |  |
| 1306 | 426 | IMS Stage 3 IETF Protocol alignment | 589d? | 2004-12-10 A | 2007-03-14 A | 100% | 2004-12-10 | 2007-03-14 | 589d? | finish no earlier than 2007-03-15 | C1 | 4712h | 4712h | IMSProtoc |  |  | Rel-7 | Frederic | 24.930 |  |  |  |
| 1307 | 427 | **Interoperability between VGCS/VBS and A/Gb flexibility** | 253d? | 2006-03-22 A | 2007-03-09 A | 100% | 2006-03-22 | 2007-03-09 | 253d? |  | C1,C4 | 3296h | 3296h | VGCSFlex | Siemens | robert.zaus@nsn.com | Rel-7 | Frederic |  |  |  |  |
| 1308 | 427.1 | CT1 aspects of VGCSFlex | 159d? | 2006-03-22 A | 2006-10-30 A | 100% | 2006-03-22 | 2006-10-30 | 159d? | finish no earlier than 2006-10-30 | C1 | 1272h | 1272h | VGCSFlex | Siemens | robert.zaus@nsn.com | Rel-7 | Frederic | 43.068, 43.069 |  |  |  |
| 1309 | 427.2 | CT4 aspects of VGCSFlex | 253d? | 2006-03-22 A | 2007-03-09 A | 100% | 2006-03-22 | 2007-03-09 | 253d? | finish no earlier than 2007-03-09 | C4 | 2024h | 2024h | VGCSFlex-c4 | Siemens | robert.zaus@nsn.com | Rel-7 | Kimmo | 29.002 |  |  |  |
| 1310 | 428 | DIAMETER on the GGSN Gi interface | 586d? | 2004-09-10 A | 2006-12-08 A | 100% | 2004-09-10 | 2006-12-08 | 586d? | finish no earlier than 2006-12-08 | C3 | 4688h | 4688h | DIAMGi | Vodafone | Nico.Gabriele@vodafone.com | Rel-7 | Gwiho | 29.061 |  |  |  |
| 1311 | 429 | DIAMETER on the PDG Wi interface | 586d? | 2004-09-10 A | 2006-12-08 A | 100% | 2004-09-10 | 2006-12-08 | 586d? | finish no earlier than 2006-12-08 | C3 | 4688h | 4688h | DIAMWi | Vodafone | Nico.Gabriele@vodafone.com | Rel-7 | Gwiho | 29.161 |  |  |  |
| 1312 | 430 | Interworking between the 3GPP CS domain with BICC or ISUP as signalling protocol and external SIP-I networks | 478d? | 2006-09-22 A | 2008-07-22 A | 100% | 2006-09-22 | 2008-07-22 | 478d? | finish no earlier than 2007-09-14 | C3 | 3824h | 3824h | ExtSIPI | Siemens | Thomas.Belling@nsn.com | Rel-7 | Gwiho | 29.164 |  |  |  |
| 1313 | 431 | PDU multiplexing at Nb Interface with IP transport | 427d? | 2006-12-04 A | 2008-07-22 A | 100% | 2006-12-04 | 2008-07-22 | 427d? | start no earlier than 2006-12-04 | C3 | 3416h | 3416h | NbIPMux | Alcatel-Lucent | Jean.Rzeznik@alcatel-lucent.fr | Rel-7 | Gwiho | 29.414 |  |  |  |
| 1314 | 432 | **Mp (MRFC - MRFP) interface** | 345d? | 2006-02-13 A | 2007-06-08 A | 100% | 2006-02-13 | 2007-06-08 | 345d? |  | C4,C1 | 4384h | 4384h | Mp | Ericsson | philip.hodges@ericsson.com | Rel-7 | Kimmo |  |  |  |  |
| 1315 | 432.1 | CT1 aspects of Mp | 1d | 2006-02-13 A | 2006-02-13 A | 100% | 2006-02-13 | 2006-02-13 | 1d | finish no earlier than 2006-02-13 | C1 | 8h | 8h | Mp | Ericsson | philip.hodges@ericsson.com | Rel-7 | Frederic | 24.229 |  |  |  |
| 1316 | 432.2 | Deleted - CT3 aspects of Mp | 1d | 2006-09-22 A | 2006-09-22 A | 100% | 2006-09-22 | 2006-09-22 | 1d | start no earlier than 2006-09-22 | C3 | 8h | 8h | Mp | Ericsson | philip.hodges@ericsson.com | Rel-7 | Gwiho | 29.162 | CP-33 |  |  |
| 1317 | 432.3 | Procedures description | 201d? | 2006-06-02 A | 2007-03-09 A | 100% | 2006-06-02 | 2007-03-09 | 201d? | finish no earlier than 2007-03-09 | C4 | 1608h | 1608h | Mp-PROCc4 | Huawei | Chencheng@huawei.com | Rel-7 | Kimmo | 23.333 |  |  |  |
| 1318 | 432.4 | Stage 3 | 345d | 2006-02-13 A | 2007-06-08 A | 100% | 2006-02-13 | 2007-06-08 | 345d | finish no earlier than 2007-06-08 | C4 | 2760h | 2760h | Mp-St3c4 | Ericsson | philip.hodges@ericsson.com | Rel-7 | Kimmo | 29.333 |  |  |  |
| 1319 | 433 | Routeing of MT-SMS via the HPLMN | 71d? | 2006-12-01 A | 2007-03-09 A | 100% | 2006-12-01 | 2007-03-09 | 71d? | finish no earlier than 2007-03-09 | C4,C1 | 568h | 568h | SMSviaH | Vodafone | Nick.Russell@vodafone.com | Rel-7 | Kimmo | 23.040, 29.002 |  |  |  |
| 1320 | 434 | Mobile Termination whilst the MS is moving to another MSC | 60d? | 2007-03-09 A | 2007-05-31 A | 100% | 2007-03-09 | 2007-05-31 | 60d? | start no earlier than 2007-03-09 | C4 | 480h | 480h | MTmovMS | Alcatel-Lucent | bruno.landais@alcatel-lucent.fr | Rel-7 | Kimmo | 23.008, 23.012, 23.018, 23.078, 23.079, 29.002 |  |  |  |
| 1321 | 435 | ISIM API for Java Card | 620d? | 2005-03-14 A | 2007-07-27 A | 100% | 2005-03-14 | 2007-07-27 | 620d? | finish no earlier than 2007-07-27 | C6 | 4960h | 4960h | APIJAVA | Sun | Sebastian Hans | Rel-7 | Xavier | 31.103, 102 241 |  |  |  |
| 1322 | 436 | Rel-7 (U)SIM API Testing (TS 31.213) | 211d? | 2009-05-30 A | 2010-03-19 A | 100% | 2009-05-30 | 2010-03-19 | 211d? | finish no earlier than 2010-03-12 | C6 | 1688h | 1688h | USIM_API_test | Sagem Orga | gerrit.hartbrod@sagem-orga.com | Rel-7 | Xavier | 31.213 |  | PCG-23 | CP-44 |
| 1323 | 437 | High speed interface between the UICC and the ME | 311d? | 2006-09-22 A | 2007-11-30 A | 100% | 2006-09-22 | 2007-11-30 | 311d? | finish no earlier than 2007-11-30 | C6 | 2488h | 2488h | HSI | Gemalto | jacques.seif@GEMALTO.COM | Rel-7 | Xavier | 31.101 |  |  |  |
| 1324 | 438 | Video Codec Performance Requirements | 634d? | 2005-01-03 A | 2007-06-07 A | 100% | 2005-01-03 | 2007-06-07 | 634d? | finish no earlier than 2007-06-07 | S4 | 5072h | 5072h | VICPer | Siemens | juergen.pandel@siemens.com | Rel-7 | Paolo | 26.234, 26.235, 26.346, 26.140, 26.902 |  |  |  |
| 1325 | 439 | Dynamic and Interactive Multimedia Scenes | 583d? | 2005-03-15 A | 2007-06-07 A | 100% | 2005-03-15 | 2007-06-07 | 583d? | finish no earlier than 2007-06-07 | S4 | 4664h | 4664h | DIMS | Streamezzo | gaelle.martin-cocher@streamezzo.com | Rel-7 | Paolo | 26.140, 26.142, 26.234, 26.244, 23.346 |  |  |  |
| 1326 | 440 | 3G-324M Video Telephony Call Setup Times Improvements | 341d? | 2005-06-08 A | 2006-09-27 A | 100% | 2005-06-08 | 2006-09-27 | 341d? | finish no earlier than 2006-09-27 | S4 | 2728h | 2728h | VTCSTI | Vodafone | edward.hall@vodafone.co.uk | Rel-7 | Paolo | 26.911 |  |  |  |

Notes:
- 1303: -
- 1304: -
- 1305: -
- 1306: TR 24.930: Signalling flows for the session setup in the IM CN subsystem based on Session Initiation Protocol (SIP)
- 1307: Voice Group Call Service
- 1308: -
- 1309: -
- 1310: -
- 1311: -
- 1312: -
- 1313: -
- 1314: -
- 1315: -
- 1316: CP#34: CT3 not involved in Mp interface definition
- 1317: -
- 1318: -
- 1319: WID approved in CP#34
- 1320: -
- 1321: -
- 1322: CP#47 completed. Update of Rel-6 (U)SIM API for Java Card Testing UID_43007 under Rel-6 UICC/USIM enhancements and interworking UID_1800
- 1323: Following ETSI publication of TS 102 600, expected to be completed at CT6 meeting 45
- 1324: -
- 1325: -
- 1326: -

| ID | WBS | Task | Type | Duration | Start | Finish | Complete | Baseline start | Baseline finish | Baseline duration | Constraint | Resources | Work | Actual work | Text1 | Text4 | Text5 | Text6 | Text8 | Text12 |
| --- | --- | --- | --- | --- | --- | --- | --- | --- | --- | --- | --- | --- | --- | --- | --- | --- | --- | --- | --- | --- |
| 1327 | 441 | **Optimizations for Multimedia Telephony over IMS** |  | 0d? | 2005-09-28 A | 2005-09-28 A | 100% | 2005-09-28 | 2005-09-28 | 0d? |  | S4 |  |  | OMTIMS | Ericsson | olle.franceschi@ericsson.com | Rel-7 | Paolo |  |
| 1328 | 441.1 | Deleted - Characterisation of Adaptive Jitter Management Performance for VoIP Services | milestone | 0d? | 2005-09-28 A | 2005-09-28 A | 100% | 2005-09-28 | 2005-09-28 | 0d? | start no earlier than 2007-03-15 | S4 |  |  | OMTIMS-CAJMP | Lucent | dhuo@lucent.com | Rel-7 | Paolo | SP-35 |
| 1329 | 442 | End-to-End Multimedia Services Performance Metrics |  | 382d? | 2005-09-28 A | 2007-03-15 A | 100% | 2005-09-28 | 2007-03-15 | 382d? | finish no earlier than 2007-03-15 | S4 | 3056h | 3056h | E2EMSPM | China Mobile | zhangyanyf@chinamobile.com | Rel-7 | Paolo |  |
| 1330 | 443 | Packet Switched Streaming Enhancements |  | 261d? | 2006-06-08 A | 2007-06-07 A | 100% | 2006-06-08 | 2007-06-07 | 261d? | finish no earlier than 2007-06-07 | S4 | 2088h | 2088h | PSSe | Ericsson | olle.franceschi@ericsson.com | Rel-7 | Paolo |  |
| 1331 | 444 | **OAM&P Rel-7** |  | 472.86d? | 2005-09-02 A | 2007-06-26 A | 100% | 2005-09-02 | 2007-06-26 | 472.86d? |  | S5 | 82725.8h | 82725.8h | OAM7 | Huawei | Christian.Toche@huawei.com | Rel-7 | Dionisio |  |
| 1332 | 444.1 | **Network Infrastructure Management** |  | 465d? | 2005-09-02 A | 2007-06-14 A | 100% | 2005-09-02 | 2007-06-14 | 465d? |  | S5 | 41800h | 41800h | OAM7-NIM |  |  | Rel-7 | Dionisio |  |
| 1333 | 444.1.1 | Enhance NRM to accommodate NGN (IMS as basis of the Next Generation Network) |  | 465d? | 2005-09-02 A | 2007-06-14 A | 100% | 2005-09-02 | 2007-06-14 | 465d? | finish no earlier than 2007-06-14 | S5 | 3720h | 3720h | OAM7-NIM | Motorola |  | Rel-7 | Dionisio |  |
| 1334 | 444.1.2 | Co-operative Element Management interface (CO-OP) (Study + Implementation) |  | 400d? | 2005-09-02 A | 2007-03-15 A | 100% | 2005-09-02 | 2007-03-15 | 400d? | finish no earlier than 2007-03-15 | S5 | 3200h | 3200h | OAM7-NIM | Motorola |  | Rel-7 | Dionisio |  |
| 1335 | 444.1.3 | Network Management (NM) Itf-N performance criteria |  | 465d? | 2005-09-02 A | 2007-06-14 A | 100% | 2005-09-02 | 2007-06-14 | 465d? | finish no earlier than 2007-06-14 | S5 | 3720h | 3720h | OAM7-NIM | China Mobile |  | Rel-7 | Dionisio |  |
| 1336 | 444.1.4 | Delta synchronization between IRP Manager and IRP Agent (Study + Implementation) |  | 465d? | 2005-09-02 A | 2007-06-14 A | 100% | 2005-09-02 | 2007-06-14 | 465d? | finish no earlier than 2007-06-14 | S5 | 3720h | 3720h | OAM7-NIM | Siemens |  | Rel-7 | Dionisio |  |
| 1337 | 444.1.5 | Subscription Management (SuM) IRP Solution Sets |  | 330d? | 2005-09-02 A | 2006-12-07 A | 100% | 2005-09-02 | 2006-12-07 | 330d? | finish no earlier than 2006-12-07 | S5 | 2640h | 2640h | OAM7-NIM | Ericsson |  | Rel-7 | Dionisio |  |
| 1338 | 444.1.6 | Integration Reference Point (IRP) Security Management |  | 400d? | 2005-09-02 A | 2007-03-15 A | 100% | 2005-09-02 | 2007-03-15 | 400d? | finish no earlier than 2007-03-15 | S5 | 3200h | 3200h | OAM7-NIM | Huawei | Christian.Toche@huawei.com | Rel-7 | Dionisio |  |
| 1339 | 444.1.7 | Partial suspension of Itf-N during maintenance/testing (Study + Implementation) |  | 465d? | 2005-09-02 A | 2007-06-14 A | 100% | 2005-09-02 | 2007-06-14 | 465d? | finish no earlier than 2007-06-14 | S5 | 3720h | 3720h | OAM7-NIM | Siemens |  | Rel-7 | Dionisio |  |
| 1340 | 444.1.8 | Deleted - Management of Legacy Equipment |  | 336d? | 2005-09-02 A | 2006-12-15 A | 100% | 2005-09-02 | 2006-12-15 | 336d? | finish no earlier than 2006-12-15 | S5 | 2688h | 2688h | OAM7-NIM | Siemens |  | Rel-7 | Dionisio | SP-35 |
| 1341 | 444.1.9 | Deleted - Rules for Vendor Specific Extensions |  | 400d? | 2005-09-02 A | 2007-03-15 A | 100% | 2005-09-02 | 2007-03-15 | 400d? | finish no earlier than 2007-03-15 | S5 | 3200h | 3200h | OAM7-NIM | Siemens |  | Rel-7 | Dionisio | SP-35 |
| 1342 | 444.1.10 | Backward and Forward Compatibility of IRP systems |  | 465d? | 2005-09-02 A | 2007-06-14 A | 100% | 2005-09-02 | 2007-06-14 | 465d? | finish no earlier than 2007-06-14 | S5 | 3720h | 3720h | OAM7-NIM | Ericsson |  | Rel-7 | Dionisio |  |
| 1343 | 444.1.11 | Repeater Network Resource Model (NRM) definition |  | 214d? | 2006-02-13 A | 2006-12-07 A | 100% | 2006-02-13 | 2006-12-07 | 214d? | finish no earlier than 2006-12-07 | S5 | 1712h | 1712h | OAM7-NIM | China Mobile |  | Rel-7 | Dionisio |  |
| 1344 | 444.1.12 | UTRAN radio channel power monitoring |  | 284d? | 2006-02-13 A | 2007-03-15 A | 100% | 2006-02-13 | 2007-03-15 | 284d? | finish no earlier than 2007-03-15 | S5 | 2272h | 2272h | OAM7-NIM | China Mobile |  | Rel-7 | Dionisio |  |
| 1345 | 444.1.13 | Notification XML Schema |  | 71d? | 2006-12-07 A | 2007-03-15 A | 100% | 2006-12-07 | 2007-03-15 | 71d? | finish no earlier than 2007-03-15 | S5 | 568h | 568h | OAM7-NIM | Huawei | Christian.Toche@huawei.com | Rel-7 | Dionisio |  |
| 1346 | 444.2 | **Performance Management** |  | 465d? | 2005-09-02 A | 2007-06-14 A | 100% | 2005-09-02 | 2007-06-14 | 465d? |  | S5 | 22992h | 22992h | OAM7-PM |  |  | Rel-7 | Dionisio |  |
| 1347 | 444.2.1 | Performance measurements definition for CN CS |  | 400d? | 2005-09-02 A | 2007-03-15 A | 100% | 2005-09-02 | 2007-03-15 | 400d? | finish no earlier than 2007-03-15 | S5 | 3200h | 3200h | OAM7-PM | China Mobile |  | Rel-7 | Dionisio |  |
| 1348 | 444.2.2 | Enhancement UTRAN performance measurements definition |  | 465d? | 2005-09-02 A | 2007-06-14 A | 100% | 2005-09-02 | 2007-06-14 | 465d? | finish no earlier than 2007-06-14 | S5 | 3720h | 3720h | OAM7-PM | China Mobile |  | Rel-7 | Dionisio |  |
| 1349 | 444.2.3 | Add TDD specific counters in Performance measurement |  | 330d? | 2005-09-02 A | 2006-12-07 A | 100% | 2005-09-02 | 2006-12-07 | 330d? | finish no earlier than 2006-12-15 | S5 | 2640h | 2640h | OAM7-PM | CATT |  | Rel-7 | Dionisio |  |
| 1350 | 444.2.4 | ATM bearer network Performance measurements |  | 400d? | 2005-09-02 A | 2007-03-15 A | 100% | 2005-09-02 | 2007-03-15 | 400d? | finish no earlier than 2007-03-15 | S5 | 3200h | 3200h | OAM7-PM | ZTE |  | Rel-7 | Dionisio |  |
| 1351 | 444.2.5 | Performance measurements definition for IMS |  | 465d? | 2005-09-02 A | 2007-06-14 A | 100% | 2005-09-02 | 2007-06-14 | 465d? | finish no earlier than 2007-06-14 | S5 | 3720h | 3720h | OAM7-PM | China Mobile |  | Rel-7 | Dionisio |  |
| 1352 | 444.2.6 | HSDPA performance measurements |  | 349d? | 2006-02-13 A | 2007-06-14 A | 100% | 2006-02-13 | 2007-06-14 | 349d? | finish no earlier than 2007-06-14 | S5 | 2792h | 2792h | OAM7-PM | China Mobile |  | Rel-7 | Dionisio |  |

Notes:
- 1327: - / Text3: 26.235, 26.236
- 1328: SP-35 stopped
- 1329: - / Text3: 26.944
- 1330: - / Text3: 26.234, 26.244
- 1331: - / Text3: TR 30.817
- 1332: -
- 1333: - / Text3: 32.731/2/3/5, 32.631/2/3/5
- 1334: - / Text3: 32.806, 32.814, 32.101
- 1335: - / Text3: 32.811
- 1336: - / Text3: 32.391/2/3/5
- 1337: - / Text3: 32.307/317/607/667/665, 32.101, 32.175
- 1338: - / Text3: 32.372/3/5, 32.111,32.30x,32.32x,32.33x,32.34x,32.35x,32.36x,32.41x,32.60x,32.61x,32.66x
- 1339: - / Text3: 32.381/2/3/5
- 1340: Request to TSG#35 to STOP the WI / Text3: new 32.xxx
- 1341: Request to TSG#35 to STOP the WI / Text3: 32.62n; For n = 1 to 5
- 1342: - / Text3: 32.154
- 1343: - / Text3: 32.721/2/3/5
- 1344: - / Text3: 32.405, 32.64n; For n = 1 to 5
- 1345: 12/2006 SP#34 WID approved / Text3: New 32.325/345/365/415, CR to 32.335/615/665
- 1346: -
- 1347: - / Text3: 32.407, 32.408
- 1348: - / Text3: 32.405
- 1349: - / Text3: 32.405
- 1350: - / Text3: No impact on 32.404, 32.405, 32.406, 32.407
- 1351: - / Text3: 32.404,32.409,32.437, 32.632/3/4/5
- 1352: - / Text3: 32.405

| ID | WBS | Task | Type | Duration | Start | Finish | Complete | Baseline start | Baseline finish | Baseline duration | Constraint | Resources | Work | Actual work | Text1 | Text4 | Text6 | Text8 | Text12 | Text5 | Text11 |
| --- | --- | --- | --- | --- | --- | --- | --- | --- | --- | --- | --- | --- | --- | --- | --- | --- | --- | --- | --- | --- | --- |
| 1353 | 44.5 | **Trace Management** |  | 472.86d? | 2005-09-02 A | 2007-06-26 A | 100% | 2005-09-02 | 2007-06-26 | 472.86d? |  | S5 | 14150.9h | 14150.9h | OAM7-Trace | Vodafone | Rel-7 | Dionisio |  |  |  |
| 1354 | 444.3.1 | End-to-end Service Level tracing for IMS |  | 350d? | 2005-11-11 A | 2007-03-15 A | 100% | 2005-11-11 | 2007-03-15 | 350d? | finish no earlier than 2007-03-15 | S5 | 2800h | 2800h | OAM7-Trace | Vodafone | Rel-7 | Dionisio | SP-31 |  |  |
| 1355 | 444.3.2 | Trace record content for UTRAN TDD |  | 330d? | 2005-09-02 A | 2006-12-07 A | 100% | 2005-09-02 | 2006-12-07 | 330d? | finish no earlier than 2006-12-07 | S5 | 2640h | 2640h | OAM7-Trace | Nokia | Rel-7 | Dionisio |  |  |  |
| 1356 | 444.3.3 | IRP for Subscriber and Equipment Trace Management |  | 465d? | 2005-09-02 A | 2007-06-14 A | 100% | 2005-09-02 | 2007-06-14 | 465d? | finish no earlier than 2007-06-14 | S5 | 3720h | 3720h | OAM7-Trace | Nokia | Rel-7 | Dionisio |  |  |  |
| 1357 | 444.3.4 | Deleted - SIP enhancements for trace | milestone | 0d? | 2007-06-15 A | 2007-06-26 A | 100% | 2007-06-15 | 2007-06-26 | 0d? | start no earlier than 2007-06-15 | C1 |  |  | OAM7-Trace |  | Rel-7 | Frederic | CP-32 |  |  |
| 1358 | 444.3.5 | Deleted - duplicated with UID 35063 - IRP for Subscriber and Equipment Trace Management |  | 336d? | 2005-09-02 A | 2006-12-15 A | 100% | 2005-09-02 | 2006-12-15 | 336d? | finish no earlier than 2006-12-15 | S5 | 2688h | 2688h | OAM7-Trace | Nokia | Rel-7 | Dionisio | SP-33 |  |  |
| 1359 | 445 | **Charging Management small Enhancements Rel-7** |  | 279d? | 2006-05-22 A | 2007-06-14 A | 100% | 2006-05-22 | 2007-06-14 | 279d? |  | S5 | 5952h | 5952h | CH7 | Orange | Rel-7 | Dionisio |  | alain.bibas@orange-ft.com |  |
| 1360 | 445.1 | Alternate Charged Party (ACP) for IMS |  | 279d? | 2006-05-22 A | 2007-06-14 A | 100% | 2006-05-22 | 2007-06-14 | 279d? | finish no earlier than 2007-06-14 | S5 | 2232h | 2232h | CH7-IMS-ACP | Lucent | Rel-7 | Dionisio |  | njmazzarella@alcatel-lucent.com |  |
| 1361 | 445.2 | Align 3GPP Charging with OMA PoC Enabler Release 2.0 |  | 186d? | 2006-09-28 A | 2007-06-14 A | 100% | 2006-09-28 | 2007-06-14 | 186d? | finish no earlier than 2007-06-14 | S5 | 1488h | 1488h | CH7-PoC | Siemens | Rel-7 | Dionisio |  | Gerald.Goermer@nsn.com |  |
| 1362 | 8.5 | **Multiple-Input Multiple-Output (MIMO) antennas** |  | 1301d? | 2003-03-14 A | 2008-03-07 A | 100% | 2003-03-14 | 2008-03-07 | 1301d? |  | R1,R5 | 45440h | 45440h | MIMO | Alcatel-Lucent | Rel-7 | Patrick |  | hchuang@Alcatel-Lucent.com | RP-070037, RP-070531 |
| 1363 | 446.1 | MIMO - Physical layer |  | 915d? | 2003-09-12 A | 2007-03-15 A | 100% | 2003-09-12 | 2007-03-15 | 915d? | finish no earlier than 2007-03-15 | R1 | 7320h | 7320h | MIMO-Phys | Alcatel-Lucent | Rel-7 | Patrick |  | hchuang@Alcatel-Lucent.com | RP-070037 |
| 1364 | 446.2 | MIMO - Layer 2,3 aspects |  | 915d? | 2003-09-12 A | 2007-03-15 A | 100% | 2003-09-12 | 2007-03-15 | 915d? | finish no earlier than 2007-03-15 | R2 | 7320h | 7320h | MIMO-L23 | Alcatel-Lucent | Rel-7 | Joern |  | hchuang@Alcatel-Lucent.com | RP-070037 |
| 1365 | 446.3 | MIMO - Iub/Iur Protocol Aspects |  | 1045d? | 2003-03-14 A | 2007-03-15 A | 100% | 2003-03-14 | 2007-03-15 | 1045d? | finish no earlier than 2007-03-15 | R3 | 8360h | 8360h | MIMO-IurIub | Alcatel-Lucent | Rel-7 | Juha |  | hchuang@Alcatel-Lucent.com | RP-070037 |
| 1366 | 446.4 | MIMO - RF Radio Transmission/Reception, System Performance Requirements and Conformance Testing |  | 982d? | 2003-12-12 A | 2007-09-17 A | 100% | 2003-12-12 | 2007-09-17 | 982d? | finish no earlier than 2007-09-17 | R4 | 7856h | 7856h | MIMO-RF | Alcatel-Lucent | Rel-7 | Issam |  | ngm@Alcatel-Lucent.com | RP-070531 |
| 1367 | 446.5 | **UE Conformance Testing for Multiple Input Multiple Output antennas (MIMO)** |  | 261d? | 2007-03-09 A | 2008-03-07 A | 100% | 2007-03-09 | 2008-03-07 | 261d? |  | R5 | 4176h | 4176h | MIMO-UEConTest | Qualcomm | Rel-7 | Ingbert |  | svora@qualcomm.com |  |
| 1368 | 446.5.1 | Conformance Test Aspects – Multiple Input Multiple Output Antennas (MIMO) for FDD |  | 261d? | 2007-03-09 A | 2008-03-07 A | 100% | 2007-03-09 | 2008-03-07 | 261d? | finish no earlier than 2008-03-07 | R5 | 2088h | 2088h | MIMO-UEConTest_FDD | Qualcomm | Rel-7 | Ingbert |  | svora@qualcomm.com |  |
| 1369 | 447 | **Rel-7 Improvements of the Radio Interface** |  | 709d? | 2004-09-15 A | 2007-06-04 A | 100% | 2004-09-15 | 2007-06-04 | 709d? |  | RP | 29696h | 29696h | RInImp |  | Rel-7 | Issam |  |  |  |
| 1370 | 447.1 | Extended UMTS 1.7/2.1 GHz |  | 198d? | 2006-03-15 A | 2006-12-15 A | 100% | 2006-03-15 | 2006-12-15 | 198d? | finish no earlier than 2006-12-15 | R4 | 1584h | 1584h | RInImp-UMTS1721Ext | Ericsson | Rel-7 | Issam |  | Johan Sköld (johan.skold@ericsson.com) | RP-060681 |
| 1371 | 447.2 | UMTS 2.6 GHz 7.68 Mcps TDD |  | 67d? | 2006-06-15 A | 2006-09-15 A | 100% | 2006-06-15 | 2006-09-15 | 67d? | finish no earlier than 2006-09-15 | R4 | 536h | 536h | RInImp-UMTS26VHCRTDD | IPWireless | Rel-7 | Issam |  | Shin Horng Wong (shwong@ipwireless.com) | RP-060451 |
| 1372 | 447.3 | UMTS 2.6 GHz |  | 195d? | 2004-09-15 A | 2005-06-14 A | 100% | 2004-09-15 | 2005-06-14 | 195d? | finish no earlier than 2005-06-14 | R4 | 1560h | 1560h | RInImp-UMTS2600 | Nokia | Rel-7 | Issam |  | jussi.numminen@nokia.com | RP-050184 |
| 1373 | 447.4 | UMTS 2.6 GHz TDD |  | 261d? | 2004-12-15 A | 2005-12-14 A | 100% | 2004-12-15 | 2005-12-14 | 261d? | finish no earlier than 2005-12-15 | R4 | 2088h | 2088h | RInImp-UMTS2600TDD | IPWireless | Rel-7 | Issam |  | Shin Horng Wong (shwong@ipwireless.com) | RP-050661 |
| 1374 | 447.5 | UMTS 900 MHz |  | 261d? | 2004-12-15 A | 2005-12-14 A | 100% | 2004-12-15 | 2005-12-14 | 261d? | finish no earlier than 2005-12-15 | R4 | 2088h | 2088h | RInImp-UMTS900 | Nortel | Rel-7 | Issam |  | Yannick Li (yli@nortelnetworks.com) | RP-050662 |
| 1375 | 447.6 | UMTS 1700 MHz |  | 197d? | 2005-03-15 A | 2005-12-14 A | 100% | 2005-03-15 | 2005-12-14 | 197d? | finish no earlier than 2005-12-15 | R4 | 1576h | 1576h | RInImp-UMTS1700 | NTT DoCoMo | Rel-7 | Issam |  | Takehiro Nakamura (nakamurata@nttdocomo.co.jp) | RP-050824 |
| 1376 | 447.7 | UE Antenna Performance Evaluation Method and Requirements |  | 644d? | 2004-12-15 A | 2007-06-04 A | 100% | 2004-12-15 | 2007-06-04 | 644d? | finish no earlier than 2007-06-04 | R4 | 5152h | 5152h | RInImp-UEAnt | TeliaSonera | Rel-7 | Issam |  | Christian.Bergljung@TeliaSonera.com | RP-070281 |
| 1377 | 447.8 | Improved Performance Requirements for HSDPA UE based on Rx Diversity (type 1) & LMMSE equalizer (type 2) | milestone | 0d? | 2005-03-15 A | 2005-03-15 A | 100% | 2005-03-15 | 2005-03-15 | 0d? | finish no earlier than 2005-03-15 | R4 |  |  | RInImp-HSPerf-Type3 | Cingular | Rel-7 | Issam |  | Marc Grant | RP-060015 |

Notes:
- 1353: -
- 1354: 07/2005: OMA (Stage 1), Stage 2/3 SA5, CT1/3/4 / Text3: CR 32.101, 32.421/2/3.
- 1355: - / Text3: CR 32.421/2/3.
- 1356: - / Text3: 32.441/2/3/5, CRs 32.632/3/5
- 1357: combined with UID 11067
- 1358: - / Text3: 32.421,32.422,32.423. 3 new 32.4x1,2,3
- 1359: - / Text3: TR 30.817
- 1360: - / Text3: 32.240, 32.260, 32.298, 32.299
- 1361: 09/2006 SP#33 WID approved / Text3: 32.240, 32.272, 32.299, 32.298
- 1362: Completed Sep 2007; SR in RP-070037and RP-070531 / Text3: 25.876, 25.996
- 1363: Completed Sep 2007; SR in RP-070037 / Text3: 25.211, 25.212, 25.213, 25.214, 25.215, 25.221
- 1364: Completed Sep 2007; SR in RP-070037 / Text3: 25.876
- 1365: Completed Sep 2007; SR in RP-070037
- 1366: Completed Sep 2007; SR in RP-070531
- 1367: BB place holder for a number of RAN5 Tasks
- 1368: - / Text3: TS 34.108, TS 34.109, TS 34.121-1, TS 34.121-2, TS 34.123-1, TS 34.123-2, TS 34.123-3
- 1369: Generic feature
- 1370: RP#34 completed. Introduction of Band X (Extended UMTS 1.7/2.1 GHz) in 25.307 / Text3: 25.806, 25.101, 25.104, 25.133, 24.141, 25.331, 25.306, 25.307, 25.423, 25.461, 25.463, 34.121
- 1371: RP#33 completed / Text3: 25.102, 25.105, 25.123, 25.113, 25.142, 34.124
- 1372: RP#28 completed / Text3: 25.101, 25.104, 25.133, 25.141, 25.331, 25.942, 25.306, 25.307, 34.121
- 1373: RP#30 completed / Text3: 25.102, 25.105, 25.113, 25.123, 25.142, 25.331, 25.942, 25.306, 25.307, 34.122, 34.124
- 1374: RP#30 completed / Text3: 25.101, 25.104, 25.113, 25.133, 25.141, 25.331, 25.942, 25.306, 25.307, 34.121
- 1375: RP#30 completed / Text3: 25.101, 25.104, 25.113, 25.133, 25.141, 25.306, 25.307, 25.331, 34.121
- 1376: RP#36 completed / Text3: 25.101, 25.963
- 1377: RP#27 completed / Text3: 25.101

| ID | WBS | Task | Type | Duration | Start | Finish | Complete | Baseline start | Baseline finish | Baseline duration | Constraint | Deadline | Resources | Work | Actual work | Text1 | Text4 | Text5 | Text6 | Text8 | Text11 | Text12 | Text9 | Text10 |
| --- | --- | --- | --- | --- | --- | --- | --- | --- | --- | --- | --- | --- | --- | --- | --- | --- | --- | --- | --- | --- | --- | --- | --- | --- |
| 1378 | 447.9 | **Additional minimum UE performance requirement for non-HSDPA channels based on type 1 enhanced receiver (Rx Diversity)** |  | 327d? | 2005-09-15 A | 2006-12-15 A | 100% | 2005-09-15 | 2006-12-15 | 327d? |  |  | R4 | 7344h | 7344h | RInImp-RxDiv | Qualcomm | Serge Willenegger (sergew@qualcomm.com) | Rel-7 | Issam |  |  |  |  |
| 1379 | 447.9.1 | Additional minimum UE performance requirement for DL physical channels in support of DCH/HS-DSCH operation based on type 1 enhanced receiver (RX-Diversity) |  | 195d? | 2005-09-15 A | 2006-06-14 A | 100% | 2005-09-15 | 2006-06-14 | 195d? | finish no earlier than 2006-06-15 |  | R4 | 1560h | 1560h | RInImp-RxDiv-DCH | Cingular | Marc Grant | Rel-7 | Issam | RP-060235 |  |  |  |
| 1380 | 447.9.2 | Additional minimum UE performance requirement for downlink physical channels in support of MTCH and MCCH operation based on type 1 enhanced receiver (Rx-Diversity) |  | 198d? | 2006-03-15 A | 2006-12-15 A | 100% | 2006-03-15 | 2006-12-15 | 198d? | finish no earlier than 2006-12-15 |  | R4 | 1584h | 1584h | RInImp-RxDiv-MBMS | Qualcomm | Serge Willenegger (sergew@qualcomm.com) | Rel-7 | Issam | RP-060678 |  |  |  |
| 1381 | 447.9.3 | Additional minimum UE performance requirement for downlink physical channels in support of E-DCH operation based on type 1 enhanced receiver (Rx-Diversity) |  | 198d? | 2006-03-15 A | 2006-12-15 A | 100% | 2006-03-15 | 2006-12-15 | 198d? | finish no earlier than 2006-12-15 |  | R4 | 1584h | 1584h | RInImp-RxDiv-EDCH | Qualcomm | Serge Willenegger (sergew@qualcomm.com) | Rel-7 | Issam | RP-060679 |  |  |  |
| 1382 | 447.10 | Deleted Improved support of gaming over HSDPA/EDCH |  | 262d? | 2005-12-15 A | 2006-12-15 A | 100% | 2005-12-15 | 2006-12-15 | 262d? | finish no earlier than 2006-12-15 |  | R2 | 2096h | 2096h | RInImp-Gaming | Cingular | Don Zelmer (dz1069@att.com) | Rel-7 | Joern | RP-060680 | RP-34 |  |  |
| 1383 | 447.11 | Deleted (not approved at PCG) - UMTS 2.6 GHz FDD DL External | milestone | 0d? | 2005-09-15 A | 2005-09-15 A | 100% | 2005-09-15 | 2005-09-15 | 0d? | finish no earlier than 2005-09-15 |  | R4 |  |  | RInImp-UMTS2600Ext | T-mobile | han.van.bussel@t-mobile.de | Rel-7 | Issam |  | RP-31 | PCG-16 |  |
| 1384 | 448 | **Rel-7 Improvements of the Radio Interface - UE Conformance Testing** |  | 741d? | 2005-11-11 A | 2008-09-12 A | 100% | 2005-11-11 | 2008-09-12 | 741d? |  |  | R5 | 17568h | 17568h | RInImp-UEConTest |  |  | Rel-7 | Ingbert |  |  |  |  |
| 1385 | 16.5.1 | UE Conformance Test for UMTS 2600 MHz |  | 146d | 2005-11-11 A | 2006-06-02 A | 100% | 2005-11-11 | 2006-06-02 | 146d | finish no earlier than 2006-06-02 | 2006-06-02 | R5 | 1168h | 1168h | RInImp-UMTS2600_Test | Nokia | Aleksi.Heino@nokia.com | Rel-7 | Ingbert |  |  |  | Fri 7/11/05 |
| 1386 | 16.5.1 | UE Conformance Test for UMTS 900 MHz (band VIII) |  | 146d | 2005-11-11 A | 2006-06-02 A | 100% | 2005-11-11 | 2006-06-02 | 146d | finish no earlier than 2006-06-02 | 2006-06-02 | R5 | 1168h | 1168h | RInImp-UMTS900_Test | Qualcomm | hanye@qualcomm.com | Rel-7 | Ingbert |  |  |  | Fri 11/03/05 |
| 1387 | 448.3 | Conformance Test Aspects – Improved Performance of HSDPA Receiver type 3 |  | 191d? | 2006-03-10 A | 2006-12-01 A | 100% | 2006-03-10 | 2006-12-01 | 191d? | finish no earlier than 2006-12-01 |  | R5 | 1528h | 1528h | RInImp-HSPerf-Type3_Test | Motorola | carolyn.taylor@motorola.com | Rel-7 | Ingbert |  |  |  |  |
| 1388 | 448.4 | UE antenna Over The Air (OTA) conformance testing |  | 518d? | 2006-09-20 A | 2008-09-12 A | 100% | 2006-09-20 | 2008-09-12 | 518d? | finish no earlier than 2008-09-12 |  | R5 | 4144h | 4144h | RInImp-UEAnt_Test | Nokia | Aleksi.Heino@nokia.com | Rel-7 | Ingbert | RP-080535 |  |  |  |
| 1389 | 448.5 | UE conformance testing for FDD Inter-Band Operation |  | 131d? | 2006-06-02 A | 2006-12-01 A | 100% | 2006-06-02 | 2006-12-01 | 131d? | finish no earlier than 2006-12-01 |  | R5 | 1048h | 1048h | RInImp-InterBand_Test | NEC, Motorola | Jacob.John@motorola.com | Rel-7 | Ingbert |  |  |  |  |
| 1390 | 448.6 | Conformance Test Aspects – Extended UMTS 1.7/2.1 GHz |  | 131d? | 2006-12-01 A | 2007-06-01 A | 100% | 2006-12-01 | 2007-06-01 | 131d? | finish no earlier than 2007-06-01 |  | R5 | 1048h | 1048h | RInImp-UEConTest_UMTS1721Ext | Motorola | carolyn.taylor@motorola.com | Rel-7 | Ingbert | RP-070312 |  |  |  |
| 1391 | 448.7 | Conformance Test Aspects – Minimum UE performance requirement for downlink physical channels in support of E-DCH operation based on type 1 enhanced receiver (Rx-Diversity) |  | 136d? | 2007-06-01 A | 2007-12-07 A | 100% | 2007-06-01 | 2007-12-07 | 136d? | finish no earlier than 2007-12-07 |  | R5 | 1088h | 1088h | RInImp-UEConTest_RxDivEDCH | Motorola | carolyn.taylor@motorola.com | Rel-7 | Ingbert | RP-070810 |  |  |  |
| 1392 | 448.8 | Conformance Test Aspects – Minimum UE performance requirement for downlink physical channels in support of MTCGH and MCCH operation based on type 1 enhanced receiver (Rx-Diversity) |  | 201d? | 2007-06-01 A | 2008-03-07 A | 100% | 2007-06-01 | 2008-03-07 | 201d? | finish no earlier than 2008-03-07 |  | R5 | 1608h | 1608h | RInImp-UEConTest_RxDivMBMS | Ericsson | leif.mattisson@ericsson.com | Rel-7 | Ingbert | RP-080056 |  |  |  |
| 1393 | 449 | **Rel-7 RAN improvements** |  | 653d? | 2004-12-15 A | 2007-06-15 A | 100% | 2004-12-15 | 2007-06-15 | 653d? |  |  | RP | 29952h | 29952h | RANimp |  |  | Rel-7 |  |  |  |  |  |
| 1394 | 449.1 | Optimization of channelisation code utilisation for 1.28 Mcps TDD |  | 523d? | 2004-12-15 A | 2006-12-15 A | 100% | 2004-12-15 | 2006-12-15 | 523d? | finish no earlier than 2006-12-15 |  | R1 | 4184h | 4184h | RANimp-RABSE-CodOptLCRTDD | UTStarcom | Ka Leong Lo (kaleong.lo@UTSTAR.COM) | Rel-7 | Patrick | RP-060682 |  |  |  |
| 1395 | 449.2 | Delay optimization for procedures applicable to CS and PS Connections |  | 394d? | 2005-03-15 A | 2006-09-15 A | 100% | 2005-03-15 | 2006-09-15 | 394d? | finish no earlier than 2006-09-15 |  | R2 | 3152h | 3152h | RANimp-DelayOpt | Nokia | juho.pirskanen@nokia.com | Rel-7 | Joern | RP-060453 |  |  |  |
| 1396 | 449.3 | Improved support of IMS Realtime Services using HSDPA/HSUPA |  | 197d? | 2005-03-15 A | 2005-12-14 A | 100% | 2005-03-15 | 2005-12-14 | 197d? | start no earlier than 2005-03-15 |  | R2 | 1576h | 1576h | RANimp-IMSRealTime | Cingular | Don Zelmer (dz1069@att.com) | Rel-7 | Joern | RP-050667 |  |  |  |
| 1397 | 449.4 | UE Performance Requirements for MBMS (TDD) |  | 328d? | 2005-03-15 A | 2006-06-15 A | 100% | 2005-03-15 | 2006-06-15 | 328d? | finish no earlier than 2006-06-15 |  | R4 | 2624h | 2624h | MBMS-RAN-RF-TDD | IPwireless | shwong@ipwireless.com | Rel-7 | Issam | RP-060477 |  |  |  |
| 1398 | 449.5 | Continuous connectivity for packet data users |  | 524d? | 2005-03-14 A | 2007-03-15 A | 100% | 2005-03-14 | 2007-03-15 | 524d? | finish no earlier than 2007-03-15 |  | R1 | 4192h | 4192h | RANimp-CPC | Siemens | Joern.Krause@siemens.com | Rel-7 | Patrick | RP-070033 |  |  |  |
| 1399 | 449.6 | Extended WCDMA Cell Range |  | 198d? | 2006-03-15 A | 2006-12-15 A | 100% | 2006-03-15 | 2006-12-15 | 198d? | finish no earlier than 2006-12-15 |  | R3 | 1584h | 1584h | RANimp-ExtCell | Ericsson | Muhammad Kazmi | Rel-7 | Juha | RP-060685 |  |  |  |
| 1400 | 449.7 | 7.68 Mcps TDD Enhanced Uplink |  | 198d? | 2006-03-15 A | 2006-12-15 A | 100% | 2006-03-15 | 2006-12-15 | 198d? | finish no earlier than 2006-12-15 |  | R1 | 1584h | 1584h | RANimp-VHCRTDD-EDCH | IPwireless | nanderson@ipwireless.com | Rel-7 | Patrick | RP-060684 |  |  |  |
| 1401 | 449.8 | Enhanced CELL_FACH State in FDD |  | 181d? | 2006-09-25 A | 2007-06-04 A | 100% | 2006-09-25 | 2007-06-04 | 181d? | finish no earlier than 2007-06-04 |  | R2 | 1448h | 1448h | RANimp-EnhState | Nokia | juho.pirskanen@nokia.com | Rel-7 | Joern | RP-070286 |  |  |  |
| 1402 | 449.9 | 64QAM for HSDPA (FDD) |  | 110d? | 2006-12-15 A | 2007-06-04 A | 100% | 2006-12-15 | 2007-06-04 | 110d? | finish no earlier than 2007-06-04 |  | R1 | 880h | 880h | RANimp-64QamDownlink | Ericsson | Johan.Bergman@ericsson.com | Rel-7 | Patrick | RP-070287 |  |  |  |
| 1403 | 449.10 | Improved L2 support for high data rates |  | 122d? | 2006-12-15 A | 2007-06-04 A | 100% | 2006-12-15 | 2007-06-04 | 122d? | finish no earlier than 2007-06-04 |  | R2 | 976h | 976h | RANimp-L2DataRates | Ericsson | Janne.Peisa@ericsson.com | Rel-7 | Joern | RP-070289 |  |  |  |
| 1404 | 449.11 | Introduction of 16QAM in HSUPA (FDD) |  | 110d? | 2006-12-15 A | 2007-06-04 A | 100% | 2006-12-15 | 2007-06-04 | 110d? | finish no earlier than 2007-06-04 |  | R1 | 880h | 880h | RANimp-16QamUplink | Nokia | Karri.Ranta-aho@nsn.com | Rel-7 | Patrick | RP-070288 |  |  |  |

Notes:
- 1378: - / Text3: 25.101
- 1379: RP#32 completed / Text3: 25.101
- 1380: RP#34 completed / Text3: 25.101
- 1381: RP#34 completed / Text3: 25.101
- 1382: RP#34 stopped. SR in RP-060680
- 1383: This item was conditionnaly approved pending decision of PCG#16 who decided not to approve it / Text3: 25.101, 25.104, 25.133, 25.141, 25.331, 25.942, 25.306, 25.307, 34.121
- 1384: Linked to Feature UID_20028 (RInImp)
- 1385: RP#32 completed / Text3: 34.108, 34.121
- 1386: RP#32 completed / Text3: 34.108, 34.121
- 1387: RP#34 completed / Text3: 34.121, 34.108
- 1388: RP#41 completed (GERAN aspects might need to be included later) / Text3: 34.114
- 1389: RP#34 completed / Text3: 34.108, 34.123-1, 34.123-2, 34.123-3
- 1390: RP#36 completed / Text3: 34.108, 34.121-1, 34.121-2
- 1391: RP#38 completed
- 1392: RP#39 completed
- 1393: Generic feature
- 1394: RP#34 completed
- 1395: RP#33 completed / Text3: 25.815, 25.321, 25.322, 25.331
- 1396: RP#30 completed
- 1397: RP#32 completed / Text3: 25.102, 25.123
- 1398: RP#35 completed / Text3: 25.903, 25.201, 25.211, 25.212, 25.214, 25.308, 25.321, 25.331, 25.423, 25.433, 25.101, 25.133
- 1399: RP#34 completed / Text3: 25.133, 25.423, 25.425, 25.433, 25.435, 25.453, 25.331
- 1400: RP#34 completed / Text3: 25.201, 25.202, 25.221, 25.222, 25.223, 25.224, 25.225, 25.331, 23.321, 25.306, 25.302, 25.401, 25.420, 25.423, 25.427, 25.433, 25.102, 25.105, 25.142
- 1401: RP#36 completed / Text3: 25.308, 25.304, 25.306, 25.321, 25.331, 25.433, 25.435, 25.423, 25.425,
- 1402: RP#36 completed / Text3: 25.308, 25.211, 25.212, 25.213, 25.306, 25.331, 25.433, 25.435, 25.423, 25.425, 25.101, 25.104, 25.141
- 1403: RP#36 completed / Text3: 25.301, 25.308,25.306, 25.321, 25.322, 25.331, 25.433, 25.435, 25.423, 25.425, 25.999
- 1404: RP#36 completed / Text3: 25.319, 25.101, 25.104, 25.133, 25.141, 25.211, 25.212, 25.213, 25.214, 25.306, 25.321, 25.331, 25.423, 25.433

| ID | WBS | Task | Duration | Start | Finish | Complete | Remaining | Baseline start | Baseline finish | Baseline duration | Total slack | Constraint | Resources | Work | Actual work | Text1 | Text4 | Text5 | Text6 | Text8 | Text11 | Text2 | Text7 |
| --- | --- | --- | --- | --- | --- | --- | --- | --- | --- | --- | --- | --- | --- | --- | --- | --- | --- | --- | --- | --- | --- | --- | --- |
| 1405 | 449.12 | **Interface to control Tower Mounted Amplifiers (TMAs)** | 271d? | 2006-06-02 A | 2007-06-15 A | 100% |  | 2006-06-02 | 2007-06-15 | 271d? |  |  | R3,S5 | 1648h | 1648h | RANImp-TMA | Vodafone | alexej.kulakov@vodafone.com | Rel-7 | Juha | RP-070140 |  |  |
| 1406 | 449.12.1 | Interface to control Tower Mounted Amplifiers (TMAs) | 206d? | 2006-06-02 A | 2007-03-16 A | 100% |  | 2006-06-02 | 2007-03-16 | 206d? |  |  | R3 | 840h | 840h | RANImp-TMA | Vodafone | alexej.kulakov@vodafone.com | Rel-7 | Juha | RP-070140 |  |  |
| 1407 | 449.12.2 | OAM aspects to Interface to control TMAs | 101d? | 2007-01-26 A | 2007-06-15 A | 100% |  | 2007-01-26 | 2007-06-15 | 101d? |  | finish no earlier than 2007-06-15 | S5 | 808h | 808h | RANImp-TMA-OAM | Vodafone | Adrian.Neal@vodafone.com | Rel-7 | Dionisio |  |  |  |
| 1408 | 450 | **Rel-7 RAN improvements - UE Conformance Testing** | 784d? | 2006-09-20 A | 2009-09-18 A | 100% |  | 2006-09-20 | 2009-09-18 | 784d? |  |  | R5 | 25472h | 25472h | RANimp-UEConTest |  |  | Rel-7 | Ingbert |  |  |  |
| 1409 | 450.1 | Conformance Test Aspects - 3.84 Mcps and 7.68 Mcps TDD Enhanced Uplink | 518d? | 2006-09-20 A | 2008-09-12 A | 100% |  | 2006-09-20 | 2008-09-12 | 518d? |  | finish no earlier than 2008-09-12 | R5 | 4144h | 4144h | RANimp-UEConTest_EDCHTDH | IPWireless | tspeight@ipwireless.com | Rel-7 | Ingbert | RP-080536 |  |  |
| 1410 | 450.2 | Conformance Test Aspects – 64QAM for HSDPA (FDD) | 257d? | 2007-03-09 A | 2008-03-03 A | 100% |  | 2007-03-09 | 2008-03-03 | 257d? |  | finish no earlier than 2008-03-03 | R5 | 2056h | 2056h | RANimp-UEConTest_64QamDownlink | Ericsson | leif.mattisson@ericsson.com | Rel-7 | Ingbert | RP-080059 |  |  |
| 1411 | 450.3 | Conformance Test Aspects – 16QAM for HSUPA (FDD) | 321d? | 2007-03-09 A | 2008-05-30 A | 100% |  | 2007-03-09 | 2008-05-30 | 321d? |  | finish no earlier than 2008-05-30 | R5 | 2568h | 2568h | RANimp-UEConTest_16QamUplink | Motorola | carolyn.taylor@motorola.com | Rel-7 | Ingbert | RP-080281 |  |  |
| 1412 | 450.4 | Conformance Test Aspects – Improved L2 support for high data rates | 321d? | 2007-03-09 A | 2008-05-30 A | 100% |  | 2007-03-09 | 2008-05-30 | 321d? |  | finish no earlier than 2008-05-30 | R5 | 2568h | 2568h | RANimp-UEConTest_L2DataRates | Ericsson | leif.mattisson@ericsson.com | Rel-7 | Ingbert | RP-080256 |  |  |
| 1413 | 450.5 | Conformance Test Aspects – Continuous connectivity for packet data users | 321d? | 2007-03-09 A | 2008-05-30 A | 100% |  | 2007-03-09 | 2008-05-30 | 321d? |  | finish no earlier than 2008-05-30 | R5 | 2568h | 2568h | RANimp-UEConTest_CPC | Nokia | jarkko.hellsten@nokia.com | Rel-7 | Ingbert | RP-080282 |  |  |
| 1414 | 450.6 | Conformance Test Aspects – Enhanced CELL_FACH state in FDD | 662d? | 2007-03-09 A | 2009-09-18 A | 100% |  | 2007-03-09 | 2009-09-18 | 662d? |  | finish no earlier than 2009-09-18 | R5 | 5296h | 5296h | RANimp-UEConTest_EnhancedCellFACHState | Nokia | jarkko.hellsten@nokia.com | Rel-7 | Ingbert | RP-090711 |  |  |
| 1415 | 451 | **7.68 Mcps TDD option** | 783d? | 2004-09-15 A | 2007-09-14 A | 100% |  | 2004-09-15 | 2007-09-14 | 783d? |  |  | RP | 24496h | 24496h | VHCRTDD | IPwireless | Martin Beale (mbeale@ipwireless.com) | Rel-7 |  | RP-060684 |  |  |
| 1416 | 451.1 | VHCRTDD: Stage 2 | 391d? | 2004-09-15 A | 2006-03-15 A | 100% |  | 2004-09-15 | 2006-03-15 | 391d? |  | finish no earlier than 2006-03-15 | R1 | 3128h | 3128h | VHCRTDD-Stage2 | IPwireless | Martin Beale (mbeale@ipwireless.com) | Rel-7 | Patrick | RP-060684 |  |  |
| 1417 | 451.2 | VHCRTDD: Physical Layer | 391d? | 2004-09-15 A | 2006-03-15 A | 100% |  | 2004-09-15 | 2006-03-15 | 391d? |  | finish no earlier than 2006-03-15 | R1 | 3128h | 3128h | VHCRTDD-Phys | IPwireless | Martin Beale (mbeale@ipwireless.com) | Rel-7 | Patrick | RP-060684 |  |  |
| 1418 | 451.3 | VHCRTDD: Layer 2 and layer 3 protocol aspects | 391d? | 2004-09-15 A | 2006-03-15 A | 100% |  | 2004-09-15 | 2006-03-15 | 391d? |  | finish no earlier than 2006-03-15 | R2 | 3128h | 3128h | VHCRTDD-L23 | IPwireless | drichards@ipwireless.com | Rel-7 | Joern | RP-060684 |  |  |
| 1419 | 451.4 | VHCRTDD: UTRAN Iub/Iur Protocol Aspects | 391d? | 2004-09-15 A | 2006-03-15 A | 100% |  | 2004-09-15 | 2006-03-15 | 391d? |  | finish no earlier than 2006-03-15 | R3 | 3128h | 3128h | VHCRTDD-IurIub | IPwireless | Peter Legg (plegg@ipwireless.com) | Rel-7 | Juha | RP-060684 |  |  |
| 1420 | 451.5 | VHCRTDD: RF Radio Transmission/ Reception, System Performance Requirements and Conformance Testing | 457d? | 2004-09-15 A | 2006-06-15 A | 100% |  | 2004-09-15 | 2006-06-15 | 457d? |  | finish no earlier than 2006-06-15 | R4 | 3656h | 3656h | VHCRTDD-RF | IPwireless | Shin Horng Wong (shwong@ipwireless.com) | Rel-7 | Issam | RP-060684 |  |  |
| 1421 | 451.6 | Conformance Test Aspects - 7.68 Mcps TDD | 258d? | 2006-09-20 A | 2007-09-14 A | 100% |  | 2006-09-20 | 2007-09-14 | 258d? |  | finish no earlier than 2007-09-10 | R5 | 2064h | 2064h | VHCRTDD-UEConTest | IPWireless | tspeight@ipwireless.com | Rel-7 | Ingbert | RP-070307 |  |  |
| 1422 | 452 | **3.84 Mcps TDD Enhanced Uplink** | 394d? | 2005-03-15 A | 2006-09-15 A | 100% |  | 2005-03-15 | 2006-09-15 | 394d? |  |  | RP | 18384h | 18384h | EDCHTDD | IPwireless | nanderson@ipwireless.com | Rel-7 |  | RP-060462 |  |  |
| 1423 | 452.1 | EDCHTDD: Stage 2 | 328d? | 2005-03-15 A | 2006-06-15 A | 100% |  | 2005-03-15 | 2006-06-15 | 328d? |  | finish no earlier than 2006-06-15 | R2 | 2624h | 2624h | EDCHTDD-Stage2 | IPwireless | nanderson@ipwireless.com | Rel-7 | Joern | RP-060462 |  |  |
| 1424 | 452.2 | EDCHTDD: Physical Layer | 394d? | 2005-03-15 A | 2006-09-15 A | 100% |  | 2005-03-15 | 2006-09-15 | 394d? |  | finish no earlier than 2006-09-15 | R1 | 3152h | 3152h | EDCHTDD-Phys | IPwireless | nanderson@ipwireless.com | Rel-7 | Patrick | RP-060462 |  |  |
| 1425 | 452.3 | EDCHTDD: Layer 2 and 3 Protocol Aspects | 394d? | 2005-03-15 A | 2006-09-15 A | 100% |  | 2005-03-15 | 2006-09-15 | 394d? |  | finish no earlier than 2006-09-15 | R2 | 3152h | 3152h | EDCHTDD-L23 | IPwireless | drichards@ipwireless.com | Rel-7 | Joern | RP-060462 |  |  |
| 1426 | 452.4 | EDCHTDD: UTRAN Iub/Iur Protocol Aspects | 394d? | 2005-03-15 A | 2006-09-15 A | 100% |  | 2005-03-15 | 2006-09-15 | 394d? |  | finish no earlier than 2006-09-15 | R3 | 3152h | 3152h | EDCHTDD-IurIub | Interdigital | jim.miller@interdigital.com | Rel-7 | Juha | RP-060462 |  |  |
| 1427 | 452.5 | EDCHTDD: RF Radio Transmission/ Reception, System Performance Requirements and Conformance Testing | 394d? | 2005-03-15 A | 2006-09-15 A | 100% |  | 2005-03-15 | 2006-09-15 | 394d? |  | finish no earlier than 2006-09-15 | R4 | 3152h | 3152h | EDCHTDD-RF | IPwireless | Shin Horng Wong (shwong@ipwireless.com) | Rel-7 | Issam | RP-060462 |  |  |
| 1428 | 453 | **1.28 Mcps TDD Enhanced Uplink** | 653d? | 2006-03-15 A | 2008-09-12 A | 100% |  | 2006-03-15 | 2008-09-12 | 653d? |  |  | RP | 14760h | 14760h | LCRTDD-EDCH | CATT | Haijing Hu | Rel-7 |  | RP-070296 |  |  |
| 1429 | 453.1 | 1.28 Mcps TDD Enhanced Uplink: Physical Layer | 262d? | 2006-03-15 A | 2007-03-15 A | 100% |  | 2006-03-15 | 2007-03-15 | 262d? |  | finish no earlier than 2007-03-15 | R1 | 2096h | 2096h | LCRTDD-EDCH-Phys | CATT | Ke Wang | Rel-7 | Patrick | RP-070038 |  |  |
| 1430 | 453.2 | 1.28 Mcps TDD Enhanced Uplink: Layer 2 and 3 Protocol Aspects | 262d? | 2006-03-15 A | 2007-03-15 A | 100% |  | 2006-03-15 | 2007-03-15 | 262d? |  | finish no earlier than 2007-03-15 | R2 | 2096h | 2096h | LCRTDD-EDCH-L23 | CATT | Haiyang Quan | Rel-7 | Joern | RP-070038 |  |  |
| 1431 | 453.3 | 1.28 Mcps TDD Enhanced Uplink: UTRAN Iub/Iur Protocol Aspects | 262d? | 2006-03-15 A | 2007-03-15 A | 100% |  | 2006-03-15 | 2007-03-15 | 262d? |  | finish no earlier than 2007-03-15 | R3 | 2096h | 2096h | LCRTDD-EDCH-IubIur | CATT | Yincheng Zhang | Rel-7 | Juha | RP-070038 |  |  |
| 1432 | 453.4 | 1.28 Mcps TDD Enhanced Uplink: RF Radio Transmission/ Reception, System Performance Requirements and Conformance Testing | 328d? | 2006-03-15 A | 2007-06-15 A | 100% |  | 2006-03-15 | 2007-06-15 | 328d? |  | finish no earlier than 2007-06-15 | R4 | 2624h | 2624h | LCRTDD-EDCH-RF | CATT | Yuexia Song | Rel-7 | Issam | RP-070296 |  |  |
| 1433 | 453.5 | 1.28 Mcps TDD Enhanced Uplink - UE Conformance Testing | 257d? | 2007-09-20 A | 2008-09-12 A | 100% |  | 2007-09-20 | 2008-09-12 | 257d? |  | finish no earlier than 2008-09-11 | R5 | 624h | 624h | LCRTDD-EDCH-UEConTest | CATT | chenxiaozhong@datangmobile.cn | Rel-7 | Ingbert | RP-080539 |  |  |
| 1434 | 454 | Conformance Test Aspects – Multiple Band and Multiple Frequency operation for LCR TDD | 326d? | 2010-09-17 A | 2011-12-16 | 20% | 260.8d? | 2010-09-17 | 2011-12-16 | 326d? | 260d | finish no earlier than 2011-12-16 | R5 | 2608h | 521.6h | LCRTDD_MB_MF_UEConTest | CATR | Ms Jun Chen (chenjun@catr.cn) | Rel-7 | Ingbert | RP-101073 | PCG-25 | RP-49 |
| 1435 | 455 | MS Antenna Performance Evaluation Method and Requirements | 731d? | 2005-01-28 A | 2007-11-16 A | 100% |  | 2005-01-28 | 2007-11-16 | 731d? |  | finish no earlier than 2007-11-16 | GP | 5848h | 5848h | APEMR | TeliaSonera | Ulf.Tegth@teliasonera.com | Rel-7 | Paolo |  |  |  |

Notes:
- 1405: RP#35 completed
- 1406: RP#35 completed
- 1407: SP#36 completed / Text3: 32.642, 32.643, 32.645 – Align with RAN 25.466
- 1408: Linked to Feature UID_20029 (RANimp)
- 1409: RP#41 completed / Text3: 34.108, 34.122, 34.123-1, 34.123-2, 34.123-3
- 1410: RP#39 completed / Text3: 34.108, 34.121-1, 34.121-2, 34.123-1, 34.123-2, 34.123-3
- 1411: RP#40 completed / Text3: 34.108, 34.121-1, 34.121-2, 34.123-1, 34.123-2, 34.123-3
- 1412: RP#40 completed / Text3: 34.108, 34.123-1, 34.123-2, 34.123-3
- 1413: RP#40 completed / Text3: 34.108, 34.121-1, 34.121-2, 34.123-1, 34.123-2, 34.123-3
- 1414: RP#45 completed / Text3: 34.108, 34.123-1, 34.123-2, 34.123-3
- 1415: RP#31 completed
- 1416: RP#31 completed / Text3: 25.202
- 1417: RP#31 completed / Text3: 25.221, 25.222, 25.223, 25.224,25.225
- 1418: RP#31 completed / Text3: 25.301, 25.302, 25.305, 25.306, 25.321, 25.331
- 1419: RP#31 completed / Text3: 25.401, 25.420, 25.423, 25.425, 25.427, 25.430, 25.433, 25.435
- 1420: RP#32 completed / Text3: 25.102, 25.105, 25.123, 25.133, 25.142
- 1421: RP#37 completed / Text3: 34.108, 34.122, 34.123-1, 34.123-2, 34.123-3
- 1422: RP#33 completed
- 1423: RP#33 completed
- 1424: RP#33 completed / Text3: 25.201, 25.221,25.222, 25.223, 25.224, 25.225
- 1425: RP#33 completed / Text3: 25.301, 25.302, 25.306, 25.321, 25.331
- 1426: RP#33 completed / Text3: 25.401, 25.420, 25.423, 25.427, 25.430, 25.433, 25.435
- 1427: RP#33 completed / Text3: 25.102, 25.105, 25.123, 25.142
- 1428: RP#35 completed
- 1429: RP#35 completed / Text3: 25.201, 25.221, 25.222, 25.223, 25.224, 25.225
- 1430: RP#35 completed / Text3: 25.301, 25.302, 25.306, 25.321, 25.331
- 1431: RP#35 completed / Text3: 25.401, 25.420, 25.423, 25.425, 25.427, 25.430, 25.433, 25.435
- 1432: RP#36 completed / Text3: 25.102, 25.105, 25.123, 25.142
- 1433: RP#41 completed / Text3: 34.108, 34.122, 34.123-1/2/3
- 1434: Core specification was introduced via Rel-7 CR under TEI7 (RP#37 RP-070650) and via 2 Rel-8 work items: RInImp9-UMTS1880TDD and RInImp8-UMTS2300TDD. / Text3: UTRA 34.108, 34.123-1, 34.123-2, 34.123-3
- 1435: GP#36 completed for R7 / Text3: 25.914, 25.144, 45.005

| ID | WBS | Task | Type | Duration | Start | Finish | Complete | Baseline start | Baseline finish | Baseline duration | Constraint | Resources | Work | Actual work | Text1 | Text4 | Text5 | Text6 | Text8 | Text12 |
| --- | --- | --- | --- | --- | --- | --- | --- | --- | --- | --- | --- | --- | --- | --- | --- | --- | --- | --- | --- | --- |
| 1436 | 456 | **Lower 700 MHz Inclusion in the GERAN Specifications** |  | 390d? | 2005-01-03 A | 2006-06-30 A | 100% | 2005-01-03 | 2006-06-30 | 390d? |  | GP | 7632h | 7632h | GSM710 | UTC | dcotton@mtview.union-tel.com | Rel-7 | Paolo |  |
| 1437 | 456.1 | Inclusion of the 698 – 746 MHz band into GERAN core specifications |  | 129d? | 2005-01-03 A | 2005-06-30 A | 100% | 2005-01-03 | 2005-06-30 | 129d? | finish no earlier than 2005-06-30 | G1 | 1032h | 1032h | GSM710-core |  |  | Rel-7 | Paolo |  |
| 1438 | 456.2 | G1 aspects of GSM710 |  | 217.5d? | 2005-08-31 A | 2006-06-30 A | 100% | 2005-08-31 | 2006-06-30 | 217.5d? | finish no earlier than 2006-06-30 | G1 | 1740h | 1740h | GSM-710-test |  |  | Rel-7 | Paolo |  |
| 1439 | 456.3 | G3 aspects of GSM710 |  | 217.5d? | 2005-08-31 A | 2006-06-30 A | 100% | 2005-08-31 | 2006-06-30 | 217.5d? | finish no earlier than 2006-06-30 | G3new | 1740h | 1740h | GSM-710-test |  |  | Rel-7 | Ingbert |  |
| 1440 | 457 | **Support of Conversational Services in A/Gb mode via the PS domain** |  | 626d? | 2005-04-08 A | 2007-08-31 A | 100% | 2005-04-08 | 2007-08-31 | 626d? |  | GP | 15442.8h | 15442.8h | SCSAGB | Ericsson | gunnar.hedby@ericsson.com | Rel-7 | Paolo |  |
| 1441 | 457.1 | Minimise the transfer delay between the SGSN and the MS |  | 604.95d? | 2005-04-08 A | 2007-08-31 A | 100% | 2005-04-08 | 2007-08-31 | 604.95d? | finish no earlier than 2007-08-31 | GP | 4839.6h | 4839.6h | SCSAGB-MTD | Ericsson | gunnar.hedby@ericsson.com | Rel-7 | Paolo |  |
| 1442 | 457.2 | Definition of radio resource management functionality |  | 626d? | 2005-04-08 A | 2007-08-31 A | 100% | 2005-04-08 | 2007-08-31 | 626d? | finish no earlier than 2007-08-31 | G1 | 5008h | 5008h | SCSAGB-RRM | Ericsson | gunnar.hedby@ericsson.com | Rel-7 | Paolo |  |
| 1443 | 457.3 | Support of Conversational Services in A/Gb mode via the PS domain – RLC Non-Persistent mode |  | 101d? | 2006-06-30 A | 2006-11-17 A | 100% | 2006-06-30 | 2006-11-17 | 101d? | finish no earlier than 2006-11-17 | G2 | 808h | 808h | SCSAGB-RLCNP | Ericsson | gunnar.hedby@ericsson.com | Rel-7 | Gert |  |
| 1444 | 457.4 | Deleted- Radio Channel Support | milestone | 0d? | 2006-07-17 A | 2006-07-17 A | 100% | 2006-07-17 | 2006-07-17 | 0d? | start no earlier than 2006-07-17 | G2 |  |  | SCSAGB-RCHS | Ericsson | gunnar.hedby@ericsson.com | Rel-7 | Gert | SP-32 |
| 1445 | 457.5 | Deleted- Modifications to FLO | milestone | 0d? | 2006-07-17 A | 2006-07-17 A | 100% | 2006-07-17 | 2006-07-17 | 0d? | start no earlier than 2006-07-17 | G2 |  |  | SCSAGB-FLO | Ericsson | gunnar.hedby@ericsson.com | Rel-7 | Gert | SP-32 |
| 1446 | 458 | **Addition of new frequency band to GSM (T-GSM810)** |  | 626d? | 2005-04-08 A | 2007-08-31 A | 100% | 2005-04-08 | 2007-08-31 | 626d? |  | GP | 12112h | 12112h | TGSM810 | Huawei | chende@huawei.com | Rel-7 | Paolo |  |
| 1447 | 458.1 | Changes to core specification |  | 106d? | 2005-04-08 A | 2005-09-02 A | 100% | 2005-04-08 | 2005-09-02 | 106d? | finish no earlier than 2005-09-02 | GP | 848h | 848h | TGSM810-Core | Huawei | chende@huawei.com | Rel-7 | Paolo |  |
| 1448 | 458.2 | Changes to MS testing specification |  | 626d? | 2005-04-08 A | 2007-08-31 A | 100% | 2005-04-08 | 2007-08-31 | 626d? | finish no earlier than 2007-08-31 | G3new | 5008h | 5008h | TGSM810-MStest | Huawei | chende@huawei.com | Rel-7 | Ingbert |  |
| 1449 | 458.3 | Changes to BTS testing specification |  | 156d? | 2005-04-08 A | 2005-11-11 A | 100% | 2005-04-08 | 2005-11-11 | 156d? | finish no earlier than 2005-11-11 | G1 | 1248h | 1248h | TGSM810-BTStest | Huawei | chende@huawei.com | Rel-7 | Paolo |  |
| 1450 | 459 | **Handover of dedicated and shared resources while in Dual Transfer Mode** |  | 421d? | 2005-04-08 A | 2006-11-17 A | 100% | 2005-04-08 | 2006-11-17 | 421d? |  | GP | 12672h | 12672h | HODSRDTM | Nokia | rami.vaittinen@nokia.com | Rel-7 | Paolo |  |
| 1451 | 459.1 | Handover of dedicated and shared resources while in Dual Transfer Mode |  | 321d? | 2005-04-08 A | 2006-06-30 A | 100% | 2005-04-08 | 2006-06-30 | 321d? | finish no earlier than 2006-06-30 | G2 | 2568h | 2568h | HODSRDTM-G2 | Nokia | rami.vaittinen@nokia.com | Rel-7 | Gert |  |
| 1452 | 459.2 | Deleted - MS Conformance Testing |  | 421d? | 2005-04-08 A | 2006-11-17 A | 100% | 2005-04-08 | 2006-11-17 | 421d? | finish no earlier than 2006-11-17 | G3new | 3368h | 3368h | HODSRDTM-Mstest | Nokia | rami.vaittinen@nokia.com | Rel-7 | Ingbert | GP-32 |
| 1453 | 459.3 | Deleted - BTS conformance testing |  | 421d? | 2005-04-08 A | 2006-11-17 A | 100% | 2005-04-08 | 2006-11-17 | 421d? | finish no earlier than 2006-11-17 | G1 | 3368h | 3368h | HODSRDTM-BTStest | Nokia | rami.vaittinen@nokia.com | Rel-7 | Paolo | GP-32 |
| 1454 | 460 | **Mobile Station Receive Diversity (DARP Phase II)** |  | 526d? | 2005-11-11 A | 2007-11-16 A | 100% | 2005-11-11 | 2007-11-16 | 526d? |  | GP | 16360h | 16360h | MSRD2 | Nokia | kent.pedersen@nokia.com | Rel-7 | Paolo |  |
| 1455 | 460.1 | Performance Requirements for Mobile Station Receive Diversity, DARP Phase II |  | 331d? | 2005-11-11 A | 2007-02-16 A | 100% | 2005-11-11 | 2007-02-16 | 331d? | finish no earlier than 2007-02-16 | GP | 2648h | 2648h | MSRD2-PerfReq | Nokia | kent.pedersen@nokia.com | Rel-7 | Paolo |  |
| 1456 | 460.2 | Capability signalling of Mobile Station Receive Diversity, DARP Phase II |  | 331d? | 2005-11-11 A | 2007-02-16 A | 100% | 2005-11-11 | 2007-02-16 | 331d? | finish no earlier than 2007-02-16 | GP | 2648h | 2648h | MSRD2-CapSig | Nokia | kent.pedersen@nokia.com | Rel-7 | Paolo |  |
| 1457 | 460.3 | Test Scenarios for Mobile Station Receive Diversity, DARP Phase II |  | 331d? | 2005-11-11 A | 2007-02-16 A | 100% | 2005-11-11 | 2007-02-16 | 331d? | finish no earlier than 2007-02-16 | GP | 2648h | 2648h | MSRD2-TestSc | Nokia | kent.pedersen@nokia.com | Rel-7 | Paolo |  |
| 1458 | 460.4 | MS conformance test of DARP Phase II (MSRD) |  | 526d? | 2005-11-11 A | 2007-11-16 A | 100% | 2005-11-11 | 2007-11-16 | 526d? | finish no earlier than 2007-11-16 | GP | 4208h | 4208h | MSRD2-Msconf | Nokia | kent.pedersen@nokia.com | Rel-7 | Ingbert |  |
| 1459 | 461 | **Downlink Dual Carrier** |  | 947d? | 2006-01-20 A | 2009-09-04 A | 100% | 2006-01-20 | 2009-09-04 | 947d? |  | GP | 15446.6h | 15446.6h | GDCDL | Nokia Siemens Networks | leonardo.provvedi@roke.co.uk | Rel-7 | Paolo |  |
| 1460 | 461.1 | Downlink Dual Carrier Stage 2 |  | 116d? | 2006-01-20 A | 2006-06-30 A | 100% | 2006-01-20 | 2006-06-30 | 116d? | finish no earlier than 2006-06-30 | G1 | 928h | 928h | GDCDL-Stage2 | Nokia Siemens Networks | leonardo.provvedi@roke.co.uk | Rel-7 | Paolo |  |
| 1461 | 461.2 | Downlink Dual Carrier Stage 3 |  | 421d? | 2006-01-20 A | 2007-08-31 A | 100% | 2006-01-20 | 2007-08-31 | 421d? | finish no earlier than 2007-08-31 | G1 | 3368h | 3368h | GDCDL-Stage2 | Nokia Siemens Networks | leonardo.provvedi@roke.co.uk | Rel-7 | Paolo |  |
| 1462 | 461.3 | Downlink Dual Carrier – MS Conformance Test |  | 446.82d? | 2006-01-20 A | 2009-09-04 A | 100% | 2006-01-20 | 2009-09-04 | 446.82d? | finish no earlier than 2009-09-04 | G3new | 3574.6h | 3574.6h | GDCDL-MStest | Nokia Siemens Networks | leonardo.provvedi@roke.co.uk | Rel-7 | Ingbert |  |
| 1463 | 462 | Support of SIGTRAN in GERAN |  | 116d? | 2006-01-20 A | 2006-06-30 A | 100% | 2006-01-20 | 2006-06-30 | 116d? | finish no earlier than 2006-06-30 | GP | 928h | 928h | GSIGT | Ericsson | peter.ostrup@ericsson.com | Rel-7 | Ingbert |  |

Notes:
- 1436: - / Text3: 24.008, 43.022, 44.018, 44.118, 45, 001, 45.005, 51.010, 51.021
- 1437: Completed / Text3: 24.008, 43.022, 44.018, 44.118, 45, 001, 45.005,
- 1438: - / Text3: 51.021
- 1439: - / Text3: 51.010
- 1440: Originally started Nov. 2003 as GP-030443
- 1441: -
- 1442: -
- 1443: - / Text3: 43.955, 43.064, 44.060, 45.001, 45.002, 45.003, 45.005, 45.010, 51.010, 51.021
- 1444: -
- 1445: -
- 1446: - / Text3: 45.005, 45.050, 24.008, 45.008, 45.001, 43.022, 43.030, 44.018, 44.060, 51.010-1, 51.021
- 1447: - / Text3: 45.005, 45.050, 24.008, 45.008, 45.001, 43.022, 43.030, 44.018, 44.060
- 1448: - / Text3: 51010-1
- 1449: - / Text3: 51021
- 1450: GP#30 completed. Started at GP#24
- 1451: GP#30 completed / Text3: 43.055, 44.018, 44.060
- 1452: Stopped, no work done. 12/2008 Marked as stopped ("deleted") / Text3: 51-010
- 1453: Stopped, no work done. 12/2008 Marked as stopped ("deleted") / Text3: 51.026
- 1454: GP#36 completed
- 1455: GP#33 completed / Text3: 45.005
- 1456: GP#33 completed / Text3: 24.008
- 1457: GP#33 completed / Text3: 45.005
- 1458: GP#36 completed / Text3: 51.010
- 1459: GP#35 completed
- 1460: GP#30 completed / Text3: 43.055, 43.064
- 1461: GP#35 completed / Text3: 24.008, 44.018, 44.060, 45.001, 45.002, 45.005, 45.008
- 1462: GP#43 completed / Text3: 51.010
- 1463: GP#30 completed / Text3: 48.001, 48.006, 43.059, 49.031

| ID | WBS | Task | Type | Duration | Start | Finish | Complete | Remaining | Baseline start | Baseline finish | Baseline duration | Total slack | Constraint | Resources | Work | Actual work | Text1 | Text4 | Text5 | Text6 | Text8 | Text12 |
| --- | --- | --- | --- | --- | --- | --- | --- | --- | --- | --- | --- | --- | --- | --- | --- | --- | --- | --- | --- | --- | --- | --- |
| 1464 | 463 | **Latency Reductions** |  | 306d? | 2006-06-30 A | 2007-08-31 A | 100% |  | 2006-06-30 | 2007-08-31 | 306d? |  |  | GP | 7344h | 7344h | LATRED | Ericsson | Hakan.Persson@Ericsson.com | Rel-7 | Paolo |  |
| 1465 | 463.1 | Improved Ack/Nack reporting |  | 306d? | 2006-06-30 A | 2007-08-31 A | 100% |  | 2006-06-30 | 2007-08-31 | 306d? |  | finish no earlier than 2007-08-31 | G2 | 2448h | 2448h | LATRED-ACKNAR | Ericsson | Hakan.Persson@Ericsson.com | Rel-7 | Gert |  |
| 1466 | 463.2 | Reduced TTI |  | 306d? | 2006-06-30 A | 2007-08-31 A | 100% |  | 2006-06-30 | 2007-08-31 | 306d? |  | finish no earlier than 2007-08-31 | G2 | 2448h | 2448h | LATRED-REDTTI | Ericsson | Hakan.Persson@Ericsson.com | Rel-7 | Gert |  |
| 1467 | 464 | PS Handover between GERAN/UTRAN mode and GAN Mode |  | 166d? | 2006-06-30 A | 2007-02-16 A | 100% |  | 2006-06-30 | 2007-02-16 | 166d? |  | finish no earlier than 2007-02-16 | G2 | 1328h | 1328h | GUGAN | Ericsson | John.Diachina@Ericsson.com | Rel-7 | Gert |  |
| 1468 | 465 | **Higher Uplink performance for GERAN Evolution** |  | 1172d? | 2006-09-08 A | 2011-03-04 | 84% | 183.42d? | 2006-09-08 | 2011-03-04 | 1172d? | 465d |  | GP | 36304h | 30621h | HUGE | Nokia Siemens Networks, Ericsson | eddie.riddington@nokia.com, stefan.g.eriksson@ericsson.com | Rel-7 | Paolo |  |
| 1469 | 465.1 | Stage 2 for HUGE |  | 261d? | 2006-09-08 A | 2007-09-07 A | 100% |  | 2006-09-08 | 2007-09-07 | 261d? |  | finish no earlier than 2007-09-07 | G1 | 2088h | 2088h | HUGE-Stage2 | Nokia Siemens Networks, Ericsson | eddie.riddington@nokia.com, stefan.g.eriksson@ericsson.com | Rel-7 | Paolo |  |
| 1470 | 465.2 | Layer 1 Support for HUGE |  | 381d? | 2006-09-08 A | 2008-02-22 A | 100% |  | 2006-09-08 | 2008-02-22 | 381d? |  | finish no earlier than 2008-02-22 | G1 | 3048h | 3048h | HUGE-Layer1 | Nokia Siemens Networks, Ericsson | eddie.riddington@nokia.com, stefan.g.eriksson@ericsson.com | Rel-7 | Paolo |  |
| 1471 | 465.3 | Layer 2/3 Support for HUGE |  | 256d? | 2006-09-08 A | 2007-08-31 A | 100% |  | 2006-09-08 | 2007-08-31 | 256d? |  | finish no earlier than 2007-08-31 | G2 | 2048h | 2048h | HUGE-Layer23 | Nokia Siemens Networks, Ericsson | eddie.riddington@nokia.com, stefan.g.eriksson@ericsson.com | Rel-7 | Gert |  |
| 1472 | 465.4 | Performance requirements for HUGE |  | 516d? | 2006-09-08 A | 2008-08-29 A | 100% |  | 2006-09-08 | 2008-08-29 | 516d? |  | finish no earlier than 2008-08-29 | G1 | 4128h | 4128h | HUGE-Perfreq | Nokia Siemens Networks, Ericsson | eddie.riddington@nokia.com, stefan.g.eriksson@ericsson.com | Rel-7 | Paolo |  |
| 1473 | 465.5 | BTS Conformance Test for HUGE |  | 782d? | 2006-09-08 A | 2009-09-04 A | 100% |  | 2006-09-08 | 2009-09-04 | 782d? |  | finish no earlier than 2009-09-04 | G1 | 6248h | 6248h | HUGE-BTStest | Nokia Siemens Networks, Ericsson | eddie.riddington@nokia.com, stefan.g.eriksson@ericsson.com | Rel-7 | Paolo |  |
| 1474 | 465.6 | MS Conformance Test for HUGE |  | 1171d? | 2006-09-08 A | 2011-03-04 | 55% | 526.95d? | 2006-09-08 | 2011-03-04 | 1171d? | 465d | finish no earlier than 2011-03-04 | G3new | 9368h | 5152.4h | HUGE-Mstest | Nokia Siemens Networks, Ericsson | eddie.riddington@nokia.com, stefan.g.eriksson@ericsson.com | Rel-7 | Ingbert |  |
| 1475 | 466 | **REduced symbol Duration, Higher Order modulation and Turbo coding (RED HOT) for downlink** |  | 1122d? | 2006-11-17 A | 2011-03-04 | 81% | 212.37d? | 2006-11-17 | 2011-03-04 | 1122d? | 465d |  | GP | 27928h | 22641.8h | REDHOT | Ericsson, Nokia Siemens Networks, Marvell | stefan.g.eriksson@ericsson.com | Rel-7 | Paolo |  |
| 1476 | 466.1 | Stage 2 for REDHOT |  | 206d? | 2006-11-17 A | 2007-08-31 A | 100% |  | 2006-11-17 | 2007-08-31 | 206d? |  | finish no earlier than 2007-08-31 | G1 | 1648h | 1648h | REDHOT-Stage2 | Ericsson, Nokia Siemens Networks, Marvell | stefan.g.eriksson@ericsson.com | Rel-7 | Paolo |  |
| 1477 | 466.2 | Stage 3 for REDHOT |  | 391d? | 2006-11-17 A | 2008-05-16 A | 100% |  | 2006-11-17 | 2008-05-16 | 391d? |  | finish no earlier than 2008-05-16 | G1 | 3128h | 3128h | REDHOT-Stage3 | Ericsson, Nokia Siemens Networks, Marvell | stefan.g.eriksson@ericsson.com | Rel-7 | Paolo |  |
| 1478 | 466.3 | BTS Conformance Tests for REDHOT |  | 651d? | 2006-11-17 A | 2009-05-15 A | 100% |  | 2006-11-17 | 2009-05-15 | 651d? |  | finish no earlier than 2009-05-15 | G1 | 5208h | 5208h | REDHOT-BTStest | Ericsson, Nokia Siemens Networks, Marvell | stefan.g.eriksson@ericsson.com | Rel-7 | Paolo |  |
| 1479 | 466.4 | MS Conformance Tests for REDHOT |  | 1121d? | 2006-11-17 A | 2011-03-04 | 60% | 448.4d? | 2006-11-17 | 2011-03-04 | 1121d? | 465d | finish no earlier than 2011-03-04 | G3new | 8968h | 5380.8h | REDHOT-Mstest | Ericsson | stefan.g.eriksson@ericsson.com | Rel-7 | Ingbert |  |
| 1480 | 467 | (Small) Technical Enhancements and Improvements for Rel-7 | milestone | 0d? | 2007-03-26 A | 2007-03-26 A | 100% |  | 2007-03-26 | 2007-03-26 | 0d? |  | start no earlier than 2007-03-26 | All |  |  | TEI7 |  |  | Rel-7 | All |  |
| 1481 | 468 | Test - (Small) Technical Enhancements and Improvements for Rel-7 |  | 389d? | 2006-06-02 A | 2007-11-28 A | 100% |  | 2006-06-02 | 2007-11-28 | 389d? |  | finish no earlier than 2010-06-04 | R5 | 3112h | 3112h | TEI7_Test | RP#48 created for submitted CRs |  | Rel-7 | Ingbert |  |
| 1482 | 469 | **Deleted - PS domain and IMS support for IMS Emergency sessions** |  | 63.69d? | 2006-06-23 A | 2006-09-21 A | 100% |  | 2006-06-23 | 2006-09-21 | 63.69d? |  |  | S2 |  |  | IMS-EMER | Nokia | curt.c.wong@nokia.com | Rel-7 | Maurice | SP-30 |
| 1483 | 469.1 | Deleted - IMS aspects to support IMS Emergency sessions | milestone | 0d? | 2006-06-23 A | 2006-09-21 A | 100% |  | 2006-06-23 | 2006-09-21 | 0d? |  | start no earlier than 2006-06-23 | S2 |  |  | IMS-EMER | Nokia | curt.c.wong@nokia.com | Rel-7 | Maurice | SP-30 |
| 1484 | 469.2 | Deleted - PS domain aspects to support IMS Emergency sessions | milestone | 0d? | 2006-06-23 A | 2006-09-21 A | 100% |  | 2006-06-23 | 2006-09-21 | 0d? |  | start no earlier than 2006-06-23 | S2 |  |  | IMS-EMER | Nokia | curt.c.wong@nokia.com | Rel-7 | Maurice | SP-30 |
| 1485 | 16.7 | **Deleted - IMS Local services** |  | 0d? | 2006-01-06 A | 2006-01-06 A | 100% |  | 2006-01-06 | 2006-01-06 | 0d? |  |  | S2 |  |  | IMSLocal |  |  | Rel-7 | Maurice | SP-28 |
| 1486 | 16.7.1 | Deleted - Stage 2 | milestone | 0d | 2006-01-06 A | 2006-01-06 A | 100% |  | 2006-01-06 | 2006-01-06 | 0d |  | start no earlier than 2006-01-06 | S2 |  |  | IMSLocal |  |  | Rel-7 | Maurice | SP-26 |
| 1487 | 470.2 | Deleted - Stage 3 for IMS Local services | milestone | 0d? | 2006-01-06 A | 2006-01-06 A | 100% |  | 2006-01-06 | 2006-01-06 | 0d? |  | finish no earlier than 2006-01-06 | C1 |  |  | IMSLocal | Lucent | Keith Drage (drage@alcatel-lucent.com) | Rel-7 | Frederic | SP-25 |
| 1488 | 471 | Deleted - IMS Phase 3 | milestone | 0d? | 2006-01-06 A | 2006-01-06 A | 100% |  | 2006-01-06 | 2006-01-06 | 0d? |  | start no earlier than 2006-01-06 | S2 |  |  |  |  |  | Rel-7 | Maurice | SP-25 |
| 1489 | 472 | Deleted - Improvements of Radio Interface | milestone | 0d? | 2004-09-15 A | 2004-09-15 A | 100% |  | 2004-09-15 | 2004-09-15 | 0d? |  | start no earlier than 2004-09-15 | RP |  |  | RInImp |  |  | Rel-7 | Issam | SP-24 |
| 1490 | 473 | Deleted: Generic User Profile Phase 2 | milestone | 0d | 2005-08-08 A | 2006-06-30 A | 100% |  | 2005-08-08 | 2006-06-30 | 0d |  |  | C4 |  |  |  |  |  | Rel-7 | Kimmo | SP-27 |
| 1491 | 30.4 | Deleted - Stage 3 - Common objects | milestone | 0d | 2005-08-08 A | 2006-06-30 A | 100% |  | 2005-08-08 | 2006-06-30 | 0d |  | finish no earlier than 2006-06-30 | C4 |  |  |  |  |  | Rel-7 | Kimmo | SP-27 |
| 1492 | 475 | Release 7 Studies |  | 841d? | 2004-06-28 A | 2007-09-17 A | 100% |  | 2004-06-28 | 2007-09-17 | 841d? |  |  | CP,GP,RP,SP | 6728h | 6728h |  |  |  | Rel-7 | All |  |
| 1493 | 476 | Study on Multimedia Telephony Capabilities for IMS |  | 276d? | 2005-07-11 A | 2006-07-31 A | 100% |  | 2005-07-11 | 2006-07-31 | 276d? |  |  | S1 | 2145.6h | 2145.6h | MITE | Ericsson | peter.bleckert@ericsson.com | Rel-7 | Alain |  |
| 1494 | 477 | Study on Behaviour of Multi system UEs |  | 384d? | 2004-06-28 A | 2005-12-15 A | 100% |  | 2004-06-28 | 2005-12-15 | 384d? |  | start no earlier than 2004-06-28 | S1 | 3072h | 3072h | BMSU | Qualcomm | dwilliams@qualcomm.com | Rel-7 | Alain |  |
| 1495 | 478 | Study on Combining CS calls and IMS sessions |  | 189d? | 2004-06-28 A | 2005-03-17 A | 100% |  | 2004-06-28 | 2005-03-17 | 189d? |  | start no earlier than 2004-06-28 | S1 | 1512h | 1512h | IRTSD-CS_IMS | TeliaSonera | robert.frank@teliasonera.com | Rel-7 | Alain |  |
| 1496 | 479 | Study on All-IP Network |  | 188d? | 2004-06-28 A | 2005-03-16 A | 100% |  | 2004-06-28 | 2005-03-16 | 188d? |  | start no earlier than 2004-06-28 | S1 | 1504h | 1504h | FS_AIPN | NTT DoCoMo | Shin-ichi Isobe (isobes@nttdocomo.co.jp) | Rel-7 | Alain |  |
| 1497 | 480 | Study on Videotelephony teleservice |  | 231d? | 2005-03-01 A | 2006-01-17 A | 100% |  | 2005-03-01 | 2006-01-17 | 231d? |  |  | S1 | 1848h | 1848h | VidTel | T-Mobile | michael.kurz@t-mobile.at | Rel-7 | Alain |  |
| 1498 | 481 | Study on Network Selection Principles |  | 193d? | 2005-03-15 A | 2005-12-08 A | 100% |  | 2005-03-15 | 2005-12-08 | 193d? |  |  | S1 | 1544h | 1544h | NetSel | O2 | chris.friel@o2.com | Rel-7 | Alain |  |
| 1499 | 482 | Study on Multimedia Priority Service |  | 851d? | 2003-03-28 A | 2006-06-30 A | 100% |  | 2003-03-28 | 2006-06-30 | 851d? |  | finish no earlier than 2005-12-16 | S1 | 6808h | 6808h | PRIOR-MM | Telcordia | James Garrahan (jgarraha@telcordia.com) | Rel-7 | Alain |  |
| 1500 | 483 | Study on Transferring of emergency Call data |  | 190d? | 2005-07-11 A | 2006-03-31 A | 100% |  | 2005-07-11 | 2006-03-31 | 190d? |  | finish no earlier than 2005-12-08 | S1 | 1520h | 1520h | eCALL | Motorola | jian.j.wu@motorola.com | Rel-7 | Alain |  |
| 1501 | 484 | Study on Enhancement of E2E QoS |  | 281.4d? | 2004-06-28 A | 2005-09-15 A | 100% |  | 2004-06-28 | 2005-09-15 | 281.4d? |  | finish no earlier than 2005-12-01 | S2 | 2251.2h | 2251.2h | QoS7 | Huawei | Robert Jaksa | Rel-7 | Maurice |  |
| 1502 | 485 | Study on SOAP/HTTP IRP Solution Sets |  | 330d? | 2005-09-02 A | 2006-12-07 A | 100% |  | 2005-09-02 | 2006-12-07 | 330d? |  | finish no earlier than 2006-12-07 | S5 | 2640h | 2640h | OAM7-NIM-XML | Nortel | Suzèle Lariven (lariven@nortel.com) | Rel-7 | Dionisio |  |
| 1503 | 486 | Study on Itf-N Implementation Conformance Statement (ICS) template |  | 400d? | 2005-09-02 A | 2007-03-15 A | 100% |  | 2005-09-02 | 2007-03-15 | 400d? |  | finish no earlier than 2007-03-15 | S5 | 3200h | 3200h | OAM7-NIM-ICS | China Mobile | Li Yewen (liyewen@chinamobile.com) | Rel-7 | Dionisio |  |
| 1504 | 487 | Study on IRP Information Model |  | 400d? | 2005-09-02 A | 2007-03-15 A | 100% |  | 2005-09-02 | 2007-03-15 | 400d? |  | finish no earlier than 2007-03-15 | S5 | 3200h | 3200h | OAM7-NIM-IM | Motorola | trevor.pirt@motorola.com | Rel-7 | Dionisio |  |
| 1505 | 488 | Study on Bandwidth Saving at Nb Interface with IP transport |  | 261d? | 2006-03-10 A | 2007-03-09 A | 100% |  | 2006-03-10 | 2007-03-09 | 261d? |  | finish no earlier than 2007-03-09 | C3 | 2088h | 2088h | BSNbIP | Siemens | Thomas.Belling@siemens.com | Rel-7 | Gwiho |  |
| 1506 | 489 | Study on Routeing of MT-SMS via the HPLMN |  | 301d? | 2005-10-07 A | 2006-12-01 A | 100% |  | 2005-10-07 | 2006-12-01 | 301d? |  | finish no earlier than 2006-12-01 | C4 | 2408h | 2408h | SMS7 | Vodafone | Nick.Russell@vodafone.com | Rel-7 | Kimmo |  |
| 1507 | 490 | Study on the TCAPsec Gateway concept |  | 96d? | 2005-10-28 A | 2006-03-10 A | 100% |  | 2005-10-28 | 2006-03-10 | 96d? |  | finish no earlier than 2006-03-10 | C4 | 768h | 768h | SEC7-TCAP | Siemens | Ulrich.wiehe@gksag.de | Rel-7 | Kimmo |  |
| 1508 | 491 | Study on using M2PA in 3GPP network |  | 318d? | 2006-03-22 A | 2007-06-08 A | 100% |  | 2006-03-22 | 2007-06-08 | 318d? |  | finish no earlier than 2007-06-08 | C4 | 2544h | 2544h | FS-M2PA | China Mobile | zhaoyuyi@chinamobile.com | Rel-7 | Kimmo |  |

Notes:
- 1464: GP#35 completed / Text3: 45.001, 45.002, 45.003, 45.005, 45.010, 43.055, 43.064, 44.060, 51.010-1, 51.021
- 1465: GP#35 completed / Text3: 45.001, 45.002, 45.003, 45.005, 45.010, 43.055, 43.064, 44.060, 51.010-1, 51.021
- 1466: GP#35 completed / Text3: 45.001, 45.002, 45.003, 45.005, 45.010, 43.055, 43.064, 44.060, 51.010-1, 51.021
- 1467: GP#33 completed / Text3: 43.318, 44.318, 43.129, 25.306, 24.008, 44.060, 25.331, 51.010
- 1468: -
- 1469: GP#35 completed / Text3: 43.055, 43.064
- 1470: GP#37 completed / Text3: 45.001, 45.002, 45.003, 45.004, 45.008
- 1471: GP#35 completed / Text3: 24.008, 44.018, 44.060
- 1472: GP#39 completed / Text3: 45.005
- 1473: GP#43 completed / Text3: 51.021
- 1474: GP#48 EGPRS2A total: 70% (both EGPRS2A and EGPRS2B: 60% of REDHOT, 55% of HUGE) / Text3: 51.010
- 1475: GP#38 completed. SP#42 split core from testing specification work.
- 1476: GP#35 completed / Text3: 43.055, 43.064
- 1477: GP#38 completed / Text3: 24.008, 44.018, 44.060, 45.001, 45.002, 45.003, 45.004, 45.005, 45.008
- 1478: GP#42 completed / Text3: 51.021
- 1479: GP#48 completion 11/10=>03/11. EGPRS2A total: 70% (both EGPRS2A and EGPRS2B: 60% of REDHOT, 55% of HUGE) / Text3: 51.010
- 1480: - / Text3: CP-070260
- 1481: -
- 1482: Approved at SP#29 / Text3: 23.867, 23.abc, 23.060, 23.002, 23.271
- 1483: Approved at SP#29 / Text3: 23.867, 23.abc, 23.060, 23.002, 23.271
- 1484: Approved at SP#29 / Text3: 23.867, 23.abc, 23.060, 23.002, 23.271
- 1485: - / Text3: 23.228
- 1486: DAB - Not yet required in SA2 as it exists in previous releases
- 1487: -
- 1488: -
- 1489: Stage 2 description of Interim conclusion
- 1490: Created at TSG#27 by A. Sultan because of the move to Rel-7 of "Common Objects".
- 1491: No progress in CN4#26. This have to be moved to Rel-7. It was deleted from WID / Text3: 24.241
- 1492: -
- 1493: Spin-off Feature UID_7038 (MTSI) / Text3: 22.973
- 1494: - / Text3: 22.936
- 1495: - / Text3: 22.979
- 1496: 07/08 Moved to Rel-7 as Study out of stopped Rel-8 Feature UID_31067 All-IP Network (AIPN) / Text3: 22.978
- 1497: - / Text3: 22.903
- 1498: Spin-off Feature Network selection enhancements (NSP-CR) UID_7041 / Text3: 22.811
- 1499: Spin-off Feature PRIOR UID_340044 / Text3: 22.953
- 1500: - / Text3: 22.967
- 1501: - / Text3: 23.802
- 1502: SP#34 completed / Text3: 32.809
- 1503: SP#35 completed / Text3: 32.812
- 1504: SP#35 completed / Text3: 32.810
- 1505: Moved to FS at CT32 (in line with slides) / Text3: 29.814
- 1506: Previously known as "Study of a SMS Centre for MT SMS" / Text3: 23.840
- 1507: TR 29.800 content moved to TS 29.204 under implementation WI UID_310005 TCAPsec Gateway / Text3: 29.800
- 1508: - / Text3: 29.801

| ID | WBS | Task | Type | Duration | Start | Finish | Complete | Baseline start | Baseline finish | Baseline duration | Constraint | Resources | Work | Actual work | Text1 | Text3 | Text4 | Text5 | Text6 | Text8 | Text11 | Text12 |
| --- | --- | --- | --- | --- | --- | --- | --- | --- | --- | --- | --- | --- | --- | --- | --- | --- | --- | --- | --- | --- | --- | --- |
| 1509 | 492 | **Study on Support of (G)MSC-S - (G)MSC-S Nc Interface based on the SIP-I protocol** |  | 350d? | 2006-05-15 A | 2007-09-14 A | 100% | 2006-05-15 | 2007-09-14 | 350d? |  | C4 | 7800h | 7800h | NcSIP | 29.802 | Vodafone | david.hutton@vodafone.com | Rel-7 | Kimmo |  |  |
| 1510 | 492.1 | CT4 aspects of NcSIP |  | 275d? | 2006-05-15 A | 2007-06-01 A | 100% | 2006-05-15 | 2007-06-01 | 275d? | finish no earlier than 2007-06-01 | C4 | 2200h | 2200h | NcSIP | 29.802 | Vodafone | david.hutton@vodafone.com | Rel-7 | Kimmo |  |  |
| 1511 | 492.2 | CT3 aspects of NcSIP |  | 350d? | 2006-05-15 A | 2007-09-14 A | 100% | 2006-05-15 | 2007-09-14 | 350d? | finish no earlier than 2007-09-14 | C3 | 2800h | 2800h | NcSIP | 29.802 | Ericsson | ragnar.huslende@ericsson.com | Rel-7 | Gwiho |  |  |
| 1512 | 493 | Study on Evolved UTRA and UTRAN |  | 458d? | 2004-12-15 A | 2006-09-15 A | 100% | 2004-12-15 | 2006-09-15 | 458d? | finish no earlier than 2006-09-15 | RP | 3664h | 3664h | RANFS-Evo | 25.912 | NTT DoCoMo | nakamurata@NTTDOCOMO.CO.JP | Rel-7 | Issam | RP-060472 |  |
| 1513 | 494 | Study on Performance Evaluation of the UE behaviour in high speed trains with speeds up to 350 kmph |  | 328d? | 2005-03-15 A | 2006-06-15 A | 100% | 2005-03-15 | 2006-06-15 | 328d? | finish no earlier than 2006-06-15 | R4 | 2624h | 2624h | RANFS-HSTrains | none | Vodafone | Mike.vogel@vodafone.com,tim.frost@vodafone.com | Rel-7 | Issam | RP-060412 |  |
| 1514 | 495 | Study on UTRA Tower Mounted Amplifier (FDD) |  | 195d? | 2005-06-15 A | 2006-03-14 A | 100% | 2005-06-15 | 2006-03-14 | 195d? | finish no earlier than 2006-03-15 | R4 | 1560h | 1560h | RANFS-TMA | 25.818 | Ericsson | Klas.Sjerling@ericsson.com | Rel-7 | Issam | RP-060035 |  |
| 1515 | 496 | Study on Continuous connectivity for packet data users |  | 132d? | 2005-03-15 A | 2005-09-14 A | 100% | 2005-03-15 | 2005-09-14 | 132d? | finish no earlier than 2005-09-15 | R1 | 1056h | 1056h | RANFS-cont-packet | none | Siemens | joerg.gustrau@siemens.com | Rel-7 | Patrick | RP-050427 |  |
| 1516 | 497 | Study on Improvement of the Multimedia Broadcast Multicast Service (MBMS) in UTRAN |  | 262d? | 2005-12-15 A | 2006-12-15 A | 100% | 2005-12-15 | 2006-12-15 | 262d? | finish no earlier than 2006-12-15 | R2 | 2096h | 2096h | RANFS-MBMSImp | 25.905 | LG Electronics | leego@lge.com | Rel-7 | Joern | RP-060692 |  |
| 1517 | 498 | Study on Performance Improvements in Small Cells using HSDPA/EDCH |  | 131d? | 2005-12-15 A | 2006-06-15 A | 100% | 2005-12-15 | 2006-06-15 | 131d? | finish no earlier than 2006-06-15 | R4 | 1048h | 1048h | SMALLCELLS | none | Cingular | Marc Grant | Rel-7 | Issam | RP-060263 |  |
| 1518 | 499 | Study on Further Improved Performance Requirements for UMTS/HSDPA UE (FDD) |  | 383d? | 2005-12-15 A | 2007-06-04 A | 100% | 2005-12-15 | 2007-06-04 | 383d? | finish no earlier than 2007-06-04 | R4 | 3064h | 3064h | RANFS-IC | 25.963 | Cingular | Marc Grant | Rel-7 | Issam | RP-070499 |  |
| 1519 | 500 | Study on Scope of future FDD HSPA Evolution |  | 394d? | 2006-03-15 A | 2007-09-17 A | 100% | 2006-03-15 | 2007-09-17 | 394d? | finish no earlier than 2007-09-17 | RP | 3152h | 3152h | RANFS-HSPAEvo | 25.999 | Cingular | Don Zelmer (dz1069@att.com) | Rel-7 | Issam | RP-070533 |  |
| 1520 | 501 | Study on Dynamically reconfiguring a FDD UE receiver to reduce power consumption when desired Quality of Service is met | milestone | 0d? | 2007-06-22 A | 2007-06-22 A | 100% | 2007-06-22 | 2007-06-22 | 0d? |  | R4 |  |  | FSUEPow | 25.906 | Nokia | Chris.callender@nokia.com, tiina.s.koskinen@nokia.com | Rel-7 | Issam | RP-070534 |  |
| 1521 | 502 | Study on Future GERAN Evolution |  | 486d? | 2005-04-08 A | 2007-02-16 A | 100% | 2005-04-08 | 2007-02-16 | 486d? | finish no earlier than 2007-02-16 | GP | 3888h | 3888h | FGE | 45.912 | Nokia | eddie.riddington@nokia.com | Rel-7 | Paolo |  |  |
| 1522 | 503 | Study on GAN Enhancements | milestone | 0d? | 2007-08-31 A | 2007-08-31 A | 100% | 2007-08-31 | 2007-08-31 | 0d? | start no earlier than 2007-08-31 | GP |  |  | EGAN | 43.902 | T-Mobile | janne.linkola@t-mobile.com | Rel-7 | Paolo |  |  |
| 1523 | 504 | Deleted - Study on IMS with real time services deployment |  | 316d? | 2004-06-28 A | 2005-09-12 A | 100% | 2004-06-28 | 2005-09-12 | 316d? |  | S1 | 2528h | 2528h | IRTSD |  |  |  | Rel-7 | Alain |  | SP-30 |
| 1524 | 505 | Deleted - Covered by SI - Personal Network (PN) and Personal Area Network (PAN) | milestone | 0d? | 2005-12-08 A | 2005-12-20 A | 100% | 2005-12-08 | 2005-12-20 | 0d? | start no earlier than 2005-12-08 | S1 |  |  | PNPAN |  | Vodafone | armin.toepfer@vodafone.com | Rel-7 | Alain |  | SP-30 |
| 1525 | 506 | Deleted - Study on Personal Network and Personal Area Network | milestone | 0d? | 2006-10-20 A | 2006-10-20 A | 100% | 2006-10-20 | 2006-10-20 | 0d? | finish no earlier than 2006-10-20 | S1 |  |  | PNPAN |  |  |  | Rel-7 | Alain |  | SP-31 |
| 1526 | 507 | Deleted - Covered by SI - Multimedia Telephony Capabilities for IMS | milestone | 0d? | 2005-12-08 A | 2005-12-20 A | 100% | 2005-12-08 | 2005-12-20 | 0d? | start no earlier than 2005-12-08 | S1 |  |  | MITE |  | Ericsson | peter.bleckert@ericsson.com | Rel-7 | Alain |  | SP-30 |
| 1527 | 508 | Deleted - Covered by SI - Transferring of emergency Call data | milestone | 0d? | 2005-12-08 A | 2005-12-08 A | 100% | 2005-12-08 | 2005-12-08 | 0d? | start no earlier than 2005-12-08 | S1 |  |  | eCALL |  | Motorola | steven.vardy@motorola.com | Rel-7 | Alain |  | SP-30 |
| 1528 | 509 | Deleted - Covered by SI - MBMS Enhancements | milestone | 0d? | 2005-12-08 A | 2005-12-08 A | 100% | 2005-12-08 | 2005-12-08 | 0d? | start no earlier than 2005-12-08 | S1 |  |  | MBMSE |  | China Mobile | liuhongyfw@chinamobile.com | Rel-7 | Alain |  | SP-30 |
| 1529 | 510 | Deleted - Study on Customised Alerting Tone (CAT) Requirements (was duplicated) | milestone | 0d? | 2006-06-30 A | 2006-06-30 A | 100% | 2006-06-30 | 2006-06-30 | 0d? | start no earlier than 2006-06-30 | S1 |  |  | CAT |  |  |  | Rel-7 | Alain |  | SP-31 |
| 1530 | 511 | Deleted - Study on LCS architecture for I-WLAN (covered by 32108) | milestone | 0d? | 2006-12-08 A | 2006-12-08 A | 100% | 2006-12-08 | 2006-12-08 | 0d? | start no earlier than 2006-12-08 | S2 |  |  | IMS-SE |  | LG Electronics | Donghee Shim dhshim@lge.com ; phede@lge.com | Rel-7 | Maurice |  | SP-33 |
| 1531 | 512 | Deleted - IMS security extensions (covered by UID33027) | milestone | 0d? | 2005-12-08 A | 2005-12-08 A | 100% | 2005-12-08 | 2005-12-08 | 0d? | start no earlier than 2005-12-08 | S3 |  |  | IMS-SE |  | Ericsson | Bengt.Sahlin@ericsson.com | Rel-7 | Dionisio |  | SP-30 |
| 1532 | 513 | **Deleted - Study on applicability of GALILEO for LCS** |  | 0d? | 2005-06-30 A | 2005-06-30 A | 100% | 2005-06-30 | 2005-06-30 | 0d? |  | S2 |  |  | Galileo |  |  |  | Rel-7 | Maurice |  | SP-25 |
| 1533 | 513.1 | Deleted - TR on Stage 2 | milestone | 0d? | 2005-06-30 A | 2005-06-30 A | 100% | 2005-06-30 | 2005-06-30 | 0d? | finish no earlier than 2005-06-30 | S2 |  |  | Galileo |  |  |  | Rel-7 | Maurice |  | SP-25 |
| 1534 | 513.2 | Deleted - GERAN review of the TR | milestone | 0d? | 2005-06-30 A | 2005-06-30 A | 100% | 2005-06-30 | 2005-06-30 | 0d? | start no earlier than 2005-06-30 | GP |  |  | Galileo |  |  |  | Rel-7 | Paolo |  | SP-26 |
| 1535 | 514 | Deleted - Study on Stage 2 (IMS services using CS bearers) |  | 316d? | 2004-06-28 A | 2005-09-12 A | 100% | 2004-06-28 | 2005-09-12 | 316d? | finish no earlier than 2005-09-12 | S2 | 2528h | 2528h | IRTSD-IMSCS | 23.899 | Nortel | Mark Watson | Rel-7 | Maurice |  | SP-30 |

Notes:
- 1509: -
- 1510: -
- 1511: -
- 1512: RP#33 (Sep 2006) completed. SR in RP-060472
- 1513: RP#32 (Jun 2006) completed. SR in RP-060412
- 1514: RP#31 (Mar 2006) completed. SR in RP-060035
- 1515: RP#29 (Sep 2006) completed. SR in RP-050427
- 1516: RP#34 (Dec 2006) completed. SR in RP-060692
- 1517: RP#32 (Jun 2006) closed (no progress). SR in RP-060263
- 1518: RP#36 (May 2007) completed. SR in RP-070499
- 1519: RP#37 (Sep 2007) completed. SR in RP-070533
- 1520: RP#37 (Sep 2007) completed. SR in RP-070534
- 1521: GP#33 completed
- 1522: GP#35 completed
- 1523: -
- 1524: -
- 1525: Moved from FS section Feb 06
- 1526: -
- 1527: -
- 1528: -
- 1529: Awaiting MCC SA3 input
- 1530: S2#52: Entry created
- 1531: -
- 1532: -
- 1533: -
- 1534: -
- 1535: SP-30: S2 has no intention for TR completion

| ID | WBS | Task | Type | Duration | Start | Finish | Complete | Baseline start | Baseline finish | Baseline duration | Constraint | Resources | Work | Actual work | Text1 | Text6 | Text8 | Text12 | Text3 | Text4 | Text5 | Text7 | Text10 |
| --- | --- | --- | --- | --- | --- | --- | --- | --- | --- | --- | --- | --- | --- | --- | --- | --- | --- | --- | --- | --- | --- | --- | --- |
| 1536 | 515 | **Deleted - VoIMS bearer related enhancements** |  | 0d? | 2006-07-21 A | 2006-07-21 A | 100% | 2006-07-21 | 2006-07-21 | 0d? |  | S2 |  |  | VoIMS | Rel-7 | Maurice | SP-32 |  |  |  |  |  |
| 1537 | 515.1 | Deleted - Study on enhancement of radio performance for VoIMS | milestone | 0d? | 2006-07-21 A | 2006-07-21 A | 100% | 2006-07-21 | 2006-07-21 | 0d? | start no earlier than 2006-07-21 | S2 |  |  | VoIMS | Rel-7 | Maurice | SP-32 | 23.807 | Nortel | Laurence Lautier (lautierl@nortel.com) |  |  |
| 1538 | 516 | Deleted - Study on IMS enhancements and optimizations for real time communication. |  | 430d? | 2005-10-10 A | 2007-06-01 A | 100% | 2005-10-10 | 2007-06-01 | 430d? | finish no earlier than 2007-06-01 | S2 | 3440h | 3440h | IMS-RT | Rel-7 | Maurice | SP-35 | 23.818 | Ericsson | stephen.terrill@ericsson.com |  |  |
| 1539 | 517 | Deleted - Study on Terminating Session handling |  | 255d? | 2006-01-09 A | 2006-12-29 A | 100% | 2006-01-09 | 2006-12-29 | 255d? | finish no earlier than 2006-12-29 | S2 | 2040h | 2040h | CSIterm | Rel-7 | Maurice | SP-32 | 23.819 | Samsung |  |  |  |
| 1540 | 518 | Deleted - Study on Transferring of emergency call data – in-band modem solution (moved to Rel-8) | milestone | 0d? | 2007-06-22 A | 2007-06-22 A | 100% | 2007-06-22 | 2007-06-22 | 0d? | start no earlier than 2007-06-22 | S4 |  |  | eCALLIBMS | Rel-7 | Paolo | SP-38 | 26.967 | Airbiquity | lhong@airbiquity.com |  |  |
| 1541 | 519 | Deleted - Study on IRP usage scenarios |  | 330d? | 2005-09-02 A | 2006-12-07 A | 100% | 2005-09-02 | 2006-12-07 | 330d? | finish no earlier than 2006-12-07 | S5 | 2640h | 2640h | OAM-Study | Rel-7 | Dionisio | SP-32 | 32.8xy | Lucent |  |  |  |
| 1542 | 520 | Deleted - Study on Interference Cancellation for UTRA FDD UE (covered by UID 20053) |  | 1d? | 2007-03-28 A | 2007-03-28 A | 100% | 2007-03-28 | 2007-03-28 | 1d? | start no earlier than 2007-03-28 | R4 | 8h | 8h | RANFS-InterfCanc | Rel-7 | Issam | SP-38 |  |  |  |  |  |
| 1543 | 521 | Deleted - Study on enhanced support of Video Telephony | milestone | 0d? | 2006-06-30 A | 2006-06-30 A | 100% | 2006-06-30 | 2006-06-30 | 0d? | start no earlier than 2006-06-30 | GP |  |  | VIDGER | Rel-7 | Paolo | SP-32 |  | Ericsson | stefan.g.eriksson@ericsson.com |  |  |
| 1544 | 522 | Release 6 Features |  | 915d? | 2002-06-28 A | 2005-12-30 A | 100% | 2002-06-28 | 2005-12-30 | 915d? |  | NP,GP, RP,SP,TP | 7320h | 7320h |  | Rel-6 | All |  |  |  |  |  |  |
| 1545 | 8 | **Rel-6 Improvements of Radio Interface** |  | 1717d? | 2000-08-14 A | 2007-03-13 A | 100% | 2000-08-14 | 2007-03-13 | 1717d? |  | RP | 57776h | 57776h | RInImp | Rel-6 |  |  |  |  |  |  |  |
| 1546 | 523.1 | Improved support of IMS Realtime Services using HSDPA/EDCH |  | 197d? | 2005-03-15 A | 2005-12-14 A | 100% | 2005-03-15 | 2005-12-14 | 197d? | finish no earlier than 2005-12-14 | R2 | 1576h | 1576h | RInImp-IMSRealTime | Rel-6 | Joern |  |  | Cingular | Don Zelmer (dz1069@att.com) |  |  |
| 1547 | 523.2 | Improving Receiver Performance Requirements for the FDD UE |  | 401d | 2002-03-08 A | 2003-09-19 A | 100% | 2002-03-08 | 2003-09-19 | 401d | start no earlier than 2002-03-08 | R4 | 3208h | 3208h | RInImp-UERecPerf | Rel-6 | Issam |  | 25.101 | Intel | shimon.moshavi@INTEL.COM |  |  |
| 1548 | 8.2 | **Base station classification** |  | 603d | 2000-08-14 A | 2002-12-04 A | 100% | 2000-08-14 | 2002-12-04 | 603d |  | R4 | 9648h | 9648h | RInImp-BSClass | Rel-6 | Issam |  |  |  |  |  |  |
| 1549 | 8.2.1 | FDD Base station classification |  | 603d | 2000-08-14 A | 2002-12-04 A | 100% | 2000-08-14 | 2002-12-04 | 603d | finish no earlier than 2002-12-04 | R4 | 4824h | 4824h | RInImp-BSClass-FDD | Rel-6 | Issam |  | 25.104, 25.141 | Nokia | antti.toskala@nokia.com |  |  |
| 1550 | 523.4 | UMTS-850 |  | 266d | 2002-12-06 A | 2003-12-12 A | 100% | 2002-12-06 | 2003-12-12 | 266d | finish no earlier than 2003-12-15 | R4 | 2128h | 2128h | RInImp-UMTS850 | Rel-6 | Issam |  | 25.101, 25.104, 25.133, 25.141, 25.307, 25.331, 25.942 | Cingular | Don Zelmer (dz1069@att.com) |  |  |
| 1551 | 523.5 | DS-CDMA introduction in the 800 MHz band |  | 196d | 2003-03-14 A | 2003-12-12 A | 100% | 2003-03-14 | 2003-12-12 | 196d | finish no earlier than 2003-12-15 | R4 | 1568h | 1568h | RInImp-UMTS800 | Rel-6 | Issam |  | 25.101, 25.104, 25.133, 25.141, 25.307, 25.331 | NTT DoCoMo | Takehiro Nakamura (nakamurata@nttdocomo.co.jp) |  |  |
| 1552 | 523.6 | UMTS 1.7/2.1 GHz | milestone | 0d? | 2003-03-14 A | 2003-03-14 A | 100% | 2003-03-14 | 2003-03-14 | 0d? |  | R4 |  |  | RInImp-UMTS1721 | Rel-6 | Issam |  | 25.101, 25.104, 25.133, 25.141, 25.307, 25.331 | Nokia | jussi.numminen@NOKIA.COM |  |  |
| 1553 | 523.7 | Conformance Test Aspects – UMTS 1.7/2.1 GHz Band |  | 191d? | 2006-03-10 A | 2006-12-01 A | 100% | 2006-03-10 | 2006-12-01 | 191d? | finish no earlier than 2006-12-01 | R5 | 1528h | 1528h | RInImp-UMTS1721_Test | Rel-6 | Ingbert |  | TS34.121, TS34.108 | Motorola | carolyn.taylor@motorola.com |  |  |
| 1554 | 523.8 | **Improved Receiver Performance Requirements for HSDPA** |  | 908d | 2003-09-19 A | 2007-03-13 A | 100% | 2003-09-19 | 2007-03-13 | 908d |  | R4,R5 | 24384h | 24384h | RInImp-HSPerf | Rel-6 | Issam |  |  | Nokia | jussi.numminen@NOKIA.COM |  |  |
| 1555 | 523.8.1 | Improved Minimum Performance Requirements for HSDPA UE categories 7 and 8 |  | 650d | 2004-09-15 A | 2007-03-13 A | 100% | 2004-09-15 | 2007-03-13 | 650d |  | R4 | 3624h | 3624h | RInImp-HSPerf-10code | Rel-6 | Issam |  | 25.101 | Nokia | jussi.numminen@nokia.com |  |  |
| 1556 | 523.8.2 | Testing of Improved Minimum Performance for HSDPA |  | 650d | 2003-09-19 A | 2006-03-16 A | 100% | 2003-09-19 | 2006-03-16 | 650d | finish no earlier than 2006-03-16 | R5 | 5200h | 5200h | RInImp-HSPerf-10Code_Test | Rel-6 | Ingbert |  | 34.108, 34.121, 34.122, 34.123-1, 34.123-2, 34.123-3 | Motorola | carolyn.taylor@motorola.com | TSG | 19/9/2003 |
| 1557 | 523.8.3 | Performance Requirements of Receive Diversity for HSDPA |  | 387d | 2003-12-15 A | 2005-06-07 A | 100% | 2003-12-15 | 2005-06-07 | 387d |  | R4 | 3096h | 3096h | RInImp-HSPerf-RxDiv | Rel-6 | Issam |  | 25.101 | NTT DoCoMo | Takehiro Nakamura (nakamurata@nttdocomo.co.jp) |  |  |
| 1558 | 523.8.4 | Testing of Performance of Receiver diversity for HSDPA |  | 650d | 2003-09-19 A | 2006-03-16 A | 100% | 2003-09-19 | 2006-03-16 | 650d | finish no earlier than 2006-03-16 | R5 | 5200h | 5200h | RInImp-HSPerf-RxDiv_Test | Rel-6 | Ingbert |  | 34.108, 34.121, 34.122, 34.123-1, 34.123-2, 34.123-3 | Motorola | carolyn.taylor@motorola.com | TSG | 19/9/2003 |
| 1559 | 524 | **Rel-6 RAN Feasibility Studies** |  | 1196d? | 2000-08-14 A | 2005-03-14 A | 100% | 2000-08-14 | 2005-03-14 | 1196d? |  | RP | 43048h | 43048h |  | Rel-6 |  |  |  |  |  |  |  |
| 1560 | 524.1 | FS of the improved access to UE measurement data for CRNC to support TDD RRM |  | 270d? | 2002-12-06 A | 2003-12-18 A | 100% | 2002-12-06 | 2003-12-18 | 270d? | finish no earlier than 2003-09-19 | R3 | 2160h | 2160h | RANimp-RRMopt-FSUEMsD | Rel-6 | Juha |  | 25.801, 25.423 | Interdigital | jim.miller@interdigital.com |  | SP-24 |
| 1561 | 524.2 | FS on Radio link performance enhancements |  | 1067d | 2000-08-14 A | 2004-09-14 A | 100% | 2000-08-14 | 2004-09-14 | 1067d | finish no earlier than 2004-09-14 | R1 | 8536h | 8536h | RInImp-Rlperf | Rel-6 | Patrick |  | 25.899 | Nokia | antti.toskala@nokia.com |  |  |
| 1562 | 524.3 | FS on Improvement of inter-frequency and inter-system measurements for 1.28 Mcps TDD |  | 461d | 2001-12-14 A | 2003-09-19 A | 100% | 2001-12-14 | 2003-09-19 | 461d | start no earlier than 2001-12-14 | R1 | 3688h | 3688h | RInImp-IfIsMLCR | Rel-6 | Patrick |  | 25.888 | Samsung | Li Xiao Qiang (xqli@samsung.co.kr) |  |  |
| 1563 | 524.4 | FS for the analysis of OFDM for UTRAN enhancement |  | 526d | 2002-06-10 A | 2004-06-14 A | 100% | 2002-06-10 | 2004-06-14 | 526d | start no earlier than 2002-06-10 | R1 | 4208h | 4208h | RInImp-FSOFDM | Rel-6 | Patrick |  | 25.892 | Nortel | Sarah Boumendil |  |  |
| 1564 | 524.5 | FS on Uplink Enhancements for Dedicated Transport Channels |  | 396d | 2002-09-06 A | 2004-03-12 A | 100% | 2002-09-06 | 2004-03-12 | 396d | finish no earlier than 2004-03-12 | R1 | 3168h | 3168h | RInImp-FSUpDTrCh | Rel-6 | Patrick |  | 25.896 | Nokia | Karri.Ranta-aho@nsn.com |  |  |
| 1565 | 524.6 | FS on Analysis on Higher Chip Rates for UTRA TDD evolutions |  | 528d | 2002-09-06 A | 2004-09-14 A | 100% | 2002-09-06 | 2004-09-14 | 528d | finish no earlier than 2004-09-14 | R1 | 4224h | 4224h | RInImp-FSVHCRTDD | Rel-6 | Patrick |  | 25.895 | IPWireless | mbeale@ipwireless.com |  |  |
| 1566 | 524.7 | FS on Low Output Powers for general purpose FDD BSs |  | 128d | 2003-06-13 A | 2004-03-12 A | 100% | 2003-06-13 | 2004-03-12 | 128d | finish no earlier than 2004-03-12 | R3 | 1024h | 1024h | RInImp-FSLoPw | Rel-6 | Juha |  | 25.807 | Telefonica | Ana Burgos (burgos_a@tsm.es) |  |  |
| 1567 | 524.8 | FS on Uplink enhancements for UTRA TDD |  | 462d | 2003-06-06 A | 2005-03-14 A | 100% | 2003-06-06 | 2005-03-14 | 462d | finish no earlier than 2005-03-14 | R1 | 3696h | 3696h | RInImp-FSUpEnhTDD | Rel-6 | Patrick |  | 25.804 | Interdigital | Marian.Rudolf@InterDigital.com |  |  |
| 1568 | 8.8 | FS on UE antenna efficiency test methods performance requirements (2) |  | 131d | 2002-03-08 A | 2002-09-06 A | 100% | 2002-03-08 | 2002-09-06 | 131d | finish no earlier than 2002-09-06 | R4 | 1048h | 1048h | RInImp-UEAnTM2 | Rel-6 | Issam |  |  | Allgon | Alf Ahlström |  |  |
| 1569 | 9.4 | Deleted - FS on the evolution of the UTRAN architecture |  | 592d | 2002-09-09 A | 2004-12-14 A | 100% | 2002-09-09 | 2004-12-14 | 592d | finish no earlier than 2004-12-15 | R3 | 4736h | 4736h | RANimp-FSEvo | Rel-6 | Juha | RP-26 |  | Nokia | woonhee.hwang@nsn.com, Antti.Toskala@nokia.com |  |  |

Notes:
- 1536: Created by MCC to group all VoIMS related items, after consultation of chairs
- 1537: WID approved SP#28: SA2#52: CLOSED - To be removed from the work plan
- 1538: abandoned at 65%
- 1539: SP#32 Jun 2006 Study abandoned => spin-off Implementation work UID_320029
- 1540: SP-38 stopped
- 1541: -
- 1542: Deleted. Same as FS on Further Improved Performance Requirements for UMTS/HSDPA UE (FDD)
- 1543: FS CLOSED at G#28 (no input)
- 1544: -
- 1545: -
- 1546: -
- 1547: -
- 1548: -
- 1549: -
- 1550: Introduction of UMTS850 (Band V) in 25.307
- 1551: Introduction of UMTS800 in 25.307
- 1552: Introduction of UMTS1700/2100 (Band IV)
- 1553: -
- 1554: -
- 1555: Approved at RP#25 as RP-040375
- 1556: -
- 1557: -
- 1558: -
- 1559: -
- 1560: -
- 1561: Study finished at RP#25
- 1562: -
- 1563: -
- 1564: -
- 1565: Study finished at RP#25
- 1566: -
- 1567: -
- 1568: The RInImp-UEAnTM FS was re-opened at TSG RP#15 upon request from WG4
- 1569: Study Closed, work will continue within the FS on evolved UTRA and UTRAN

| ID | WBS | Task | Type | Duration | Start | Finish | Complete | Baseline start | Baseline finish | Baseline duration | Constraint | Deadline | Resources | Work | Actual work | Text1 | Text4 | Text5 | Text6 | Text3 | Text8 | Text7 | Text9 | Text10 | Text12 |
| --- | --- | --- | --- | --- | --- | --- | --- | --- | --- | --- | --- | --- | --- | --- | --- | --- | --- | --- | --- | --- | --- | --- | --- | --- | --- |
| 1570 | 525 | **FDD Enhanced Uplink** |  | 915d | 2004-03-15 A | 2007-09-14 A | 100% | 2004-03-15 | 2007-09-14 | 915d |  |  | RP | 23664h | 23664h | EDCH | Ericsson | Joakim Bergström | Rel-6 |  |  |  |  |  |  |
| 1571 | 525.1 | FDD Enhanced Uplink - Stage 2 |  | 197d | 2004-03-15 A | 2004-12-14 A | 100% | 2004-03-15 | 2004-12-14 | 197d | finish no earlier than 2004-12-14 |  | R2 | 1576h | 1576h | EDCH-Stage2 |  |  | Rel-6 | 25.309 | Joern |  |  |  |  |
| 1572 | 525.2 | FDD Enhanced Uplink - Physical Layer |  | 261d | 2004-03-15 A | 2005-03-14 A | 100% | 2004-03-15 | 2005-03-14 | 261d | finish no earlier than 2005-03-14 |  | R1 | 2088h | 2088h | EDCH-Phys | Nokia | Karri.Ranta-aho@nsn.com | Rel-6 | 25.211, 25.212, 25.213, 25.214, 25.215 | Patrick |  |  |  |  |
| 1573 | 525.3 | FDD Enhanced Uplink - Layer 2 and 3 Protocol Aspects |  | 261d | 2004-03-15 A | 2005-03-14 A | 100% | 2004-03-15 | 2005-03-14 | 261d | finish no earlier than 2005-03-14 |  | R2 | 2088h | 2088h | EDCH-L23 | Ericsson | Joakim Bergström | Rel-6 | 25.301, 25.302, 25.306, 25.321, 25.331 | Joern |  |  |  |  |
| 1574 | 525.4 | FDD Enhanced Uplink - UTRAN Iub/Iur Protocol Aspects |  | 261d | 2004-03-15 A | 2005-03-14 A | 100% | 2004-03-15 | 2005-03-14 | 261d | finish no earlier than 2005-03-14 |  | R3 | 2088h | 2088h | EDCH-IurIub | Nortel | Saso Stojanovski | Rel-6 | 25.401, 25.420, 25.423, 25.430, 25.433 | Juha |  |  |  |  |
| 1575 | 525.5 | FDD Enhanced Uplink - RF Radio Transmission/ Reception, System Performance Requirements and Conformance Testing |  | 74d | 2004-03-15 A | 2004-06-24 A | 100% | 2004-03-15 | 2004-06-24 | 74d |  |  | R4 | 592h | 592h | EDCH-RF | Ericsson | thomas.unshelm@ERICSSON.COM | Rel-6 | 25.101, 25.104, 25.133, 25.141 | Issam |  |  |  |  |
| 1576 | 525.6 | Conformance Test Aspects – FDD Enhanced Uplink |  | 596d | 2005-06-03 A | 2007-09-14 A | 100% | 2005-06-03 | 2007-09-14 | 596d | finish no earlier than 2007-09-14 | 2006-06-02 | R5 | 4768h | 4768h | EDCH_Test | Ericsson | Leif.Mattisson@ericsson.com | Rel-6 | 34.108, 34.109, 34.121, 34.123-1, 34.123-2, 34.123-3 | Ingbert | TSG | BB | Fri 03/06/05 |  |
| 1577 | 525.7 | FDD Enhanced Uplink - RF Radio Transmission/ Reception, System Performance Requirements and Conformance Testing |  | 393d | 2004-03-15 A | 2005-09-14 A | 100% | 2004-03-15 | 2005-09-14 | 393d | finish no earlier than 2005-09-15 |  | R4 | 3144h | 3144h | EDCH-RF | Ericsson | thomas.unshelm@ERICSSON.COM | Rel-6 | 25.101, 25.104, 25.133, 25.141 | Issam |  |  |  |  |
| 1578 | 526 | **Rel-6 RAN improvements** |  | 656d? | 2002-09-09 A | 2005-03-14 A | 100% | 2002-09-09 | 2005-03-14 | 656d? |  |  | RP | 28312h | 28312h | RANimp |  |  | Rel-6 |  |  |  |  |  |  |
| 1579 | 9.2 | **RAB support enhancement** |  | 522d? | 2003-03-14 A | 2005-03-14 A | 100% | 2003-03-14 | 2005-03-14 | 522d? |  |  | R2 | 9360h | 9360h | RANimp-RABSE | Nokia | Jussi Kähtävä (juha.mikola@nokia.com) | Rel-6 | 25.862 | Joern |  |  |  |  |
| 1580 | 526.1.1 | Optimization of downlink channelisation code utilisation |  | 262d | 2004-03-12 A | 2005-03-14 A | 100% | 2004-03-12 | 2005-03-14 | 262d | finish no earlier than 2005-03-14 |  | R1 | 2096h | 2096h | RANimp-RABSE-CodeOptFDD | Nortel | Sarah Boumendil | Rel-6 |  | Patrick |  |  |  |  |
| 1581 | 526.1.2 | optimization of channelisation code utilisation for 3.84 Mcps TDD |  | 261d | 2004-03-15 A | 2005-03-14 A | 100% | 2004-03-15 | 2005-03-14 | 261d | finish no earlier than 2005-03-15 |  | R1 | 2088h | 2088h | RANimp-RABSE-CodOptTDD | IPWireless | Nicholas Anderson | Rel-6 |  | Patrick |  |  |  |  |
| 1582 | 526.1.3 | HS-DPCCH ACK/NACK Enhancement |  | 65d? | 2004-09-15 A | 2004-12-14 A | 100% | 2004-09-15 | 2004-12-14 | 65d? | finish no earlier than 2004-12-15 |  | R1 | 520h | 520h | RANimp-RABSE-ACKNACK | Nokia | Jussi Kähtävä (juha.mikola@nokia.com) | Rel-6 | 25.212, 25.214, 24.331, 25.433 | Patrick |  |  |  |  |
| 1583 | 526.1.4 | Deleted - Iu enhancements for IMS support in RAN |  | 320d? | 2003-03-14 A | 2004-06-03 A | 100% | 2003-03-14 | 2004-06-03 | 320d? | start no earlier than 2003-03-14 |  | R3 | 2560h | 2560h | RANimp-RABSE-IuEnhIMS | Nortel | Philippe.Godin@nortelnetworks.com | Rel-6 |  | Juha |  |  |  | RP-24 |
| 1584 | 526.1.5 | Deleted - Improvement of RRM across RNS and RNS/BSS | milestone | 0d? | 2003-12-05 A | 2003-12-05 A | 100% | 2003-12-05 | 2003-12-05 | 0d? | finish no earlier than 2003-12-05 |  | R3 |  |  | RANimp-RRM1 | Nokia | antti.toskala@nokia.com | Rel-6 |  | Juha |  |  |  | RP-23 |
| 1585 | 9.1 | Beamforming Enhancements |  | 66d | 2003-09-19 A | 2003-12-19 A | 100% | 2003-09-19 | 2003-12-19 | 66d | finish no earlier than 2004-03-12 |  | R1 | 528h | 528h | RANimp-BFE | Nokia | Jussi Kähtävä (juha.mikola@nokia.com) | Rel-6 | 24.215, 25.423, 25.425, 25.433, 25.435 | Patrick |  |  |  |  |
| 1586 | 526.3 | **Rel6 RRM optimization for Iur and Iub** |  | 126d | 2003-09-19 A | 2004-03-12 A | 100% | 2003-09-19 | 2004-03-12 | 126d |  |  | R3 | 2016h | 2016h | RANimp-RRMopt | Ericsson | Gert-Jan.van.Lieshout@eln.ericsson.se | Rel-6 |  | Juha |  |  |  |  |
| 1587 | 526.3.1 | Improved access to UE measurement data for CRNC to support TDD RRM |  | 126d | 2003-09-19 A | 2004-03-12 A | 100% | 2003-09-19 | 2004-03-12 | 126d | finish no earlier than 2004-03-15 |  | R3 | 1008h | 1008h | RANimp-RRMopt-UEMsD | Interdigital | jim.miller@interdigital.com | Rel-6 | 25.423 | Juha |  |  |  | RP-22 |
| 1588 | 526.4 | **Remote Control of Electrical Tilting Antennas** |  | 395d? | 2003-03-14 A | 2004-09-16 A | 100% | 2003-03-14 | 2004-09-16 | 395d? |  |  | R3 | 7464h | 7464h | RANimp-TiltAnt | Vodafone | Andreas.Hauser@vodafone.com | Rel-6 |  | Juha |  |  |  |  |
| 1589 | 526.4.1 | Tilting Antenna - RAN aspects |  | 393d? | 2003-03-14 A | 2004-09-14 A | 100% | 2003-03-14 | 2004-09-14 | 393d? | finish no earlier than 2004-09-14 |  | R3 | 3144h | 3144h | RANimp-TiltAnt | Vodafone | Andreas.Hauser@vodafone.com | Rel-6 | 25.460, 25.461, 25.462, 25.463 | Juha |  |  |  |  |
| 1590 | 526.4.2 | OAM&P impacts |  | 145d | 2004-02-27 A | 2004-09-16 A | 100% | 2004-02-27 | 2004-09-16 | 145d | finish no earlier than 2004-09-16 |  | S5 | 1160h | 1160h | RANimp-TiltAnt-OAM | Vodafone | Adrian.Neal@vodafone.com | Rel-6 | 32.804, 32.64x | Dionisio |  |  | SP-24 |  |
| 1591 | 526.5 | Network Assisted Cell Change (NACC) from UTRAN to GERAN - network-side aspects |  | 462d? | 2002-09-09 A | 2004-06-15 A | 100% | 2002-09-09 | 2004-06-15 | 462d? | finish no earlier than 2004-06-15 |  | R3 | 3696h | 3696h | RANimp-NACC | Vodafone | Brendan.McWilliams@gb.vodafone.co.uk | Rel-6 |  | Juha |  |  |  |  |
| 1592 | 12 | **Location Services enhancements 2** |  | 1024d? | 2001-01-15 A | 2004-12-16 A | 100% | 2001-01-15 | 2004-12-16 | 1024d? |  |  | S2,S5,N4,RP | 78152h | 78152h | LCS2 |  |  | Rel-6 | 23.271 | Maurice |  |  |  |  |
| 1593 | 12.1 | **Improvement on Le interface** |  | 653d? | 2002-06-17 A | 2004-12-15 A | 100% | 2002-06-17 | 2004-12-15 | 653d? |  |  | S2 | 9872h | 9872h | LCS2 |  |  | Rel-6 |  | Maurice |  |  |  |  |
| 1594 | 527.1.1 | Stage 2 |  | 331d? | 2002-06-17 A | 2003-09-22 A | 100% | 2002-06-17 | 2003-09-22 | 331d? | start no earlier than 2002-06-17 |  | S2 | 2648h | 2648h | LCS2 |  |  | Rel-6 |  | Maurice |  |  |  |  |
| 1595 | 527.1.2 | Stage 3 - impacts MLP (Mobile Location Protocol) |  | 250d? | 2004-01-01 A | 2004-12-15 A | 100% | 2004-01-01 | 2004-12-15 | 250d? | finish no earlier than 2004-12-15 |  | OMA | 2000h | 2000h | LCS2 |  | OMA-LIAISON@mail.openmobilealliance.org | Rel-6 |  |  |  |  |  |  |

Notes:
- 1570: -
- 1571: -
- 1572: -
- 1573: -
- 1574: -
- 1575: -
- 1576: -
- 1577: -
- 1578: Generic feature
- 1579: building block without particular end date
- 1580: -
- 1581: WIDS modified in RP#26, RP-040551
- 1582: Approved at RP#25 as RP-040390
- 1583: Closed RP#24 due to the lack of progress
- 1584: abandoned RP-23
- 1585: -
- 1586: -
- 1587: -
- 1588: -
- 1589: Finished at RP#25
- 1590: SP#25 09/2004 completed
- 1591: -
- 1592: -
- 1593: -
- 1594: -
- 1595: Updated according to SP-040232

| ID | WBS | Task | Type | Duration | Start | Finish | Complete | Baseline start | Baseline finish | Baseline duration | Constraint | Resources | Work | Actual work | Text1 | Text6 | Text8 | Text5 | Text4 | Text12 |
| --- | --- | --- | --- | --- | --- | --- | --- | --- | --- | --- | --- | --- | --- | --- | --- | --- | --- | --- | --- | --- |
| 1596 | 12.2 | **Enhanced support for anonymity and user privacy** |  | 638d? | 2002-07-08 A | 2004-12-15 A | 100% | 2002-07-08 | 2004-12-15 | 638d? |  | S2 | 9144h | 9144h | LCS2 | Rel-6 | Maurice |  |  |  |
| 1597 | 527.2.1 | Stage 2 |  | 255d? | 2002-07-08 A | 2003-06-27 A | 100% | 2002-07-08 | 2003-06-27 | 255d? | finish no earlier than 2003-06-27 | S2 | 2040h | 2040h | LCS2 | Rel-6 | Maurice |  |  |  |
| 1598 | 527.2.2 | Stage 3 - impacts MLP and RLP |  | 250d? | 2004-01-01 A | 2004-12-15 A | 100% | 2004-01-01 | 2004-12-15 | 250d? | finish no earlier than 2004-12-15 | OMA | 2000h | 2000h | LCS2 | Rel-6 |  | OMA-LIAISON@mail.openmobilealliance.org |  |  |
| 1599 | 12.3 | **Enhanced inter-GMLC interface** |  | 648d? | 2002-06-24 A | 2004-12-15 A | 100% | 2002-06-24 | 2004-12-15 | 648d? |  | S2 | 9704h | 9704h | LCS2 | Rel-6 | Maurice |  |  |  |
| 1600 | 527.3.1 | Stage 2 |  | 315d? | 2002-06-24 A | 2003-09-05 A | 100% | 2002-06-24 | 2003-09-05 | 315d? | finish no earlier than 2003-09-05 | S2 | 2520h | 2520h | LCS2 | Rel-6 | Maurice |  |  |  |
| 1601 | 527.3.2 | Stage 3 - definition of RLP and PCP |  | 250d? | 2004-01-01 A | 2004-12-15 A | 100% | 2004-01-01 | 2004-12-15 | 250d? | finish no earlier than 2004-12-15 | OMA | 2000h | 2000h | LCS2 | Rel-6 |  | OMA-LIAISON@mail.openmobilealliance.org |  |  |
| 1602 | 12.4 | **Location Services support for IMS public identities** |  | 473d? | 2003-02-24 A | 2004-12-15 A | 100% | 2003-02-24 | 2004-12-15 | 473d? |  | S2 | 7704h | 7704h | LCS2 | Rel-6 | Maurice |  |  |  |
| 1603 | 527.4.1 | Stage 2 |  | 240d? | 2003-02-24 A | 2004-01-23 A | 100% | 2003-02-24 | 2004-01-23 | 240d? | finish no earlier than 2004-01-23 | S2 | 1920h | 1920h | LCS2 | Rel-6 | Maurice |  |  |  |
| 1604 | 527.4.2 | Stage 3 - impacts MLP, RLP and PCP |  | 250d? | 2004-01-01 A | 2004-12-15 A | 100% | 2004-01-01 | 2004-12-15 | 250d? | finish no earlier than 2004-12-15 | OMA | 2000h | 2000h | LCS2 | Rel-6 |  | OMA-LIAISON@mail.openmobilealliance.org |  |  |
| 1605 | 12.5 | **New area event for location service triggering reports** |  | 663d? | 2002-06-03 A | 2004-12-15 A | 100% | 2002-06-03 | 2004-12-15 | 663d? |  | S2 | 11416h | 11416h | LCS2 | Rel-6 | Maurice |  |  |  |
| 1606 | 527.5.1 | Stage 2 |  | 280d? | 2002-06-03 A | 2003-06-27 A | 100% | 2002-06-03 | 2003-06-27 | 280d? | finish no earlier than 2003-06-27 | S2 | 2240h | 2240h | LCS2 | Rel-6 | Maurice |  |  |  |
| 1607 | 527.5.2 | Stage 3 for UE-CN signalling |  | 234d? | 2003-10-09 A | 2004-08-31 A | 100% | 2003-10-09 | 2004-08-31 | 234d? | start no earlier than 2003-10-09 | N4 | 1872h | 1872h | LCS2 | Rel-6 | Kimmo |  |  |  |
| 1608 | 527.5.3 | Stage 3 - impacts MLP, RLP and PCP |  | 250d? | 2004-01-01 A | 2004-12-15 A | 100% | 2004-01-01 | 2004-12-15 | 250d? | finish no earlier than 2004-12-15 | OMA | 2000h | 2000h | LCS2 | Rel-6 |  | OMA-LIAISON@mail.openmobilealliance.org |  |  |
| 1609 | 12.7 | **UE positioning** |  | 957d? | 2001-01-15 A | 2004-09-14 A | 100% | 2001-01-15 | 2004-09-14 | 957d? |  | RP | 18480h | 18480h | LCS2-UEpos | Rel-6 | Issam |  |  |  |
| 1610 | 12.8 | Open SMLC-SRNC Interface within the UTRAN to support UTRAN Rel4 positioning methods |  | 700d? | 2001-01-15 A | 2003-09-19 A | 100% | 2001-01-15 | 2003-09-19 | 700d? | finish no earlier than 2003-09-19 | R2 | 5600h | 5600h | LCS-Rel4Pos | Rel-6 | Joern | Meik.Kottkamp@siemens.com | Siemens |  |
| 1611 | 527.6.2 | A-GPS minimum performance specification |  | 333d? | 2003-06-06 A | 2004-09-14 A | 100% | 2003-06-06 | 2004-09-14 | 333d? | finish no earlier than 2004-09-14 | R4 | 2664h | 2664h | LCS-UEPos-AGPSPerf | Rel-6 | Issam | donglin.shen@attws.com | AT&T Wireless |  |
| 1612 | 12.7.2 | FS on Enhancements to OTDOA Positioning using advanced blanking methods |  | 320d | 2002-07-01 A | 2003-09-19 A | 100% | 2002-07-01 | 2003-09-19 | 320d | finish no earlier than 2003-09-19 | R2 | 2560h | 2560h | LCS2-UEpos-FSBlank | Rel-6 | Joern | david.bartlett@cursor-system.com | Cambridge Positioning Systems |  |
| 1613 | 527.6.4 | Deleted - UE positioning enhancements - other methods | milestone | 0d? | 2003-09-26 A | 2003-09-26 A | 100% | 2003-09-26 | 2003-09-26 | 0d? | finish no earlier than 2003-09-26 | R2 |  |  | LCS2-UEpos-enh | Rel-6 | Joern | Meik.Kottkamp@siemens.com | Siemens | RP-24 |
| 1614 | 527.7 | LCS charging |  | 455d? | 2003-03-21 A | 2004-12-16 A | 100% | 2003-03-21 | 2004-12-16 | 455d? | start no earlier than 2003-03-21 | S5 | 3640h | 3640h | LCS2-CH | Rel-6 | Dionisio | alain.bibas@orange-ft.com | France Telecom |  |
| 1615 | 14 | **Rel-6 Security enhancements** |  | 1018d? | 2001-01-03 A | 2004-11-26 A | 100% | 2001-01-03 | 2004-11-26 | 1018d? |  | S3 | 28824h | 28824h | SEC1 | Rel-6 | Dionisio | Peter.Howard@vodafone.com | Vodafone |  |
| 1616 | 14.1 | **Enhanced HE control of security (including positive authentication reporting)** |  | 712d | 2001-01-03 A | 2003-09-25 A | 100% | 2001-01-03 | 2003-09-25 | 712d |  | S3 | 14064h | 14064h | SEC1 | Rel-6 | Dionisio | Peter.Howard@vodafone.com | Vodafone |  |
| 1617 | 14.1.1 | Deleted - SEC1 Stage 2 (Enhanced HE control of security) |  | 378d | 2001-01-03 A | 2002-06-14 A | 100% | 2001-01-03 | 2002-06-14 | 378d | finish no earlier than 2002-06-14 | S3 | 3024h | 3024h | SEC1 | Rel-6 | Dionisio |  |  | SP-16 |
| 1618 | 14.1.3 | **Network domain security** |  | 334d | 2002-06-17 A | 2003-09-25 A | 100% | 2002-06-17 | 2003-09-25 | 334d |  | S3 | 5344h | 5344h | SEC1-NDS | Rel-6 | Dionisio | Geir-myrdahl.koien@telenor.com | Telenor |  |
| 1619 | 14.1.3.1 | IP network layer security (NDS/IP) |  | 334d | 2002-06-17 A | 2003-09-25 A | 100% | 2002-06-17 | 2003-09-25 | 334d | finish no earlier than 2003-09-25 | S3 | 2672h | 2672h | SEC1-NDS-IP | Rel-6 | Dionisio |  |  |  |
| 1620 | 528.2 | Network Domain Security; Authentication Framework (NDS/AF) |  | 521d? | 2002-02-15 A | 2004-02-13 A | 100% | 2002-02-15 | 2004-02-13 | 521d? | finish no earlier than 2004-02-13 | S3 | 4168h | 4168h | SEC1-NDS-AF | Rel-6 | Dionisio | tommi.viitanen@nokia.com | Nokia |  |
| 1621 | 528.3 | Key Management of group keys for Voice Group Call Services |  | 306d | 2003-09-26 A | 2004-11-26 A | 100% | 2003-09-26 | 2004-11-26 | 306d | finish no earlier than 2004-11-26 | S3 | 2448h | 2448h | SECGKYV | Rel-6 | Dionisio | benno.tietz@vodafone.com | Vodafone |  |

Notes:
- 1596: -
- 1597: -
- 1598: Updated according to SP-040232
- 1599: -
- 1600: -
- 1601: Updated according to SP-040232
- 1602: -
- 1603: -
- 1604: Updated according to SP-040232
- 1605: -
- 1606: -
- 1607: 31/10/2003 work has started. Current stage 3 fullfills the requirements of stage 2. ......
- 1608: Updated according to SP-040232
- 1609: -
- 1610: - / Text3: 25.305, 25.401, 25.450, 25.452, 25.453
- 1611: Finished at RP#25 / Text3: 25.171
- 1612: -
- 1613: building block without particular end date
- 1614: SP#26 12/2004 completed / Text3: 32.271
- 1615: Added BB UE authentication and rapporteur added.
- 1616: Added by SP-000575 without any dates. 18/10/00: Change of WI title, added hyperlink rapporteur new end date 03/01. New end date and correct Release to be decided S3#18
- 1617: New end date and correct Release to be decided S3#18. Marked as stopped 12/2008
- 1618: WID approved for Rel-6 at SP#17. Completed 2004-12
- 1619: Should be complete after SA3#27. Completed 2004-12 / Text3: 33.210
- 1620: WID approved SP#19. Work started after FS approved SP#18
- 1621: Approved TSG#21. Completed 2004-12 / Text3: 42.068, 43.068, 44.068, 42.069, 43.069, 44.069, 31.102, 24.008, 48.008, 42.009, 43.020

| ID | WBS | Task | Type | Duration | Start | Finish | Complete | Baseline start | Baseline finish | Baseline duration | Constraint | Resources | Work | Actual work | Text1 | Text3 | Text6 | Text8 | Text4 | Text5 | Text12 |
| --- | --- | --- | --- | --- | --- | --- | --- | --- | --- | --- | --- | --- | --- | --- | --- | --- | --- | --- | --- | --- | --- |
| 1622 | 16 | **IMS Phase 2** |  | 1840d? | 2000-08-28 A | 2007-09-14 A | 100% | 2000-08-28 | 2007-09-14 | 1840d? |  | S1,S2,S3,S5,NP,R5 | 136976h | 136976h | IMS2 | 23.228 | Rel-6 | Alain |  |  |  |
| 1623 | 529.1 | Enhancements to the Cx and Sh interfaces |  | 323d? | 2003-06-06 A | 2004-08-31 A | 100% | 2003-06-06 | 2004-08-31 | 323d? | finish no earlier than 2004-08-31 | N4 | 2584h | 2584h | IMS2-CCR |  | Rel-6 | Kimmo |  |  |  |
| 1624 | 529.2 | Conformance Test Aspects – IMS Call Control Rel-6 enhancements |  | 396d? | 2006-03-10 A | 2007-09-14 A | 100% | 2006-03-10 | 2007-09-14 | 396d? | finish no earlier than 2007-09-14 | R5 | 3168h | 3168h | IMS2_CCR_Test | 34.229-1, 34.229-2, 34.229-3, 34.108 | Rel-6 | Ingbert | Ericsson | Jacob.John@motorola.com, Leif.Mattisson@ericsson.com |  |
| 1625 | 16.12 | **IMS Group Management** |  | 715d? | 2002-03-14 A | 2004-12-08 A | 100% | 2002-03-14 | 2004-12-08 | 715d? |  | S1 | 12680h | 12680h | IMSGM |  | Rel-6 | Alain | Nokia | juha.kalliokulju@nokia.com |  |
| 1626 | 16.12.1 | Stage 1 - TS on IMS group management |  | 193d | 2002-03-14 A | 2002-12-09 A | 100% | 2002-03-14 | 2002-12-09 | 193d | finish no earlier than 2002-12-09 | S1 | 1544h | 1544h | IMSGM |  | Rel-6 | Alain | Nokia | juha.kalliokulju@nokia.com |  |
| 1627 | 529.3.2 | Stage 2 |  | 158d? | 2003-05-26 A | 2003-12-31 A | 100% | 2003-05-26 | 2003-12-31 | 158d? | finish no earlier than 2003-12-31 | S2 | 1264h | 1264h | IMSGM |  | Rel-6 | Maurice |  |  |  |
| 1628 | 529.3.3 | Stage 3 for IMS Group management (e.g. chat) |  | 519d? | 2002-12-13 A | 2004-12-08 A | 100% | 2002-12-13 | 2004-12-08 | 519d? | finish no earlier than 2004-12-08 | N1 | 4152h | 4152h | IMSGM |  | Rel-6 | Frederic | Lucent | Keith Drage (drage@alcatel-lucent.com) |  |
| 1629 | 529.4 | **IMS Conferencing** |  | 548d? | 2002-11-04 A | 2004-12-08 A | 100% | 2002-11-04 | 2004-12-08 | 548d? |  | N1 | 10960h | 10960h |  |  | Rel-6 | Frederic |  |  |  |
| 1630 | 529.4.1 | Stage 2 |  | 303d? | 2002-11-04 A | 2003-12-31 A | 100% | 2002-11-04 | 2003-12-31 | 303d? | finish no earlier than 2003-12-31 | S2 | 2424h | 2424h |  |  | Rel-6 | Maurice |  |  |  |
| 1631 | 529.4.2 | Stage 3 |  | 519d? | 2002-12-13 A | 2004-12-08 A | 100% | 2002-12-13 | 2004-12-08 | 519d? | finish no earlier than 2004-12-08 | N1 | 4152h | 4152h |  |  | Rel-6 | Frederic | Lucent | Keith Drage (drage@alcatel-lucent.com) |  |
| 1632 | 16.11 | **IMS Messaging** |  | 992d? | 2002-03-14 A | 2005-12-30 A | 100% | 2002-03-14 | 2005-12-30 | 992d? |  | S1 | 23912h | 23912h | IMSM |  | Rel-6 | Alain | Nokia | juha.kalliokulju@nokia.com |  |
| 1633 | 16.11.1 | TR on support of messaging in the IMS |  | 193d | 2002-03-14 A | 2002-12-09 A | 100% | 2002-03-14 | 2002-12-09 | 193d | finish no earlier than 2002-12-09 | S1 | 1544h | 1544h | IMSM-TR | new 22.940 | Rel-6 | Alain | Nokia | juha.kalliokulju@nokia.com |  |
| 1634 | 529.5.2 | Stage 1 22.340 |  | 23d? | 2002-11-11 A | 2002-12-11 A | 100% | 2002-11-11 | 2002-12-11 | 23d? | finish no earlier than 2002-12-11 | S1 | 184h | 184h | IMSM-TS | 22.340 | Rel-6 | Alain | Nokia | juha.kalliokulju@nokia.com |  |
| 1635 | 529.5.3 | CRs to 22.140 & 22.228 |  | 263d? | 2002-03-14 A | 2003-03-17 A | 100% | 2002-03-14 | 2003-03-17 | 263d? | finish no earlier than 2003-03-17 | S1 | 2104h | 2104h | IMSM-CR | 22.140,22.228 | Rel-6 | Alain | Nokia | juha.kalliokulju@nokia.com |  |
| 1636 | 16.11.3 | Stage 2 |  | 477d | 2002-11-04 A | 2004-08-31 A | 100% | 2002-11-04 | 2004-08-31 | 477d | finish no earlier than 2004-08-31 | S2 | 3816h | 3816h | IMSM |  | Rel-6 | Maurice |  |  |  |
| 1637 | 529.5.5 | Stage 3 for IMS Messaging |  | 519d? | 2002-12-13 A | 2004-12-08 A | 100% | 2002-12-13 | 2004-12-08 | 519d? | finish no earlier than 2004-12-08 | N1 | 4152h | 4152h | IMSM |  | Rel-6 | Frederic | Lucent | Keith Drage (drage@alcatel-lucent.com) |  |
| 1638 | 529.5.6 | SIP/SIMPLE Instant messaging |  | 522d? | 2004-01-01 A | 2005-12-30 A | 100% | 2004-01-01 | 2005-12-30 | 522d? | finish no earlier than 2005-06-30 | OMA | 4176h | 4176h |  |  | Rel-6 |  |  | OMA-LIAISON@mail.openmobilealliance.org |  |
| 1639 | 529.6 | **Additional SIP Capabilities support not covered by Rel-5** |  | 680d? | 2002-11-11 A | 2005-06-17 A | 100% | 2002-11-11 | 2005-06-17 | 680d? |  | N1 | 13392h | 13392h |  |  | Rel-6 | Frederic |  |  |  |
| 1640 | 529.6.1 | Stage 2 for add SIP cap (e.g. forking) |  | 335d? | 2002-11-11 A | 2004-02-20 A | 100% | 2002-11-11 | 2004-02-20 | 335d? | finish no earlier than 2004-02-20 | S2 | 2680h | 2680h |  |  | Rel-6 | Maurice |  |  |  |
| 1641 | 529.6.2 | Stage 3 for Additional SIP Capabilities |  | 454d? | 2002-12-13 A | 2004-09-08 A | 100% | 2002-12-13 | 2004-09-08 | 454d? | finish no earlier than 2004-09-08 | N1 | 3632h | 3632h |  |  | Rel-6 | Frederic | Lucent | Keith Drage (drage@alcatel-lucent.com) |  |
| 1642 | 529.6.3 | Procedured associated with IMS-ALG |  | 205d? | 2004-09-06 A | 2005-06-17 A | 100% | 2004-09-06 | 2005-06-17 | 205d? | start no earlier than 2004-09-06 | N1 | 1640h | 1640h |  |  | Rel-6 | Frederic |  |  |  |
| 1643 | 529.7 | Review additional SIP Capabilities against IMS |  | 454d? | 2002-12-13 A | 2004-09-08 A | 100% | 2002-12-13 | 2004-09-08 | 454d? | finish no earlier than 2004-09-08 | N1 | 3632h | 3632h |  |  | Rel-6 | Frederic | Lucent | Keith Drage (drage@alcatel-lucent.com) |  |
| 1644 | 16.5 | **Interworking between IMS and IP networks** |  | 1118d? | 2000-08-28 A | 2004-12-08 A | 100% | 2000-08-28 | 2004-12-08 | 1118d? |  | N3 | 31712h | 31712h | IMS-CCR-IWIP | 23.821, 29.061, 29.162 | Rel-6 | Gwiho | BT | nigel.holland@bt.com |  |
| 1645 | 16.5.1 | Interworking for 3GPP_SIP and IETF_SIP |  | 730d | 2000-08-28 A | 2003-06-13 A | 100% | 2000-08-28 | 2003-06-13 | 730d | finish no earlier than 2003-06-13 | N3 | 5840h | 5840h |  | New 29.962 | Rel-6 | Gwiho | Siemens | Thomas.Belling@nsn.com |  |
| 1646 | 16.5.2 | Interworking for IPv6 to IPv4 |  | 1118d | 2000-08-28 A | 2004-12-08 A | 100% | 2000-08-28 | 2004-12-08 | 1118d | finish no earlier than 2004-12-08 | N3 | 8944h | 8944h |  | 29.163 | Rel-6 | Gwiho |  |  |  |
| 1647 | 529.8.3 | Interworking for IPv6 to IPv4 (SIP / SDP aspects) |  | 87d? | 2004-05-11 A | 2004-09-08 A | 100% | 2004-05-11 | 2004-09-08 | 87d? | finish no earlier than 2004-09-08 | N1 | 696h | 696h |  |  | Rel-6 | Frederic |  |  |  |
| 1648 | 16.8.1 | stage 3 of interworking with non-IMS IP networks |  | 911d | 2001-03-14 A | 2004-09-08 A | 100% | 2001-03-14 | 2004-09-08 | 911d | finish no earlier than 2004-09-08 | N1 | 7288h | 7288h |  |  | Rel-6 | Frederic |  |  |  |
| 1649 | 16.6.1 | Interworking between IMS and CS networks |  | 929d? | 2000-08-28 A | 2004-03-18 A | 100% | 2000-08-28 | 2004-03-18 | 929d? | finish no earlier than 2004-03-18 | N3 | 7432h | 7432h | IMS-CCR-IWCS | 29.163, 29.061, 24.228, and new CN4 specification | Rel-6 | Gwiho | Vodafone | Brendan.McWilliams@gb.vodafone.co.uk |  |
| 1650 | 16.10 | Mn interface (IM-MGW to MGCF) enhancements (CN4 Part) |  | 418d | 2001-08-07 A | 2004-09-01 A | 100% | 2001-08-07 | 2004-09-01 | 418d | finish no earlier than 2004-09-01 | N4 | 3344h | 3344h | IMS-CCR-Mn |  | Rel-6 | Kimmo |  |  |  |
| 1651 | 529.11 | Study of subscriber and operators relationship in IMS and related ISIM requirements for Rel 6” |  | 20d? | 2002-11-15 A | 2002-12-12 A | 100% | 2002-11-15 | 2002-12-12 | 20d? | finish no earlier than 2002-12-12 | S1 | 160h | 160h |  |  | Rel-6 | Alain | Nokia | juha.kalliokulju@nokia.com |  |
| 1652 | 529.12 | Lawful Interception in the 3GPP Rel-6 architecture |  | 269d? | 2002-12-09 A | 2003-12-18 A | 100% | 2002-12-09 | 2003-12-18 | 269d? | finish no earlier than 2003-12-18 | S3 | 2152h | 2152h | SEC1-LI | 33.106, 33.107, 33.108 | Rel-6 | Dionisio | Reg TP | berthold.wilhelm@regtp.de |  |
| 1653 | 529.13 | IMS Subscription and access scenarios |  | 130d? | 2002-12-16 A | 2003-06-13 A | 100% | 2002-12-16 | 2003-06-13 | 130d? | start no earlier than 2002-12-16 | S1 | 1040h | 1040h |  | 22.800 | Rel-6 | Alain | TeliaSonera | FRANK, Robert |  |
| 1654 | 529.14 | IMS charging |  | 455d? | 2003-03-21 A | 2004-12-16 A | 100% | 2003-03-21 | 2004-12-16 | 455d? | finish no earlier than 2004-12-16 | S5 | 3640h | 3640h | IMS2-CH | 32.260 | Rel-6 | Dionisio | Ericsson | Patrik TEPPO |  |
| 1655 | 529.15 | IMS Management objects |  | 306d? | 2004-09-03 A | 2005-11-04 A | 100% | 2004-09-03 | 2005-11-04 | 306d? | finish no earlier than 2005-03-04 | N1 | 2448h | 2448h |  | 24.167 | Rel-6 | Frederic |  |  |  |
| 1656 | 529.16 | Deleted - Stage 2 of IMS Phase 2 | milestone | 0d? | 2003-09-19 A | 2003-09-19 A | 100% | 2003-09-19 | 2003-09-19 | 0d? | finish no earlier than 2003-09-19 | S2 |  |  | IMS2 |  | Rel-6 | Maurice |  |  | SP-21 |

Notes:
- 1622: Not yet available: verbally approved at SA15, actual WID to be provided at SA16 by Lucent
- 1623: Shared public user identities need to be solved. If email approval CR is accepted. Work 100% done....
- 1624: -
- 1625: -
- 1626: -
- 1627: -
- 1628: Depends on CN decision on CPCP in Rel-6. Complete, if unresolved IETF dependencies are dropped (-> LS to CN plenary)
- 1629: -
- 1630: -
- 1631: Depends on CN decision on IETF dependencies in Rel-6. Higher figure if CPCP is dropped (-> LS to CN plenary)
- 1632: -
- 1633: -
- 1634: -
- 1635: -
- 1636: -
- 1637: -
- 1638: Updated according to SP-040232
- 1639: -
- 1640: -
- 1641: -
- 1642: -
- 1643: -
- 1644: [DAB 14.02.02] - end date pushed back to March 2003
- 1645: [DAB - 20.08.03] - CN Part of TR Complete @ CN#20
- 1646: -
- 1647: -
- 1648: -
- 1649: [DAB - 25.05.04] - CN3 consider this work to be complete
- 1650: TISPAN issue is open
- 1651: -
- 1652: -
- 1653: -
- 1654: SP#26 12/2004 completed
- 1655: -
- 1656: -

| ID | WBS | Task | Type | Duration | Start | Finish | Complete | Baseline start | Baseline finish | Baseline duration | Constraint | Resources | Work | Actual work | Text1 | Text4 | Text5 | Text6 | Text8 | Text3 | Text10 | Text12 |
| --- | --- | --- | --- | --- | --- | --- | --- | --- | --- | --- | --- | --- | --- | --- | --- | --- | --- | --- | --- | --- | --- | --- |
| 1657 | 530 | **3GPP Enablers for services like Push to Talk over Cellular (PoC)** |  | 459d? | 2003-09-08 A | 2005-06-09 A | 100% | 2003-09-08 | 2005-06-09 | 459d? |  | S2,S4,S5 | 10696h | 10696h | PoC | Ericsson | Shabnam Sultana | Rel-6 | Maurice |  |  |  |
| 1658 | 530.1 | Feasibility Study |  | 322d? | 2003-09-08 A | 2004-11-30 A | 100% | 2003-09-08 | 2004-11-30 | 322d? | finish no earlier than 2004-11-30 | S2 | 2576h | 2576h | PoC | Ericsson | Shabnam Sultana | Rel-6 | Maurice | 23.979 | SP-24 |  |
| 1659 | 530.2 | Dependencies on OMA PoC |  | 303d? | 2004-01-01 A | 2005-02-28 A | 100% | 2004-01-01 | 2005-02-28 | 303d? | finish no earlier than 2004-12-30 | OMA | 2424h | 2424h | PoC |  | OMA-LIAISON@mail.openmobilealliance.org | Rel-6 |  |  | SP-24 |  |
| 1660 | 530.3 | Selection of one or more PoC codec(s) for PoC |  | 69d? | 2004-09-13 A | 2004-12-16 A | 100% | 2004-09-13 | 2004-12-16 | 69d? | start no earlier than 2004-09-13 | S4 | 552h | 552h | PoC |  |  | Rel-6 | Paolo | 26.235, 26.236 | SP-25 |  |
| 1661 | 530.4 | PoC charging |  | 184d? | 2004-09-27 A | 2005-06-09 A | 100% | 2004-09-27 | 2005-06-09 | 184d? | finish no earlier than 2005-06-09 | S5 | 1472h | 1472h | PoC-CH | Siemens | Gerald.Goermer@nsn.com | Rel-6 | Dionisio | 32.272 |  |  |
| 1662 | 531 | Study on Interworking aspects and migration scenarios for IPv4 based IMS Implementations |  | 210d? | 2003-09-08 A | 2004-06-25 A | 100% | 2003-09-08 | 2004-06-25 | 210d? | finish no earlier than 2004-06-25 | S2 | 1680h | 1680h | IPv4IMS | Siemens | Alexander Milinski | Rel-6 | Maurice | 23.981 |  |  |
| 1663 | 16.3 | **Interoperability and Commonality between IMS using different IP-connectivity Networks** |  | 325d? | 2002-09-16 A | 2003-12-12 A | 100% | 2002-09-16 | 2003-12-12 | 325d? |  | S2 | 9176h | 9176h | IMSCOOP |  |  | Rel-6 | Maurice | 23.864 |  |  |
| 1664 | 16.3.1 | Stage 2 for Interoperability |  | 272d | 2002-09-16 A | 2003-09-30 A | 100% | 2002-09-16 | 2003-09-30 | 272d | finish no earlier than 2003-09-30 | S2 | 2176h | 2176h | IMSCOOP | Nokia | balazs.bertenyi@nsn.com | Rel-6 | Maurice | 23.864 |  |  |
| 1665 | 532.2 | Stage 2 for commonality |  | 265d? | 2002-09-16 A | 2003-09-19 A | 100% | 2002-09-16 | 2003-09-19 | 265d? | start no earlier than 2002-09-16 | S2 | 2120h | 2120h | IMSCOOP | Nokia | balazs.bertenyi@nsn.com | Rel-6 | Maurice | 23.864 |  |  |
| 1666 | 16.3.2 | Stage 3 |  | 305d | 2002-10-14 A | 2003-12-12 A | 100% | 2002-10-14 | 2003-12-12 | 305d | finish no earlier than 2003-12-12 | N1 | 2440h | 2440h | IMSCOOP | Lucent | Keith Drage (drage@alcatel-lucent.com) | Rel-6 | Frederic |  |  |  |
| 1667 | 17 | **Support of Push Services** |  | 823d | 2001-01-03 A | 2004-02-27 A | 100% | 2001-01-03 | 2004-02-27 | 823d |  | S1 | 11390.6h | 11390.6h | PUSH | NTT Comware | Yoshinori Kitada | Rel-6 | Alain | 23.976 |  |  |
| 1668 | 17.1 | Stage 1 |  | 378d | 2001-01-03 A | 2002-06-14 A | 100% | 2001-01-03 | 2002-06-14 | 378d | finish no earlier than 2002-06-14 | S1 | 3024h | 3024h | PUSH |  |  | Rel-6 | Alain |  |  |  |
| 1669 | 17.3 | TR 23.976 on Push Architecture |  | 340d | 2002-11-11 A | 2004-02-27 A | 100% | 2002-11-11 | 2004-02-27 | 340d | finish no earlier than 2004-02-27 | S2 | 2720h | 2720h | PUSH | RIM | Nick Alfano | Rel-6 | Maurice | 23.976 |  |  |
| 1670 | 18 | **Multimedia Messaging (MMS) enhancements** |  | 865d? | 2002-08-15 A | 2005-12-07 A | 100% | 2002-08-15 | 2005-12-07 | 865d? |  | T2,S1,S4,S5,OMA | 31936h | 31936h | MMS6 | Siemens | Josef.Laumen@SAL.SIEMENS.DE | Rel-6 | Kimmo |  |  |  |
| 1671 | 18.1 | **Definition of service requirements** |  | 286d? | 2002-11-15 A | 2003-12-19 A | 100% | 2002-11-15 | 2003-12-19 | 286d? |  | S1 | 4576h | 4576h | MMS6-SR |  |  | Rel-6 | Alain | 22.140 |  |  |
| 1672 | 534.1.1 | Definition of service requirements charging |  | 286d? | 2002-11-15 A | 2003-12-19 A | 100% | 2002-11-15 | 2003-12-19 | 286d? | finish no earlier than 2003-12-20 | S1 | 2288h | 2288h | MMS6-SR | Siemens | Josef.Laumen@SAL.SIEMENS.DE | Rel-6 | Alain | 22.140 |  |  |
| 1673 | 18.2 | Technical realization |  | 591d | 2002-09-06 A | 2004-12-10 A | 100% | 2002-09-06 | 2004-12-10 | 591d | finish no earlier than 2004-12-10 | T2 | 4728h | 4728h | MMS6 | Siemens | Josef.Laumen@SAL.SIEMENS.DE | Rel-6 | Kimmo | 23.140 |  |  |
| 1674 | 18.3 | OMA dependencies |  | 446d | 2003-08-15 A | 2005-04-29 A | 100% | 2003-08-15 | 2005-04-29 | 446d | finish no earlier than 2004-12-10 | OMA | 3568h | 3568h | MMS6 |  |  | Rel-6 | Kimmo | OMA specs |  |  |
| 1675 | 18.4 | MMS formats and codecs |  | 865d | 2002-08-15 A | 2005-12-07 A | 100% | 2002-08-15 | 2005-12-07 | 865d | finish no earlier than 2005-12-07 | S4 | 6920h | 6920h | MMS6-Codec | Nokia | roberto.castagno@nokia.com | Rel-6 | Paolo | 26.140, 26.936 |  |  |
| 1676 | 534.5 | Handling of private addressing schemes in MMS |  | 263d | 2003-12-10 A | 2004-12-10 A | 100% | 2003-12-10 | 2004-12-10 | 263d | finish no earlier than 2004-12-10 | T2 | 2104h | 2104h | MMS6 | T-Mobile | Steffen.Habermann@T-MOBILE.DE | Rel-6 | Kimmo | 23.140 |  |  |
| 1677 | 534.6 | MMS charging |  | 390d? | 2003-03-21 A | 2004-09-16 A | 100% | 2003-03-21 | 2004-09-16 | 390d? | start no earlier than 2003-03-21 | S5 | 3120h | 3120h | MMS6-CH |  |  | Rel-6 | Dionisio | 32.270 |  |  |
| 1678 | 534.7 | Deleted - FS Multiple MMS Relay/Server Architecture | milestone | 0d | 2004-12-10 A | 2004-12-10 A | 100% | 2004-12-10 | 2004-12-10 | 0d | finish no earlier than 2004-12-10 | T2 |  |  | MMS6 | Telefónica Móviles | Juan Gorospe (gorospe_j@tsm.es) | Rel-6 | Kimmo | probably Annex to 23.140 |  | TP-26 |
| 1679 | 19 | **Rel-6 MExE enhancements** |  | 326d | 2002-03-08 A | 2003-06-06 A | 100% | 2002-03-08 | 2003-06-06 | 326d |  | T2 | 7328h | 7328h | MEXE6 |  |  | Rel-6 | Kimmo |  |  |  |
| 1680 | 19.1 | MExE Rel-6 Improvements and Investigations |  | 264d | 2002-03-08 A | 2003-03-12 A | 100% | 2002-03-08 | 2003-03-12 | 264d | finish no earlier than 2003-03-12 | T2 | 2112h | 2112h | MEXE6-ENHANC | TTPCom | Lars Brenk ( (lsb_ttpcom@HOTMAIL.COM) | Rel-6 | Kimmo |  |  |  |
| 1681 | 19.2 | MExE Run-Time Independent Framework Feasibility Study |  | 326d | 2002-03-08 A | 2003-06-06 A | 100% | 2002-03-08 | 2003-06-06 | 326d | finish no earlier than 2003-06-06 | T2 | 2608h | 2608h | MEXE6-RTIF | Nokia Siemens Networks | BERTENYI, Balazs | Rel-6 | Kimmo | 22.857 |  |  |
| 1682 | 21 | Subscription Management |  | 650d | 2002-09-20 A | 2005-03-17 A | 100% | 2002-09-20 | 2005-03-17 | 650d | finish no earlier than 2005-03-17 | S5 | 5200h | 5200h | SuM | T-Mobile | istvan.aba@t-mobile.at | Rel-6 | Dionisio | 32.140/1, 32.171/2/5, 32.803 |  |  |

Notes:
- 1657: -
- 1658: -
- 1659: Updated according to SP-040232
- 1660: Completed
- 1661: SP#28 06/2005 completed
- 1662: -
- 1663: -
- 1664: No contributions assumed that no more will be done in 3GPP hence work may need to be done in 3GPP2
- 1665: -
- 1666: -
- 1667: Changed from FS to actual support of Push
- 1668: -
- 1669: -
- 1670: -
- 1671: -
- 1672: -
- 1673: -
- 1674: -
- 1675: -
- 1676: -
- 1677: SP#25 09/2004 completed
- 1678: originally it was intended to create a FS TR but most likely the work will become an Annex of 23.140
- 1679: -
- 1680: -
- 1681: -
- 1682: SP#27 03/2005 completed

| ID | WBS | Task | Duration | Start | Finish | Complete | Baseline start | Baseline finish | Baseline duration | Constraint | Resources | Work | Actual work | Text1 | Text4 | Text5 | Text6 | Text8 | Text3 |
| --- | --- | --- | --- | --- | --- | --- | --- | --- | --- | --- | --- | --- | --- | --- | --- | --- | --- | --- | --- |
| 1683 | 22 | **Presence Capability** | 1233d? | 2001-03-19 A | 2005-12-07 A | 100% | 2001-03-19 | 2005-12-07 | 1233d? |  | S1 | 37112h | 37112h | PRESNC | Motorola | Mark Cataldo | Rel-6 | Alain |  |
| 1684 | 22.1 | Stage 1 | 610d | 2001-03-19 A | 2003-07-18 A | 100% | 2001-03-19 | 2003-07-18 | 610d | finish no earlier than 2003-07-18 | S1 | 4880h | 4880h | PRESNC |  |  | Rel-6 | Alain | 22.141 |
| 1685 | 22.2 | Stage 2 | 268d | 2001-09-12 A | 2002-09-20 A | 100% | 2001-09-12 | 2002-09-20 | 268d | finish no earlier than 2002-09-20 | S2 | 2144h | 2144h | PRESNC | Nokia | balazs.bertenyi@nsn.com | Rel-6 | Maurice |  |
| 1686 | 22.3 | Stage 3 | 703d | 2002-04-01 A | 2004-12-08 A | 100% | 2002-04-01 | 2004-12-08 | 703d | finish no earlier than 2004-12-08 | N1 | 5624h | 5624h | PRESNC | Lucent | Keith Drage (drage@alcatel-lucent.com) | Rel-6 | Frederic |  |
| 1687 | 537.4 | Stage 3 (CN3 Part Pk interface) | 770d? | 2002-04-01 A | 2005-03-11 A | 100% | 2002-04-01 | 2005-03-11 | 770d? | finish no earlier than 2005-03-11 | N3 | 6160h | 6160h | PRESNC |  |  | Rel-6 | Gwiho |  |
| 1688 | 537.5 | Media Codecs and Formats for IMS Messaging and Presence | 650d? | 2003-06-12 A | 2005-12-07 A | 100% | 2003-06-12 | 2005-12-07 | 650d? | finish no earlier than 2005-12-07 | S4 | 5200h | 5200h | PRESNC-COFIMP | Nokia | harri.honko@nokia.com | Rel-6 | Paolo | 26.141, 26.936 |
| 1689 | 22.4 | Security issues | 79d | 2002-08-26 A | 2002-12-12 A | 100% | 2002-08-26 | 2002-12-12 | 79d | finish no earlier than 2002-12-12 | S3 | 632h | 632h | PRESNC |  |  | Rel-6 | Dionisio |  |
| 1690 | 537.7 | SIMPLE Presence | 326d? | 2004-01-01 A | 2005-03-31 A | 100% | 2004-01-01 | 2005-03-31 | 326d? | finish no earlier than 2004-12-30 | OMA | 2608h | 2608h | PRESNC |  | OMA-LIAISON@mail.openmobilealliance.org | Rel-6 |  |  |
| 1691 | 25 | **Enhanced A/Gb feasibility study** | 51d? | 2002-08-30 A | 2002-11-08 A | 100% | 2002-08-30 | 2002-11-08 | 51d? |  | GP | 3264h | 3264h | AGbEnFS | Vodafone | jose-luis.carrizo@vodafone.co.uk | Rel-6 | Paolo | None |
| 1692 | 25.1 | **Feasibility study on A/Gb enhancements** | 51d? | 2002-08-30 A | 2002-11-08 A | 100% | 2002-08-30 | 2002-11-08 | 51d? |  | G2 | 2856h | 2856h | AGbEnFS-FS | Vodafone | jose-luis.carrizo@vodafone.co.uk | Rel-6 | Gert | None |
| 1693 | 25.1.1 | Requirements for the support of conversational services | 51d | 2002-08-30 A | 2002-11-08 A | 100% | 2002-08-30 | 2002-11-08 | 51d | finish no earlier than 2002-11-08 | GP | 408h | 408h | AGbEnFS-FS |  |  | Rel-6 | Paolo | None |
| 1694 | 538.1.2 | Identification of the different building blocks for the provision of conversational services on the existing A/Gb protocol stack | 51d? | 2002-08-30 A | 2002-11-08 A | 100% | 2002-08-30 | 2002-11-08 | 51d? | finish no earlier than 2002-11-08 | GP | 408h | 408h | AGbEnFS-FS |  |  | Rel-6 | Paolo | None |
| 1695 | 538.1.3 | Outline of impact and feasibility of these building blocks and their different solutions | 51d? | 2002-08-30 A | 2002-11-08 A | 100% | 2002-08-30 | 2002-11-08 | 51d? | finish no earlier than 2002-11-08 | GP | 408h | 408h | AGbEnFS-FS |  |  | Rel-6 | Paolo | None |
| 1696 | 25.1.4 | Impact on 3GPP architecture and requirement to co-ordinatge with other TSGs (CN, SA) | 51d | 2002-08-30 A | 2002-11-08 A | 100% | 2002-08-30 | 2002-11-08 | 51d | finish no earlier than 2002-11-08 | GP | 408h | 408h | AGbEnFS-FS |  |  | Rel-6 | Paolo | None |
| 1697 | 25.1.5 | Standardisation effort | 51d | 2002-08-30 A | 2002-11-08 A | 100% | 2002-08-30 | 2002-11-08 | 51d | finish no earlier than 2002-11-08 | GP | 408h | 408h | AGbEnFS-FS |  |  | Rel-6 | Paolo | None |
| 1698 | 25.1.6 | Dependency to other features | 51d | 2002-08-30 A | 2002-11-08 A | 100% | 2002-08-30 | 2002-11-08 | 51d | finish no earlier than 2002-11-08 | GP | 408h | 408h | AGbEnFS-FS |  |  | Rel-6 | Paolo | None |
| 1699 | 26 | **Flexible Layer One for GERAN** | 1171d | 2000-01-03 A | 2004-06-25 A | 100% | 2000-01-03 | 2004-06-25 | 1171d |  | GP | 71551h | 71551h | FLOGER | Nokia | benoist.sebire@nokia.com | Rel-6 | Paolo |  |
| 1700 | 26.1 | **Realisation of a Flexible Layer One** | 1126d | 2000-01-03 A | 2004-04-23 A | 100% | 2000-01-03 | 2004-04-23 | 1126d |  | GP | 42816h | 42816h | FLOGER-Real | Nokia | benoist.sebire@nokia.com | Rel-6 | Paolo |  |
| 1701 | 26.1.1 | Technical Report | 471d | 2002-04-19 A | 2004-02-06 A | 100% | 2002-04-19 | 2004-02-06 | 471d | finish no earlier than 2004-02-06 | GP | 3768h | 3768h | FLOGER-Real |  |  | Rel-6 | Paolo |  |
| 1702 | 26.1.2 | Architecture in 45.001 and 43.051 | 526d | 2002-04-19 A | 2004-04-23 A | 100% | 2002-04-19 | 2004-04-23 | 526d | finish no earlier than 2004-04-23 | G1 | 4208h | 4208h | FLOGER-Real |  |  | Rel-6 | Paolo |  |
| 1703 | 26.1.3 | Multiplexing in 45.002 | 526d | 2002-04-19 A | 2004-04-23 A | 100% | 2002-04-19 | 2004-04-23 | 526d | finish no earlier than 2004-04-23 | G1 | 4208h | 4208h | FLOGER-Real |  |  | Rel-6 | Paolo |  |
| 1704 | 26.1.4 | Channel Coding in 45.003 | 526d | 2002-04-19 A | 2004-04-23 A | 100% | 2002-04-19 | 2004-04-23 | 526d | finish no earlier than 2004-04-23 | G1 | 4208h | 4208h | FLOGER-Real |  |  | Rel-6 | Paolo |  |
| 1705 | 26.1.5 | Performance Requirements in 45.005 | 1126d | 2000-01-03 A | 2004-04-23 A | 100% | 2000-01-03 | 2004-04-23 | 1126d | finish no earlier than 2004-04-23 | G1 | 9000h | 9000h | FLOGER-Real |  |  | Rel-6 | Paolo |  |
| 1706 | 26.1.6 | Radio subsystem link control in 45.008 | 526d | 2002-04-19 A | 2004-04-23 A | 100% | 2002-04-19 | 2004-04-23 | 526d | finish no earlier than 2004-04-23 | G1 | 4208h | 4208h | FLOGER-Real |  |  | Rel-6 | Paolo |  |
| 1707 | 26.1.7 | Requirements in 44.004 | 526d | 2002-04-19 A | 2004-04-23 A | 100% | 2002-04-19 | 2004-04-23 | 526d | finish no earlier than 2004-04-23 | G2 | 4208h | 4208h | FLOGER-Real |  |  | Rel-6 | Gert |  |

Notes:
- 1683: merged "Presence Service Enhancements" (UID31028, PRES1) to this feature as no answer was provided on why Presence and Presence Encmts had same target completion date
- 1684: -
- 1685: -
- 1686: Dependency to 2 IETF drafts, no known work at the moment
- 1687: No Contributions so far - only requires a little work
- 1688: -
- 1689: LSs handled in SA3. WID approved SP#17 Contribution at S3#25 & following e-mail discussion. Marked as closed 12/2008 (was marked 90% complete)
- 1690: Updated according to SP-040232
- 1691: -
- 1692: -
- 1693: -
- 1694: -
- 1695: -
- 1696: -
- 1697: -
- 1698: -
- 1699: -
- 1700: -
- 1701: -
- 1702: -
- 1703: -
- 1704: -
- 1705: -
- 1706: -
- 1707: -

| ID | WBS | Task | Type | Duration | Start | Finish | Complete | Baseline start | Baseline finish | Baseline duration | Constraint | Resources | Work | Actual work | Text1 | Text4 | Text5 | Text6 | Text8 | Text12 | Text3 |
| --- | --- | --- | --- | --- | --- | --- | --- | --- | --- | --- | --- | --- | --- | --- | --- | --- | --- | --- | --- | --- | --- |
| 1708 | 26.2 | **Signalling and protocol support for a Flexible Layer One** |  | 571d | 2002-04-19 A | 2004-06-25 A | 100% | 2002-04-19 | 2004-06-25 | 571d |  | G2 | 13704h | 13704h | FLOGER-SigPro | Nokia | benoist.sebire@nokia.com | Rel-6 | Gert |  |  |
| 1709 | 26.2.1 | Modifications to RLC/MAC in 44.060 and 44.160 |  | 571d | 2002-04-19 A | 2004-06-25 A | 100% | 2002-04-19 | 2004-06-25 | 571d | finish no earlier than 2004-06-25 | G2 | 4568h | 4568h | FLOGER-SigPro |  |  | Rel-6 | Gert |  |  |
| 1710 | 26.2.2 | Modifications to RRC in 44.118 and 44.018 |  | 571d | 2002-04-19 A | 2004-06-25 A | 100% | 2002-04-19 | 2004-06-25 | 571d | finish no earlier than 2004-06-25 | G2 | 4568h | 4568h | FLOGER-SigPro |  |  | Rel-6 | Gert |  |  |
| 1711 | 26.3 | **Security for a Flexible Layer One** |  | 356d | 2002-04-19 A | 2003-08-29 A | 100% | 2002-04-19 | 2003-08-29 | 356d |  | S3, G2 | 5663.03h | 5663.03h | FLOGER-SecFLO | Nokia | benoist.sebire@nokia.com | Rel-6 | Dionisio |  |  |
| 1712 | 26.3.1 | Ciphering in 44.160,44.118, 44.060 and 44.018 |  | 356d | 2002-04-19 A | 2003-08-29 A | 100% | 2002-04-19 | 2003-08-29 | 356d | finish no earlier than 2003-08-29 | S3, G2 | 2848h | 2848h | FLOGER-SecFLO |  |  | Rel-6 | Dionisio |  |  |
| 1713 | 26.4 | **Deleted - GERAN MS Conformance test for the Flexible Layer One - DELETE** |  | 0d | 2004-02-06 A | 2004-02-06 A | 100% | 2004-02-06 | 2004-02-06 | 0d |  | G4,G5 |  |  | FLOGER-Msconf | Nokia | benoist.sebire@nokia.com | Rel-6 | Paolo | GP-27 |  |
| 1714 | 26.4.1 | Deleted at TSG #27 - MS Test in 51.010 | milestone | 0d | 2004-02-06 A | 2004-02-06 A | 100% | 2004-02-06 | 2004-02-06 | 0d | finish no earlier than 2004-02-06 | G4,G5 |  |  | FLOGER-Msconf |  |  | Rel-6 | Paolo | GP-22 |  |
| 1715 | 26.5 | **Deleted - GERAN BTS Conformance test for the Flexible Layer One - DELETE** |  | 0d | 2004-02-06 A | 2004-02-06 A | 100% | 2004-02-06 | 2004-02-06 | 0d |  | G3new |  |  | FLOGER-BTSconf | Nokia | benoist.sebire@nokia.com | Rel-6 | Ingbert | GP-27 |  |
| 1716 | 26.5.1 | Deleted at TGS #27 - BTS Test in 51.021 - DELETE | milestone | 0d | 2004-02-06 A | 2004-02-06 A | 100% | 2004-02-06 | 2004-02-06 | 0d | finish no earlier than 2004-02-06 | G3new |  |  | FLOGER-BTSconf |  |  | Rel-6 | Ingbert | GP-22 |  |
| 1717 | 27 | Uplink TDOA feasibility study |  | 151d | 2001-11-30 A | 2002-06-28 A | 100% | 2001-11-30 | 2002-06-28 | 151d | finish no earlier than 2002-06-28 | GP | 1208h | 1208h | TDOAF | TruePosition | Bob Gross (rlgross@trueposition.com) | Rel-6 | Paolo |  | 45.811 |
| 1718 | 28 | **Multimedia Broadcast and Multicast Service** |  | 1781d? | 2001-05-11 A | 2008-03-07 A | 100% | 2001-05-11 | 2008-03-07 | 1781d? |  | S1,S2,S4,S5,RP,R5,GP | 158712h | 158712h | MBMS |  |  | Rel-6 | Alain |  |  |
| 1719 | 28.1 | Stage 1 |  | 232d | 2001-05-11 A | 2002-04-01 A | 100% | 2001-05-11 | 2002-04-01 | 232d | finish no earlier than 2002-04-01 | S1 | 1856h | 1856h | MBMS |  |  | Rel-6 | Alain |  | 22.146, 22.101 |
| 1720 | 28.2 | **Stage 2** |  | 648d | 2001-09-24 A | 2004-03-17 A | 100% | 2001-09-24 | 2004-03-17 | 648d |  | S2 | 10408h | 10408h | MBMS |  |  | Rel-6 | Maurice |  |  |
| 1721 | 28.2.1 | TR on Architectural Study |  | 240d | 2001-09-24 A | 2002-08-23 A | 100% | 2001-09-24 | 2002-08-23 | 240d | finish no earlier than 2002-08-23 | S2 | 1920h | 1920h | MBMS |  |  | Rel-6 | Maurice |  | 23.846 |
| 1722 | 28.2.2 | Stage 2 Specification Work |  | 413d | 2002-08-19 A | 2004-03-17 A | 100% | 2002-08-19 | 2004-03-17 | 413d | finish no earlier than 2004-03-17 | S2 | 3304h | 3304h | MBMS |  |  | Rel-6 | Maurice |  | 23.246 |
| 1723 | 28.3 | **Introduction of MBMS in RAN** |  | 967d? | 2002-01-01 A | 2005-09-14 A | 100% | 2002-01-01 | 2005-09-14 | 967d? |  | R2 | 15992h | 15992h | MBMS-RAN | Nokia | juho.pirskanen@nokia.com | Rel-6 | Joern |  | 25.346, 25.304, 25.321, 25.322, 25.323, 25.331 |
| 1724 | 541.3.1 | Introduction of MBMS in RAN (physical & upper layers, access network interfaces) |  | 771d? | 2002-01-01 A | 2004-12-14 A | 100% | 2002-01-01 | 2004-12-14 | 771d? | finish no earlier than 2004-12-14 | R2 | 6168h | 6168h | MBMS-RAN | Nokia | juho.pirskanen@nokia.com | Rel-6 | Joern |  | 25.346, 25.304, 25.321, 25.322, 25.323 |
| 1725 | 541.3.2 | UE Performance Requirements for MBMS |  | 261d? | 2004-09-15 A | 2005-09-14 A | 100% | 2004-09-15 | 2005-09-14 | 261d? | finish no earlier than 2005-09-15 | R4 | 2088h | 2088h | MBMS-RAN-RF | Ericsson | Torgny.Palenius@ericsson.com | Rel-6 | Issam |  | 25.101, 25.133 |
| 1726 | 28.4 | Support of the MBMS in CN protocols |  | 647d | 2002-06-18 A | 2004-12-08 A | 100% | 2002-06-18 | 2004-12-08 | 647d | finish no earlier than 2004-12-08 | N1 | 5176h | 5176h | MBMS |  |  | Rel-6 | Frederic |  |  |
| 1727 | 541.5 | Gmb interface for MBMS (CN3 part) |  | 334d | 2003-08-29 A | 2004-12-08 A | 100% | 2003-08-29 | 2004-12-08 | 334d | finish no earlier than 2004-12-08 | N3 | 2672h | 2672h | MBMS |  |  | Rel-6 | Gwiho |  | 29.061 |
| 1728 | 28.5 | Security Aspects of MBMS |  | 710d | 2002-07-01 A | 2005-03-18 A | 100% | 2002-07-01 | 2005-03-18 | 710d | finish no earlier than 2005-03-18 | S3 | 5680h | 5680h | MBMS |  | adrian.escott@three.co.uk | Rel-6 | Dionisio |  |  |
| 1729 | 28.6 | **Support of MBMS in GERAN** |  | 892d? | 2001-08-30 A | 2005-01-28 A | 100% | 2001-08-30 | 2005-01-28 | 892d? |  | GP | 71040h | 71040h | MBMS-GERAN |  |  | Rel-6 | Paolo |  |  |
| 1730 | 28.6.1 | Impact on the logical and physical channels |  | 631d | 2002-08-30 A | 2005-01-28 A | 100% | 2002-08-30 | 2005-01-28 | 631d | finish no earlier than 2005-01-28 | GP | 5048h | 5048h | MBMS-GERAN |  |  | Rel-6 | Paolo |  |  |
| 1731 | 28.6.4 | Re-synchronisation at cell change |  | 631d | 2002-08-30 A | 2005-01-28 A | 100% | 2002-08-30 | 2005-01-28 | 631d | finish no earlier than 2005-01-28 | G2 | 5048h | 5048h | MBMS-GERAN |  |  | Rel-6 | Gert |  |  |
| 1732 | 541.7.3 | Simultaneous support of MBMS services |  | 631d? | 2002-08-30 A | 2005-01-28 A | 100% | 2002-08-30 | 2005-01-28 | 631d? | finish no earlier than 2005-01-28 | GP | 5048h | 5048h | MBMS-GERAN |  |  | Rel-6 | Paolo |  |  |
| 1733 | 541.7.4 | Simultaneous support of MBMS and non-MBMS services |  | 892d? | 2001-08-30 A | 2005-01-28 A | 100% | 2001-08-30 | 2005-01-28 | 892d? | finish no earlier than 2005-01-28 | GP | 7136h | 7136h | MBMS-GERAN |  |  | Rel-6 | Paolo |  |  |
| 1734 | 541.7.5 | Resynchronisation at cell change |  | 892d? | 2001-08-30 A | 2005-01-28 A | 100% | 2001-08-30 | 2005-01-28 | 892d? | finish no earlier than 2005-01-28 | GP | 7136h | 7136h | MBMS-GERAN |  |  | Rel-6 | Paolo |  |  |
| 1735 | 28.6.5 | Decision making process between point-to-point or pont-to-multipoint configurations |  | 631d | 2002-08-30 A | 2005-01-28 A | 100% | 2002-08-30 | 2005-01-28 | 631d | finish no earlier than 2005-01-28 | GP | 5048h | 5048h | MBMS-GERAN |  |  | Rel-6 | Paolo |  |  |
| 1736 | 28.6.6 | MBMS channel allocations procedures to multiple MSs |  | 631d | 2002-08-30 A | 2005-01-28 A | 100% | 2002-08-30 | 2005-01-28 | 631d | finish no earlier than 2005-01-28 | GP | 5048h | 5048h | MBMS-GERAN |  |  | Rel-6 | Paolo |  |  |
| 1737 | 28.6.7 | Changes to the Gb interface |  | 631d | 2002-08-30 A | 2005-01-28 A | 100% | 2002-08-30 | 2005-01-28 | 631d | finish no earlier than 2005-01-28 | GP | 5048h | 5048h | MBMS-GERAN |  |  | Rel-6 | Paolo |  |  |
| 1738 | 28.6.8 | GERAN specific changes to the Iu-ps interface |  | 631d | 2002-08-30 A | 2005-01-28 A | 100% | 2002-08-30 | 2005-01-28 | 631d | finish no earlier than 2005-01-28 | GP | 5048h | 5048h | MBMS-GERAN |  |  | Rel-6 | Paolo |  |  |
| 1739 | 28.6.9 | Interaction between MBMS and Iu-flex |  | 631d | 2002-08-30 A | 2005-01-28 A | 100% | 2002-08-30 | 2005-01-28 | 631d | finish no earlier than 2005-01-28 | GP | 5048h | 5048h | MBMS-GERAN |  |  | Rel-6 | Paolo |  |  |
| 1740 | 28.6.10 | Security aspects |  | 631d | 2002-08-30 A | 2005-01-28 A | 100% | 2002-08-30 | 2005-01-28 | 631d | finish no earlier than 2005-01-28 | GP | 5048h | 5048h | MBMS-GERAN |  |  | Rel-6 | Paolo |  |  |
| 1741 | 541.7.12 | MBMS-GERAN - MS conformance tests |  | 786d? | 2002-01-25 A | 2005-01-28 A | 100% | 2002-01-25 | 2005-01-28 | 786d? | finish no earlier than 2005-01-28 | G3new | 6288h | 6288h | MBMS-GERAN |  |  | Rel-6 | Ingbert |  |  |
| 1742 | 541.7.13 | Deleted - MS conformance tests - G5 | milestone | 0d? | 2003-06-27 A | 2003-06-27 A | 100% | 2003-06-27 | 2003-06-27 | 0d? | start no earlier than 2003-06-27 | G5 |  |  | MBMS-GERAN |  |  | Rel-6 | Paolo | GP-19 |  |

Notes:
- 1708: -
- 1709: -
- 1710: -
- 1711: -
- 1712: -
- 1713: -
- 1714: -
- 1715: -
- 1716: -
- 1717: -
- 1718: Title renamed at SP#13
- 1719: This may or may not be a separate stage 1. In the meantime, CRs are proposed for 22.101
- 1720: -
- 1721: -
- 1722: -
- 1723: -
- 1724: Was "Introduction of MBMS in RAN" before RP#25. Created w/o WIDS after RAN approved the WT for RF aspects.Take WIDS from the parent BB
- 1725: Approved at RP#25 as RP-040370
- 1726: -
- 1727: -
- 1728: WID approved SP#17. 2004-12: Expected completion March 2005
- 1729: -
- 1730: -
- 1731: -
- 1732: -
- 1733: -
- 1734: -
- 1735: -
- 1736: -
- 1737: -
- 1738: -
- 1739: -
- 1740: -
- 1741: -
- 1742: -

| ID | WBS | Task | Type | Duration | Start | Finish | Complete | Baseline start | Baseline finish | Baseline duration | Constraint | Deadline | Resources | Work | Actual work | Text1 | Text6 | Text8 | Text4 | Text5 | Text10 | Text12 |
| --- | --- | --- | --- | --- | --- | --- | --- | --- | --- | --- | --- | --- | --- | --- | --- | --- | --- | --- | --- | --- | --- | --- |
| 1743 | 28.1 | **MBMS User Services** |  | 743d? | 2003-05-13 A | 2006-03-16 A | 100% | 2003-05-13 | 2006-03-16 | 743d? |  |  | S1 | 13576h | 13576h | MBMS | Rel-6 | Alain |  |  |  |  |
| 1744 | 28.1 | MBMS User Services Stage 1 |  | 233d | 2003-05-13 A | 2004-04-01 A | 100% | 2003-05-13 | 2004-04-01 | 233d | start no earlier than 2003-05-13 |  | S1 | 1864h | 1864h | MBMS | Rel-6 | Alain |  |  |  |  |
| 1745 | 541.8.2 | Definition of MBMS user services, media codecs, formats and transport/application protocols using MBMS |  | 721d? | 2003-06-12 A | 2006-03-16 A | 100% | 2003-06-12 | 2006-03-16 | 721d? | finish no earlier than 2006-03-16 |  | S4 | 5768h | 5768h | MBMS-TSMBMS | Rel-6 | Paolo | Nokia | igor.curcio@nokia.com |  |  |
| 1746 | 541.9 | MBMS charging |  | 108d? | 2005-01-11 A | 2005-06-09 A | 100% | 2005-01-11 | 2005-06-09 | 108d? | start no earlier than 2005-01-11 |  | S5 | 864h | 864h | MBMS-CH | Rel-6 | Dionisio |  |  |  |  |
| 1747 | 541.10 | **MBMS UE Conformance Testing** |  | 521d? | 2006-03-10 A | 2008-03-07 A | 100% | 2006-03-10 | 2008-03-07 | 521d? |  |  | R5,T1 | 17200h | 17200h | MBMS-UEConTest | Rel-6 | Ingbert |  |  |  |  |
| 1748 | 16.5.1 | RF/RRM Conformance Test Aspects – MBMS (FDD) |  | 461d | 2006-06-02 A | 2008-03-07 A | 100% | 2006-06-02 | 2008-03-07 | 461d | finish no earlier than 2008-03-07 | 2006-06-02 | R5,T1 | 3688h | 3688h | MBMS-RAN-RF_Test | Rel-6 | Ingbert | Ericsson | leif.mattisson@ericsson.com | Fri 11/03/05 |  |
| 1749 | 541.10.2 | Conformance Test Aspects - MBMS for 3.84 Mcps and 7.68 Mcps TDD |  | 318d? | 2006-09-20 A | 2007-12-07 A | 100% | 2006-09-20 | 2007-12-07 | 318d? | finish no earlier than 2007-12-07 |  | R5,T1 | 2544h | 2544h | MBMS-UEConTest_TDH | Rel-6 | Ingbert | IPWireless | Timothy Speight (tspeight@ipwireless.com) |  |  |
| 1750 | 541.10.3 | Signalling Conformance Test Aspects – MBMS for LCR TDD |  | 318d? | 2006-09-20 A | 2007-12-07 A | 100% | 2006-09-20 | 2007-12-07 | 318d? | finish no earlier than 2007-12-07 |  | R5,T1 | 2544h | 2544h | MBMS-UEConTest_SIGTDL | Rel-6 | Ingbert | DATANG | zhaojian@datangmobile.cn |  |  |
| 1751 | 541.10.4 | Conformance Test Aspects – MBMS |  | 396d? | 2006-03-10 A | 2007-09-14 A | 100% | 2006-03-10 | 2007-09-14 | 396d? | finish no earlier than 2007-09-14 |  | R5,T1 | 3168h | 3168h | MBMS_Test | Rel-6 | Ingbert | Qualcomm | Shubhang Vora (svora@qualcomm.com) |  |  |
| 1752 | 16.5.1 | Conformance Test Aspects - 1.28 Mcps TDD MBMS RF/RRM |  | 136d | 2007-06-01 A | 2007-12-07 A | 100% | 2007-06-01 | 2007-12-07 | 136d | finish no earlier than 2007-12-07 | 2006-06-02 | R5,T1 | 1088h | 1088h | MBMS-UEConTest_RFTDL | Rel-6 | Ingbert | Datang Mobile | chenxiaozhong@datangmobile.cn | Fri 11/03/05 |  |
| 1753 | 29 | **Speech Recognition and Speech Enabled Services** |  | 1105d? | 2001-10-08 A | 2005-12-30 A | 100% | 2001-10-08 | 2005-12-30 | 1105d? |  |  | S1 | 20176h | 20176h | SRSES | Rel-6 | Alain |  |  |  |  |
| 1754 | 29.1 | Speech Enabled Services Based on Distributed Speech Recognition (DSR) |  | 115d | 2001-10-08 A | 2002-03-15 A | 100% | 2001-10-08 | 2002-03-15 | 115d | finish no earlier than 2002-03-15 |  | S1 | 920h | 920h | DSR | Rel-6 | Alain | Qualcomm | Dwilliams@qualcomm.com |  |  |
| 1755 | 29.2 | TR on Architectural impacts |  | 212d | 2003-05-12 A | 2004-03-02 A | 100% | 2003-05-12 | 2004-03-02 | 212d | finish no earlier than 2004-03-02 |  | S2 | 1696h | 1696h | SRSES | Rel-6 | Maurice |  |  |  |  |
| 1756 | 542.3 | Codec Work to Support Speech Recognition Framework for Automated Voice Services |  | 568d? | 2002-10-15 A | 2004-12-16 A | 100% | 2002-10-15 | 2004-12-16 | 568d? | finish no earlier than 2004-12-16 |  | S4 | 4544h | 4544h | SRSES-Codec | Rel-6 | Paolo | Motorola | David Pearce (bdp003@motorola.com) |  |  |
| 1757 | 542.4 | Multimodal support |  | 522d? | 2004-01-01 A | 2005-12-30 A | 100% | 2004-01-01 | 2005-12-30 | 522d? | finish no earlier than 2005-06-30 |  | OMA | 4176h | 4176h | SRSES | Rel-6 | Paolo |  | OMA-LIAISON@mail.openmobilealliance.org | SP-24 |  |
| 1758 | 542.5 | Deleted - SES codec negotiation at Session Description Protocol (SDP) | milestone | 0d? | 2003-06-04 A | 2003-06-04 A | 100% | 2003-06-04 | 2003-06-04 | 0d? | start no earlier than 2003-06-04 |  | N1 |  |  | SRSES | Rel-6 | Frederic |  |  |  | NP-23 |
| 1759 | 30 | **Generic User Profile Rel-6** |  | 889d | 2001-10-08 A | 2005-03-03 A | 100% | 2001-10-08 | 2005-03-03 | 889d |  |  | S1 | 24295.8h | 24295.8h | GUP | Rel-6 | Alain |  |  |  |  |
| 1760 | 30.1 | Stage 1 - Requirements |  | 430d | 2001-10-08 A | 2003-05-30 A | 100% | 2001-10-08 | 2003-05-30 | 430d | finish no earlier than 2002-12-09 |  | S1 | 3440h | 3440h | GUP | Rel-6 | Alain | T-Mobile | kurt.bischinger@t-mobile.at |  |  |
| 1761 | 30.3 | Stage 2 - Architecture |  | 355d | 2002-01-28 A | 2003-06-06 A | 100% | 2002-01-28 | 2003-06-06 | 355d | finish no earlier than 2003-06-06 |  | S2 | 2840h | 2840h | GUP | Rel-6 | Maurice | Nokia | harri.o.koskinen@nokia.com |  |  |
| 1762 | 30.2 | Stage 2 - Data Description Method |  | 586d | 2002-12-05 A | 2005-03-03 A | 100% | 2002-12-05 | 2005-03-03 | 586d | finish no earlier than 2005-03-03 |  | N4 | 4688h | 4688h | GUP | Rel-6 | Kimmo | T-Mobile | kurt.bischinger@t-mobile.at |  |  |
| 1763 | 30.5 | Stage 3 - Network |  | 468.98d | 2003-05-19 A | 2005-03-03 A | 100% | 2003-05-19 | 2005-03-03 | 468.98d | finish no earlier than 2005-03-03 |  | N4 | 3751.83h | 3751.83h | GUP | Rel-6 | Kimmo |  |  |  |  |
| 1764 | 30.6 | Security Aspects |  | 308d | 2002-07-16 A | 2003-09-18 A | 100% | 2002-07-16 | 2003-09-18 | 308d | finish no earlier than 2003-09-18 |  | S3 | 2464h | 2464h | GUP | Rel-6 | Dionisio | Lucent | Owen, Bradley (bvowen@lucent.com) |  |  |
| 1765 | 31 | **Digital Rights Management** |  | 690d? | 2001-10-08 A | 2004-05-28 A | 100% | 2001-10-08 | 2004-05-28 | 690d? |  |  | S1 | 10152h | 10152h | DRM | Rel-6 | Alain |  |  |  |  |
| 1766 | 31.1 | Requirements |  | 179d | 2001-10-08 A | 2002-06-13 A | 100% | 2001-10-08 | 2002-06-13 | 179d | finish no earlier than 2002-06-13 |  | S1 | 1432h | 1432h | DRM | Rel-6 | Alain | Openwave | nicholas.wood@openwave.com |  |  |
| 1767 | 544.2 | Stage 2 |  | 107d? | 2004-01-01 A | 2004-05-28 A | 100% | 2004-01-01 | 2004-05-28 | 107d? | finish no earlier than 2004-05-28 |  | OMA | 856h | 856h | DRM | Rel-6 |  |  | OMA-LIAISON@mail.openmobilealliance.org | SP-24 |  |
| 1768 | 544.3 | Stage 3 |  | 107d? | 2004-01-01 A | 2004-05-28 A | 100% | 2004-01-01 | 2004-05-28 | 107d? | finish no earlier than 2004-05-28 |  | OMA | 856h | 856h | DRM | Rel-6 |  |  | OMA-LIAISON@mail.openmobilealliance.org | SP-24 |  |
| 1769 | 31.3 | Security |  | 186d | 2002-06-17 A | 2003-03-03 A | 100% | 2002-06-17 | 2003-03-03 | 186d | finish no earlier than 2003-03-03 |  | OMA | 1488h | 1488h | DRM | Rel-6 |  |  |  |  |  |
| 1770 | 544.5 | Deleted - Monitoring of Stages 2 and 3 progress (actual work to be done by OMA) | milestone | 0d? | 2003-03-21 A | 2003-03-21 A | 100% | 2003-03-21 | 2003-03-21 | 0d? | start no earlier than 2002-08-19 |  | S1 |  |  | DRM | Rel-6 | Alain |  |  |  | SP-19 |

Notes:
- 1743: - / Text3: 22.246
- 1744: - / Text3: 22.246
- 1745: TR26.946 tbc by March 06 / Text3: 26.346, 26.936, 26.946
- 1746: SP#28 06/2005 completed / Text3: 32.273
- 1747: BB place holder for a number of RAN5 Tasks. Moved in from the Stoyan/Testing WP / Text3: 34.108, 34.109, 34.121-1, 34.121-2, 34.122, 34.123-1, 34.123-2, 34.123-3
- 1748: TS 34.109 is under RAN2; RAN5 need to identify possible new requirements on UE test loop functionality to enable testing / Text3: 34.108, 34.109, 34.121-1, 34.121-2
- 1749: - / Text3: 34.108, 34.122, 34.123-1, 34.123-2, 34.123-3
- 1750: - / Text3: 34.108, 34.123-1, 34.123-2, 34.123-3
- 1751: - / Text3: 34.108, 34.123-1, 34.123-2, 34.123-3
- 1752: - / Text3: 34.108, 34.109, 34.122
- 1753: -
- 1754: - / Text3: 22.977, 22.941, 23.207, 22.243
- 1755: - / Text3: 23.877
- 1756: - / Text3: 26.235, 26.236, 26.243, 26.177, 26.943
- 1757: -
- 1758: Abandoned NP-23
- 1759: -
- 1760: - / Text3: 22.240, 22.228
- 1761: - / Text3: 23.240
- 1762: TR approved in CN#26 / Text3: 23.241
- 1763: - / Text3: 29.240
- 1764: WID approved SP#17. SA WG3 progress slow, depends on progress in other groups. / Text3: 33.102, 33.203, 33.210
- 1765: Foreseen start and completion dates introduced by MCC (no indication at all on the WID)
- 1766: -
- 1767: -
- 1768: -
- 1769: SA3 acknowledge role in WI at SA3#20. Active contribution S3#24, S3#25. S3 WID approved SP#17
- 1770: Replaced by UID 60005 and 60006

| ID | WBS | Task | Type | Duration | Start | Finish | Complete | Baseline start | Baseline finish | Baseline duration | Constraint | Deadline | Resources | Work | Actual work | Text1 | Text4 | Text5 | Text6 | Text8 | Text3 | Text10 |
| --- | --- | --- | --- | --- | --- | --- | --- | --- | --- | --- | --- | --- | --- | --- | --- | --- | --- | --- | --- | --- | --- | --- |
| 1771 | 32 | **WLAN-UMTS Interworking Rel-6** |  | 1495d? | 2000-01-03 A | 2005-09-22 A | 100% | 2000-01-03 | 2005-09-22 | 1495d? |  |  | S1 | 45472h | 45472h | WLAN | Telenor | frederic.paint@telenor.com | Rel-6 | Alain |  |  |
| 1772 | 32.1 | Technical Report |  | 901d? | 2000-01-03 A | 2003-06-13 A | 100% | 2000-01-03 | 2003-06-13 | 901d? | finish no earlier than 2003-06-13 |  | S1 | 7200h | 7200h | WLAN-TR | T-mobile | Mark.Younge@t-mobile.com | Rel-6 | Alain | 22.934 |  |
| 1773 | 545.2 | Stage 1 |  | 375d? | 2003-01-06 A | 2004-06-11 A | 100% | 2003-01-06 | 2004-06-11 | 375d? |  |  | S1 | 920h | 920h | WLAN-TS | Telenor | frederic.paint@telenor.com | Rel-6 | Alain | 22.101, 22.105 | SP-24 |
| 1774 | 32.2 | Architecture Definition for scenarii 2 and 3 |  | 571d | 2002-03-25 A | 2004-05-31 A | 100% | 2002-03-25 | 2004-05-31 | 571d | finish no earlier than 2004-05-31 |  | S2 | 4568h | 4568h | WLAN |  |  | Rel-6 | Maurice | 23.234 |  |
| 1775 | 32.3 | Security |  | 125d | 2002-09-30 A | 2003-03-21 A | 100% | 2002-09-30 | 2003-03-21 | 125d | finish no earlier than 2003-03-21 |  | S3 | 1000h | 1000h | WLAN | Ericsson | luis.lopez-soria@ece.ericsson.se | Rel-6 | Dionisio | 21.133, 33.106, 33.107, 33.108, 33.200, 33.203, 33.210 |  |
| 1776 | 545.5 | Stage 3 - CN4 aspects |  | 334d? | 2003-05-23 A | 2004-09-01 A | 100% | 2003-05-23 | 2004-09-01 | 334d? | finish no earlier than 2004-09-01 |  | N4 | 2672h | 2672h | WLAN-IW | Nokia | raquel.rodriguez@nokia.com | Rel-6 | Kimmo | 29.234, 29.061 |  |
| 1777 | 545.6 | Stage 3 - CN3 aspects (Wi Interface for Scenario 3) |  | 355d? | 2003-05-23 A | 2004-09-30 A | 100% | 2003-05-23 | 2004-09-30 | 355d? | start no earlier than 2003-05-23 |  | N3 | 2840h | 2840h | WLAN |  |  | Rel-6 | Gwiho | 29.161 | SP-24 |
| 1778 | 545.7 | Stage 3 for scenario 2 |  | 339d? | 2003-05-23 A | 2004-09-08 A | 100% | 2003-05-23 | 2004-09-08 | 339d? | finish no earlier than 2004-09-08 |  | N1 | 2712h | 2712h | WLAN |  |  | Rel-6 | Frederic |  |  |
| 1779 | 545.8 | Stage 3 for scenario 3 |  | 404d? | 2003-05-23 A | 2004-12-08 A | 100% | 2003-05-23 | 2004-12-08 | 404d? | finish no earlier than 2004-12-08 |  | N1 | 3232h | 3232h | WLAN |  |  | Rel-6 | Frederic |  | SP-24 |
| 1780 | 545.9 | WLAN charging |  | 655d? | 2003-03-21 A | 2005-09-22 A | 100% | 2003-03-21 | 2005-09-22 | 655d? | finish no earlier than 2005-09-22 |  | S5 | 5240h | 5240h | WLAN-CH | Nokia | Benni ALEXANDER | Rel-6 | Dionisio | 32.252 |  |
| 1781 | 545.10 | USIM enhancements for WLAN Interworking |  | 391d? | 2003-09-05 A | 2005-03-04 A | 100% | 2003-09-05 | 2005-03-04 | 391d? | finish no earlier than 2005-03-04 |  | T3 | 3128h | 3128h | WLAN | Axalto | Jabellan@axalto.com | Rel-6 | Xavier |  |  |
| 1782 | 33 | **Priority Service** |  | 347d? | 2002-05-30 A | 2003-09-26 A | 100% | 2002-05-30 | 2003-09-26 | 347d? |  |  | S1 | 6464h | 6464h | PRIOR1 | Telcordia | James Garrahan (jgarraha@telcordia.com) | Rel-6 | Alain |  |  |
| 1783 | 33.1 | Feasibility Study |  | 1d | 2002-06-14 A | 2002-06-14 A | 100% | 2002-06-14 | 2002-06-14 | 1d | finish no earlier than 2002-06-14 |  | S1 | 8h | 8h | PRIOR-FS | Telcordia | James Garrahan (jgarraha@telcordia.com) | Rel-6 | Alain | 22.950 |  |
| 1784 | 33.2 | Stage 1 - Requirements |  | 340d | 2002-05-30 A | 2003-09-17 A | 100% | 2002-05-30 | 2003-09-17 | 340d | finish no earlier than 2003-09-17 |  | S1 | 2720h | 2720h | PRIOR-SR | Telcordia | James Garrahan (jgarraha@telcordia.com) | Rel-6 | Alain |  |  |
| 1785 | 546.3 | Priority service implementation guide |  | 131d? | 2003-03-28 A | 2003-09-26 A | 100% | 2003-03-28 | 2003-09-26 | 131d? | finish no earlier than 2003-09-26 |  | S1 | 1048h | 1048h | PRIOR1 | Telcordia | James Garrahan (jgarraha@telcordia.com) | Rel-6 | Alain | 22.952 |  |
| 1786 | 34 | **Network Sharing** |  | 820d? | 2003-01-20 A | 2006-03-10 A | 100% | 2003-01-20 | 2006-03-10 | 820d? |  |  | S1,S2,N1,R2,R5 | 18696h | 18696h | NTShar | T-Mobile | michele.zarri@t-mobile.co.uk | Rel-6 | Alain |  |  |
| 1787 | 34.1 | Technical Report |  | 240d? | 2003-01-20 A | 2003-12-19 A | 100% | 2003-01-20 | 2003-12-19 | 240d? |  |  | S1 | 1920h | 1920h | NTShar-TR | T-Mobile | michele.zarri@t-mobile.co.uk | Rel-6 | Alain | 22.951 |  |
| 1788 | 547.2 | Stage 1 - CRs to implement Network Sharing |  | 240d? | 2003-01-20 A | 2003-12-19 A | 100% | 2003-01-20 | 2003-12-19 | 240d? | finish no earlier than 2003-12-19 |  | S1 | 1920h | 1920h | NTSharCR | T-Mobile | michele.zarri@t-mobile.co.uk | Rel-6 | Alain | 22.011, 22.101, 22.115, 22.129 |  |
| 1789 | 547.3 | Stage 2 |  | 372d? | 2003-02-27 A | 2004-07-30 A | 100% | 2003-02-27 | 2004-07-30 | 372d? | finish no earlier than 2004-07-30 |  | S2 | 2976h | 2976h | NTShar | T-Mobile | michele.zarri@t-mobile.co.uk | Rel-6 | Maurice | 23.002, 23.060, 23.221, 23.236, new 23.251 |  |
| 1790 | 547.4 | Network sharing - stage 3 |  | 404d? | 2003-05-23 A | 2004-12-08 A | 100% | 2003-05-23 | 2004-12-08 | 404d? | finish no earlier than 2004-12-08 |  | N1 | 3232h | 3232h | NTShar | T-Mobile | michele.zarri@t-mobile.co.uk | Rel-6 | Frederic | 23.008, 23.122, 24.007, 24.008, 29.018 |  |
| 1791 | 547.5 | Enhancement of the support of network sharing in the UTRAN | milestone | 0d | 2003-09-19 A | 2003-09-19 A | 100% | 2003-09-19 | 2003-09-19 | 0d |  |  | R2 |  |  | NTShar-UTRANEnh | TeliaSonera | Anders.Dahlen@TeliaSonera.com | Rel-6 | Joern | 25.401, 25.413, 25.331, 25.304 |  |
| 1792 | 16.5.1 | Conformance Test Aspects – Network Sharing |  | 261d | 2005-03-11 A | 2006-03-10 A | 100% | 2005-03-11 | 2006-03-10 | 261d | finish no earlier than 2006-03-10 | 2006-03-10 | R5 | 2088h | 2088h | NTShar-UTRANEnh_Test | TeliaSonera | Niklas.Wiren@TeliaSonera.com | Rel-6 | Ingbert | 34.108, 34.123-1, 34.123-2, 34.123-3 | Fri 11/03/05 |
| 1793 | 35 | **QoS Improvements** |  | 628d? | 2002-07-15 A | 2004-12-08 A | 100% | 2002-07-15 | 2004-12-08 | 628d? |  |  | S2,N3 | 13128h | 13128h | QoS1 | Nokia |  | Rel-6 | Maurice | 23.107, 23.207, 23.221 |  |
| 1794 | 35.1 | FS on Dynamic Policy control enhancements for end-to-end QoS |  | 465d | 2002-07-15 A | 2004-04-23 A | 100% | 2002-07-15 | 2004-04-23 | 465d | finish no earlier than 2004-04-23 |  | S2 | 3720h | 3720h | QoS1 | Nortel | Claire Mousset | Rel-6 | Maurice | 23.917 withdrawn (Contents all in 23.207) |  |
| 1795 | 548.2 | Definition of the Gq interface |  | 214d? | 2003-07-01 A | 2004-04-23 A | 100% | 2003-07-01 | 2004-04-23 | 214d? | finish no earlier than 2004-04-23 |  | S2 | 1712h | 1712h | QoS1 |  | Janne Rinne | Rel-6 | Maurice | 23.207 |  |
| 1796 | 548.3 | Gq interface specification for Dynamic Policy control enhancements – Stage 3 |  | 334d | 2003-08-29 A | 2004-12-08 A | 100% | 2003-08-29 | 2004-12-08 | 334d | finish no earlier than 2004-12-08 |  | N3 | 2672h | 2672h | QoS1 | Nokia | Anna.Sillanpaai@nokia.com | Rel-6 | Gwiho | 29.207, 29.208, 29.209 |  |

Notes:
- 1771: -
- 1772: -
- 1773: -
- 1774: -
- 1775: Active contribution S3#24, S3#25. WID approved SP#17
- 1776: WID approved at CN#19
- 1777: -
- 1778: -
- 1779: -
- 1780: SP#28: delayed 09/2005. WT also under SA5 BB 35017 Charging Management for Bearer level
- 1781: -
- 1782: -
- 1783: -
- 1784: -
- 1785: -
- 1786: -
- 1787: -
- 1788: -
- 1789: -
- 1790: -
- 1791: -
- 1792: -
- 1793: -
- 1794: -
- 1795: -
- 1796: [DAB - 25.05.04] - Delayed to Sept - possibly Dec 2004

| ID | WBS | Task | Type | Duration | Start | Finish | Complete | Baseline start | Baseline finish | Baseline duration | Constraint | Resources | Work | Actual work | Text1 | Text4 | Text5 | Text6 | Text8 | Text10 | Text12 |
| --- | --- | --- | --- | --- | --- | --- | --- | --- | --- | --- | --- | --- | --- | --- | --- | --- | --- | --- | --- | --- | --- |
| 1797 | 36 | **Subscriber certificates** |  | 728d? | 2002-02-25 A | 2004-12-08 A | 100% | 2002-02-25 | 2004-12-08 | 728d? |  | S3,S2,N1,N4,T3,OMA | 12888h | 12888h | SEC1-SC | Nokia | valtteri.niemi@nokia.com | Rel-6 | Dionisio |  |  |
| 1798 | 36.1 | Stage 1 |  | 144d | 2002-02-25 A | 2002-09-12 A | 100% | 2002-02-25 | 2002-09-12 | 144d | finish no earlier than 2002-09-12 | S3 | 1152h | 1152h | SEC1-SC | Nokia | valtteri.niemi@nokia.com | Rel-6 | Dionisio |  |  |
| 1799 | 36.2 | Architecture review |  | 24d | 2002-10-14 A | 2002-11-14 A | 100% | 2002-10-14 | 2002-11-14 | 24d | finish no earlier than 2002-11-14 | S2 | 192h | 192h | SEC1-SC | Nokia |  | Rel-6 | Maurice |  |  |
| 1800 | 549.3 | Stage 3 |  | 313d? | 2003-09-19 A | 2004-11-30 A | 100% | 2003-09-19 | 2004-11-30 | 313d? | finish no earlier than 2004-11-30 | N4,T3 | 2504h | 2504h | SEC1-SC | Nokia | Lauri Laitinen | Rel-6 | Kimmo |  |  |
| 1801 | 549.4 | Stage 3 Ua & Ub interfaces |  | 288d? | 2003-11-03 A | 2004-12-08 A | 100% | 2003-11-03 | 2004-12-08 | 288d? | finish no earlier than 2004-12-08 | N1 | 2304h | 2304h | SEC1-SC | Nokia |  | Rel-6 | Frederic |  |  |
| 1802 | 549.5 | OMA dependencies on Subscriber certificates |  | 114d? | 2004-01-01 A | 2004-06-08 A | 100% | 2004-01-01 | 2004-06-08 | 114d? | finish no earlier than 2004-06-08 | OMA | 912h | 912h | SEC1-SC | Nokia | OMA-LIAISON@mail.openmobilealliance.org | Rel-6 |  | SP-24 |  |
| 1803 | 550 | **Rel-6 OSA enhancements** |  | 616d? | 2002-10-31 A | 2005-03-10 A | 100% | 2002-10-31 | 2005-03-10 | 616d? |  | N5 | 22576h | 22576h | OSA3 | Alcatel | Chelo.Abarca@alcatel.fr | Rel-6 | Kimmo |  |  |
| 1804 | 550.1 | Scope of the Open Service Access Release 6 |  | 66d? | 2003-03-28 A | 2003-06-27 A | 100% | 2003-03-28 | 2003-06-27 | 66d? | finish no earlier than 2003-06-27 | S1 | 528h | 528h | OSA3 |  |  | Rel-6 | Alain |  |  |
| 1805 | 550.2 | OSA Stage 2 |  | 150d? | 2004-08-13 A | 2005-03-10 A | 100% | 2004-08-13 | 2005-03-10 | 150d? | finish no earlier than 2005-03-10 | N5 | 1200h | 1200h | OSA3 |  |  | Rel-6 | Kimmo |  |  |
| 1806 | 550.3 | Multi Media Messaging function |  | 487d? | 2002-10-31 A | 2004-09-10 A | 100% | 2002-10-31 | 2004-09-10 | 487d? | finish no earlier than 2004-09-10 | N5 | 3896h | 3896h | OSA3 |  |  | Rel-6 | Kimmo |  |  |
| 1807 | 550.4 | Policy management extensions |  | 292d? | 2002-10-31 A | 2003-12-12 A | 100% | 2002-10-31 | 2003-12-12 | 292d? | finish no earlier than 2003-12-12 | N5 | 2336h | 2336h | OSA3 |  |  | Rel-6 | Kimmo |  |  |
| 1808 | 550.5 | TS on Presence and Availability Management (from the PRESNC WI) |  | 367d? | 2002-10-31 A | 2004-03-26 A | 100% | 2002-10-31 | 2004-03-26 | 367d? | finish no earlier than 2004-03-26 | N5 | 2936h | 2936h | OSA3 |  |  | Rel-6 | Kimmo |  |  |
| 1809 | 550.6 | OSA interfaces at different levels of abstractions (Parlay X, Web services) |  | 305d? | 2003-07-14 A | 2004-09-10 A | 100% | 2003-07-14 | 2004-09-10 | 305d? | finish no earlier than 2004-09-10 | N5 | 2440h | 2440h | OSA3 |  |  | Rel-6 | Kimmo |  |  |
| 1810 | 550.7 | Introduction of migration support mechanism |  | 290d? | 2002-10-31 A | 2003-12-10 A | 100% | 2002-10-31 | 2003-12-10 | 290d? | finish no earlier than 2003-12-12 | N5 | 2320h | 2320h | OSA3 |  |  | Rel-6 | Kimmo |  |  |
| 1811 | 550.8 | Framework Function for Federation |  | 225d? | 2003-02-03 A | 2003-12-12 A | 100% | 2003-02-03 | 2003-12-12 | 225d? | finish no earlier than 2003-12-12 | N5 | 1800h | 1800h | OSA3 |  |  | Rel-6 | Kimmo |  |  |
| 1812 | 550.9 | OMA potential overlaps with 3GPP OSA Stage 3 (Web services) |  | 196d? | 2003-12-18 A | 2004-09-16 A | 100% | 2003-12-18 | 2004-09-16 | 196d? | start no earlier than 2003-12-18 | OMA | 1568h | 1568h | OSA3 |  |  | Rel-6 |  | SP-24 |  |
| 1813 | 550.10 | Deleted - TR on Presence and Availability Management (from the PRESNC WI) | milestone | 0d? | 2004-09-17 A | 2004-09-17 A | 100% | 2004-09-17 | 2004-09-17 | 0d? | start no earlier than 2004-09-17 | N5 |  |  | OSA3 |  |  | Rel-6 | Kimmo |  | NP-24 |
| 1814 | 39 | **Addition of frequency bands to GSM (TAPS)** |  | 676d | 2002-06-28 A | 2005-01-28 A | 100% | 2002-06-28 | 2005-01-28 | 676d |  | GP | 16640h | 16640h | TAPS | Nokia | Torben Themsen | Rel-6 | Paolo |  |  |
| 1815 | 39.1 | **Addition of frequency bands to GSM – Changes to core specs** |  | 26d | 2002-11-15 A | 2002-12-20 A | 100% | 2002-11-15 | 2002-12-20 | 26d |  | G1 | 416h | 416h | TAPS-Specs | Nokia | Torben Themsen | Rel-6 | Paolo |  |  |
| 1816 | 39.1.1 | Changes to core specs |  | 26d | 2002-11-15 A | 2002-12-20 A | 100% | 2002-11-15 | 2002-12-20 | 26d | finish no earlier than 2002-12-20 | G1 | 208h | 208h | TAPS-Specs | Nokia | Torben Themsen | Rel-6 | Paolo |  |  |
| 1817 | 39.2 | **Deleted - Addition of frequency bands to GSM – Changes for conformance tests** |  | 676d | 2002-06-28 A | 2005-01-28 A | 100% | 2002-06-28 | 2005-01-28 | 676d |  | G4 | 10816h | 10816h | TAPS-Conf | Nokia | Torben Themsen | Rel-6 | Paolo |  | GP-23 |
| 1818 | 39.2.1 | Deleted - 51.010-1 Add testing |  | 676d | 2002-06-28 A | 2005-01-28 A | 100% | 2002-06-28 | 2005-01-28 | 676d | finish no earlier than 2005-01-28 | G4 | 5408h | 5408h | TAPS-Conf | Nokia | Torben Themsen | Rel-6 | Paolo |  | GP-23 |
| 1819 | 40 | **Seamless support of streaming services in A/Gb mode** |  | 1426d? | 2000-01-03 A | 2005-06-17 A | 100% | 2000-01-03 | 2005-06-17 | 1426d? |  | GP | 53096h | 53096h | SSStrea | Vodafone | José Luis Carrizo Martínez | Rel-6 | Paolo |  |  |
| 1820 | 40.1 | **Identification of requirements for streaming** |  | 46d? | 2003-06-27 A | 2003-08-29 A | 100% | 2003-06-27 | 2003-08-29 | 46d? |  | G1 | 736h | 736h | SSStrea | Vodafone | José Luis Carrizo Martínez | Rel-6 | Paolo |  |  |
| 1821 | 552.1.1 | Requirements |  | 46d? | 2003-06-27 A | 2003-08-29 A | 100% | 2003-06-27 | 2003-08-29 | 46d? | finish no earlier than 2003-08-29 | G1 | 368h | 368h | SSStrea | Vodafone | José Luis Carrizo Martínez | Rel-6 | Paolo |  |  |

Notes:
- 1797: Approved at SP#14. May require BBs from CN1, CN4, SA5 and T3
- 1798: Contribution received S3#24, S3#25 / Text3: 33.220, 33.221, 33.222, 33.246, new TR 33.919
- 1799: -
- 1800: Finished in CN4#26 / Text3: 23.003, 23.008, 29.109, 29.230, T3 31.102, 31.103, 31.111
- 1801: - / Text3: 24.109
- 1802: Updated according to SP-040420
- 1803: CN#25: Updated WID NP-040351 replaces NP-040144. / Text3: 22.127, 23.198, 29.198, 29.199, 29.998
- 1804: -
- 1805: Inherited by CN5 from SA2 at TSG#25 Sep 2004. SA2's 23.127 (OSA/VHE Stage 2) replaced from Rel-6 onwards by a new CN5 TS 23.198 (Stage 2 OSA-only). / Text3: 23.198 OSA Stage 2-ONLY replaces 23.127 (OSA/VHE) from Rel-6 onwards
- 1806: - / Text3: 29.198-15
- 1807: - / Text3: 29.198, 29.998
- 1808: N5#26: Split WI into TS & TR. / Text3: 29.198-14
- 1809: - / Text3: 29.199
- 1810: - / Text3: 29.198, 29.998
- 1811: - / Text3: 29.198, 29.998
- 1812: TSG#25 Approved CN5 29.199 Parlay X Web services. Ongoing 3GPP/OMA co-ordination to avoid OMA producing conflicting/OVERLAPING specs (NP-040283/SP-040493).
- 1813: N5#26:TR Completion 09/04; consistent with CN1 delayed Rel-6 completion.
- 1814: -
- 1815: -
- 1816: -
- 1817: -
- 1818: -
- 1819: -
- 1820: -
- 1821: -

| ID | WBS | Task | Duration | Start | Finish | Complete | Baseline start | Baseline finish | Baseline duration | Constraint | Resources | Work | Actual work | Text1 | Text4 | Text5 | Text6 | Text8 | Text12 | Text3 |
| --- | --- | --- | --- | --- | --- | --- | --- | --- | --- | --- | --- | --- | --- | --- | --- | --- | --- | --- | --- | --- |
| 1822 | 40.2 | **Performance study of cell change mechanisms** | 956d? | 2000-01-03 A | 2003-08-29 A | 100% | 2000-01-03 | 2003-08-29 | 956d? |  | G1 | 30568h | 30568h | SSStrea | Vodafone | José Luis Carrizo Martínez | Rel-6 | Paolo |  |  |
| 1823 | 552.2.1 | Performance of NACC | 956d? | 2000-01-03 A | 2003-08-29 A | 100% | 2000-01-03 | 2003-08-29 | 956d? | finish no earlier than 2003-08-29 | G1 | 7640h | 7640h | SSStrea | Vodafone | José Luis Carrizo Martínez | Rel-6 | Paolo |  |  |
| 1824 | 552.2.2 | Performance of cell change in DTM for the PS domain | 956d? | 2000-01-03 A | 2003-08-29 A | 100% | 2000-01-03 | 2003-08-29 | 956d? | finish no earlier than 2003-08-29 | G1 | 7640h | 7640h | SSStrea | Vodafone | José Luis Carrizo Martínez | Rel-6 | Paolo |  |  |
| 1825 | 552.2.3 | Handover | 956d? | 2000-01-03 A | 2003-08-29 A | 100% | 2000-01-03 | 2003-08-29 | 956d? | finish no earlier than 2003-08-29 | G1 | 7640h | 7640h | SSStrea | Vodafone | José Luis Carrizo Martínez | Rel-6 | Paolo |  |  |
| 1826 | 40.3 | **Reduction of service interruption times and packet loss during mobility procedures** | 516d? | 2003-06-27 A | 2005-06-17 A | 100% | 2003-06-27 | 2005-06-17 | 516d? |  | G2 | 10800h | 10800h | SSStrea | Vodafone | José Luis Carrizo Martínez | Rel-6 | Gert |  |  |
| 1827 | 552.3.1 | optimizations of existing mechanisms/procedures | 106d? | 2003-06-27 A | 2003-11-21 A | 100% | 2003-06-27 | 2003-11-21 | 106d? | finish no earlier than 2003-11-21 | G2 | 848h | 848h | SSStrea | Vodafone | José Luis Carrizo Martínez | Rel-6 | Gert |  |  |
| 1828 | 552.3.2 | Inter-system NACC | 106d? | 2003-06-27 A | 2003-11-21 A | 100% | 2003-06-27 | 2003-11-21 | 106d? | finish no earlier than 2003-11-21 | G2 | 848h | 848h | SSStrea | Vodafone | José Luis Carrizo Martínez | Rel-6 | Gert |  |  |
| 1829 | 552.3.3 | PS Handover (within GERAN and between GERAN and UTRAN) | 516d? | 2003-06-27 A | 2005-06-17 A | 100% | 2003-06-27 | 2005-06-17 | 516d? | finish no earlier than 2003-11-21 | G2 | 4128h | 4128h | SSStrea | Vodafone | José Luis Carrizo Martínez | Rel-6 | Gert |  |  |
| 1830 | 552.3.4 | Dependency to other features | 106d? | 2003-06-27 A | 2003-11-21 A | 100% | 2003-06-27 | 2003-11-21 | 106d? | finish no earlier than 2003-11-21 | G2 | 848h | 848h | SSStrea | Vodafone | José Luis Carrizo Martínez | Rel-6 | Gert |  |  |
| 1831 | 40.5 | **Deleted - MS conformance testing** | 31d? | 2003-12-19 A | 2004-01-30 A | 100% | 2003-12-19 | 2004-01-30 | 31d? |  | G3new | 248h | 248h | SSStrea | Vodafone | José Luis Carrizo Martínez | Rel-6 | Ingbert | GP-27 |  |
| 1832 | 552.4.1 | Deleted - MS conformance tests | 31d? | 2003-12-19 A | 2004-01-30 A | 100% | 2003-12-19 | 2004-01-30 | 31d? | finish no earlier than 2004-01-30 | G4,G5 | 248h | 248h | SSStrea | Vodafone | José Luis Carrizo Martínez | Rel-6 | Ingbert | GP-27 |  |
| 1833 | 552.5 | GERAN A/Gb mode security enhancements | 612d? | 2002-09-26 A | 2005-01-28 A | 100% | 2002-09-26 | 2005-01-28 | 612d? | finish no earlier than 2005-01-28 | S3 | 4896h | 4896h | SSStrea | Vodafone | peter.howard@vodafone.com | Rel-6 | Dionisio |  | 33.102 |
| 1834 | 41 | Performance characterisation of default codecs for PS conversational multimedia application | 455d | 2002-09-13 A | 2004-06-10 A | 100% | 2002-09-13 | 2004-06-10 | 455d | finish no earlier than 2004-06-10 | S4 | 3640h | 3640h | CODCAR | Nokia | pasi.s.ojala@nokia.com | Rel-6 | Paolo |  | 26.935 |
| 1835 | 43 | Study on Privacy Capability | 83d | 2003-11-10 A | 2004-03-03 A | 100% | 2003-11-10 | 2004-03-03 | 83d | start no earlier than 2003-11-10 | S1 | 664h | 664h | PrivCap | Lucent | Michael Boote (mboote@alcatel-lucent.com) | Rel-6 | Alain |  | 22.949 |
| 1836 | 44 | **OAM&P Rel-6** | 652d? | 2002-09-12 A | 2005-03-11 A | 100% | 2002-09-12 | 2005-03-11 | 652d? |  | S5 | 30819.5h | 30819.5h | OAM | Motorola |  | Rel-6 | Dionisio |  |  |
| 1837 | 44.1 | Principles, high level Requirements and Architecture | 526d | 2002-09-12 A | 2004-09-16 A | 100% | 2002-09-12 | 2004-09-16 | 526d | finish no earlier than 2004-09-16 | S5 | 4208h | 4208h | OAM-AR | Motorola |  | Rel-6 | Dionisio |  | 32.101, 32.102 |
| 1838 | 44.2 | Performance Management | 591d | 2002-09-12 A | 2004-12-16 A | 100% | 2002-09-12 | 2004-12-16 | 591d | finish no earlier than 2004-12-16 | S5 | 4728h | 4728h | OAM-PM | Nortel |  | Rel-6 | Dionisio |  | 32.401/3, 52.402, 32.411/2/3, 32.432/5/6 |
| 1839 | 44.4 | Network Infrastructure Management | 591d | 2002-09-12 A | 2004-12-16 A | 100% | 2002-09-12 | 2004-12-16 | 591d | finish no earlier than 2004-12-16 | S5 | 4728h | 4728h | OAM-NIM | Ericsson | thomas.tovinger@ericsson.com | Rel-6 | Dionisio |  | 32.15x, 32.3/6/7xy |
| 1840 | 44.5 | **Trace Management Rel-6** | 646d? | 2002-09-20 A | 2005-03-11 A | 100% | 2002-09-20 | 2005-03-11 | 646d? |  | S5 | 12061.9h | 12061.9h | OAM-Trace | Nokia | kari.t.ronka@nokia.com | Rel-6 | Dionisio |  | 32.42x, 52.008 |
| 1841 | 555.4.1 | Subscriber and UE trace management | 585d | 2002-09-20 A | 2004-12-16 A | 100% | 2002-09-20 | 2004-12-16 | 585d | finish no earlier than 2004-12-16 | S5 | 4680h | 4680h | OAM-Trace | Nokia | kari.t.ronka@nokia.com | Rel-6 | Dionisio |  | 32.421/2/3, 52.008 |
| 1842 | 555.4.2 | Subscriber and equipment trace in UTRAN | 268d? | 2003-06-06 A | 2004-06-15 A | 100% | 2003-06-06 | 2004-06-15 | 268d? | finish no earlier than 2004-06-15 | R3 | 2144h | 2144h | OAM-Trace-RAN | Nortel | Yann Sehedi (sehedic@nortelnetworks.com) | Rel-6 | Juha |  | 25.413, 25.420, 25.423 |
| 1843 | 555.4.3 | Trace Management, Stage3 | 193.74d? | 2004-06-09 A | 2005-03-11 A | 100% | 2004-06-09 | 2005-03-11 | 193.74d? | finish no earlier than 2005-03-11 | N4 | 1549.92h | 1549.92h | OAM-Trace | Nokia | seppo.kauntola@nokia.com | Rel-6 | Kimmo |  | 23.205, 29.232, 29.060, 29.002, 29.228 |
| 1844 | 556 | **Charging Management** | 666d? | 2002-11-21 A | 2005-06-09 A | 100% | 2002-11-21 | 2005-06-09 | 666d? |  | S5 | 55320h | 55320h | CH | T-Mobile | karl-heinz.nenner@t-mobile.de | Rel-6 | Dionisio |  | 32.2xy |
| 1845 | 556.1 | Charging architecture and principles | 390d? | 2003-03-21 A | 2004-09-16 A | 100% | 2003-03-21 | 2004-09-16 | 390d? | start no earlier than 2003-03-21 | S5 | 3120h | 3120h | CH |  |  | Rel-6 | Dionisio |  | 32.240 |
| 1846 | 556.2 | Charging Data Record (CDR) file format and transfer | 260d? | 2003-03-21 A | 2004-03-18 A | 100% | 2003-03-21 | 2004-03-18 | 260d? | start no earlier than 2003-03-21 | S5 | 2080h | 2080h | CH |  |  | Rel-6 | Dionisio |  | 32.297 |
| 1847 | 556.3 | CDR parameter description | 580d? | 2003-03-21 A | 2005-06-09 A | 100% | 2003-03-21 | 2005-06-09 | 580d? | finish no earlier than 2005-06-09 | S5 | 4640h | 4640h | CH |  |  | Rel-6 | Dionisio |  | 32.298 |
| 1848 | 556.4 | Diameter charging applications | 390d? | 2003-03-21 A | 2004-09-16 A | 100% | 2003-03-21 | 2004-09-16 | 390d? | start no earlier than 2003-03-21 | S5 | 3120h | 3120h | CH |  |  | Rel-6 | Dionisio |  | 32.299 |
| 1849 | 556.5 | Online Charging System (OCS) architecture study | 130d? | 2003-03-21 A | 2003-09-18 A | 100% | 2003-03-21 | 2003-09-18 | 130d? | start no earlier than 2003-03-21 | S5 | 1040h | 1040h | CH |  |  | Rel-6 | Dionisio |  | 32.815 |
| 1850 | 556.6 | OCS: Applications and interfaces | 455d? | 2003-03-21 A | 2004-12-16 A | 100% | 2003-03-21 | 2004-12-16 | 455d? | start no earlier than 2003-03-21 | S5 | 3640h | 3640h | CH |  |  | Rel-6 | Dionisio |  | 32.296 |

Notes:
- 1822: -
- 1823: -
- 1824: -
- 1825: -
- 1826: Completed at GERP#17
- 1827: -
- 1828: -
- 1829: -
- 1830: -
- 1831: Marked as stopped 10/2009
- 1832: Marked as stopped 10/2009
- 1833: Possible changes to 33.102 or new specification needed
- 1834: -
- 1835: -
- 1836: SP#26: Updated WID SP-040766 was SP-020445. Completion delayed 12/04->03/05 due to OAM-Trace in CN1/4.
- 1837: SP#25 09/2004 completed
- 1838: SP#26 12/2004 completed
- 1839: SP#26 12/2004 completed
- 1840: SP#26 12/2004 SA5 completed 12/04. Signalling Based Trace Activation for IMS (SIP) moved to Rel-7. Reason: CN1 cannot complete 24.229 trace without IETF dependency => estimate 05/2005.
- 1841: SP#26 12/2004 completed
- 1842: -
- 1843: -
- 1844: SP#28 Target 09/2005 for WLAN Charging 32.252
- 1845: SP#25 09/2004 completed
- 1846: SP#23 03/2004 completed
- 1847: SP#28 06/2005 completed
- 1848: SP#25 09/2004 completed
- 1849: SP#21 09/2003 completed
- 1850: SP#26 12/2004 completed

| ID | WBS | Task | Duration | Start | Finish | Complete | Baseline start | Baseline finish | Baseline duration | Constraint | Resources | Work | Actual work | Text1 | Text4 | Text5 | Text6 | Text8 | Text10 | Text12 |
| --- | --- | --- | --- | --- | --- | --- | --- | --- | --- | --- | --- | --- | --- | --- | --- | --- | --- | --- | --- | --- |
| 1851 | 556.7 | **Charging Management for Bearer level** | 390d? | 2003-03-21 A | 2004-09-16 A | 100% | 2003-03-21 | 2004-09-16 | 390d? |  | S5 | 11440h | 11440h | CH-BC | Nokia | Benni ALEXANDER | Rel-6 | Dionisio |  |  |
| 1852 | 556.7.1 | CS domain charging | 260d? | 2003-03-21 A | 2004-03-18 A | 100% | 2003-03-21 | 2004-03-18 | 260d? | start no earlier than 2003-03-21 | S5 | 2080h | 2080h | CH |  |  | Rel-6 | Dionisio |  |  |
| 1853 | 556.7.2 | PS domain charging | 390d? | 2003-03-21 A | 2004-09-16 A | 100% | 2003-03-21 | 2004-09-16 | 390d? | start no earlier than 2003-03-21 | S5 | 3120h | 3120h | CH |  |  | Rel-6 | Dionisio |  |  |
| 1854 | 556.7.3 | CDR transfer | 390d? | 2003-03-21 A | 2004-09-16 A | 100% | 2003-03-21 | 2004-09-16 | 390d? | start no earlier than 2003-03-21 | S5 | 3120h | 3120h | CH |  |  | Rel-6 | Dionisio |  |  |
| 1855 | 556.8 | Charging Management for the IMS | 455d? | 2003-03-21 A | 2004-12-16 A | 100% | 2003-03-21 | 2004-12-16 | 455d? | finish no earlier than 2004-12-16 | S5 | 3640h | 3640h | IMS2-CH | Ericsson | Patrik TEPPO | Rel-6 | Dionisio |  |  |
| 1856 | 556.9 | Charging Management for the Service domain | 580d? | 2003-03-21 A | 2005-06-09 A | 100% | 2003-03-21 | 2005-06-09 | 580d? | finish no earlier than 2005-06-09 | S5 | 4640h | 4640h | CH | Siemens | Gerald.Goermer@nsn.com | Rel-6 | Dionisio |  |  |
| 1857 | 556.10 | **Overall architectural aspects of IP flow based bearer level charging** | 602d? | 2002-11-21 A | 2005-03-11 A | 100% | 2002-11-21 | 2005-03-11 | 602d? |  | S2 | 12632h | 12632h | CH-FBC |  |  | Rel-6 | Maurice |  |  |
| 1858 | 556.10.1 | Overall definition of FBC architecture | 334d? | 2002-11-21 A | 2004-03-02 A | 100% | 2002-11-21 | 2004-03-02 | 334d? | start no earlier than 2002-11-21 | S2 | 2672h | 2672h | CH-FBC |  |  | Rel-6 | Maurice | SP-24 |  |
| 1859 | 556.10.2 | Study on providing policy control with FBC | 130d? | 2004-02-02 A | 2004-07-30 A | 100% | 2004-02-02 | 2004-07-30 | 130d? | start no earlier than 2004-02-01 | S2 | 1040h | 1040h | CH-FBC |  |  | Rel-6 | Maurice | SP-24 |  |
| 1860 | 556.10.3 | Gx interface for flow based charging | 223d? | 2004-02-02 A | 2004-12-08 A | 100% | 2004-02-02 | 2004-12-08 | 223d? | start no earlier than 2004-02-01 | N3 | 1784h | 1784h | CH-FBC | Nokia | juha.a.rasanen@nokia.com | Rel-6 | Gwiho | SP-25 |  |
| 1861 | 556.10.4 | Rx interface for flow based charging | 290d? | 2004-02-02 A | 2005-03-11 A | 100% | 2004-02-02 | 2005-03-11 | 290d? | finish no earlier than 2005-03-11 | N3 | 2320h | 2320h | CH-FBC | Nortel | Javier Gonzalez Gallego | Rel-6 | Gwiho | SP-25 |  |
| 1862 | 13 | **Rel-6 UICC/USIM enhancements and interworking** | 1164d? | 2000-09-25 A | 2005-03-10 A | 100% | 2000-09-25 | 2005-03-10 | 1164d? |  | T3 | 43088h | 43088h | USAT1 |  |  | Rel-6 | Xavier |  |  |
| 1863 | 13.1 | **UICC API** | 777d | 2002-03-20 A | 2005-03-10 A | 100% | 2002-03-20 | 2005-03-10 | 777d |  | T3 | 15024h | 15024h | USAT1-API |  |  | Rel-6 | Xavier |  |  |
| 1864 | 13.1.1 | Java API Test specification | 59d | 2002-03-20 A | 2002-06-10 A | 100% | 2002-03-20 | 2002-06-10 | 59d | finish no earlier than 2002-09-20 | T3 | 472h | 472h | USAT1-API | Microelectrónica Española | Mario Pérez | Rel-6 | Xavier |  |  |
| 1865 | 557.1.2 | 2G/3G Java Card™ API based applet interworking | 255d | 2003-03-17 A | 2004-03-05 A | 100% | 2003-03-17 | 2004-03-05 | 255d | finish no earlier than 2004-02-19 | T3 | 2040h | 2040h | USAT1-API | Oberthur Card Systems | Stéphane Andrau | Rel-6 | Xavier |  |  |
| 1866 | 557.1.3 | (U)SIM API for Java Card Testing | 519d | 2003-03-17 A | 2005-03-10 A | 100% | 2003-03-17 | 2005-03-10 | 519d | finish no earlier than 2005-03-10 | T3 | 4152h | 4152h | USAT1-API | Axalto | Christophe Begassat (cbegassat@axalto.com) | Rel-6 | Xavier |  |  |
| 1867 | 13.1.2 | Deleted - Java API Test specification (TS 43.019 Rel-5) | 268d | 2002-05-30 A | 2003-06-09 A | 100% | 2002-05-30 | 2003-06-09 | 268d | finish no earlier than 2003-09-17 | T3 | 2144h | 2144h | USAT1-API | Microelectrónica Española | Mario Pérez | Rel-6 | Xavier |  | TP-20 |
| 1868 | 557.2 | **Rel-6 USIM toolkit enhancements** | 1160d? | 2000-09-25 A | 2005-03-04 A | 100% | 2000-09-25 | 2005-03-04 | 1160d? |  | T3 | 21848h | 21848h | USAT1-API-MULTOS | Aspects Software | Neil Livingston | Rel-6 | Xavier |  |  |
| 1869 | 557.2.1 | **C SIM API** | 525d | 2000-09-25 A | 2002-09-27 A | 100% | 2000-09-25 | 2002-09-27 | 525d |  | T3 | 9960h | 9960h | USAT1-API-MULTOS | Aspects Software | Neil Livingston | Rel-6 | Xavier |  |  |
| 1870 | 557.2.1.1 | Specification | 525d | 2000-09-25 A | 2002-09-27 A | 100% | 2000-09-25 | 2002-09-27 | 525d | finish no earlier than 2002-09-27 | T3 | 4200h | 4200h | USAT1-API-MULTOS | Aspects Software | Neil Livingston | Rel-6 | Xavier |  |  |
| 1871 | 557.2.1.2 | Test specification | 195d | 2001-01-01 A | 2001-09-28 A | 100% | 2001-01-01 | 2001-09-28 | 195d | finish no earlier than 2001-09-28 | T3 | 1560h | 1560h | USAT1-API-MULTOS | Aspects Software | Neil Livingston | Rel-6 | Xavier |  |  |
| 1872 | 557.2.2 | USIM application toolkit Conformance Test Specification for Mobile Equipments | 326d? | 2003-12-05 A | 2005-03-04 A | 100% | 2003-12-05 | 2005-03-04 | 326d? | start no earlier than 2003-12-05 | T3 | 2608h | 2608h | USAT1-API-MULTOS | Gemplus | Eric.laffont@gemplus.com | Rel-6 | Xavier |  |  |
| 1873 | 558 | **Packet Switched Streaming Services Rel-6** | 798d? | 2002-11-18 A | 2005-12-07 A | 100% | 2002-11-18 | 2005-12-07 | 798d? |  | S4,S1 | 13304h | 13304h | PSSrel6 | Ericsson | olle.franceschi@ericsson.com | Rel-6 | Paolo |  |  |
| 1874 | 558.1 | Stage 1 | 86d? | 2002-11-18 A | 2003-03-17 A | 100% | 2002-11-18 | 2003-03-17 | 86d? | finish no earlier than 2003-03-17 | S1 | 688h | 688h | PSSrel6 | Ericsson |  | Rel-6 | Alain |  |  |
| 1875 | 558.2 | Stage 3 | 779d? | 2002-12-13 A | 2005-12-07 A | 100% | 2002-12-13 | 2005-12-07 | 779d? | finish no earlier than 2005-12-07 | S4 | 6232h | 6232h | PSSrel6-Stage3 | Ericsson | olle.franceschi@ericsson.com | Rel-6 | Paolo |  |  |
| 1876 | 559 | AMR-WB extension for high audio quality | 779d | 2002-12-13 A | 2005-12-07 A | 100% | 2002-12-13 | 2005-12-07 | 779d | finish no earlier than 2005-12-07 | S4 | 6232h | 6232h | AMRWB+ | Nokia | janne.m.vainio@nokia.com | Rel-6 | Paolo |  |  |
| 1877 | 560 | Codec Enhancements for Packet Switched Conversational Multimedia Applications | 198d? | 2004-03-16 A | 2004-12-16 A | 100% | 2004-03-16 | 2004-12-16 | 198d? | finish no earlier than 2004-12-16 | S4 | 1584h | 1584h | CEPSCM | Nokia | miska.hannuksela@nokia.com | Rel-6 | Paolo |  |  |
| 1878 | 561 | 3G-324M Improvements | 198d? | 2004-03-16 A | 2004-12-16 A | 100% | 2004-03-16 | 2004-12-16 | 198d? | finish no earlier than 2004-12-16 | S4 | 1584h | 1584h | 3G-324MI | Ericsson | bo.burman@ericsson.com | Rel-6 | Paolo |  |  |
| 1879 | 562 | Single Antenna Receiver Interference Cancellation (SAIC) | 420.92d? | 2002-11-15 A | 2004-06-25 A | 100% | 2002-11-15 | 2004-06-25 | 420.92d? | finish no earlier than 2004-08-27 | GP,G1 | 3367.36h | 3367.36h | SAIC | Cingular | Marc Grant | Rel-6 | Paolo |  |  |

Notes:
- 1851: SP#28 Target 09/2005 for WLAN Charging 32.252
- 1852: SP#23 03/2004 completed / Text3: 32.250
- 1853: SP#25 09/2004 completed / Text3: 32.251
- 1854: SP#25 09/2004 completed / Text3: 32.295
- 1855: SP#26 12/2004 completed / Text3: 32.260
- 1856: SP#26: Updated WID SP-040778 was SP-030050. Target completion 06/2005. Consisting of MMS-CH, LCS-CH, WLAN-CH, POC-CH, MBMS-CH / Text3: 32.252, 32.270, 32.271, 32.272
- 1857: - / Text3: 23.125
- 1858: -
- 1859: -
- 1860: - / Text3: 29.210
- 1861: - / Text3: 29.209
- 1862: -
- 1863: 8/3/2001: test spec is based on R99 core spec, so deleted from Workplan
- 1864: -
- 1865: -
- 1866: - / Text3: 31.213
- 1867: MOVED to Rel-5 WP
- 1868: -
- 1869: - / Text3: 31.101, 31.102, 31.103, 31.111, 31.113, new 31.115, 31.116
- 1870: -
- 1871: -
- 1872: - / Text3: 31.124
- 1873: -
- 1874: 2nd resp SA4 / Text3: 22.233
- 1875: TR tbc by Sept. 05 / Text3: 26.233, 26.234, 26.244, 26.245, 26.246, 26.401, 26.402, 26.403, 26.404, 26.405, 26.406, 26.410, 26.411, 26.412, 26.273, 26.290, 26.304, 26.412, 26.274, 26.936
- 1876: TR tbc by Sept. 05 / Text3: 26.290, 26.304, 26.273, 26.274, 26.412, 26.936
- 1877: - / Text3: 26.235, 26.236
- 1878: - / Text3: 26.111, 26.911
- 1879: - / Text3: 45.903

| ID | WBS | Task | Type | Duration | Start | Finish | Complete | Baseline start | Baseline finish | Baseline duration | Constraint | Resources | Work | Actual work | Text1 | Text3 | Text4 | Text5 | Text6 | Text8 | Text12 |
| --- | --- | --- | --- | --- | --- | --- | --- | --- | --- | --- | --- | --- | --- | --- | --- | --- | --- | --- | --- | --- | --- |
| 1880 | 563 | **Enhancement of dialled service for CAMEL** |  | 199d | 2003-03-28 A | 2003-12-31 A | 100% | 2003-03-28 | 2003-12-31 | 199d |  | S1,N2,N4 | 3184h | 3184h | EDCAMEL | 22.078 | Samsung | Craig Bishop | Rel-6 | Alain |  |
| 1881 | 563.1 | Stages 2 and 3 |  | 199d | 2003-03-28 A | 2003-12-31 A | 100% | 2003-03-28 | 2003-12-31 | 199d | finish no earlier than 2003-09-19 | N2,N4 | 1592h | 1592h | EDCAMEL | 23.008, 23.016, 23.018, 23.078, 29.002, 29.078 | Samsung | Richard Brook | Rel-6 | Kimmo |  |
| 1882 | 564 | Study on Bandwidth and resource savings in CS networks |  | 273d? | 2003-06-01 A | 2004-06-16 A | 100% | 2003-06-01 | 2004-06-16 | 273d? | finish no earlier than 2004-06-16 | S2 | 2184h | 2184h | BARS | 23.977 |  |  | Rel-6 | Maurice |  |
| 1883 | 565 | FS on (U)SIM Security Reuse by Peripheral Devices on Local Interfaces |  | 127d? | 2003-07-03 A | 2003-12-26 A | 100% | 2003-07-03 | 2003-12-26 | 127d? | finish no earlier than 2003-12-26 | S3 | 1016h | 1016h |  | 33.817 | Toshiba | Raziq Yaqub (ryaqub@tari.toshiba.com) | Rel-6 | Dionisio |  |
| 1884 | 566 | **Multiple TBF in A/Gb mode** |  | 736d? | 2002-04-05 A | 2005-01-28 A | 100% | 2002-04-05 | 2005-01-28 | 736d? |  | GP,G2 | 17600h | 17600h | MULTBF |  | Ericsson | gunnar.mildh@era.ericsson.se | Rel-6 | Paolo |  |
| 1885 | 566.1 | **Multiple TBF in A/Gb mode** |  | 366d? | 2002-04-05 A | 2003-08-29 A | 100% | 2002-04-05 | 2003-08-29 | 366d? |  | GP,G2 | 11712h | 11712h | MULTBF-Agbmode |  | Ericsson | gunnar.mildh@era.ericsson.se | Rel-6 | Paolo |  |
| 1886 | 566.1.1 | Multiple TBF Concept paper |  | 366d? | 2002-04-05 A | 2003-08-29 A | 100% | 2002-04-05 | 2003-08-29 | 366d? | finish no earlier than 2003-08-29 | GP,G2 | 2928h | 2928h | MULTBF-Agbmode |  |  |  | Rel-6 | Paolo |  |
| 1887 | 566.1.2 | Multiple TBF Stage 2 (43.064) CRs |  | 366d? | 2002-04-05 A | 2003-08-29 A | 100% | 2002-04-05 | 2003-08-29 | 366d? | finish no earlier than 2003-08-29 | GP,G2 | 2928h | 2928h | MULTBF-Agbmode |  |  |  | Rel-6 | Paolo |  |
| 1888 | 566.1.3 | Multiple TBF Stage 3 (44.060) CRs |  | 366d? | 2002-04-05 A | 2003-08-29 A | 100% | 2002-04-05 | 2003-08-29 | 366d? | finish no earlier than 2003-08-29 | GP,G2 | 2928h | 2928h | MULTBF-Agbmode |  |  |  | Rel-6 | Paolo |  |
| 1889 | 566.2 | Deleted - Multiple TBF in A/Gb mode – MS testing | milestone | 0d? | 2005-01-28 A | 2005-01-28 A | 100% | 2005-01-28 | 2005-01-28 | 0d? | start no earlier than 2005-01-28 | G3new |  |  | MULTBF-Testing |  | Ericsson | gunnar.mildh@era.ericsson.se | Rel-6 | Paolo | GP-27 |
| 1890 | 567 | **Alignment between the test-regimes for GERAN capable MS** |  | 526d? | 2003-08-29 A | 2005-09-02 A | 100% | 2003-08-29 | 2005-09-02 | 526d? |  | G3new | 4208h | 4208h | ALTERE |  | Ericsson | Toubassi | Rel-6 | Ingbert |  |
| 1891 | 567.1 | Determine the controversial test cases in the different test regimes and align them with 3GPP GERAN test specifications. Such test cases to be added to TS 51.010. |  | 526d? | 2003-08-29 A | 2005-09-02 A | 100% | 2003-08-29 | 2005-09-02 | 526d? | finish no earlier than 2005-09-02 | G3new | 4208h | 4208h | ALTERE-TC |  |  |  | Rel-6 | Ingbert |  |
| 1892 | 568 | Addition of U-TDOA in the CS domain |  | 111d? | 2003-11-21 A | 2004-04-23 A | 100% | 2003-11-21 | 2004-04-23 | 111d? | finish no earlier than 2004-04-23 | GP | 888h | 888h | UTDOACS |  | TruePosition | Bob Gross, Rhys Robinson (rlgross@trueposition.com) | Rel-6 | Paolo |  |
| 1893 | 569 | Addition of U-TDOA in the PS domain |  | 361d? | 2003-06-27 A | 2004-11-12 A | 100% | 2003-06-27 | 2004-11-12 | 361d? | finish no earlier than 2004-11-12 | GP | 2888h | 2888h | UTDOAPS |  | TruePosition | Bob Gross, Rhys Robinson (rlgross@trueposition.com) | Rel-6 | Paolo |  |
| 1894 | 570 | **Downlink Advanced Receiver Performance** |  | 466d? | 2003-11-21 A | 2005-09-02 A | 100% | 2003-11-21 | 2005-09-02 | 466d? |  | GP | 19160h | 19160h | DARP |  | Nokia | tommy.bysted@nokia.com | Rel-6 | Paolo |  |
| 1895 | 570.1 | DARP test scenarios |  | 201d? | 2003-11-21 A | 2004-08-27 A | 100% | 2003-11-21 | 2004-08-27 | 201d? | finish no earlier than 2004-08-27 | GP | 1608h | 1608h | DARP-TS |  | Nokia | tommy.bysted@nokia.com | Rel-6 | Paolo |  |
| 1896 | 570.2 | **DARP for GMSK modulated voice services** |  | 201d? | 2004-02-06 A | 2004-11-12 A | 100% | 2004-02-06 | 2004-11-12 | 201d? |  | GP | 4824h | 4824h | DARP-GMSK |  | Nokia | tommy.bysted@nokia.com | Rel-6 | Paolo |  |
| 1897 | 570.2.1 | Performance requirements in 45.005 |  | 201d? | 2004-02-06 A | 2004-11-12 A | 100% | 2004-02-06 | 2004-11-12 | 201d? | finish no earlier than 2004-11-12 | GP | 1608h | 1608h | DARP-GMSK-Perf |  |  |  | Rel-6 | Paolo |  |
| 1898 | 570.2.2 | Radio subsystem link control in 45.008 |  | 201d? | 2004-02-06 A | 2004-11-12 A | 100% | 2004-02-06 | 2004-11-12 | 201d? | finish no earlier than 2004-11-12 | GP | 1608h | 1608h | DARP-GMSK-LC |  |  |  | Rel-6 | Paolo |  |
| 1899 | 570.3 | **DARP for GPRS and EGPRS MCS1-MCS4** |  | 201d? | 2004-02-06 A | 2004-11-12 A | 100% | 2004-02-06 | 2004-11-12 | 201d? |  | GP | 4824h | 4824h | DARP-GPRSE |  | Nokia | tommy.bysted@nokia.com | Rel-6 | Paolo |  |
| 1900 | 570.3.1 | Performance requirements in 45.005 |  | 201d? | 2004-02-06 A | 2004-11-12 A | 100% | 2004-02-06 | 2004-11-12 | 201d? | finish no earlier than 2004-11-12 | GP | 1608h | 1608h | DARP-GPRSE-Perf |  |  |  | Rel-6 | Paolo |  |
| 1901 | 570.3.2 | Radio subsystem link control in 45.008 |  | 201d? | 2004-02-06 A | 2004-11-12 A | 100% | 2004-02-06 | 2004-11-12 | 201d? | finish no earlier than 2004-11-12 | GP | 1608h | 1608h | DARP-GPRSE-LC |  |  |  | Rel-6 | Paolo |  |
| 1902 | 570.4 | DARP Capability signalling |  | 256d? | 2003-11-21 A | 2004-11-12 A | 100% | 2003-11-21 | 2004-11-12 | 256d? | finish no earlier than 2004-11-12 | GP | 2048h | 2048h | DARP-CAPSIG |  | Nokia | tommy.bysted@nokia.com | Rel-6 | Paolo |  |
| 1903 | 570.5 | GERAN MS Conformance test for DARP |  | 266d? | 2004-08-27 A | 2005-09-02 A | 100% | 2004-08-27 | 2005-09-02 | 266d? | finish no earlier than 2005-06-24 | G3new | 2128h | 2128h | ARP-ConfTest |  | Nokia | tommy.bysted@nokia.com | Rel-6 | Ingbert |  |

Notes:
- 1880: -
- 1881: -
- 1882: -
- 1883: Approved TSG#20
- 1884: GP#17 Nov 2003 Moved from Rel-5 UID_50058 MULTBF (Only Multiple TBF Concept paper produced in Rel-5)
- 1885: -
- 1886: -
- 1887: -
- 1888: -
- 1889: -
- 1890: -
- 1891: -
- 1892: Completed, except for potential LMU performance specs
- 1893: -
- 1894: -
- 1895: -
- 1896: -
- 1897: -
- 1898: -
- 1899: -
- 1900: -
- 1901: -
- 1902: -
- 1903: -

| ID | WBS | Task | Type | Duration | Start | Finish | Complete | Baseline start | Baseline finish | Baseline duration | Constraint | Resources | Work | Actual work | Text1 | Text4 | Text5 | Text6 | Text8 | Text12 | Text3 | Text10 |
| --- | --- | --- | --- | --- | --- | --- | --- | --- | --- | --- | --- | --- | --- | --- | --- | --- | --- | --- | --- | --- | --- | --- |
| 1904 | 571 | **Reduction of PS service interruption in Dual Transfer Mode** |  | 416d? | 2003-11-21 A | 2005-06-24 A | 100% | 2003-11-21 | 2005-06-24 | 416d? |  | G2 | 8360h | 8360h | PSintDTM | Siemens | toby.proctor@roke.co.uk | Rel-6 | Gert |  |  |  |
| 1905 | 571.1 | Use case and requirement definition |  | 111d? | 2003-11-21 A | 2004-04-23 A | 100% | 2003-11-21 | 2004-04-23 | 111d? | finish no earlier than 2004-04-23 | G2 | 888h | 888h | PSintDTM-Req | Siemens | toby.proctor@roke.co.uk | Rel-6 | Gert |  |  |  |
| 1906 | 571.2 | Performance Study of Current Procedures |  | 111d? | 2003-11-21 A | 2004-04-23 A | 100% | 2003-11-21 | 2004-04-23 | 111d? | start no earlier than 2003-11-21 | G2 | 888h | 888h | PSintDTM-Perf | Siemens | toby.proctor@roke.co.uk | Rel-6 | Gert |  |  |  |
| 1907 | 571.3 | Reduction of service interruption times and packet loss during Dual Transfer Mode and mobility procedures |  | 146d? | 2004-04-23 A | 2004-11-12 A | 100% | 2004-04-23 | 2004-11-12 | 146d? | finish no earlier than 2004-11-12 | G2 | 1168h | 1168h | PSintDTM-Reduct | Siemens | toby.proctor@roke.co.uk | Rel-6 | Gert |  |  |  |
| 1908 | 571.4 | Deleted - MS Conformance testing - Reduction of PS service interruption in DTM |  | 261d? | 2004-06-25 A | 2005-06-24 A | 100% | 2004-06-25 | 2005-06-24 | 261d? | finish no earlier than 2005-06-24 | G3new | 2088h | 2088h | PSintDTM-ConfMS |  |  | Rel-6 | Ingbert | GP-25 |  |  |
| 1909 | 571.5 | Deleted - BTS Conformance testing - Reduction of PS service interruption in DTM | milestone | 0d? | 2005-06-24 A | 2005-06-24 A | 100% | 2005-06-24 | 2005-06-24 | 0d? | finish no earlier than 2005-06-24 | G3new |  |  | PSintDTM-ConfBTS |  |  | Rel-6 | Ingbert | GP-25 |  |  |
| 1910 | 572 | CAMEL prepay interworking with SCUDIF |  | 216.3d | 2003-12-08 A | 2004-10-05 A | 100% | 2003-12-08 | 2004-10-05 | 216.3d |  | N4,N3,S1 | 1730.4h | 1730.4h | SCCAMEL | Nokia | Keijo.Palviainen@Nokia.Com | Rel-6 | Kimmo |  | 22.078, 23.078, 29.078, 29.002, 23.172 |  |
| 1911 | 573 | **Circuit Switched Video and Voice Service Improvements** |  | 430d? | 2004-01-12 A | 2005-09-02 A | 100% | 2004-01-12 | 2005-09-02 | 430d? |  | S2,C1 | 9256h | 9256h | CS_VSS | Vodafone | John Watson | Rel-6 | Alain |  |  |  |
| 1912 | 573.1 | Deleted - Stage 1 - Requirements |  | 199d | 2004-01-12 A | 2004-10-14 A | 100% | 2004-01-12 | 2004-10-14 | 199d | finish no earlier than 2004-10-14 | S1 | 1592h | 1592h | CS_VSS | Vodafone | John Watson | Rel-6 | Alain | SP-26 | 22.101 |  |
| 1913 | 573.2 | Stage 2 Study on architecture alternatives |  | 244d? | 2004-01-12 A | 2004-12-16 A | 100% | 2004-01-12 | 2004-12-16 | 244d? | finish no earlier than 2004-08-13 | S2 | 1952h | 1952h | CS_VSS | Vodafone | Chris Pudney | Rel-6 | Maurice |  | 23.903 | SP-24 |
| 1914 | 573.3 | Deleted - Stage 2 description on Redial |  | 164d? | 2004-05-03 A | 2004-12-16 A | 100% | 2004-05-03 | 2004-12-16 | 164d? | finish no earlier than 2004-12-16 | S2 | 1312h | 1312h | CS_VSS | Vodafone | Chris Pudney | Rel-6 | Maurice | SP-26 |  | SP-24 |
| 1915 | 573.4 | Switching between voice and video call - Redial solution |  | 120d? | 2005-01-03 A | 2005-06-17 A | 100% | 2005-01-03 | 2005-06-17 | 120d? | start no earlier than 2005-01-03 | C1 | 960h | 960h | CS_VSS | Vodafone |  | Rel-6 | Frederic |  | 23.009, 24.008 |  |
| 1916 | 573.5 | Deleted - CS_VSS - GERAN2 Part | milestone | 0d | 2005-09-02 A | 2005-09-02 A | 100% | 2005-09-02 | 2005-09-02 | 0d | start no earlier than 2005-09-02 | G2 |  |  | CS_VSS | Vodafone |  | Rel-6 | Gert | GP-26 |  |  |
| 1917 | 573.6 | Deleted - CS_VSS - CN3 Part | milestone | 0d? | 2004-10-14 A | 2004-10-14 A | 100% | 2004-10-14 | 2004-10-14 | 0d? | start no earlier than 2004-10-14 | N3 |  |  | CS_VSS | Vodafone |  | Rel-6 | Gwiho | TP-26 |  |  |
| 1918 | 574 | Network Domain Security; MAP application layer security (NDS/MAPsec) |  | 127d? | 2004-07-06 A | 2004-12-29 A | 100% | 2004-07-06 | 2004-12-29 | 127d? | finish no earlier than 2003-12-26 | S3 | 1016h | 1016h | MAPSEC | Vodafone | Peter.Howard@vodafone.com | Rel-6 | Dionisio |  |  |  |
| 1919 | 575 | FS on Security for early IMS |  | 127d? | 2004-10-01 A | 2005-03-28 A | 100% | 2004-10-01 | 2005-03-28 | 127d? | finish no earlier than 2003-12-26 | S3 | 1016h | 1016h | SEC-IMS | Vodafone | Peter.Howard@vodafone.com | Rel-6 | Dionisio |  | 33.978 |  |
| 1920 | 576 | Reorganisation of CS Data Specifications |  | 14d? | 2004-11-19 A | 2004-12-08 A | 100% | 2004-11-19 | 2004-12-08 | 14d? | finish no earlier than 2004-12-24 | N3 | 112h | 112h | CS Data | Siemens | Thomas.Belling@nsn.com | Rel-6 | Gwiho |  | 23.910, 29.007, new 23.202 |  |
| 1921 | 577 | **Generic Access to A/Gb Interface (GAAI)** |  | 411d? | 2004-06-25 A | 2006-01-20 A | 100% | 2004-06-25 | 2006-01-20 | 411d? |  | GP | 9160h | 9160h | GAAI | Motorola |  | Rel-6 | Paolo |  |  |  |
| 1922 | 577.1 | FS on GAAI |  | 46d? | 2004-06-25 A | 2004-08-27 A | 100% | 2004-06-25 | 2004-08-27 | 46d? | finish no earlier than 2004-08-27 | GP | 368h | 368h | GAAG | Motorola |  | Rel-6 | Paolo |  | 43.901 |  |
| 1923 | 577.2 | GAAI – Stage 2 |  | 161d? | 2004-08-27 A | 2005-04-08 A | 100% | 2004-08-27 | 2005-04-08 | 161d? | finish no earlier than 2005-04-08 | GP | 1288h | 1288h | GAAI-Stage2 | Ericsson | jari.vikberg@ericsson.com | Rel-6 | Paolo |  | 43.318 |  |
| 1924 | 577.3 | GAAI – Stage 3 |  | 161d? | 2004-08-27 A | 2005-04-08 A | 100% | 2004-08-27 | 2005-04-08 | 161d? | finish no earlier than 2005-04-08 | GP | 1288h | 1288h | GAAI-Stage3 |  |  | Rel-6 | Paolo |  | 44.318 |  |
| 1925 | 577.4 | MS Conformance Test for GAAI |  | 366d? | 2004-08-27 A | 2006-01-20 A | 100% | 2004-08-27 | 2006-01-20 | 366d? | finish no earlier than 2006-01-20 | GP | 2928h | 2928h | GAAI-CT |  |  | Rel-6 | Ingbert |  |  |  |
| 1926 | 578 | **Support of PS Handover for GERAN A/Gb mode** |  | 473d? | 2003-11-03 A | 2005-08-24 A | 100% | 2003-11-03 | 2005-08-24 | 473d? |  | GP,G2 | 11352h | 11352h | SPSHAGB | Ericsson | gunnar.hedby@ericsson.com | Rel-6 | Paolo |  |  |  |
| 1927 | 578.1 | Stage 2 |  | 473d? | 2003-11-03 A | 2005-08-24 A | 100% | 2003-11-03 | 2005-08-24 | 473d? | finish no earlier than 2005-09-02 | GP,G2 | 3784h | 3784h | SPSHAGB-Stage2 | Ericsson | gunnar.hedby@ericsson.com | Rel-6 | Paolo |  | 43.129 |  |
| 1928 | 578.2 | PS handover |  | 473d? | 2003-11-03 A | 2005-08-24 A | 100% | 2003-11-03 | 2005-08-24 | 473d? | finish no earlier than 2005-09-02 | GP,G2 | 3784h | 3784h | SPSHAGB-PSHO | Ericsson | gunnar.hedby@ericsson.com | Rel-6 | Paolo |  |  |  |
| 1929 | 578.3 | Definition of radio resource management functionality |  | 473d? | 2003-11-03 A | 2005-08-24 A | 100% | 2003-11-03 | 2005-08-24 | 473d? | finish no earlier than 2005-09-02 | GP,G2 | 3784h | 3784h | SPSHAGB-RRM | Ericsson | gunnar.hedby@ericsson.com | Rel-6 | Paolo |  |  |  |
| 1930 | 579 | (Small) Technical Enhancements and Improvements for Rel-6 |  | 503d? | 2006-06-02 A | 2008-05-06 A | 100% | 2006-06-02 | 2008-05-06 | 503d? |  | All |  |  | TEI6 |  |  | Rel-6 | all |  |  |  |
| 1931 | 580 | Test - (Small) Technical Enhancements and Improvements for Rel-6 |  | 503d? | 2006-06-02 A | 2008-05-06 A | 100% | 2006-06-02 | 2008-05-06 | 503d? | start no earlier than 2006-06-02 | R5,T1 | 4024h | 4024h | TEI6_Test |  |  | Rel-6 | Ingbert |  | 34.108,34.121-1/2,34.122,34.123-1/2/3 |  |
| 1932 | 581 | Deleted - Study of Feature Interactions Requirements | milestone | 0d? | 2004-09-16 A | 2004-09-16 A | 100% | 2004-09-16 | 2004-09-16 | 0d? | finish no earlier than 2004-10-01 | S1 |  |  | FINTER |  |  | Rel-6 | Alain | SP-25 |  |  |
| 1933 | 582 | Deleted - Enhancements of VGCS in public networks for communication of public authority officials |  | 7d? | 2005-08-24 A | 2005-09-02 A | 100% | 2005-08-24 | 2005-09-02 | 7d? | start no earlier than 2005-08-24 | GP,G2 | 56h | 56h | EVGCS | Siemens | kenneth.isaacs@roke.co.uk | Rel-6 | Paolo | GP-26 | 44.018, 44.068, 48.008 |  |

Notes:
- 1904: -
- 1905: -
- 1906: -
- 1907: -
- 1908: -
- 1909: -
- 1910: -
- 1911: -
- 1912: -
- 1913: -
- 1914: -
- 1915: -
- 1916: -
- 1917: -
- 1918: Approved TSG#24. Marked as closed 12/2008 (was marked 20% complete)
- 1919: SP#24 approved WID. SP#27 completed. SP#46 TR 33.978 withdrawn from Rel-8 onwards
- 1920: Created at TSG#27 as 100 % complete
- 1921: -
- 1922: Feasibility Study
- 1923: -
- 1924: -
- 1925: Marked as closed 12/2008 (was marked 90% complete)
- 1926: Replaces SCSAGB- Originally Started Nov 2003 as GP-030443
- 1927: Replaces SCSAGB-Stage2
- 1928: Replaces SCSAGB-PSH
- 1929: Replaces SCSAGB-RRM
- 1930: "Joker" WI, to be used for a Rel 6 CR not related to any feature and with very limited impact on the system. Moved in from Stoyan/Testing WP
- 1931: "Joker" WI, to be used for small modifications applicable to Rel 4 conformance testing
- 1932: SP#25 stopped
- 1933: GP#26 moved to Rel-7 as UID_11045 Enhancements of VGCS in public networks for communication of public authority officials

| ID | WBS | Task | Type | Duration | Start | Finish | Complete | Baseline start | Baseline finish | Baseline duration | Constraint | Resources | Work | Actual work | Text1 | Text4 | Text5 | Text6 | Text8 | Text12 | Text3 | Text7 | Text10 |
| --- | --- | --- | --- | --- | --- | --- | --- | --- | --- | --- | --- | --- | --- | --- | --- | --- | --- | --- | --- | --- | --- | --- | --- |
| 1934 | 583 | **Deleted - Support of Conversational Services in A/Gb mode via the PS domain** |  | 64d? | 2003-11-21 A | 2004-02-19 A | 100% | 2003-11-21 | 2004-02-19 | 64d? |  | GP,N1 | 1024h | 1024h | SCSAGB | Ericsson | David Bladsjö (david.bladsjo@ericsson.com) | Rel-6 | Paolo | GP-18 |  |  |  |
| 1935 | 583.1 | Deleted - Creation of a TR | milestone | 0d? | 2003-11-21 A | 2003-11-21 A | 100% | 2003-11-21 | 2003-11-21 | 0d? | start no earlier than 2003-11-21 | GP |  |  | SCSAGB-TR | Ericsson | David Bladsjö (david.bladsjo@ericsson.com) | Rel-6 | Paolo | GP-17 |  |  |  |
| 1936 | 583.2 | Deleted - Stage 2 | milestone | 0d? | 2003-11-21 A | 2003-11-21 A | 100% | 2003-11-21 | 2003-11-21 | 0d? | finish no earlier than 2003-11-21 | GP |  |  | SCSAGB-Stage2 | Ericsson | David Bladsjö (david.bladsjo@ericsson.com) | Rel-6 | Paolo | GP-17 |  |  |  |
| 1937 | 583.3 | Deleted - Radio Channel Support | milestone | 0d? | 2003-11-21 A | 2003-11-21 A | 100% | 2003-11-21 | 2003-11-21 | 0d? | finish no earlier than 2003-11-21 | GP |  |  | SCSAGB-RCS | Ericsson | David Bladsjö (david.bladsjo@ericsson.com) | Rel-6 | Paolo | GP-17 |  |  |  |
| 1938 | 583.4 | Deleted - Definition of radio resource management functionality | milestone | 0d? | 2003-11-21 A | 2003-11-21 A | 100% | 2003-11-21 | 2003-11-21 | 0d? | finish no earlier than 2003-11-21 | GP |  |  | SCSAGB-RRM | Ericsson | David Bladsjö (david.bladsjo@ericsson.com) | Rel-6 | Paolo | GP-17 |  |  |  |
| 1939 | 583.5 | Deleted - replaced by 50561 - PS Handover |  | 64d | 2003-11-21 A | 2004-02-19 A | 100% | 2003-11-21 | 2004-02-19 | 64d | start no earlier than 2003-11-21 | GP,N1 | 512h | 512h | SCSAGB-PSH | Ericsson | David Bladsjö (david.bladsjo@ericsson.com) | Rel-6 | Paolo | GP-18 |  |  |  |
| 1940 | 583.6 | Deleted - Modifications to FLO | milestone | 0d? | 2003-11-21 A | 2003-11-21 A | 100% | 2003-11-21 | 2003-11-21 | 0d? | finish no earlier than 2003-11-21 | GP |  |  | SCSAGB-FLO | Ericsson | David Bladsjö (david.bladsjo@ericsson.com) | Rel-6 | Paolo | RP-29 |  |  |  |
| 1941 | 584 | Deleted - Rel-6 Evolutions of the transport in the UTRAN | milestone | 0d | 2003-12-31 A | 2003-12-31 A | 100% | 2003-12-31 | 2003-12-31 | 0d | start no earlier than 2003-12-31 | RP |  |  | ETRAN | Alcatel | Francois Courau | Rel-6 | Issam | RP-22 |  |  |  |
| 1942 | 585 | Release 5 Features |  | 325d? | 2001-03-30 A | 2002-06-28 A | 100% | 2001-03-30 | 2002-06-28 | 325d? |  | NP,GP, RP,SP,TP | 2600h | 2600h |  |  |  | Rel-5 | All |  |  |  |  |
| 1943 | 75 | IP transport in the UTRAN |  | 445d | 2000-07-17 A | 2002-03-29 A | 100% | 2000-07-17 | 2002-03-29 | 445d | finish no earlier than 2002-03-29 | R3 | 3560h | 3560h | ETRAN-IPtrans | Alcatel | Nicolas Drevon | Rel-5 | Juha |  |  |  |  |
| 1944 | 76 | FS on Usage of SUA |  | 205d | 2001-03-12 A | 2001-12-21 A | 100% | 2001-03-12 | 2001-12-21 | 205d | finish no earlier than 2001-12-21 | N4 | 1640h | 1640h | SS7IP |  |  | Rel-5 | Kimmo |  |  |  |  |
| 1945 | 77 | **High Speed Downlink Packet Access** |  | 1550d? | 2001-04-02 A | 2007-03-09 A | 100% | 2001-04-02 | 2007-03-09 | 1550d? |  | R2,R5 | 31488h | 31488h | HSDPA | Motorola | Ravi Kuchibhotla | Rel-5 | Joern |  |  |  |  |
| 1946 | 77.1 | Physical Layer |  | 257d | 2001-04-05 A | 2002-03-29 A | 100% | 2001-04-05 | 2002-03-29 | 257d | finish no earlier than 2002-03-29 | R1 | 2056h | 2056h | HSDPA-Phys | Motorola | Amitava Ghosh | Rel-5 | Patrick |  |  |  |  |
| 1947 | 77.2 | Layer 2 and 3 aspects |  | 257d | 2001-04-05 A | 2002-03-29 A | 100% | 2001-04-05 | 2002-03-29 | 257d | finish no earlier than 2002-03-29 | R2 | 2056h | 2056h | HSDPA-L23 | Motorola | Ravi Kuchibhotla | Rel-5 | Joern |  |  |  |  |
| 1948 | 77.3 | Iub/Iur protocol aspects |  | 260d | 2001-04-02 A | 2002-03-29 A | 100% | 2001-04-02 | 2002-03-29 | 260d | finish no earlier than 2002-03-29 | R3 | 2080h | 2080h | HSDPA-IubIur | Motorola | Mike Diesen | Rel-5 | Juha |  |  |  |  |
| 1949 | 77.4 | RF Radio Transmission/ Reception, System Performance Requirements and Conformance Testing |  | 565d | 2001-04-09 A | 2003-06-06 A | 100% | 2001-04-09 | 2003-06-06 | 565d | finish no earlier than 2003-06-06 | R4 | 4520h | 4520h | HSDPA-RF | Motorola | Howard Benn | Rel-5 | Issam |  |  |  |  |
| 1950 | 588.5 | Conformance Testing of HSDPA |  | 786d | 2003-09-19 A | 2006-09-22 A | 100% | 2003-09-19 | 2006-09-22 | 786d | finish no earlier than 2006-09-22 | R5 | 6288h | 6288h | HSDPA_Test | Motorola | carolyn.taylor@motorola.com | Rel-5 | Ingbert |  | 34.108, 34.121, 34.122, 34.123-1, 34.123-2, 34.123-3 | TSG | 19/9/2003 |
| 1951 | 588.6 | Conformance Testing of HCR TDD HSDPA |  | 261d? | 2006-03-10 A | 2007-03-09 A | 100% | 2006-03-10 | 2007-03-09 | 261d? | finish no earlier than 2007-03-09 | R5 | 2088h | 2088h | HSDPA_HCRTDD_Test | IPWireless | drichards@ipwireless.com | Rel-5 | Ingbert |  | 34.108, 34.122, 34.123-1, 34.123-2, 34.123-3 |  |  |
| 1952 | 78 | **Rel-5 Improvements of Radio Interface** |  | 535d | 2000-08-14 A | 2002-08-30 A | 100% | 2000-08-14 | 2002-08-30 | 535d |  | RP | 30376h | 30376h | RInImp |  |  | Rel-5 |  |  |  |  |  |
| 1953 | 78.1 | **Base station classification** |  | 480d | 2000-08-14 A | 2002-06-14 A | 100% | 2000-08-14 | 2002-06-14 | 480d |  | R4 | 9208h | 9208h | RInImp-BSClass | Nokia | antti.toskala@nokia.com | Rel-5 | Issam |  |  |  |  |
| 1954 | 78.1.1 | TDD Base station classification |  | 410d | 2000-08-14 A | 2002-03-08 A | 100% | 2000-08-14 | 2002-03-08 | 410d | finish no earlier than 2002-03-08 | R4 | 3280h | 3280h | RInImp-BSClass-TDD | Nokia | antti.toskala@nokia.com | Rel-5 | Issam |  |  |  |  |
| 1955 | 78.1.2 | Base Station Classification for 1.28 Mcps TDD option |  | 261d | 2001-06-15 A | 2002-06-14 A | 100% | 2001-06-15 | 2002-06-14 | 261d | finish no earlier than 2002-06-14 | R4 | 2088h | 2088h | RInImp-BSClass-LCRTDD | Siemens | Meik.Kottkamp@siemens.com | Rel-5 | Issam |  |  |  |  |
| 1956 | 78.2 | Enhancement on the DSCH hard split mode |  | 271d | 2001-03-16 A | 2002-03-29 A | 100% | 2001-03-16 | 2002-03-29 | 271d | finish no earlier than 2002-03-29 | R1 | 2168h | 2168h | RInImp-DSCHhsp | Samsung | Jaeyoel KIM | Rel-5 | Patrick |  |  |  |  |
| 1957 | 78.3 | Hybrid ARQ II/III |  | 355d | 2000-08-21 A | 2001-12-28 A | 100% | 2000-08-21 | 2001-12-28 | 355d | finish no earlier than 2001-12-28 | R2 | 2840h | 2840h | RInImp-HARQ | Siemens | A. Sitte | Rel-5 | Joern | RP-14 |  |  |  |
| 1958 | 78.4 | FS on USTS |  | 355d | 2000-08-14 A | 2001-12-21 A | 100% | 2000-08-14 | 2001-12-21 | 355d | finish no earlier than 2001-12-21 | R1 | 2840h | 2840h | RInImp-USTS | SK Telecom | D. Kim | Rel-5 | Patrick |  |  |  |  |
| 1959 | 78.5 | FS on UE antenna efficiency test method performance requirements |  | 255d | 2000-09-25 A | 2001-09-14 A | 100% | 2000-09-25 | 2001-09-14 | 255d | finish no earlier than 2001-09-14 | R4 | 2040h | 2040h | RInImp-UEAnTM | Allgon | O. Edvardsson | Rel-5 | Issam |  |  |  |  |
| 1960 | 78.6 | FS on the re-introduction of the downlink SIR measurement |  | 200d | 2001-03-12 A | 2001-12-14 A | 100% | 2001-03-12 | 2001-12-14 | 200d | finish no earlier than 2001-12-14 | R4 | 1600h | 1600h | RInImp-SIR | Ericsson | Torgny.Palenius@ericsson.com | Rel-5 | Issam |  |  |  |  |
| 1961 | 78.7 | FS on mitigating the effect of CPICH interference at the UE |  | 255d | 2001-03-19 A | 2002-03-08 A | 100% | 2001-03-19 | 2002-03-08 | 255d | finish no earlier than 2002-03-08 | R4 | 2040h | 2040h | RInImp-CPICH_Intf | Intel | shimon.moshavi@INTEL.COM | Rel-5 | Issam |  |  |  |  |

Notes:
- 1934: -
- 1935: -
- 1936: Started
- 1937: Not started
- 1938: Not started
- 1939: Started
- 1940: Not started
- 1941: Generic feature
- 1942: -
- 1943: -
- 1944: -
- 1945: -
- 1946: -
- 1947: -
- 1948: -
- 1949: -
- 1950: -
- 1951: -
- 1952: -
- 1953: -
- 1954: -
- 1955: -
- 1956: -
- 1957: Stopped at RP#14; work on this task was performed as part of High Speed Downlink Packet Access feature
- 1958: -
- 1959: -
- 1960: -
- 1961: -

| ID | WBS | Task | Duration | Start | Finish | Complete | Baseline start | Baseline finish | Baseline duration | Constraint | Deadline | Resources | Work | Actual work | Text6 | Text8 | Text12 | Text1 | Text4 | Text5 | Text3 | Text10 |
| --- | --- | --- | --- | --- | --- | --- | --- | --- | --- | --- | --- | --- | --- | --- | --- | --- | --- | --- | --- | --- | --- | --- |
| 1962 | 78.8 | **Deleted - Conformance Test Spec. improvements in Radio Interface** | 140d | 2002-02-18 A | 2002-08-30 A | 100% | 2002-02-18 | 2002-08-30 | 140d |  |  | T1 | 3360h | 3360h | Rel-5 | Ingbert | TP-17 |  |  |  |  |  |
| 1963 | 78.8.1 | Deleted - Testing improvement of inter-frequency and inter-system measurement | 140d | 2002-02-18 A | 2002-08-30 A | 100% | 2002-02-18 | 2002-08-30 | 140d | finish no earlier than 2002-08-30 |  | T1 | 1120h | 1120h | Rel-5 | Ingbert | TP-17 |  |  |  |  |  |
| 1964 | 78.8.2 | Deleted - Testing Hybrid ARQ II/III | 140d | 2002-02-18 A | 2002-08-30 A | 100% | 2002-02-18 | 2002-08-30 | 140d | finish no earlier than 2002-08-30 |  | T1 | 1120h | 1120h | Rel-5 | Ingbert | TP-17 |  |  |  |  |  |
| 1965 | 79 | **Rel-5 RAN improvements** | 1561d? | 2001-03-16 A | 2007-03-09 A | 100% | 2001-03-16 | 2007-03-09 | 1561d? |  |  | RP | 49424h | 49424h | Rel-5 |  |  | RANimp |  |  |  |  |
| 1966 | 79.1 | **RRM optimization for Iur and Iub** | 318d | 2001-03-16 A | 2002-06-04 A | 100% | 2001-03-16 | 2002-06-04 | 318d |  |  | R3 | 8904h | 8904h | Rel-5 | Juha |  | RANimp-RRMopt | Ericsson | Gert-Jan.van.Lieshout@eln.ericsson.se |  |  |
| 1967 | 79.1.1 | Iur common transport channel efficiency optimization | 271d | 2001-03-16 A | 2002-03-29 A | 100% | 2001-03-16 | 2002-03-29 | 271d | finish no earlier than 2002-03-29 |  | R3 | 2168h | 2168h | Rel-5 | Juha |  | RANimp-RRMopt-ctc | Ericsson | Shahrokh Amirijoo |  |  |
| 1968 | 79.1.2 | Iur neighbouring cell reporting efficiency optimization | 271d | 2001-03-16 A | 2002-03-29 A | 100% | 2001-03-16 | 2002-03-29 | 271d | finish no earlier than 2002-03-29 |  | R3 | 2168h | 2168h | Rel-5 | Juha |  | RANimp-RRMopt-ncr | Ericsson | Shahrokh Amirijoo |  |  |
| 1969 | 79.1.3 | FS Introduction of direct transport bearers between SRNC and Node-B | 253d | 2001-06-15 A | 2002-06-04 A | 100% | 2001-06-15 | 2002-06-04 | 253d | finish no earlier than 2002-06-28 |  | R3 | 2024h | 2024h | Rel-5 | Juha |  | RAN-imp-RRMopt-DTB | Ericsson | Risto Sepponen |  |  |
| 1970 | 79.2 | RL Timing Adjustment | 271d | 2001-03-16 A | 2002-03-29 A | 100% | 2001-03-16 | 2002-03-29 | 271d | finish no earlier than 2002-03-29 |  | R3 | 2168h | 2168h | Rel-5 | Juha |  | RANimp-RLTA | Ericsson | Elena Voltolina |  |  |
| 1971 | 79.3 | Separation of resource reservation and radio link activation | 271d | 2001-03-16 A | 2002-03-29 A | 100% | 2001-03-16 | 2002-03-29 | 271d | finish no earlier than 2002-03-29 |  | R3 | 2168h | 2168h | Rel-5 | Juha |  | RANimp-SepRR | Ericsson | Gert-Jan.van.Lieshout@eln.ericsson.se |  |  |
| 1972 | 79.4 | FS SRNS Relocation Procedure Enhancement | 318d | 2001-06-15 A | 2002-09-03 A | 100% | 2001-06-15 | 2002-09-03 | 318d | finish no earlier than 2002-09-06 |  | R3 | 2544h | 2544h | Rel-5 | Juha |  | RANimp-SRNS | Nokia | Olivier Guyot |  |  |
| 1973 | 79.5 | FS Improvement of Radio Resource Management across RNS and RNS/PSS | 201d | 2001-03-16 A | 2001-12-21 A | 100% | 2001-03-16 | 2001-12-21 | 201d | finish no earlier than 2001-12-21 |  | R3 | 1608h | 1608h | Rel-5 | Juha |  | RANimp-ImpRRM | Nokia | antti.toskala@nokia.com |  |  |
| 1974 | 79.6 | Re-arrangements of Iub transport bearers | 271d | 2001-03-16 A | 2002-03-29 A | 100% | 2001-03-16 | 2002-03-29 | 271d | finish no earlier than 2002-03-29 |  | R3 | 2168h | 2168h | Rel-5 | Juha |  | RANimp-TTPS | Nokia | antti.toskala@nokia.com |  |  |
| 1975 | 79.7 | RAB support enhancement for Rel-5 | 325d | 2001-04-02 A | 2002-06-28 A | 100% | 2001-04-02 | 2002-06-28 | 325d |  |  | R2 | 2600h | 2600h | Rel-5 | Joern |  | RANimp-RABSE5 | Nokia | Juha Mikola |  |  |
| 1976 | 16.5.1 | Testing of ROHC performance | 391d | 2005-09-09 A | 2007-03-09 A | 100% | 2005-09-09 | 2007-03-09 | 391d | finish no earlier than 2007-03-09 | 2006-06-02 | R5 | 3128h | 3128h | Rel-5 | Ingbert |  | RANimp-RABSE5_Test | Nokia | jarkko.hellsten@nokia.com | 34.108, 34.123-1, 34.123-2, 34.123-3 | Fri 11/03/05 |
| 1977 | 79.8 | Beamforming requirements for UE | 61d | 2001-09-21 A | 2001-12-14 A | 100% | 2001-09-21 | 2001-12-14 | 61d | finish no earlier than 2001-12-14 |  | R1 | 488h | 488h | Rel-5 | Patrick |  | RANimp-BFR-UE | Nokia | Jussi Kähtävä (juha.mikola@nokia.com) |  |  |
| 1978 | 79.9 | Support of Site Selection Diversity Transmission in UTRAN | 123d | 2001-12-14 A | 2002-06-04 A | 100% | 2001-12-14 | 2002-06-04 | 123d | finish no earlier than 2002-06-04 |  | R1 | 984h | 984h | Rel-5 | Patrick |  | RANimp-SSDT | NEC |  |  |  |
| 1979 | 79.10 | Node B Synchronisation for 1.28 Mcps TDD | 271d | 2001-03-16 A | 2002-03-29 A | 100% | 2001-03-16 | 2002-03-29 | 271d | finish no earlier than 2002-03-29 |  | R1 | 2168h | 2168h | Rel-5 | Patrick |  | RANimp-NBSLCR | CATT | Jinling HU |  |  |
| 1980 | 79.12 | **Deleted - Conformance Test Aspects - RAN Improvements** | 565d? | 2002-01-01 A | 2004-03-01 A | 100% | 2002-01-01 | 2004-03-01 | 565d? |  |  | T1 | 8008h | 8008h | Rel-5 | Ingbert | TP-23 |  |  |  | 0% |  |
| 1981 | 79.12.1 | Deleted - Testing Radio access bearer support enhancements | 175d | 2002-01-01 A | 2002-09-02 A | 100% | 2002-01-01 | 2002-09-02 | 175d | finish no earlier than 2002-09-02 |  | T1 | 1400h | 1400h | Rel-5 | Ingbert | TP-17 |  |  |  |  |  |
| 1982 | 590.12.2 | Deleted - General changes to TS34.121 and TS34.122 corresponding to release 5 | 261d? | 2003-03-03 A | 2004-03-01 A | 100% | 2003-03-03 | 2004-03-01 | 261d? | finish no earlier than 2004-03-01 |  | T1 | 2088h | 2088h | Rel-5 | Ingbert | TP-23 | RANimp-test |  |  | 34.108, 34.121, 34.122 |  |
| 1983 | 80 | UTRAN Sharing in Connected Mode | 197d | 2001-12-03 A | 2002-09-03 A | 100% | 2001-12-03 | 2002-09-03 | 197d | finish no earlier than 2002-09-06 |  | R3 | 1576h | 1576h | Rel-5 | Juha |  | NETSHARE | Ericsson | Martin Israelsson |  |  |
| 1984 | 81 | **Provisioning of IP-based multimedia services** | 1806d | 2000-01-03 A | 2006-12-01 A | 100% | 2000-01-03 | 2006-12-01 | 1806d |  |  | S1,S2,S5,R5 | 205676h | 205676h | Rel-5 | Alain |  | IMS | Openwave | Mark Cataldo |  |  |
| 1985 | 81.1 | **Call control and roaming to support IMS in UMTS** | 1806d | 2000-01-03 A | 2006-12-01 A | 100% | 2000-01-03 | 2006-12-01 | 1806d |  |  | S2,R5 | 95312h | 95312h | Rel-5 | Maurice |  | IMS-CCR | Lucent | Liz Daniel |  |  |
| 1986 | 81.1.1 | Stage 1 | 215d | 2000-02-21 A | 2000-12-15 A | 100% | 2000-02-21 | 2000-12-15 | 215d | finish no earlier than 2000-09-21 |  | S1 | 1720h | 1720h | Rel-5 | Alain |  | IMS-CCR | Motorola | Mark Cataldo | 22.228 |  |
| 1987 | 81.1.2 | Stage 2 (Architecture and Main flows) | 246d | 2000-04-14 A | 2001-03-23 A | 100% | 2000-04-14 | 2001-03-23 | 246d | finish no earlier than 2001-03-23 |  | S2 | 1968h | 1968h | Rel-5 | Maurice |  | IMS-CCR | Lucent | Liz Daniel | 23.228 |  |
| 1988 | 81.1.3 | Impact on MM/CC/SM | 400d | 2000-08-28 A | 2002-03-08 A | 100% | 2000-08-28 | 2002-03-08 | 400d | finish no earlier than 2002-03-08 |  | N1 | 3200h | 3200h | Rel-5 | Frederic |  | IMS-CCR-IWMM | Lucent | Keith Drage (drage@alcatel-lucent.com) |  |  |

Notes:
- 1962: Marked as stopped 12/2008
- 1963: Marked as stopped 12/2008
- 1964: Marked as stopped 12/2008
- 1965: -
- 1966: -
- 1967: -
- 1968: -
- 1969: FS was closed and introduction of WI not agreed at RAN #16
- 1970: -
- 1971: -
- 1972: -
- 1973: FS was closed and WI was introduced at RAN #14
- 1974: -
- 1975: RFC 3095 context relocation
- 1976: -
- 1977: -
- 1978: RP-020356
- 1979: -
- 1980: Marked as stopped 12/2008
- 1981: Marked as stopped 12/2008
- 1982: Marked as stopped 12/2008
- 1983: Formerly 'Shared Network support in connected mode', renamed at RAN #16.
- 1984: -
- 1985: -
- 1986: Issues include e.g.: Roaming requirements, Requirements on supplementary services, Interworking requirements
- 1987: Issues include e.g.: Mobile IP, RAB selection principles, Optimized VoIP bearer mechanisms, SIP multimedia protocol
- 1988: Per 26/2-02: This is understood to be the PCO & TFT CRs which CN1 provides to TSGN #15 for approval. If this is correct understanding, then the task is 100 % complete.

| ID | WBS | Task | Duration | Start | Finish | Complete | Baseline start | Baseline finish | Baseline duration | Constraint | Deadline | Resources | Work | Actual work | Text1 | Text3 | Text4 | Text5 | Text6 | Text8 | Text10 |
| --- | --- | --- | --- | --- | --- | --- | --- | --- | --- | --- | --- | --- | --- | --- | --- | --- | --- | --- | --- | --- | --- |
| 1989 | 81.1.4 | **SIP Call Control protocol for the IMS** | 385d | 2000-10-02 A | 2002-03-22 A | 100% | 2000-10-02 | 2002-03-22 | 385d |  |  | N1 | 12320h | 12320h | IMS-CCR | 24.228, 24.229, 23.218 | Lucent | Keith Drage (drage@alcatel-lucent.com) | Rel-5 | Frederic |  |
| 1990 | 81.1.4.1 | IMS signalling flows | 385d | 2000-10-02 A | 2002-03-22 A | 100% | 2000-10-02 | 2002-03-22 | 385d | finish no earlier than 2002-03-22 |  | N1 | 3080h | 3080h | IMS-CCR | 24.228 |  |  | Rel-5 | Frederic |  |
| 1991 | 81.1.4.2 | IMS stage 3 | 385d | 2000-10-02 A | 2002-03-22 A | 100% | 2000-10-02 | 2002-03-22 | 385d | finish no earlier than 2002-03-22 |  | N1 | 3080h | 3080h | IMS-CCR | 24.229 |  |  | Rel-5 | Frederic |  |
| 1992 | 81.1.4.3 | IMS Session Handling; stage 2 | 385d | 2000-10-02 A | 2002-03-22 A | 100% | 2000-10-02 | 2002-03-22 | 385d | finish no earlier than 2002-03-22 |  | N1 | 3080h | 3080h | IMS-CCR | 23.218 |  |  | Rel-5 | Frederic |  |
| 1993 | 16.5.1 | Conformance Test Aspects – IMS Call Control | 451d | 2005-03-11 A | 2006-12-01 A | 100% | 2005-03-11 | 2006-12-01 | 451d |  | 2006-06-02 | R5 | 3608h | 3608h | IMS-CCR_Test | 34.108, 34.229-1, 34.229-2, 34.229-3 | Motorola | Jacob.John@motorola.com | Rel-5 | Ingbert | Fri 11/03/05 |
| 1994 | 81.1.4.4 | **Main IETF dependencies** | 641d | 2000-01-03 A | 2002-06-14 A | 100% | 2000-01-03 | 2002-06-14 | 641d |  |  | NP | 58048h | 58048h | IMS |  |  |  | Rel-5 | Kimmo |  |
| 1995 | 81.1.4.4.1 | IETF: RFC 3261 (Session Initiation Protocol) | 346d | 2000-11-24 A | 2002-03-22 A | 100% | 2000-11-24 | 2002-03-22 | 346d | finish no earlier than 2002-03-22 |  | N1 | 2768h | 2768h | IMS |  |  |  | Rel-5 | Frederic |  |
| 1996 | 81.1.4.4.2 | IETF: RFC 3262 (Reliability of provisional responses) | 346d | 2000-11-24 A | 2002-03-22 A | 100% | 2000-11-24 | 2002-03-22 | 346d | finish no earlier than 2002-03-22 |  | N1 | 2768h | 2768h | IMS |  |  |  | Rel-5 | Frederic |  |
| 1997 | 81.1.4.4.3 | IETF: RFC 3312 (Without COMET)(Integration of resource management and SIP) | 382d | 2000-11-24 A | 2002-05-13 A | 100% | 2000-11-24 | 2002-05-13 | 382d | finish no earlier than 2002-05-13 |  | N1 | 3056h | 3056h | IMS |  |  |  | Rel-5 | Frederic |  |
| 1998 | 81.1.4.4.4 | IETF: RFC 3323 (SIP extensions for caller identity and privacy) | 382d | 2000-11-24 A | 2002-05-13 A | 100% | 2000-11-24 | 2002-05-13 | 382d | finish no earlier than 2002-05-13 |  | N1 | 3056h | 3056h | IMS |  |  |  | Rel-5 | Frederic |  |
| 1999 | 81.1.4.4.5 | IETF: RFC 3313 (SIP extensions for media authorization) | 382d | 2000-11-24 A | 2002-05-13 A | 100% | 2000-11-24 | 2002-05-13 | 382d | finish no earlier than 2002-05-13 |  | N1 | 3056h | 3056h | IMS |  |  |  | Rel-5 | Frederic |  |
| 2000 | 81.1.4.4.6 | IETF: RFC 3265 (specific event notification) | 346d | 2000-11-24 A | 2002-03-22 A | 100% | 2000-11-24 | 2002-03-22 | 346d | finish no earlier than 2002-03-22 |  | N1 | 2768h | 2768h | IMS |  |  |  | Rel-5 | Frederic |  |
| 2001 | 81.1.4.4.7 | IETF: RFC editor Queue (refer method) | 401d | 2000-11-24 A | 2002-06-07 A | 100% | 2000-11-24 | 2002-06-07 | 401d | finish no earlier than 2002-06-07 |  | N1 | 3208h | 3208h | IMS |  |  |  | Rel-5 | Frederic |  |
| 2002 | 81.1.4.4.8 | IETF: RFC editor Queue (DHCP options for SIP servers) | 382d | 2000-11-24 A | 2002-05-13 A | 100% | 2000-11-24 | 2002-05-13 | 382d | finish no earlier than 2002-05-13 |  | N1 | 3056h | 3056h | IMS |  |  |  | Rel-5 | Frederic |  |
| 2003 | 81.1.4.4.10 | IETF: RFC 3267 (AMR and AMR WB RTP and SDP) | 346d | 2000-11-24 A | 2002-03-22 A | 100% | 2000-11-24 | 2002-03-22 | 346d | finish no earlier than 2002-03-22 |  | N1 | 2768h | 2768h | IMS |  |  |  | Rel-5 | Frederic |  |
| 2004 | 81.1.4.4.11 | IETF: RFC 3266 (IPv6 support within SDP) | 581d | 2000-01-03 A | 2002-03-22 A | 100% | 2000-01-03 | 2002-03-22 | 581d | finish no earlier than 2002-03-22 |  | N1 | 4640h | 4640h | IMS |  |  |  | Rel-5 | Frederic |  |
| 2005 | 81.1.4.4.12 | IETF: RFC 3311 (The Update method) | 382d | 2000-11-24 A | 2002-05-13 A | 100% | 2000-11-24 | 2002-05-13 | 382d | finish no earlier than 2002-05-13 |  | N1 | 3056h | 3056h | IMS |  |  |  | Rel-5 | Frederic |  |
| 2006 | 81.1.4.4.13 | IETF: RFC 3324 (Network Asserted Identity) | 382d | 2000-11-24 A | 2002-05-13 A | 100% | 2000-11-24 | 2002-05-13 | 382d | finish no earlier than 2002-05-13 |  | N1 | 3056h | 3056h | IMS |  |  |  | Rel-5 | Frederic |  |
| 2007 | 81.1.4.4.14 | IETF: RFC editor Queue (Various 3GPP Private Extensions) | 382d | 2000-11-24 A | 2002-05-13 A | 100% | 2000-11-24 | 2002-05-13 | 382d | finish no earlier than 2002-05-13 |  | N1 | 3056h | 3056h | IMS |  |  |  | Rel-5 | Frederic |  |
| 2008 | 81.1.4.5 | **Addressing** | 380d | 2000-10-09 A | 2002-03-22 A | 100% | 2000-10-09 | 2002-03-22 | 380d |  |  | S2 | 7744h | 7744h | IMS |  |  |  | Rel-5 | Maurice |  |
| 2009 | 81.1.4.5.1 | Architectural issues | 235d | 2000-10-09 A | 2001-08-31 A | 100% | 2000-10-09 | 2001-08-31 | 235d | finish no earlier than 2001-03-16 |  | S2 | 1880h | 1880h | IMS |  |  |  | Rel-5 | Maurice |  |
| 2010 | 81.1.4.5.2 | Impact on HSS | 353d | 2000-11-15 A | 2002-03-22 A | 100% | 2000-11-15 | 2002-03-22 | 353d | finish no earlier than 2002-03-22 |  | N4 | 2824h | 2824h | IMS |  |  |  | Rel-5 | Kimmo |  |
| 2011 | 81.1.4.6 | **Service Examples (Work stopped)** | 304d | 2001-04-17 A | 2002-06-14 A | 100% | 2001-04-17 | 2002-06-14 | 304d |  |  | S1 | 4864h | 4864h | IMS-Sex | 22.928 | Motorola | Mark Cataldo | Rel-5 | Alain |  |
| 2012 | 81.1.4.6.1 | IMS Framework Report (work stopped) | 304d | 2001-04-17 A | 2002-06-14 A | 100% | 2001-04-17 | 2002-06-14 | 304d | finish no earlier than 2002-06-14 |  | S1 | 2432h | 2432h | IMS-FrWk | 22.941 | SBC | Randolph Wohlert (rwohlert@tri.sbc.com) | Rel-5 | Alain |  |

Notes:
- 1989: TSGN_10 approved the change:CN1 - SA2 SIP joint meeting spotted one more place for improvement: work tasks with ID 1998 and 1278 are actually subtasks under of single CN1 WT. One WI has been approved for the CN1 WT with title "SIP Call Control protocol
- 1990: 24.228
- 1991: 24.229
- 1992: 23.218
- 1993: -
- 1994: -
- 1995: -
- 1996: -
- 1997: -
- 1998: -
- 1999: -
- 2000: -
- 2001: -
- 2002: -
- 2003: -
- 2004: -
- 2005: -
- 2006: -
- 2007: -
- 2008: -
- 2009: -
- 2010: Covered by 29.228 & 29228
- 2011: -
- 2012: -

| ID | WBS | Task | Duration | Start | Finish | Complete | Baseline start | Baseline finish | Baseline duration | Constraint | Resources | Work | Actual work | Text1 | Text4 | Text5 | Text6 | Text8 | Text3 |
| --- | --- | --- | --- | --- | --- | --- | --- | --- | --- | --- | --- | --- | --- | --- | --- | --- | --- | --- | --- |
| 2013 | 81.2 | **Access Security for IMS** | 190d | 2001-10-08 A | 2002-06-28 A | 100% | 2001-10-08 | 2002-06-28 | 190d |  | S3 | 4120h | 4120h | IMS-ASEC | Ericsson | krister.boman@emw.ericsson.se | Rel-5 | Dionisio |  |
| 2014 | 81.2.2 | IMS impacts on UICC (ISIM application) | 185d | 2001-10-08 A | 2002-06-21 A | 100% | 2001-10-08 | 2002-06-21 | 185d | finish no earlier than 2002-06-21 | T3 | 1480h | 1480h |  | Vodafone | Jeremy Norris | Rel-5 | Xavier |  |
| 2015 | 81.2.3 | SIP extensions for Integrity protection | 140d | 2001-12-17 A | 2002-06-28 A | 100% | 2001-12-17 | 2002-06-28 | 140d | finish no earlier than 2002-06-28 | N1 | 1120h | 1120h |  |  |  | Rel-5 | Frederic |  |
| 2016 | 81.3 | Security Aspects of Requirement for Network Configuration Independence | 130d | 2001-07-02 A | 2001-12-28 A | 100% | 2001-07-02 | 2001-12-28 | 130d | finish no earlier than 2001-12-28 | S3 | 1040h | 1040h | SEC1-NCI | AT&T Wireless | hugh.shieh@attws.com | Rel-5 | Dionisio |  |
| 2017 | 81.4 | Lawful interception | 410d | 2000-09-04 A | 2002-03-29 A | 100% | 2000-09-04 | 2002-03-29 | 410d | finish no earlier than 2002-03-29 | S3 | 3280h | 3280h | IMS-LI | Reg TP | berthold.wilhelm@regtp.de | Rel-5 | Dionisio | 33.106, 33.107, new 33.108 |
| 2018 | 81.5 | Charging and OAM&P for IMS | 383d | 2000-12-25 A | 2002-06-12 A | 100% | 2000-12-25 | 2002-06-12 | 383d | finish no earlier than 2002-06-12 | S5 | 3064h | 3064h | IMS-OAM | VoiceStream, Motorola |  | Rel-5 | Dionisio | 32-series |
| 2019 | 81.6 | **Multimedia codecs and protocols for conversational PS services** | 568d | 2000-07-26 A | 2002-09-27 A | 100% | 2000-07-26 | 2002-09-27 | 568d |  | S4 | 15640h | 15640h | IMS-CODEC | Toshiba, Nokia | B. Aronson (Toshiba), pasi.s.ojala@nokia.com | Rel-5 | Paolo | 26.235, 26.236 |
| 2020 | 81.6.1 | Codecs | 427d | 2000-07-26 A | 2002-03-14 A | 100% | 2000-07-26 | 2002-03-14 | 427d | finish no earlier than 2001-03-21 | S4 | 3416h | 3416h |  |  |  | Rel-5 | Paolo | 26.235, 26.236 |
| 2021 | 81.6.2 | Transport protocols | 1d | 2002-03-12 A | 2002-03-12 A | 100% | 2002-03-12 | 2002-03-12 | 1d | finish no earlier than 2002-03-12 | S4 | 8h | 8h | IMS-CODEC | Nokia | P. Ojala | Rel-5 | Paolo | 26.236 |
| 2022 | 81.6.4 | recommendation for QoS parameter values for various media types | 195d | 2001-12-31 A | 2002-09-27 A | 100% | 2001-12-31 | 2002-09-27 | 195d | finish no earlier than 2002-09-27 | S4 | 1560h | 1560h |  |  |  | Rel-5 | Paolo |  |
| 2023 | 81.6.5 | IETF: RFC 3310 (HTTP Digest Authentication using AKA) | 382d | 2000-11-24 A | 2002-05-13 A | 100% | 2000-11-24 | 2002-05-13 | 382d | finish no earlier than 2002-05-13 | N1 | 3056h | 3056h |  |  |  | Rel-5 | Frederic |  |
| 2024 | 81.6.6 | IETF: RFC 3329 (Security mechanism agreement for SIP connections) | 382d | 2000-11-24 A | 2002-05-13 A | 100% | 2000-11-24 | 2002-05-13 | 382d | finish no earlier than 2002-05-13 | N1 | 3056h | 3056h |  |  |  | Rel-5 | Frederic |  |
| 2025 | 81.7 | **SIP message compression** | 185d | 2001-09-24 A | 2002-06-07 A | 100% | 2001-09-24 | 2002-06-07 | 185d |  | S2 | 3128h | 3128h |  |  |  | Rel-5 | Maurice |  |
| 2026 | 81.7.1 | Stage 2 | 25d | 2001-09-24 A | 2001-10-26 A | 100% | 2001-09-24 | 2001-10-26 | 25d | finish no earlier than 2001-10-26 | S2 | 200h | 200h |  |  |  | Rel-5 | Maurice |  |
| 2027 | 81.7.2 | Compression signalling | 181d | 2001-09-28 A | 2002-06-07 A | 100% | 2001-09-28 | 2002-06-07 | 181d | finish no earlier than 2002-06-07 | N1 | 1448h | 1448h |  |  |  | Rel-5 | Frederic |  |
| 2028 | 81.8 | **Stage 3 description of IMS interfaces** | 383d | 2001-03-14 A | 2002-08-30 A | 100% | 2001-03-14 | 2002-08-30 | 383d |  | NP | 29531.6h | 29531.6h |  |  |  | Rel-5 | Kimmo |  |
| 2029 | 81.8.1 | Cx interface (HSS to CSCF) | 135.95d | 2001-03-14 A | 2002-06-07 A | 100% | 2001-03-14 | 2002-06-07 | 135.95d | finish no earlier than 2002-06-07 | N4 | 1087.58h | 1087.58h |  |  |  | Rel-5 | Kimmo |  |
| 2030 | 81.8.2 | Mp interface (MRFC - MRFP) enhancements | 258d | 2001-03-14 A | 2002-03-08 A | 100% | 2001-03-14 | 2002-03-08 | 258d | finish no earlier than 2002-06-07 | N4 | 2064h | 2064h |  |  |  | Rel-5 | Kimmo |  |
| 2031 | 81.8.3 | Mw interface (CSCF to P-CSCF) | 323d | 2001-03-14 A | 2002-06-07 A | 100% | 2001-03-14 | 2002-06-07 | 323d | finish no earlier than 2002-06-07 | N1 | 2584h | 2584h |  |  |  | Rel-5 | Frederic |  |
| 2032 | 81.8.4 | Mr interface (CSCF to MRF) | 273d | 2001-03-14 A | 2002-03-29 A | 100% | 2001-03-14 | 2002-03-29 | 273d | finish no earlier than 2002-03-29 | N1 | 2184h | 2184h |  |  |  | Rel-5 | Frederic |  |
| 2033 | 81.8.5 | Dx interface (I-CSCF to SLF) | 323d | 2001-03-14 A | 2002-06-07 A | 100% | 2001-03-14 | 2002-06-07 | 323d | finish no earlier than 2002-06-07 | N4 | 2584h | 2584h |  |  |  | Rel-5 | Kimmo |  |
| 2034 | 81.8.6 | Go interface (GGSN to PCF) | 323d | 2001-03-14 A | 2002-06-07 A | 100% | 2001-03-14 | 2002-06-07 | 323d | finish no earlier than 2002-06-07 | N3 | 2584h | 2584h |  |  |  | Rel-5 | Gwiho |  |
| 2035 | 81.8.7 | ISC (IMS Service Control) Interface | 323d | 2001-03-14 A | 2002-06-07 A | 100% | 2001-03-14 | 2002-06-07 | 323d | finish no earlier than 2002-06-07 | N1 | 2584h | 2584h |  |  |  | Rel-5 | Frederic |  |
| 2036 | 81.8.8 | Sh interface (HSS to AS) | 82d | 2002-02-14 A | 2002-06-07 A | 100% | 2002-02-14 | 2002-06-07 | 82d | finish no earlier than 2002-06-07 | N4 | 656h | 656h |  |  |  | Rel-5 | Kimmo |  |
| 2037 | 81.8.9 | Si interface (HSS to IM-SSF) | 162.5d | 2002-01-16 A | 2002-08-30 A | 100% | 2002-01-16 | 2002-08-30 | 162.5d | finish no earlier than 2002-06-07 | N4 | 1300h | 1300h |  |  |  | Rel-5 | Kimmo |  |
| 2038 | 81.8.10 | Gm interface (UE to CSCF) | 323d | 2001-03-14 A | 2002-06-07 A | 100% | 2001-03-14 | 2002-06-07 | 323d | finish no earlier than 2002-06-07 | N1 | 2584h | 2584h |  |  |  | Rel-5 | Frederic |  |
| 2039 | 81.8.11 | Mi interface (CSCF to BGCF) | 323d | 2001-03-14 A | 2002-06-07 A | 100% | 2001-03-14 | 2002-06-07 | 323d | finish no earlier than 2002-06-07 | N1 | 2584h | 2584h |  |  |  | Rel-5 | Frederic |  |
| 2040 | 81.8.12 | Mj interface (BGCF to MGCF) | 323d | 2001-03-14 A | 2002-06-07 A | 100% | 2001-03-14 | 2002-06-07 | 323d | finish no earlier than 2002-06-07 | N1 | 2584h | 2584h |  |  |  | Rel-5 | Frederic |  |
| 2041 | 81.8.13 | Mk interface (BGCF to BGCF) | 323d | 2001-03-14 A | 2002-06-07 A | 100% | 2001-03-14 | 2002-06-07 | 323d | finish no earlier than 2002-06-07 | N1 | 2584h | 2584h |  |  |  | Rel-5 | Frederic |  |
| 2042 | 81.9 | Support of VHE/OSA by entities and protocols of the IMS (e.g. CSCF) | 186d | 2001-09-21 A | 2002-06-07 A | 100% | 2001-09-21 | 2002-06-07 | 186d | finish no earlier than 2002-06-07 | N5 | 1488h | 1488h | IMS-ONOSA | Ericsson | Ard.Jan.Moerdijk@eln.ericsson.se | Rel-5 | Kimmo | 29.198, 29.998 |

Notes:
- 2013: TS33.203 will be presented for info at SP#14 and is scheduled for approval at SP#15. Dependencies on IETF exist. Approved SP#15
- 2014: -
- 2015: Per 26/2-02: CN1 is not aware of any requirements and is not doing anything on this task.
- 2016: Incorporated into IMS access security TS (33.203) which will be presented for info at SP#14 and is scheduled for approval at SP#15.Editors notes removed SP#16&17
- 2017: SA#17 completed
- 2018: -
- 2019: -
- 2020: -
- 2021: -
- 2022: -
- 2023: -
- 2024: -
- 2025: -
- 2026: -
- 2027: -
- 2028: -
- 2029: -
- 2030: [DAB 08-03-02] - No work required in CN4
- 2031: -
- 2032: -
- 2033: CN4#11 30/11/01: No inputs received in CN4 / 14/02/02 Completed(introduced in 29.228)
- 2034: [DAB - 23/05/03] - 100 % complete
- 2035: -
- 2036: CN4#11 30/11/01: No inputs received in CN4 / CN4#12bis 14/02/02: WID approved / 17th May 100% complete. 3GPP TS 29.329 will be sent for approval in CN#16
- 2037: SA16: Part of Rel5 only if completed in September 02. Marked as closed 12/2008 (was marked 72% complete)
- 2038: -
- 2039: -
- 2040: -
- 2041: -
- 2042: -

| ID | WBS | Task | Duration | Start | Finish | Predecessors | Complete | Baseline start | Baseline finish | Baseline duration | Constraint | Resources | Work | Actual work | Text1 | Text4 | Text5 | Text6 | Text8 | Text12 | Text3 |
| --- | --- | --- | --- | --- | --- | --- | --- | --- | --- | --- | --- | --- | --- | --- | --- | --- | --- | --- | --- | --- | --- |
| 2043 | 81.10 | **CAMEL control of IMS services** | 365d | 2001-04-16 A | 2002-09-06 A |  | 100% | 2001-04-16 | 2002-09-06 | 365d |  | N2 | 9952h | 9952h | IMS-CAMEL | Lucent | Angelica Remoquillo | Rel-5 | Kimmo |  |  |
| 2044 | 81.10.1 | Stage2 work 'general' | 365d | 2001-04-16 A | 2002-09-06 A |  | 100% | 2001-04-16 | 2002-09-06 | 365d | finish no earlier than 2002-09-06 | N2 | 2920h | 2920h |  |  |  | Rel-5 | Kimmo |  |  |
| 2045 | 81.10.2 | Stage3 work 'CAP' | 175d | 2002-01-07 A | 2002-09-06 A |  | 100% | 2002-01-07 | 2002-09-06 | 175d | finish no earlier than 2002-09-06 | N2 | 1400h | 1400h |  |  |  | Rel-5 | Kimmo |  |  |
| 2046 | 81.10.3 | Stage2 work 'Si interface' | 175d | 2002-01-07 A | 2002-09-06 A |  | 100% | 2002-01-07 | 2002-09-06 | 175d | finish no earlier than 2002-09-06 | N2 | 1400h | 1400h |  |  |  | Rel-5 | Kimmo |  |  |
| 2047 | 81.10.4 | Stage3 work 'Si interface' | 82d | 2002-02-14 A | 2002-06-07 A |  | 100% | 2002-02-14 | 2002-06-07 | 82d | finish no earlier than 2002-06-07 | N4 | 656h | 656h |  |  |  | Rel-5 | Kimmo |  |  |
| 2048 | 81.10.5 | Deleted - SDM issues for CAMEL control of IMS | 82d | 2002-02-14 A | 2002-06-07 A |  | 100% | 2002-02-14 | 2002-06-07 | 82d | finish no earlier than 2002-06-07 | N4 | 656h | 656h |  |  |  | Rel-5 | Kimmo | NP-17 |  |
| 2049 | 81.11 | Pre-pay/real-time charging in IMS | 196d | 2001-06-15 A | 2002-03-15 A |  | 100% | 2001-06-15 | 2002-03-15 | 196d | finish no earlier than 2002-03-15 | S1 | 1568h | 1568h |  |  |  | Rel-5 | Alain |  |  |
| 2050 | 81.12 | **Charging** | 289d | 2001-08-06 A | 2002-09-12 A |  | 100% | 2001-08-06 | 2002-09-12 | 289d |  | S2,S5 | 6632h | 6632h | OAM-CH | T-Mobile | karl-heinz.nenner@t-mobile.de | Rel-5 | Dionisio |  | 32.225 |
| 2051 | 81.12.1 | Charging Implications of IMS architecture | 75d | 2001-08-06 A | 2001-11-16 A |  | 100% | 2001-08-06 | 2001-11-16 | 75d | finish no earlier than 2001-11-16 | S2 | 600h | 600h |  |  |  | Rel-5 | Maurice |  |  |
| 2052 | 81.12.2 | Charging management for IMS (off-line & on-line) | 214d | 2001-11-19 A | 2002-09-12 A | 2051 | 100% | 2001-11-19 | 2002-09-12 | 214d | finish no earlier than 2002-09-12 | S5 | 1712h | 1712h | OAM-CH |  |  | Rel-5 | Dionisio |  | 32.225 |
| 2053 | 86.1.6.10 | Billing, accounting and call detail record aspects | 251d | 2001-09-27 A | 2002-09-12 A |  | 100% | 2001-09-27 | 2002-09-12 | 251d | finish no earlier than 2002-09-12 | S5 | 2008h | 2008h | OAM-CH | T-Mobile | Karl-Heinz.Nenner@T-MOBILE.DE | Rel-5 | Dionisio |  | 32.225 |
| 2054 | 81.13 | **Other IETF dependencies** | 401d | 2000-11-24 A | 2002-06-07 A |  | 100% | 2000-11-24 | 2002-06-07 | 401d |  | NP | 9624h | 9624h |  |  |  | Rel-5 |  |  |  |
| 2055 | 81.13.1 | IETF: draft-ietf-aaa-diameter - should be CN4 | 401d | 2000-11-24 A | 2002-06-07 A |  | 100% | 2000-11-24 | 2002-06-07 | 401d | finish no earlier than 2002-06-07 | NP | 3208h | 3208h |  |  |  | Rel-5 |  |  |  |
| 2056 | 81.13.2 | IETF: draft-johansson-aaa-diameter-mm-app - should be CN4 | 401d | 2000-11-24 A | 2002-06-07 A |  | 100% | 2000-11-24 | 2002-06-07 | 401d | finish no earlier than 2002-06-07 | NP | 3208h | 3208h |  |  |  | Rel-5 |  |  |  |
| 2057 | 81.15 | Conformance Test Aspects - Provisioning of IMS | 205d | 2002-03-18 A | 2002-12-27 A |  | 100% | 2002-03-18 | 2002-12-27 | 205d | finish no earlier than 2002-12-27 | T1 | 1640h | 1640h | IMS-TEST |  |  | Rel-5 | Ingbert |  |  |
| 2058 | 81.16 | Testing of support for IMS - prose | 270d | 2002-09-18 A | 2003-09-30 A |  | 100% | 2002-09-18 | 2003-09-30 | 270d | finish no earlier than 2003-09-30 | T1 | 2160h | 2160h |  | Anritsu | dan.fox@eu.anritsu.com | Rel-5 | Ingbert |  | 34.108, 34.123 |
| 2059 | 81.17 | Testing of support for IMS - TTCN | 381d | 2002-09-18 A | 2004-03-03 A |  | 100% | 2002-09-18 | 2004-03-03 | 381d | finish no earlier than 2004-03-03 | T1 | 3048h | 3048h |  | Anritsu | dan.fox@eu.anritsu.com | Rel-5 | Ingbert |  | 34.108, 34.123 |
| 2060 | 82 | **Extended Transparent End-to-End PS Streaming Service** | 313d? | 2002-01-03 A | 2003-03-17 A |  | 100% | 2002-01-03 | 2003-03-17 | 313d? |  | S4 | 6224h | 6224h | PSS-E | Ericsson | olle.franceschi@ericsson.com | Rel-5 | Paolo |  | 26.233, 26.234 |
| 2061 | 82.1 | **Stage 1** | 86d? | 2002-11-18 A | 2003-03-17 A |  | 100% | 2002-11-18 | 2003-03-17 | 86d? |  | S1 | 1376h | 1376h |  | Vodafone | stephen.wolak@vodafone.com | Rel-5 | Alain |  | 22.233 |
| 2062 | 593.1.1 | Interaction with other services | 86d? | 2002-11-18 A | 2003-03-17 A |  | 100% | 2002-11-18 | 2003-03-17 | 86d? | finish no earlier than 2003-03-17 | S1 | 688h | 688h |  | Vodafone | stephen.wolak@vodafone.com | Rel-5 | Alain |  | 22.233 |
| 2063 | 82.2 | Stage 2 (version Rel5 of TS 26.234) | 51d | 2002-01-03 A | 2002-03-14 A |  | 100% | 2002-01-03 | 2002-03-14 | 51d | finish no earlier than 2002-03-26 | S4 | 408h | 408h |  |  |  | Rel-5 | Paolo |  | 26.234 |
| 2064 | 82.3 | RTP usage model | 242d | 2002-01-03 A | 2002-12-06 A |  | 100% | 2002-01-03 | 2002-12-06 | 242d | finish no earlier than 2002-12-06 | S4 | 1936h | 1936h |  |  |  | Rel-5 | Paolo |  | 26.937 |
| 2065 | 83 | **Rel-5 OSA enhancements** | 955d | 1999-04-27 A | 2002-12-20 A |  | 100% | 1999-04-27 | 2002-12-20 | 955d |  | S1 | 62480h | 62480h | OSA1 | Siemens | Joerg Swetina (joerg.swetina@nw.neclab.eu) | Rel-5 | Alain |  | 22.127, 23.127, 29.198-x, 29.998-x |
| 2066 | 83.1 | General Stage 2 for Rel5 | 194d | 2001-09-11 A | 2002-06-07 A |  | 100% | 2001-09-11 | 2002-06-07 | 194d |  | S2 | 1232h | 1232h |  |  |  | Rel-5 | Maurice |  |  |

Notes:
- 2043: -
- 2044: DAB 12.12.01 split into cn4 and cn2 parts
- 2045: DAB 12.12.01 split into cn4 and cn2 parts
- 2046: DAB 12.12.01 split into cn4 and cn2 parts
- 2047: [DAB 08-03-02] - UID 12004 is MASTER of UID 14998 / 17 May need to be recearch possible impact on 23.008 & 23.016, changes to 29.002 are done.
- 2048: Marked as stopped 12/2008
- 2049: Marked as closed 12/2008 (was marked 60% complete)
- 2050: -
- 2051: -
- 2052: -
- 2053: -
- 2054: Was introduced at SP#13 by Ileana Leuca (exact position in the WP and related WG have to be defined)
- 2055: Marked as closed 12/2008 (was marked 90% complete)
- 2056: Marked as closed 12/2008 (was marked 50% complete)
- 2057: The task is a building block, individual work items are being considered but are constrained by lack of supporting companies. Marked as stopped 12/2008
- 2058: Marked as stopped 12/2008
- 2059: Marked as stopped 12/2008
- 2060: -
- 2061: 2nd resp SA4
- 2062: 2nd resp SA4. Marked as closed 12/2008 (was marked 65% complete)
- 2063: 2nd resp SA2
- 2064: Marked as closed 12/2008 (was marked 90% complete)
- 2065: -
- 2066: Marked as closed 12/2008 (was marked 47% complete)

| ID | WBS | Task | Duration | Start | Finish | Predecessors | Complete | Baseline start | Baseline finish | Baseline duration | Constraint | Resources | Work | Actual work | Text1 | Text6 | Text8 | Text3 | Text4 | Text5 |
| --- | --- | --- | --- | --- | --- | --- | --- | --- | --- | --- | --- | --- | --- | --- | --- | --- | --- | --- | --- | --- |
| 2067 | 83.2 | **OSA APIs for Multimedia Call Control** | 499d | 2000-07-11 A | 2002-06-07 A |  | 100% | 2000-07-11 | 2002-06-07 | 499d |  | S2 | 5960h | 5960h | OSA1-CSCF | Rel-5 | Maurice |  |  |  |
| 2068 | 83.2.1 | Stage 1 | 438d | 2000-07-11 A | 2002-03-14 A |  | 100% | 2000-07-11 | 2002-03-14 | 438d | finish no earlier than 2002-03-14 | S1 | 3504h | 3504h |  | Rel-5 | Alain | 22.127 | Siemens | Manfred.leitgeb@siemens.at |
| 2069 | 83.2.2 | Multimedia Call Control - Stages 2 and 3 | 194d | 2001-09-11 A | 2002-06-07 A |  | 100% | 2001-09-11 | 2002-06-07 | 194d | finish no earlier than 2002-06-07 | N5 | 1552h | 1552h |  | Rel-5 | Kimmo | 29.198-04 |  |  |
| 2070 | 83.3 | Generic user interaction - Stage 3 | 194d | 2001-09-11 A | 2002-06-07 A |  | 100% | 2001-09-11 | 2002-06-07 | 194d | finish no earlier than 2002-06-07 | N5 | 1552h | 1552h |  | Rel-5 | Kimmo | 29.198-05 |  |  |
| 2071 | 83.4 | Charging - Stage 3 | 194d | 2001-09-11 A | 2002-06-07 A |  | 100% | 2001-09-11 | 2002-06-07 | 194d | finish no earlier than 2002-06-07 | N5 | 1552h | 1552h |  | Rel-5 | Kimmo | 29.198-12 |  |  |
| 2072 | 83.5 | Call Control Service Mapping; Multiparty Call Control SIP - Stage 3 | 194d | 2001-09-11 A | 2002-06-07 A |  | 100% | 2001-09-11 | 2002-06-07 | 194d | finish no earlier than 2002-06-07 | N5 | 1552h | 1552h |  | Rel-5 | Kimmo | 29.998-04-4 |  |  |
| 2073 | 83.6 | WSDL APIs for SOAP/HTTP - Stage 3 | 455d | 2000-09-11 A | 2002-06-07 A |  | 100% | 2000-09-11 | 2002-06-07 | 455d | finish no earlier than 2002-06-07 | N5 | 3640h | 3640h |  | Rel-5 | Kimmo | 29.198, 29.998 |  |  |
| 2074 | 83.7 | **OSA security** | 639d | 2000-07-11 A | 2002-12-20 A |  | 100% | 2000-07-11 | 2002-12-20 | 639d |  | S3 | 15000h | 15000h | OSA1-SEC | Rel-5 | Dionisio |  | BT | colin.blanchard@bt.com |
| 2075 | 83.7.1 | Stage 1 | 349d | 2000-07-11 A | 2001-11-09 A |  | 100% | 2000-07-11 | 2001-11-09 | 349d | finish no earlier than 2001-11-09 | S1 | 2792h | 2792h |  | Rel-5 | Alain | 22.127 | Siemens | Manfred.leitgeb@siemens.at |
| 2076 | 83.7.2 | Stage 3 | 430d | 2000-10-23 A | 2002-06-14 A |  | 100% | 2000-10-23 | 2002-06-14 | 430d | finish no earlier than 2002-06-14 | S3 | 3440h | 3440h |  | Rel-5 | Dionisio |  |  |  |
| 2077 | 83.7.3 | security related SCF(s) definition | 186d | 2001-09-21 A | 2002-06-07 A |  | 100% | 2001-09-21 | 2002-06-07 | 186d | finish no earlier than 2002-06-07 | N5 | 1488h | 1488h |  | Rel-5 | Kimmo | 29.198, 29.998 | Ericsson | Ard.Jan.Moerdijk@eln.ericsson.se |
| 2078 | 83.7.4 | changes required from supporting platforms, e.g. gsmSCF, HLR | 69d | 2000-09-11 A | 2000-12-14 A |  | 100% | 2000-09-11 | 2000-12-14 | 69d | finish no earlier than 2000-12-14 | S3 | 552h | 552h |  | Rel-5 | Dionisio |  |  |  |
| 2079 | 594.7.5 | Security (moved from Rel-6) | 202d | 2002-03-14 A | 2002-12-20 A |  | 100% | 2002-03-14 | 2002-12-20 | 202d | finish no earlier than 2002-12-20 | S3 | 1616h | 1616h |  | Rel-5 | Dionisio |  |  |  |
| 2080 | 83.8 | **Interactions OSA - e-commerce** | 815d | 1999-04-27 A | 2002-06-07 A |  | 100% | 1999-04-27 | 2002-06-07 | 815d |  | S2 | 6152h | 6152h | OSA1-ECOM | Rel-5 | Maurice |  |  |  |
| 2081 | 83.8.1 | Stage 1 | 439d | 1999-04-27 A | 2000-12-28 A |  | 100% | 1999-04-27 | 2000-12-28 | 439d | finish no earlier than 2000-12-28 | S1 | 3504h | 3504h |  | Rel-5 | Alain | 22.127 | Siemens | Joerg Swetina (joerg.swetina@nw.neclab.eu) |
| 2082 | 83.8.2 | Stages 2 and 3 | 186d | 2001-09-21 A | 2002-06-07 A |  | 100% | 2001-09-21 | 2002-06-07 | 186d | finish no earlier than 2002-06-07 | N5 | 1488h | 1488h |  | Rel-5 | Kimmo | 29.198, 29.998 | Ericsson | Ard.Jan.Moerdijk@eln.ericsson.se |
| 2083 | 83.9 | Policy Management - Stage 3 | 194d | 2001-09-11 A | 2002-06-07 A |  | 100% | 2001-09-11 | 2002-06-07 | 194d | finish no earlier than 2002-06-07 | N5 | 1552h | 1552h |  | Rel-5 | Kimmo | 29.198-13 |  |  |
| 2084 | 83.10 | Presence and Availability Management (PAM) - Stage 3 | 194d | 2001-09-11 A | 2002-06-07 A |  | 100% | 2001-09-11 | 2002-06-07 | 194d | finish no earlier than 2002-06-07 | N5 | 1552h | 1552h |  | Rel-5 | Kimmo | 29.198-14 |  |  |
| 2085 | 83.11 | **CHECK STATUS - LCS - OSA interfaces** | 455d | 2000-09-11 A | 2002-06-07 A |  | 100% | 2000-09-11 | 2002-06-07 | 455d |  | S1 | 5656h | 5656h | OSA1-LCSI | Rel-5 | Alain |  | Siemens | Joerg Swetina (joerg.swetina@nw.neclab.eu) |
| 2086 | 83.11.1 | Stage 1 | 65d | 2000-09-11 A | 2000-12-08 A |  | 100% | 2000-09-11 | 2000-12-08 | 65d | finish no earlier than 2000-12-08 | S1 | 520h | 520h |  | Rel-5 | Alain | 22.127 | Siemens | Joerg Swetina (joerg.swetina@nw.neclab.eu) |
| 2087 | 83.11.2 | Stage 2 | 1d | 2000-12-11 A | 2000-12-11 A | 2086 | 100% | 2000-12-11 | 2000-12-11 | 1d | finish no earlier than 2000-12-11 | S2 | 8h | 8h |  | Rel-5 | Maurice | 23.127 | Ericsson | Christophe GOURRAUD |
| 2088 | 83.11.3 | Stage 3 | 186d | 2001-09-21 A | 2002-06-07 A | 2087 | 100% | 2001-09-21 | 2002-06-07 | 186d | finish no earlier than 2002-06-07 | N5 | 1488h | 1488h |  | Rel-5 | Kimmo | 29.198, 29.998 | Ericsson | Ard.Jan.Moerdijk@eln.ericsson.se |
| 2089 | 594.12 | Access to User Profile | 145d | 2001-06-01 A | 2001-12-20 A |  | 100% | 2001-06-01 | 2001-12-20 | 145d | finish no earlier than 2001-12-20 | S1 | 1160h | 1160h | OSA2-UP | Rel-5 | Alain |  |  |  |
| 2090 | 594.13 | **Retrieval of Terminal capabilities** | 634d | 2000-07-11 A | 2002-12-13 A |  | 100% | 2000-07-11 | 2002-12-13 | 634d |  | S2 | 10808h | 10808h | OSA2-TC | Rel-5 | Maurice |  |  |  |
| 2091 | 594.13.1 | Stage 1 | 132d | 2000-07-11 A | 2001-01-10 A |  | 100% | 2000-07-11 | 2001-01-10 | 132d | finish no earlier than 2001-01-10 | S1 | 1056h | 1056h |  | Rel-5 | Alain | 22.127 | Siemens | Joerg Swetina (joerg.swetina@nw.neclab.eu) |
| 2092 | 594.13.2 | Stages 2 and 3 | 321d | 2001-09-21 A | 2002-12-13 A | 2091 | 100% | 2001-09-21 | 2002-12-13 | 321d | finish no earlier than 2002-12-13 | N5 | 2568h | 2568h |  | Rel-5 | Kimmo | 29.198, 29.998 | Ericsson | Ard.Jan.Moerdijk@eln.ericsson.se |
| 2093 | 594.13.3 | Provisioning of the terminal capabilities | 445d | 2001-04-02 A | 2002-12-13 A |  | 100% | 2001-04-02 | 2002-12-13 | 445d | finish no earlier than 2002-12-13 | T2 | 3560h | 3560h |  | Rel-5 |  | 23.057 |  |  |

Notes:
- 2067: For Rel5 even if completed by March
- 2068: -
- 2069: -
- 2070: -
- 2071: -
- 2072: -
- 2073: -
- 2074: CR to correct security specifications in 29.198 scheduled for approval at CN#15
- 2075: -
- 2076: Marked as closed 12/2008 (was marked 80% complete)
- 2077: -
- 2078: -
- 2079: Contribution at S3#25
- 2080: -
- 2081: Marked as closed 12/2008 (was marked 95% complete)
- 2082: -
- 2083: -
- 2084: -
- 2085: az: CN#13 - changed to Rel5
- 2086: -
- 2087: az 24/05/01: Rel4 completion 90->100%.
- 2088: -
- 2089: -
- 2090: -
- 2091: -
- 2092: -
- 2093: According to T2 SWG1 M. Cataldo this is automatically supported by the MExE support of UAProf therefore 100% complete

| ID | WBS | Task | Duration | Start | Finish | Predecessors | Complete | Baseline start | Baseline finish | Baseline duration | Constraint | Resources | Work | Actual work | Text1 | Text4 | Text5 | Text6 | Text8 | Text3 |
| --- | --- | --- | --- | --- | --- | --- | --- | --- | --- | --- | --- | --- | --- | --- | --- | --- | --- | --- | --- | --- |
| 2094 | 84 | **CAMEL phase 4** | 625d | 2000-04-17 A | 2002-09-06 A |  | 100% | 2000-04-17 | 2002-09-06 | 625d |  | S1 | 41104h | 41104h | CAMEL4 | Nokia | keijo.palviainen@nokia.com | Rel-5 | Alain |  |
| 2095 | 84.1 | Service requirements | 565d | 2000-04-17 A | 2002-06-14 A |  | 100% | 2000-04-17 | 2002-06-14 | 565d | finish no earlier than 2002-06-14 | S1 | 4520h | 4520h |  |  |  | Rel-5 | Alain |  |
| 2096 | 84.2 | Call Party Handling | 500d | 2000-07-10 A | 2002-06-07 A |  | 100% | 2000-07-10 | 2002-06-07 | 500d | finish no earlier than 2002-06-07 | N2 | 4000h | 4000h | CAMEL4-CPH |  |  | Rel-5 | Kimmo |  |
| 2097 | 84.3 | Mid call procedure for MO and MT calls | 495d | 2000-07-17 A | 2002-06-07 A |  | 100% | 2000-07-17 | 2002-06-07 | 495d | finish no earlier than 2002-06-07 | N2 | 3960h | 3960h | CAMEL4-MCP |  |  | Rel-5 | Kimmo |  |
| 2098 | 84.4 | Interactions with Optimal Routing | 430d | 2000-07-17 A | 2002-03-08 A |  | 100% | 2000-07-17 | 2002-03-08 | 430d | finish no earlier than 2002-03-08 | N2 | 3440h | 3440h | CAMEL4-IOR |  |  | Rel-5 | Kimmo |  |
| 2099 | 84.5 | Inclusion of flexible tone injection | 430d | 2000-07-17 A | 2002-03-08 A |  | 100% | 2000-07-17 | 2002-03-08 | 430d | finish no earlier than 2002-03-08 | N2 | 3440h | 3440h | CAMEL4-IFTI |  |  | Rel-5 | Kimmo |  |
| 2100 | 84.6 | CSE control over MT SMS | 430d | 2000-07-17 A | 2002-03-08 A |  | 100% | 2000-07-17 | 2002-03-08 | 430d | finish no earlier than 2002-03-08 | N2 | 3440h | 3440h | CAMEL4-CCSMS |  |  | Rel-5 | Kimmo |  |
| 2101 | 84.7 | Notification of GPRS mobility management to CSE | 331d | 2001-03-02 A | 2002-06-07 A |  | 100% | 2001-03-02 | 2002-06-07 | 331d | finish no earlier than 2002-06-07 | N2 | 2648h | 2648h | CAMEL4-NMM |  |  | Rel-5 | Kimmo |  |
| 2102 | 84.8 | Provision of location information of called subscriber | 266d | 2001-03-02 A | 2002-03-08 A |  | 100% | 2001-03-02 | 2002-03-08 | 266d | finish no earlier than 2002-03-08 | N2 | 2128h | 2128h | CAMEL4-LOCB |  |  | Rel-5 | Kimmo |  |
| 2103 | 84.9 | Inclusion of ODB data in the CSE_HLR interface | 175d | 2001-07-09 A | 2002-03-08 A |  | 100% | 2001-07-09 | 2002-03-08 | 175d | finish no earlier than 2002-03-08 | N2 | 1400h | 1400h | CAMEL4-ODB |  |  | Rel-5 | Kimmo |  |
| 2104 | 84.10 | Location information during an ongoing call (Handover DP) | 280d | 2001-05-14 A | 2002-06-07 A |  | 100% | 2001-05-14 | 2002-06-07 | 280d | finish no earlier than 2002-06-07 | N2 | 2240h | 2240h | CAMEL4-HODP |  |  | Rel-5 | Kimmo |  |
| 2105 | 84.11 | GPRS Any Time Interrogation | 240d | 2001-07-09 A | 2002-06-07 A |  | 100% | 2001-07-09 | 2002-06-07 | 240d | finish no earlier than 2002-06-07 | N2 | 1920h | 1920h | CAMEL4-ATI |  |  | Rel-5 | Kimmo |  |
| 2106 | 84.12 | Transfer of IMEI (with SW version) to CSE | 240d | 2001-07-09 A | 2002-06-07 A |  | 100% | 2001-07-09 | 2002-06-07 | 240d | finish no earlier than 2002-06-07 | N2 | 1920h | 1920h | CAMEL4-ATI |  |  | Rel-5 | Kimmo |  |
| 2107 | 84.13 | Handling of partial implementations of CAMEL4 | 131d | 2002-03-08 A | 2002-09-06 A |  | 100% | 2002-03-08 | 2002-09-06 | 131d | finish no earlier than 2002-06-07 | N2 | 1048h | 1048h | CAMEL4-SUB |  |  | Rel-5 | Kimmo |  |
| 2108 | 85 | **Rel-5 MExE enhancements** | 250d | 2001-03-26 A | 2002-03-08 A |  | 100% | 2001-03-26 | 2002-03-08 | 250d |  | T2 | 2880h | 2880h | MEXE5 |  |  | Rel-5 | Kimmo |  |
| 2109 | 85.1 | MExE Rel-5 Improvements and Investigations | 110d | 2001-03-26 A | 2002-03-08 A |  | 100% | 2001-03-26 | 2002-03-08 | 110d | finish no earlier than 2001-12-17 | T2 | 880h | 880h | MEXE5-ENHANC | Motorola | Mark Cataldo | Rel-5 | Kimmo | 22.057, 23.057 |
| 2110 | 86 | **Wideband Telephony Service - AMR** | 1036d | 2000-01-01 A | 2003-12-19 A |  | 100% | 2000-01-01 | 2003-12-19 | 1036d |  | S4 | 81496h | 81496h | AMRWB | Siemens | Imre.Varga@mch.siemens.de | Rel-5 | Paolo |  |
| 2111 | 86.1 | **Specification** | 636d | 2000-01-01 A | 2002-06-07 A |  | 100% | 2000-01-01 | 2002-06-07 | 636d |  | S4 | 19984h | 19984h |  |  |  | Rel-5 | Paolo |  |
| 2112 | 86.1.1 | Stage 1 | 125d | 2001-10-01 A | 2002-03-22 A |  | 100% | 2001-10-01 | 2002-03-22 | 125d | finish no earlier than 2002-03-22 | S1 | 1000h | 1000h |  |  |  | Rel-5 | Alain |  |
| 2113 | 86.1.2 | **Stage 2** | 77d | 2000-01-03 A | 2000-04-17 A |  | 100% | 2000-01-03 | 2000-04-17 | 77d |  | S4 | 1232h | 1232h |  |  |  | Rel-5 | Paolo |  |
| 2114 | 86.1.2.1 | Design Constraints | 27d | 2000-01-03 A | 2000-02-07 A |  | 100% | 2000-01-03 | 2000-02-07 | 27d |  | S4 [96.3%] | 208h | 208h |  |  |  | Rel-5 | Paolo |  |
| 2115 | 86.1.2.2 | General Description | 51d | 2000-02-07 A | 2000-04-17 A | 2114 | 100% | 2000-02-07 | 2000-04-17 | 51d | start no earlier than 2000-09-25 | S4 | 408h | 408h |  |  |  | Rel-5 | Paolo |  |
| 2116 | 86.1.3 | Feasibility Study | 26d | 2000-04-28 A | 2000-06-02 A | 2115 | 100% | 2000-04-28 | 2000-06-02 | 26d | finish no earlier than 2000-06-02 | S4 | 208h | 208h |  |  |  | Rel-5 | Paolo | 26.901 |
| 2117 | 86.1.4 | N1 Aspects | 66d | 2001-09-21 A | 2001-12-21 A |  | 100% | 2001-09-21 | 2001-12-21 | 66d | finish no earlier than 2001-12-21 | N1 | 528h | 528h |  |  |  | Rel-5 | Frederic |  |
| 2118 | 86.1.5 | N4 work | 83d | 2002-02-13 A | 2002-06-07 A |  | 100% | 2002-02-13 | 2002-06-07 | 83d | finish no earlier than 2002-06-07 | N4 | 664h | 664h |  |  |  | Rel-5 | Kimmo |  |

Notes:
- 2094: -
- 2095: -
- 2096: -
- 2097: -
- 2098: -
- 2099: -
- 2100: -
- 2101: -
- 2102: -
- 2103: Added on May 29, 2001
- 2104: -
- 2105: -
- 2106: -
- 2107: stage2 and stage3 CRs for approval at CN#17
- 2108: -
- 2109: -
- 2110: -
- 2111: -
- 2112: -
- 2113: -
- 2114: -
- 2115: -
- 2116: S4,TD SP-000024: TR 26.901 v.4.0.0
- 2117: Some of N1 tasks: Indication of supported codecs by the MS, Bearer cap negociation, codec indication to MS... / One common set of codec negotiation procedures will be specified as in ID1657.
- 2118: CN4#11 30/11/01: No inputs to CN4 at this meeting / 14/02/02 work started 50% reached / 17 May work is done 100%

| ID | WBS | Task | Duration | Start | Finish | Predecessors | Complete | Baseline start | Baseline finish | Baseline duration | Constraint | Resources | Work | Actual work | Text6 | Text8 | Text1 | Text3 | Text12 | Text4 | Text5 |
| --- | --- | --- | --- | --- | --- | --- | --- | --- | --- | --- | --- | --- | --- | --- | --- | --- | --- | --- | --- | --- | --- |
| 2119 | 86.1.6 | **Codec issues** | 636d | 2000-01-03 A | 2002-06-07 A |  | 100% | 2000-01-03 | 2002-06-07 | 636d |  | S4 | 9496h | 9496h | Rel-5 | Paolo |  |  |  |  |  |
| 2120 | 86.1.6.1 | Codec qualification | 86d | 2000-02-02 A | 2000-05-31 A |  | 100% | 2000-02-02 | 2000-05-31 | 86d | finish no earlier than 2000-05-31 | S4 | 688h | 688h | Rel-5 | Paolo |  |  |  |  |  |
| 2121 | 86.1.6.2 | Codec selection tests | 102d | 2000-06-01 A | 2000-10-20 A | 2120 | 100% | 2000-06-01 | 2000-10-20 | 102d | finish no earlier than 2000-10-20 | S4 | 816h | 816h | Rel-5 | Paolo |  |  |  |  |  |
| 2122 | 86.1.6.3 | Codec selection | 5d | 2000-10-23 A | 2000-10-27 A | 2121 | 100% | 2000-10-23 | 2000-10-27 | 5d | finish no earlier than 2000-10-27 | S4 | 40h | 40h | Rel-5 | Paolo |  |  |  |  |  |
| 2123 | 86.1.6.4 | TFO AMR-WB | 63d | 2001-12-18 A | 2002-03-14 A |  | 100% | 2001-12-18 | 2002-03-14 | 63d | finish no earlier than 2002-03-14 | S4 | 504h | 504h | Rel-5 | Paolo | AMRWB-TFO |  |  |  |  |
| 2124 | 86.1.6.5 | Other codec issues (verif., characterization) | 441d | 2000-09-29 A | 2002-06-07 A |  | 100% | 2000-09-29 | 2002-06-07 | 441d | finish no earlier than 2002-06-07 | S4 | 3528h | 3528h | Rel-5 | Paolo |  | 26.976 |  |  |  |
| 2125 | 86.1.6.6 | AMR-WB and narrrowband interworking | 121d | 2001-09-27 A | 2002-03-14 A |  | 100% | 2001-09-27 | 2002-03-14 | 121d | finish no earlier than 2002-03-14 | S4 | 968h | 968h | Rel-5 | Paolo | AMRWB-IWG |  |  |  |  |
| 2126 | 86.1.6.7 | Interworking with fixed broadband networks | 121d | 2001-09-27 A | 2002-03-14 A |  | 100% | 2001-09-27 | 2002-03-14 | 121d | finish no earlier than 2002-03-14 | S4 | 968h | 968h | Rel-5 | Paolo |  |  |  |  |  |
| 2127 | 86.1.6.8 | Tones and announcements | 121d | 2001-09-27 A | 2002-03-14 A |  | 100% | 2001-09-27 | 2002-03-14 | 121d | finish no earlier than 2002-03-14 | S4 | 968h | 968h | Rel-5 | Paolo |  |  |  |  |  |
| 2128 | 86.1.6.9 | Deleted - WB Conferencing and WB Voice Group calls | 1d | 2000-01-03 A | 2000-01-03 A |  | 100% | 2000-01-03 | 2000-01-03 | 1d | finish no earlier than 2000-01-03 | S1 | 8h | 8h | Rel-5 | Alain |  |  | SP-07 |  |  |
| 2129 | 86.1.8 | **Conformance tests (CRs to 34 series)** | 74d | 2000-01-01 A | 2000-04-12 A |  | 100% | 2000-01-01 | 2000-04-12 | 74d |  | T1 | 1768h | 1768h | Rel-5 | Ingbert |  |  |  |  |  |
| 2130 | 86.1.8.1 | **Terminal Acoustic Characteristics** | 74d | 2000-01-01 A | 2000-04-12 A |  | 100% | 2000-01-01 | 2000-04-12 | 74d |  | S4 | 1176h | 1176h | Rel-5 | Paolo |  |  |  |  |  |
| 2131 | 86.1.8.1.1 | Definition | 22d | 2000-01-01 A | 2000-01-31 A |  | 100% | 2000-01-01 | 2000-01-31 | 22d | finish no earlier than 2000-01-28 | S4 | 168h | 168h | Rel-5 | Paolo |  | 26.131 |  |  |  |
| 2132 | 86.1.8.1.2 | Test specification | 52d | 2000-02-01 A | 2000-04-12 A | 2131 | 100% | 2000-02-01 | 2000-04-12 | 52d | finish no earlier than 2000-03-13 | S4 | 416h | 416h | Rel-5 | Paolo |  | 26.132 |  |  |  |
| 2133 | 86.2 | Floating-point ANSI-C code for the AMR-WB speech codec | 123d | 2001-09-25 A | 2002-03-14 A |  | 100% | 2001-09-25 | 2002-03-14 | 123d | finish no earlier than 2002-03-14 | S4 | 984h | 984h | Rel-5 | Paolo | AMRWB-FP | 26.204 |  | Nokia | janne.m.vainio@nokia.com |
| 2134 | 86.3 | **Support of AMR-WB in GERAN: GMSK and 8PSK WB FR / HR** | 651d | 2000-01-03 A | 2002-06-28 A |  | 100% | 2000-01-03 | 2002-06-28 | 651d |  | GP | 23488h | 23488h | Rel-5 | Paolo | GAMRWB |  |  |  |  |
| 2135 | 86.3.1 | Channel coding in 45.003 | 591d | 2000-01-03 A | 2002-04-05 A |  | 100% | 2000-01-03 | 2002-04-05 | 591d |  | GP | 4720h | 4720h | Rel-5 | Paolo |  |  |  |  |  |
| 2136 | 86.3.2 | Signalling for the A interface | 391d | 2000-01-03 A | 2001-06-29 A |  | 100% | 2000-01-03 | 2001-06-29 | 391d | finish no earlier than 2001-06-29 | GP | 3120h | 3120h | Rel-5 | Paolo |  |  |  |  |  |
| 2137 | 86.3.3 | Signalling for Iu | 651d | 2000-01-03 A | 2002-06-28 A |  | 100% | 2000-01-03 | 2002-06-28 | 651d | finish no earlier than 2002-06-28 | GP | 5200h | 5200h | Rel-5 | Paolo |  |  |  |  |  |
| 2138 | 86.3.4 | Receiver performance in TS 45.005 | 325d | 2001-04-02 A | 2002-06-28 A |  | 100% | 2001-04-02 | 2002-06-28 | 325d | finish no earlier than 2002-06-28 | GP | 2600h | 2600h | Rel-5 | Paolo |  |  |  |  |  |
| 2139 | 86.3.5 | Link Adaptation in 45.009 | 330d | 2001-03-26 A | 2002-06-28 A |  | 100% | 2001-03-26 | 2002-06-28 | 330d | finish no earlier than 2002-06-28 | GP | 2640h | 2640h | Rel-5 | Paolo |  |  |  |  |  |
| 2140 | 86.4 | **Deleted - GERAN MS conformance test for AMR-WB** | 1036d | 2000-01-03 A | 2003-12-19 A |  | 100% | 2000-01-03 | 2003-12-19 | 1036d |  | GP | 16568h | 16568h | Rel-5 | Paolo |  |  |  |  |  |
| 2141 | 86.4.1 | Deleted - MS test for AMR-WB | 1036d | 2000-01-03 A | 2003-12-19 A |  | 100% | 2000-01-03 | 2003-12-19 | 1036d | finish no earlier than 2003-12-19 | GP | 8280h | 8280h | Rel-5 | Paolo |  |  | GP-17 |  |  |
| 2142 | 86.5 | **GERAN BTS conformance test for AMR-WB** | 762d | 2000-01-03 A | 2002-12-02 A |  | 100% | 2000-01-03 | 2002-12-02 | 762d |  | GP | 12184h | 12184h | Rel-5 | Paolo |  |  |  |  |  |
| 2143 | 86.5.1 | BTS test | 762d | 2000-01-03 A | 2002-12-02 A |  | 100% | 2000-01-03 | 2002-12-02 | 762d | finish no earlier than 2002-12-02 | GP | 6088h | 6088h | Rel-5 | Paolo |  |  |  |  |  |

Notes:
- 2119: -
- 2120: -
- 2121: -
- 2122: -
- 2123: -
- 2124: ANSI C-Code , Test Sequences, Speech Transcoding Functions, Error Concealment of lost frames, Source Controlled Bit-Rate Operation, Voice Activity Detector, Frame Structure
- 2125: -
- 2126: -
- 2127: -
- 2128: -
- 2129: -
- 2130: -
- 2131: -
- 2132: -
- 2133: -
- 2134: -
- 2135: 50098 -> 50298
- 2136: -
- 2137: -
- 2138: -
- 2139: -
- 2140: Not started 02/2003. Marked as stopped 12/2008
- 2141: Marked as stopped 12/2008
- 2142: -
- 2143: -

| ID | WBS | Task | Duration | Start | Finish | Complete | Baseline start | Baseline finish | Baseline duration | Constraint | Resources | Work | Actual work | Text1 | Text6 | Text8 | Text3 | Text4 | Text5 |
| --- | --- | --- | --- | --- | --- | --- | --- | --- | --- | --- | --- | --- | --- | --- | --- | --- | --- | --- | --- |
| 2144 | 11 | **Terminal interfaces** | 223d | 2001-05-14 A | 2002-03-20 A | 100% | 2001-05-14 | 2002-03-20 | 223d |  | T2 | 3568h | 3568h | TI | Rel-5 | Kimmo |  |  |  |
| 2145 | 87 | Terminal local model enhancements | 223d | 2001-05-14 A | 2002-03-20 A | 100% | 2001-05-14 | 2002-03-20 | 223d | finish no earlier than 2002-03-20 | T2 | 1784h | 1784h | TLM5 | Rel-5 |  | 23.227 |  |  |
| 2146 | 88 | **Rel-5 Location Services enhancements** | 845d | 2000-04-03 A | 2003-06-27 A | 100% | 2000-04-03 | 2003-06-27 | 845d |  | S2,S5 | 86804h | 86804h | LCS1 | Rel-5 | Maurice |  | Nokia | Jan Kall |
| 2147 | 88.1 | **UE positioning** | 315d | 2001-01-15 A | 2002-03-29 A | 100% | 2001-01-15 | 2002-03-29 | 315d |  | RP | 5560h | 5560h | LCS1-UEpos | Rel-5 | Issam |  |  |  |
| 2148 | 88.1.1 | UE positioning enhancements for 1.28 Mcps TDD | 255d | 2001-04-09 A | 2002-03-29 A | 100% | 2001-04-09 | 2002-03-29 | 255d | finish no earlier than 2002-03-29 | R2 | 2040h | 2040h | LCS-128Pos | Rel-5 | Joern |  | CATT | Xiaohua Mei |
| 2149 | 88.1.2 | Open SMLC-SRNC Interface within the UTRAN to support A-GPS Positioning | 195d | 2001-01-15 A | 2001-10-12 A | 100% | 2001-01-15 | 2001-10-12 | 195d |  | R2 | 1560h | 1560h | LCS-INTF | Rel-5 | Joern |  | Qualcomm | Kirk Burroughs |
| 2150 | 88.2 | **Event based and Periodic LCS** | 535d | 2000-05-22 A | 2002-06-07 A | 100% | 2000-05-22 | 2002-06-07 | 535d |  | S1 | 6288h | 6288h | LCS1-EBP | Rel-5 | Alain |  |  |  |
| 2151 | 88.2.1 | Stage 1 | 130d | 2000-05-22 A | 2000-11-17 A | 100% | 2000-05-22 | 2000-11-17 | 130d | finish no earlier than 2000-07-21 | S1 | 1040h | 1040h |  | Rel-5 | Alain | 22.071 | Pacific Bell Wireless | Randolph Wohlert (rwohlert@tri.sbc.com) |
| 2152 | 88.2.2 | Stage 2 specification | 60d | 2000-11-06 A | 2001-01-26 A | 100% | 2000-11-06 | 2001-01-26 | 60d | finish no earlier than 2001-01-26 | S2 | 480h | 480h |  | Rel-5 | Maurice |  |  |  |
| 2153 | 88.2.3 | Impact on MAP | 61d | 2002-03-15 A | 2002-06-07 A | 100% | 2002-03-15 | 2002-06-07 | 61d | finish no earlier than 2002-06-07 | N4 | 488h | 488h |  | Rel-5 | Kimmo |  |  |  |
| 2154 | 88.3 | **Location Services for GERAN in A/Gb Mode** | 485d | 2000-04-03 A | 2002-02-08 A | 100% | 2000-04-03 | 2002-02-08 | 485d |  | GP | 14760h | 14760h | LCS-GERAN | Rel-5 | Paolo |  |  |  |
| 2155 | 88.3.1 | GERAN LCS Stage 2 (first release) | 485d | 2000-04-03 A | 2002-02-08 A | 100% | 2000-04-03 | 2002-02-08 | 485d | finish no earlier than 2002-02-08 | GP,S2,G1,G2 | 3880h | 3880h |  | Rel-5 | Paolo |  |  |  |
| 2156 | 88.3.2 | Gb interface support for LCS | 370d | 2000-04-03 A | 2001-08-31 A | 100% | 2000-04-03 | 2001-08-31 | 370d | finish no earlier than 2001-08-31 | GP | 2960h | 2960h |  | Rel-5 | Paolo |  |  |  |
| 2157 | 88.3.3 | L3 protocol support for LCS | 305d | 2000-04-03 A | 2001-06-01 A | 100% | 2000-04-03 | 2001-06-01 | 305d | finish no earlier than 2001-06-01 | GP | 2440h | 2440h |  | Rel-5 | Paolo |  |  |  |
| 2158 | 88.3.4 | Stage 3 specifications | 305d | 2000-04-03 A | 2001-06-01 A | 100% | 2000-04-03 | 2001-06-01 | 305d | finish no earlier than 2001-06-01 | GP | 2440h | 2440h |  | Rel-5 | Paolo |  |  |  |
| 2159 | 88.4 | **Location Services for GERAN in Iu Mode** | 585d | 2000-04-03 A | 2002-06-28 A | 100% | 2000-04-03 | 2002-06-28 | 585d |  | S2,G1,G2,R2,R3 | 20996h | 20996h |  | Rel-5 | Paolo |  |  |  |
| 2160 | 88.4.1 | GERAN LCS Stage 2 | 585d | 2000-04-03 A | 2002-06-28 A | 100% | 2000-04-03 | 2002-06-28 | 585d | finish no earlier than 2002-06-28 | S2,G1,G2 | 4680h | 4680h |  | Rel-5 | Paolo |  |  |  |
| 2161 | 88.4.2 | Iu-ps interface support for LCS | 585d | 2000-04-03 A | 2002-06-28 A | 100% | 2000-04-03 | 2002-06-28 | 585d | finish no earlier than 2002-06-28 | R2,R3 | 4680h | 4680h |  | Rel-5 | Paolo |  |  |  |
| 2162 | 88.4.3 | Iu-cs interface support for LCS | 585d | 2000-04-03 A | 2002-06-28 A | 100% | 2000-04-03 | 2002-06-28 | 585d | finish no earlier than 2002-06-28 | R2,R3 | 4680h | 4680h |  | Rel-5 | Paolo |  |  |  |
| 2163 | 88.4.4 | Iur-g interface support for LCS | 62.5d | 2002-01-23 A | 2002-04-19 A | 100% | 2002-01-23 | 2002-04-19 | 62.5d | finish no earlier than 2002-04-19 | G1,G2 | 500h | 500h |  | Rel-5 | Paolo |  |  |  |
| 2164 | 88.4.5 | RRC protocol support for LCS | 75d | 2001-08-20 A | 2001-11-30 A | 100% | 2001-08-20 | 2001-11-30 | 75d | finish no earlier than 2001-11-30 | G1,G2,R2,R3 | 600h | 600h |  | Rel-5 | Paolo |  |  |  |
| 2165 | 88.4.6 | Additional impacts on Broadcast of LCS data on packet channels | 77.5d | 2001-08-20 A | 2001-12-05 A | 100% | 2001-08-20 | 2001-12-05 | 77.5d | finish no earlier than 2001-12-05 | G1,G2,R2,R3 | 620h | 620h |  | Rel-5 | Paolo |  |  |  |
| 2166 | 88.4.7 | Stage 3 specifications | 69.5d | 2002-03-25 A | 2002-06-28 A | 100% | 2002-03-25 | 2002-06-28 | 69.5d | finish no earlier than 2002-06-28 | G1,G2,R2,R3 | 556h | 556h |  | Rel-5 | Paolo |  |  |  |
| 2167 | 88.5 | **GERAN MS Conformance test for LCS** | 280d | 2002-06-03 A | 2003-06-27 A | 100% | 2002-06-03 | 2003-06-27 | 280d |  | GP | 6720h | 6720h | LCS-GERAN-MSconf | Rel-5 | Paolo |  |  |  |
| 2168 | 88.5.1 | Develop LCS MS test case work plan (Release 98/99/4) | 280d | 2002-06-03 A | 2003-06-27 A | 100% | 2002-06-03 | 2003-06-27 | 280d | finish no earlier than 2003-06-27 | G4,G5 | 2240h | 2240h |  | Rel-5 | Paolo |  |  |  |
| 2169 | 88.5.2 | Develop LCS MS test cases | 280d | 2002-06-03 A | 2003-06-27 A | 100% | 2002-06-03 | 2003-06-27 | 280d | finish no earlier than 2003-06-27 | G4,G5 | 2240h | 2240h |  | Rel-5 | Paolo |  |  |  |

Notes:
- 2144: -
- 2145: -
- 2146: -
- 2147: -
- 2148: -
- 2149: Finished at RP#13
- 2150: -
- 2151: Evaluate Event based and Periodic LCS to be included in R00, corresponding Stage 1 description
- 2152: Marked as closed 12/2008 (was marked 51% complete)
- 2153: Possible impact on UTRAN of LCS quality level request / 17 May No stage 2 for event-based & periodic LCS. Work 100% completefor current stage 2
- 2154: -
- 2155: -
- 2156: -
- 2157: -
- 2158: -
- 2159: -
- 2160: -
- 2161: -
- 2162: -
- 2163: FFS
- 2164: -
- 2165: -
- 2166: -
- 2167: -
- 2168: Marked as closed 12/2008 (was marked 60% complete)
- 2169: Marked as closed 12/2008 (was marked 60% complete)

| ID | WBS | Task | Duration | Start | Finish | Predecessors | Complete | Baseline start | Baseline finish | Baseline duration | Constraint | Resources | Work | Actual work | Text1 | Text6 | Text8 | Text12 | Text3 | Text4 | Text5 |
| --- | --- | --- | --- | --- | --- | --- | --- | --- | --- | --- | --- | --- | --- | --- | --- | --- | --- | --- | --- | --- | --- |
| 2170 | 88.6 | **Deleted - GERAN BTS Conformance test for LCS** | 280d | 2002-06-03 A | 2003-06-27 A |  | 100% | 2002-06-03 | 2003-06-27 | 280d |  | GP | 6720h | 6720h | LCS-GERAN-BTSconf | Rel-5 | Paolo | GP-15 |  |  |  |
| 2171 | 88.6.1 | Deleted - Develop LCS BTS test case work plan (Release 98/99/4) | 280d | 2002-06-03 A | 2003-06-27 A |  | 100% | 2002-06-03 | 2003-06-27 | 280d | finish no earlier than 2003-06-27 | G4,G5 | 2240h | 2240h |  | Rel-5 | Paolo | GP-15 |  |  |  |
| 2172 | 88.6.2 | Deleted - Develop LCS BTS test cases | 280d | 2002-06-03 A | 2003-06-27 A |  | 100% | 2002-06-03 | 2003-06-27 | 280d | finish no earlier than 2003-06-27 | G4,G5 | 2240h | 2240h |  | Rel-5 | Paolo | GP-15 |  |  |  |
| 2173 | 88.7 | LCS interoperation stage 2 aspects | 480d | 2000-08-28 A | 2002-06-28 A |  | 100% | 2000-08-28 | 2002-06-28 | 480d |  | S2 | 3840h | 3840h |  | Rel-5 | Maurice |  |  |  |  |
| 2174 | 88.8 | **LCS interoperability aspects to GERAN** | 480d | 2000-08-28 A | 2002-06-28 A |  | 100% | 2000-08-28 | 2002-06-28 | 480d |  | GP,S5 | 7680h | 7680h | LCS-GERAN | Rel-5 | Paolo |  |  |  |  |
| 2175 | 88.8.1 | Co-ordinated development of GSM LCS Phase 2 and UMTS LCS, S2 and GERAN | 480d | 2000-08-28 A | 2002-06-28 A |  | 100% | 2000-08-28 | 2002-06-28 | 480d | finish no earlier than 2002-06-28 | GP,S2,S5,R2,R3,G2,G1 | 3840h | 3840h | LCS-GERAN | Rel-5 | Paolo |  |  |  |  |
| 2176 | 88.9 | FS on LCS support in the IMS | 90d | 2001-02-12 A | 2002-01-18 A |  | 100% | 2001-02-12 | 2002-01-18 | 90d | start no earlier than 2001-02-12 | S1 | 720h | 720h |  | Rel-5 | Alain |  |  |  |  |
| 2177 | 88.10 | Charging and OAM&P for LCS enhancements | 201d | 2001-09-21 A | 2002-06-28 A |  | 100% | 2001-09-21 | 2002-06-28 | 201d | finish no earlier than 2002-06-28 | S5 | 1608h | 1608h | LCS1-OAM | Rel-5 | Dionisio |  | 32-series | VoiceStream, Motorola |  |
| 2178 | 88.11 | New security aspects of LCS (not identified) | 446d | 2000-04-14 A | 2001-12-28 A |  | 100% | 2000-04-14 | 2001-12-28 | 446d | finish no earlier than 2001-12-28 | S3 | 3568h | 3568h | LCS1-SEC | Rel-5 | Dionisio |  |  | Nokia | valtteri.niemi@nokia.com |
| 2179 | 88.12 | Specification for the Le Interface | 45d | 2002-01-14 A | 2002-03-15 A |  | 100% | 2002-01-14 | 2002-03-15 | 45d | start no earlier than 2002-01-14 | S2 | 360h | 360h | LCS1-Le | Rel-5 | Maurice |  |  |  |  |
| 2180 | 88.13 | Deleted - CHECK STATUS - Inter-GMLC interface | 153d | 2002-05-30 A | 2002-12-30 A |  | 100% | 2002-05-30 | 2002-12-30 | 153d | finish no earlier than 2002-12-30 | S2 | 1224h | 1224h |  | Rel-5 | Maurice | SP-10 |  |  |  |
| 2181 | 89 | **Rel-5 Security enhancements** | 615d | 2000-02-21 A | 2002-06-28 A |  | 100% | 2000-02-21 | 2002-06-28 | 615d |  | S3 | 29974.9h | 29974.9h |  | Rel-5 | Dionisio |  |  | Vodafone | Peter.Howard@vodafone.com |
| 2182 | 89.1 | **Network domain security** | 615d | 2000-02-21 A | 2002-06-28 A |  | 100% | 2000-02-21 | 2002-06-28 | 615d |  | S3 | 25054.9h | 25054.9h | SEC1-NDS | Rel-5 | Dionisio |  |  | Telenor | Geir-myrdahl.koien@telenor.com |
| 2183 | 89.1.1 | **Deleted -Control plane protection in core network (e.g., GTP, CAP, MAP/IP, provided by IPsec)** | 541d | 2000-05-12 A | 2002-06-07 A |  | 100% | 2000-05-12 | 2002-06-07 | 541d |  | S3 | 7118.9h | 7118.9h |  | Rel-5 | Dionisio | SP-16 |  |  |  |
| 2184 | 89.1.1.1 | Deleted - Main aspects | 290d | 2000-05-12 A | 2001-06-21 A |  | 100% | 2000-05-12 | 2001-06-21 | 290d | finish no earlier than 2001-06-21 | S3 | 2320h | 2320h |  | Rel-5 | Dionisio | SP-12 |  |  |  |
| 2185 | 89.1.1.2 | Deleted -Integration of GTP signalling security architecture | 191d | 2001-09-14 A | 2002-06-07 A |  | 100% | 2001-09-14 | 2002-06-07 | 191d | finish no earlier than 2002-06-07 | N4 | 1528h | 1528h |  | Rel-5 | Kimmo | NP-16 |  |  |  |
| 2186 | 89.1.2 | **Deleted -User plane protection in core network (e.g., provided by IPsec)** | 615d | 2000-02-21 A | 2002-06-28 A |  | 100% | 2000-02-21 | 2002-06-28 | 615d |  | S3 | 9360h | 9360h |  | Rel-5 | Dionisio | SP-16 |  |  |  |
| 2187 | 89.1.2.1 | Deleted -Main aspects | 349d | 2000-02-21 A | 2001-06-21 A |  | 100% | 2000-02-21 | 2001-06-21 | 349d | finish no earlier than 2001-06-21 | S3 | 2792h | 2792h |  | Rel-5 | Dionisio | SP-12 |  |  |  |
| 2188 | 89.1.2.2 | Deleted -Integration of GTP signalling security architecture | 206d | 2001-09-14 A | 2002-06-28 A |  | 100% | 2001-09-14 | 2002-06-28 | 206d | finish no earlier than 2002-06-28 | N4 | 1648h | 1648h |  | Rel-5 | Kimmo | NP-16 |  |  |  |
| 2189 | 89.1.3 | IP network layer security (NDS/IP) | 457d | 2000-06-15 A | 2002-03-15 A |  | 100% | 2000-06-15 | 2002-03-15 | 457d | finish no earlier than 2002-03-15 | S3 | 3656h | 3656h | SEC1-NDS-IP | Rel-5 | Dionisio |  | 33.210 | Telenor | Geir-myrdahl.koien@telenor.com |
| 2190 | 90 | **Intra Domain Connection of RAN Nodes to Multiple CN Nodes** | 455d | 2000-10-02 A | 2002-06-28 A |  | 100% | 2000-10-02 | 2002-06-28 | 455d |  | S2 | 15136h | 15136h | IUFLEX | Rel-5 | Alain |  | 23.236 | Ericsson | stephen.terrill@ericsson.com |
| 2191 | 90.1 | Overall System Architecture | 188d | 2001-01-03 A | 2001-09-21 A |  | 100% | 2001-01-03 | 2001-09-21 | 188d | finish no earlier than 2001-06-01 | S2 | 1504h | 1504h |  | Rel-5 | Maurice |  |  |  |  |
| 2192 | 90.2 | Stage 3: RAN node selecting CN node | 130d | 2001-09-24 A | 2002-03-22 A | 2191 | 100% | 2001-09-24 | 2002-03-22 | 130d | finish no earlier than 2002-03-22 | R3 | 1040h | 1040h |  | Rel-5 | Juha |  |  | Vodafone | Brendan.McWilliams@gb.vodafone.co.uk |
| 2193 | 90.3 | N1 work | 205d | 2001-09-17 A | 2002-06-28 A |  | 100% | 2001-09-17 | 2002-06-28 | 205d | start no earlier than 2001-09-17 | N1 | 1640h | 1640h |  | Rel-5 | Frederic |  | 24.008 and check 29.018 |  |  |
| 2194 | 90.4 | N4 work | 375d | 2000-10-02 A | 2002-03-08 A |  | 100% | 2000-10-02 | 2002-03-08 | 375d | finish no earlier than 2002-03-15 | N4 | 3000h | 3000h |  | Rel-5 | Kimmo |  |  |  |  |

Notes:
- 2170: Not started 02/3003. Marked as stopped 12/2008
- 2171: Marked as stopped 12/2008
- 2172: Marked as stopped 12/2008
- 2173: Marked as closed 12/2008 (was marked 17% complete)
- 2174: -
- 2175: -
- 2176: Marked as closed 12/2008 (was marked 75% complete)
- 2177: -
- 2178: 14/09/00: WI may need to be split to improve on this date. S3#17 15% complete. No progress since S3#17
- 2179: -
- 2180: Marked as stopped 12/2008
- 2181: Added BB UE authentication and rapporteur added. TO BE DELETED
- 2182: S3#17: All due in Rel5. (WI Update at S3#18). Replaced by NDS-IP and NDS-MAP. TO BE DELETED OR MOVED TO HISTORY FILE
- 2183: Marked as stopped 12/2008
- 2184: TO BE DELETED. Marked as stopped 12/2008
- 2185: Waiting for input from SA3!.... Marked as stopped 12/2008
- 2186: TO BE DELETED. Marked as stopped 12/2008
- 2187: -
- 2188: 14/02/2002 requirements are not clear/not received...Marked as closed 12/2008 (was marked 95 complete)
- 2189: 2002/12: All IPsec RFCs are stable STD Track RFCs. WID updated SP#17
- 2190: No clear indication on the end date. Put to Rel5 by AS.
- 2191: -
- 2192: Not identified
- 2193: -
- 2194: DAB 12.12.01 - % complete to 66% / 14/02/02 Work completed

| ID | WBS | Task | Duration | Start | Finish | Complete | Baseline start | Baseline finish | Baseline duration | Constraint | Resources | Work | Actual work | Text1 | Text4 | Text5 | Text6 | Text8 | Text12 | Text3 |
| --- | --- | --- | --- | --- | --- | --- | --- | --- | --- | --- | --- | --- | --- | --- | --- | --- | --- | --- | --- | --- |
| 2195 | 90.5 | **GERAN work for Intra Domain Connection of RAN Nodes to Multiple CN Nodes** | 101d | 2002-02-08 A | 2002-06-28 A | 100% | 2002-02-08 | 2002-06-28 | 101d |  | GP | 4848h | 4848h | IDCRAN-GERAN | Ericsson | ingemar.backlund@era.ericsson.se | Rel-5 | Paolo |  |  |
| 2196 | 90.5.1 | Stage 2 (changes to ) | 101d | 2002-02-08 A | 2002-06-28 A | 100% | 2002-02-08 | 2002-06-28 | 101d | finish no earlier than 2002-06-28 | G1 | 808h | 808h |  |  |  | Rel-5 | Paolo |  |  |
| 2197 | 90.5.2 | 43.051 Introduction of support for IDNNS in GERAN Iu mode | 101d | 2002-02-08 A | 2002-06-28 A | 100% | 2002-02-08 | 2002-06-28 | 101d | finish no earlier than 2002-06-28 | G1 | 808h | 808h |  |  |  | Rel-5 | Paolo |  |  |
| 2198 | 90.5.3 | Stage 3 (changes to ) | 101d | 2002-02-08 A | 2002-06-28 A | 100% | 2002-02-08 | 2002-06-28 | 101d | finish no earlier than 2002-06-28 | G2 | 808h | 808h |  |  |  | Rel-5 | Gert |  |  |
| 2199 | 90.5.4 | 48.016 Use of Gb interface concepts when a network applies IDNNS | 101d | 2002-02-08 A | 2002-06-28 A | 100% | 2002-02-08 | 2002-06-28 | 101d | finish no earlier than 2002-06-28 | G2 | 808h | 808h |  |  |  | Rel-5 | Gert |  |  |
| 2200 | 90.5.5 | 48.018 Include MSC/VLR identity in CS IMSI paging | 101d | 2002-02-08 A | 2002-06-28 A | 100% | 2002-02-08 | 2002-06-28 | 101d | finish no earlier than 2002-06-28 | G2 | 808h | 808h |  |  |  | Rel-5 | Gert |  |  |
| 2201 | 91 | **Deleted - GERAN improvements 3 (new transport layer on interface A)** | 446d | 2001-04-06 A | 2002-12-20 A | 100% | 2001-04-06 | 2002-12-20 | 446d |  | GP | 14272h | 14272h | GEIMP3 |  |  | Rel-5 | Paolo |  |  |
| 2202 | 91.1 | **Deleted - Evolution of the transport for A** | 446d | 2001-04-06 A | 2002-12-20 A | 100% | 2001-04-06 | 2002-12-20 | 446d |  | GP | 10704h | 10704h | GEIMP3-EtA |  |  | Rel-5 | Paolo | GP-12 |  |
| 2203 | 91.1.1 | Deleted - Definition of a new A/Ater interface Transport Layer option based on the Iu Interface Transport Layer | 446d | 2001-04-06 A | 2002-12-20 A | 100% | 2001-04-06 | 2002-12-20 | 446d | finish no earlier than 2002-12-20 | GP | 3568h | 3568h |  |  |  | Rel-5 | Paolo | GP-12 |  |
| 2204 | 91.1.2 | Deleted - Adaptation of the Layer 3 BSSMAP procedures as required | 446d | 2001-04-06 A | 2002-12-20 A | 100% | 2001-04-06 | 2002-12-20 | 446d | finish no earlier than 2002-12-20 | GP | 3568h | 3568h |  |  |  | Rel-5 | Paolo | GP-12 |  |
| 2205 | 92 | **Rel-5 Charging and OAM&P** | 264d | 2001-09-10 A | 2002-09-12 A | 100% | 2001-09-10 | 2002-09-12 | 264d |  | S5 | 9976h | 9976h | OAM | VoiceStream, Motorola |  | Rel-5 | Dionisio |  |  |
| 2206 | 92.1 | Rel5 Principles, high level Requirements and Architecture | 205d | 2001-09-17 A | 2002-06-28 A | 100% | 2001-09-17 | 2002-06-28 | 205d | finish no earlier than 2002-06-28 | S5 | 1640h | 1640h | OAM-AR/PR | Motorola |  | Rel-5 | Dionisio |  | 32.101, 32.102 |
| 2207 | 92.2 | Rel5 Performance Management | 259d | 2001-09-17 A | 2002-09-12 A | 100% | 2001-09-17 | 2002-09-12 | 259d | finish no earlier than 2002-09-12 | S5 | 2072h | 2072h | OAM-PM | Nortel |  | Rel-5 | Dionisio |  | 32.4xy, 52.402 |
| 2208 | 92.3 | Rel5 Charging Management | 264d | 2001-09-10 A | 2002-09-12 A | 100% | 2001-09-10 | 2002-09-12 | 264d | finish no earlier than 2002-09-12 | S5 | 2112h | 2112h | OAM-CH | T-Mobile | Karl-Heinz.Nenner@T-MOBILE.DE | Rel-5 | Dionisio |  | 32.200, 32.205, 32.215, 32.225, 32.235 |
| 2209 | 92.4 | Rel5 Network Infrastructure Management | 255d | 2001-09-21 A | 2002-09-12 A | 100% | 2001-09-21 | 2002-09-12 | 255d | finish no earlier than 2002-09-12 | S5 | 2040h | 2040h | OAM-NIM | Ericsson | thomas.tovinger@ericsson.com | Rel-5 | Dionisio |  | 32.6xy, 32.3xy |
| 2210 | 93 | **GERAN enhancements for streaming services 1 (RLC enhancements)** | 430d | 2000-11-06 A | 2002-06-28 A | 100% | 2000-11-06 | 2002-06-28 | 430d |  | GP | 8944h | 8944h |  |  |  | Rel-5 | Paolo |  |  |
| 2211 | 93.1 | Concept | 258d | 2000-11-06 A | 2001-10-31 A | 100% | 2000-11-06 | 2001-10-31 | 258d | finish no earlier than 2001-10-31 | GP | 2064h | 2064h |  |  |  | Rel-5 | Paolo |  |  |
| 2212 | 93.2 | RLC protocol enhancement (SDU Discard) | 430d | 2000-11-06 A | 2002-06-28 A | 100% | 2000-11-06 | 2002-06-28 | 430d | finish no earlier than 2002-06-28 | GP | 3440h | 3440h |  |  |  | Rel-5 | Paolo |  |  |
| 2213 | 94 | **GERAN enhancements for streaming services 2 (usage of ECSD)** | 430d | 2000-11-06 A | 2002-06-28 A | 100% | 2000-11-06 | 2002-06-28 | 430d |  | GP | 19840h | 19840h |  | Ericsson | Frank Muller | Rel-5 | Paolo |  |  |
| 2214 | 94.1 | Usage of ECSD Concept | 380d | 2000-11-06 A | 2002-04-19 A | 100% | 2000-11-06 | 2002-04-19 | 380d | finish no earlier than 2002-04-19 | GP | 3040h | 3040h |  |  |  | Rel-5 | Paolo |  |  |
| 2215 | 94.2 | Stage 2 | 380d | 2000-11-06 A | 2002-04-19 A | 100% | 2000-11-06 | 2002-04-19 | 380d | finish no earlier than 2002-04-19 | GP | 3040h | 3040h |  |  |  | Rel-5 | Paolo |  |  |
| 2216 | 94.3 | Stage 3 | 430d | 2000-11-06 A | 2002-06-28 A | 100% | 2000-11-06 | 2002-06-28 | 430d | finish no earlier than 2002-06-28 | GP | 3440h | 3440h |  |  |  | Rel-5 | Paolo |  |  |
| 2217 | 94.4 | RLC PDU formats | 430d | 2000-11-06 A | 2002-06-28 A | 100% | 2000-11-06 | 2002-06-28 | 430d | finish no earlier than 2002-06-28 | GP | 3440h | 3440h |  |  |  | Rel-5 | Paolo |  |  |
| 2218 | 94.5 | MAC header | 430d | 2000-11-06 A | 2002-06-28 A | 100% | 2000-11-06 | 2002-06-28 | 430d | finish no earlier than 2002-06-28 | GP | 3440h | 3440h |  |  |  | Rel-5 | Paolo |  |  |

Notes:
- 2195: Accept changes Gb over IP
- 2196: -
- 2197: -
- 2198: -
- 2199: Closed, accept changes for Gb over IP
- 2200: -
- 2201: Terminated - not standardized. Marked as stopped 12/2008
- 2202: TERMINATED - NOT STANDARDIZED. Marked as stopped 12/2008
- 2203: TERMINATED - NOT STANDARDIZED. Marked as stopped 12/2008
- 2204: TERMINATED - NOT STANDARDIZED. Marked as stopped 12/2008
- 2205: -
- 2206: -
- 2207: -
- 2208: -
- 2209: -
- 2210: -
- 2211: -
- 2212: -
- 2213: AWS, Nokia, Ericsson, Nortel, Siemens, Motorola, Vodafone
- 2214: -
- 2215: -
- 2216: -
- 2217: -
- 2218: -

| ID | WBS | Task | Duration | Start | Finish | Predecessors | Complete | Baseline start | Baseline finish | Baseline duration | Constraint | Resources | Work | Actual work | Text1 | Text4 | Text5 | Text6 | Text8 |
| --- | --- | --- | --- | --- | --- | --- | --- | --- | --- | --- | --- | --- | --- | --- | --- | --- | --- | --- | --- |
| 2219 | 95 | **GERAN/UTRAN interface evolution 1 (evolution of Iu PS)** | 476d | 2000-09-01 A | 2002-06-28 A |  | 100% | 2000-09-01 | 2002-06-28 | 476d |  | GP,R3 | 10688h | 10688h | GERUEV1 | SBC | Marc Grant | Rel-5 | Paolo |
| 2220 | 95.1 | **Evolution of Iu ps** | 476d | 2000-09-01 A | 2002-06-28 A |  | 100% | 2000-09-01 | 2002-06-28 | 476d |  | GP,R3 | 7248h | 7248h | GERUEV1-IuPS |  |  | Rel-5 | Paolo |
| 2221 | 95.1.1 | Identification of GERAN requirements on Iu ps | 326d | 2000-09-01 A | 2001-11-30 A |  | 100% | 2000-09-01 | 2001-11-30 | 326d | finish no earlier than 2001-11-30 | GP,R3 | 2608h | 2608h |  |  |  | Rel-5 | Paolo |
| 2222 | 95.1.2 | Update of specifications | 150d | 2001-12-03 A | 2002-06-28 A | 2221 | 100% | 2001-12-03 | 2002-06-28 | 150d | finish no earlier than 2002-06-28 | GP,R3 | 1200h | 1200h |  |  |  | Rel-5 | Paolo |
| 2223 | 96 | **GERAN/UTRAN interface evolution 2 (evolution of Iu CS)** | 476d | 2000-09-01 A | 2002-06-28 A |  | 100% | 2000-09-01 | 2002-06-28 | 476d |  | GP,R3 | 12816h | 12816h | GERUEV2 |  |  | Rel-5 | Paolo |
| 2224 | 96.1 | **Evolution of Iu cs** | 476d | 2000-09-01 A | 2002-06-28 A |  | 100% | 2000-09-01 | 2002-06-28 | 476d |  | GP,R3 | 10016h | 10016h | GERUEV2-IuCS | Lucent | Krishna Balachandran | Rel-5 | Paolo |
| 2225 | 96.1.1 | Identification of GERAN requirements on Iu cs | 426d | 2000-09-01 A | 2002-06-24 A |  | 100% | 2000-09-01 | 2002-06-24 | 426d | finish no earlier than 2002-04-19 | GP,R3 | 3408h | 3408h |  |  |  | Rel-5 | Paolo |
| 2226 | 96.1.2 | Update of specifications | 476d | 2000-09-01 A | 2002-06-28 A |  | 100% | 2000-09-01 | 2002-06-28 | 476d | finish no earlier than 2002-06-28 | GP,R3 | 3808h | 3808h |  |  |  | Rel-5 | Paolo |
| 2227 | 97 | **End to End QoS for PS Domain including IMS** | 480d | 2000-08-28 A | 2002-06-28 A |  | 100% | 2000-08-28 | 2002-06-28 | 480d |  | S2 | 9856h | 9856h | E2EQoS | Ericsson | Johnson.oyama@era.ericcson.se | Rel-5 | Maurice |
| 2228 | 97.1 | E2E QoSConcept and Architecture | 178d | 2001-01-03 A | 2001-09-07 A |  | 100% | 2001-01-03 | 2001-09-07 | 178d | finish no earlier than 2001-09-07 | S2 | 1424h | 1424h |  |  |  | Rel-5 | Maurice |
| 2229 | 97.2 | E2E QoS interworking | 465d | 2000-08-28 A | 2002-06-07 A |  | 100% | 2000-08-28 | 2002-06-07 | 465d | finish no earlier than 2002-06-07 | N3 | 3720h | 3720h | E2EQoS-IW | Lucent | Daisuke Yokota (yokota@lucent.com) | Rel-5 | Gwiho |
| 2230 | 97.3 | QoS Management (Provisioning and Monitoring) | 201d | 2001-09-21 A | 2002-06-28 A |  | 100% | 2001-09-21 | 2002-06-28 | 201d | finish no earlier than 2002-06-28 | S5 | 1608h | 1608h | E2EQoS-OAM | VoiceStream, Motorola |  | Rel-5 | Dionisio |
| 2231 | 98 | **Messaging enhancements Rel-5** | 467d | 2001-06-15 A | 2003-03-31 A |  | 100% | 2001-06-15 | 2003-03-31 | 467d |  | T2 | 19000h | 19000h | MESS5 |  |  | Rel-5 | Kimmo |
| 2232 | 98.1 | **Multimedia Messaging (MMS) enhancements** | 467d | 2001-06-15 A | 2003-03-31 A |  | 100% | 2001-06-15 | 2003-03-31 | 467d |  | T2 | 11688h | 11688h | MESS5-MMS | Siemens | Josef.Laumen@SAL.SIEMENS.DE | Rel-5 | Alain |
| 2233 | 98.1.1 | Definition of service requirements | 196d | 2001-06-15 A | 2002-03-15 A |  | 100% | 2001-06-15 | 2002-03-15 | 196d | finish no earlier than 2002-03-15 | S1 | 1568h | 1568h | MESS5-SR | Siemens | Josef.Laumen@SAL.SIEMENS.DE | Rel-5 | Alain |
| 2234 | 98.1.2 | Technical realization | 256d | 2001-06-15 A | 2002-06-07 A |  | 100% | 2001-06-15 | 2002-06-07 | 256d | finish no earlier than 2002-06-07 | T2 | 2048h | 2048h |  | Siemens | Josef.Laumen@SAL.SIEMENS.DE | Rel-5 |  |
| 2235 | 98.1.3 | WAP Forum dependency: MM1 stage 3 | 467d | 2001-06-15 A | 2003-03-31 A |  | 100% | 2001-06-15 | 2003-03-31 | 467d | finish no earlier than 2003-03-31 | T2 | 3736h | 3736h |  |  |  | Rel-5 |  |
| 2236 | 98.1.4 | MMS formats and codecs | 75d | 2001-12-03 A | 2002-03-15 A |  | 100% | 2001-12-03 | 2002-03-15 | 75d | finish no earlier than 2002-03-15 | S4 | 600h | 600h |  |  |  | Rel-5 | Paolo |
| 2237 | 98.2 | **Enhanced Messaging Service (EMS) enhancements** | 191d | 2001-06-15 A | 2002-03-08 A |  | 100% | 2001-06-15 | 2002-03-08 | 191d |  | T2 | 3584h | 3584h | MESS5-EMS | Ericsson | Alan.Baldwin@EML.ERICSSON.SE | Rel-5 | Kimmo |
| 2238 | 98.2.1 | Definition of service requirements | 66d | 2001-06-15 A | 2001-09-14 A |  | 100% | 2001-06-15 | 2001-09-14 | 66d | finish no earlier than 2001-09-14 | S1 | 528h | 528h |  | Ericsson | Alan.Baldwin@EML.ERICSSON.SE | Rel-5 | Alain |
| 2239 | 98.2.2 | Technical realization | 191d | 2001-06-15 A | 2002-03-08 A |  | 100% | 2001-06-15 | 2002-03-08 | 191d | finish no earlier than 2002-03-08 | T2 | 1528h | 1528h |  | Ericsson | Alan.Baldwin@EML.ERICSSON.SE | Rel-5 | Kimmo |
| 2240 | 99 | **GERAN Inter BSC NACC improvements over the Gb Interface** | 215d | 2001-09-03 A | 2002-06-28 A |  | 100% | 2001-09-03 | 2002-06-28 | 215d |  | GP | 8200h | 8200h | GERNACC |  |  | Rel-5 | Paolo |
| 2241 | 99.1 | **Modification of core network protocols for GERAN Inter BSC NACC over Gb Interface** | 165d | 2001-09-03 A | 2002-04-19 A |  | 100% | 2001-09-03 | 2002-04-19 | 165d |  | N4,S2 | 4064h | 4064h | GERNACC-Cnmod |  |  | Rel-5 | Kimmo |
| 2242 | 99.1.1 | Stage 2 - Concept | 43d | 2001-09-03 A | 2001-10-31 A |  | 100% | 2001-09-03 | 2001-10-31 | 43d | finish no earlier than 2001-10-31 | N4,S2 | 344h | 344h |  |  |  | Rel-5 | Kimmo |
| 2243 | 99.1.2 | Stage 2 - 23.060 change - Definition of Inter BSC NACC | 165d | 2001-09-03 A | 2002-04-19 A |  | 100% | 2001-09-03 | 2002-04-19 | 165d | finish no earlier than 2002-04-19 | N4,S2 | 1320h | 1320h |  |  |  | Rel-5 | Kimmo |
| 2244 | 99.1.3 | Stage 3 (changes to TS 29.060) | 135d | 2001-09-03 A | 2002-03-08 A |  | 100% | 2001-09-03 | 2002-03-08 | 135d | finish no earlier than 2002-03-08 | N4 | 1080h | 1080h |  |  |  | Rel-5 | Kimmo |

Notes:
- 2219: SBC, Motorola, Nokia, Ericsson, Nortel
- 2220: -
- 2221: -
- 2222: -
- 2223: -
- 2224: Lucent, Ericsson, AWS, Nortel
- 2225: -
- 2226: -
- 2227: -
- 2228: - / Text3: 23.207
- 2229: [DAB - 30/07/02] - % complete to 95% (if we exclude Diffserv). Marked as closed 12/2008 (was marked 95% complete) / Text3: 29.208, 29.207, 27.060, 29.061, 24.008, 24.228, , 24.229, 29.060, 29.163
- 2230: - / Text3: 32-series
- 2231: support of UAProf, so this in my opinion is 100% complete
- 2232: -
- 2233: - / Text3: 22.140
- 2234: stage 3 MM7 is missing / Text3: 23.140
- 2235: Marked as closed 12/2008 (was marked 80% complete)
- 2236: - / Text3: 26.140
- 2237: - / Text3: 23.040
- 2238: -
- 2239: - / Text3: 23.040
- 2240: -
- 2241: -
- 2242: -
- 2243: -
- 2244: IP 30/11/01: Input awaited from GERAN2 to CN4 / 17 May Work complete 100%

| ID | WBS | Task | Duration | Start | Finish | Complete | Baseline start | Baseline finish | Baseline duration | Constraint | Resources | Work | Actual work | Text1 | Text6 | Text8 | Text12 | Text3 | Text4 | Text5 |
| --- | --- | --- | --- | --- | --- | --- | --- | --- | --- | --- | --- | --- | --- | --- | --- | --- | --- | --- | --- | --- |
| 2245 | 99.2 | **Modification of Gb protocols for GERAN Inter BSC NACC over Gb Interface** | 151d | 2001-11-30 A | 2002-06-28 A | 100% | 2001-11-30 | 2002-06-28 | 151d |  | GP | 2416h | 2416h | GERNACC-Gbmod | Rel-5 | Paolo |  |  |  |  |
| 2246 | 99.2.1 | Stage 3 (changes to TS 48.018) | 151d | 2001-11-30 A | 2002-06-28 A | 100% | 2001-11-30 | 2002-06-28 | 151d | finish no earlier than 2002-06-28 | GP | 1208h | 1208h |  | Rel-5 | Paolo |  |  |  |  |
| 2247 | 100 | **Enhanced Power Control** | 540d | 2001-11-26 A | 2003-12-19 A | 100% | 2001-11-26 | 2003-12-19 | 540d |  | GP | 12840h | 12840h | EPC | Rel-5 | Paolo |  |  |  |  |
| 2248 | 100.1 | Realization of Enhanced power control and signalling support | 5d | 2001-11-26 A | 2001-11-30 A | 100% | 2001-11-26 | 2001-11-30 | 5d | finish no earlier than 2001-11-30 | GP | 40h | 40h |  | Rel-5 | Paolo |  |  |  |  |
| 2249 | 100.2 | Deleted - GERAN MS Conformance test for Enhanced Power Control | 530d | 2001-12-10 A | 2003-12-19 A | 100% | 2001-12-10 | 2003-12-19 | 530d | finish no earlier than 2003-12-19 | GP | 4240h | 4240h |  | Rel-5 | Paolo | GP-17 |  |  |  |
| 2250 | 100.3 | Deleted - GERAN BTS Conformance test for Enhanced Power Control | 530d | 2001-12-10 A | 2003-12-19 A | 100% | 2001-12-10 | 2003-12-19 | 530d | finish no earlier than 2003-12-19 | GP | 4240h | 4240h |  | Rel-5 | Paolo | GP-17 |  |  |  |
| 2251 | 101 | **8PSK AMR HR** | 530d | 2001-12-10 A | 2003-12-19 A | 100% | 2001-12-10 | 2003-12-19 | 530d |  | GP | 21080h | 21080h | 8PSK-AH | Rel-5 | Paolo |  |  |  |  |
| 2252 | 101.1 | **Definition of channel coding, performance requirements and signalling support** | 145d | 2001-12-10 A | 2002-06-28 A | 100% | 2001-12-10 | 2002-06-28 | 145d |  | GP | 10440h | 10440h |  | Rel-5 | Paolo |  |  |  |  |
| 2253 | 101.1.1 | Concept | 145d | 2001-12-10 A | 2002-06-28 A | 100% | 2001-12-10 | 2002-06-28 | 145d | finish no earlier than 2002-06-28 | GP | 1160h | 1160h |  | Rel-5 | Paolo |  |  |  |  |
| 2254 | 101.1.2 | Changes to 44.018 | 145d | 2001-12-10 A | 2002-06-28 A | 100% | 2001-12-10 | 2002-06-28 | 145d | finish no earlier than 2002-06-28 | G2 | 1160h | 1160h |  | Rel-5 | Gert |  |  |  |  |
| 2255 | 101.1.3 | Changes to 45.001 | 145d | 2001-12-10 A | 2002-06-28 A | 100% | 2001-12-10 | 2002-06-28 | 145d | finish no earlier than 2002-06-28 | G1 | 1160h | 1160h |  | Rel-5 | Paolo |  |  |  |  |
| 2256 | 101.1.4 | Changes to 45.002 | 145d | 2001-12-10 A | 2002-06-28 A | 100% | 2001-12-10 | 2002-06-28 | 145d | finish no earlier than 2002-06-28 | G1 | 1160h | 1160h |  | Rel-5 | Paolo |  |  |  |  |
| 2257 | 101.1.5 | Changes to 45.003 | 145d | 2001-12-10 A | 2002-06-28 A | 100% | 2001-12-10 | 2002-06-28 | 145d | finish no earlier than 2002-06-28 | G1 | 1160h | 1160h |  | Rel-5 | Paolo |  |  |  |  |
| 2258 | 101.1.6 | Changes to 45.005 | 145d | 2001-12-10 A | 2002-06-28 A | 100% | 2001-12-10 | 2002-06-28 | 145d | finish no earlier than 2002-06-28 | G1 | 1160h | 1160h |  | Rel-5 | Paolo |  |  |  |  |
| 2259 | 101.1.7 | Changes to 24.008 | 145d | 2001-12-10 A | 2002-06-28 A | 100% | 2001-12-10 | 2002-06-28 | 145d | finish no earlier than 2002-06-28 | G2 | 1160h | 1160h |  | Rel-5 | Gert |  |  |  |  |
| 2260 | 101.1.8 | Changes to 48.058 | 145d | 2001-12-10 A | 2002-06-28 A | 100% | 2001-12-10 | 2002-06-28 | 145d | finish no earlier than 2002-06-28 | G2 | 1160h | 1160h |  | Rel-5 | Gert |  |  |  |  |
| 2261 | 101.2 | Deleted - GERAN MS Conformance test for 8PSK HR | 530d | 2001-12-10 A | 2003-12-19 A | 100% | 2001-12-10 | 2003-12-19 | 530d | finish no earlier than 2003-12-19 | GP | 4240h | 4240h |  | Rel-5 | Paolo | GP-17 |  |  |  |
| 2262 | 101.3 | GERAN BTS Conformance test for 8PSK HR | 270d | 2001-12-10 A | 2002-12-20 A | 100% | 2001-12-10 | 2002-12-20 | 270d | finish no earlier than 2002-12-20 | GP | 2160h | 2160h |  | Rel-5 | Paolo |  |  |  |  |
| 2263 | 102 | Service Change and UDI Fallback | 175d | 2001-10-08 A | 2002-06-07 A | 100% | 2001-10-08 | 2002-06-07 | 175d | finish no earlier than 2002-06-07 | N3 | 1400h | 1400h | SCUDIF | Rel-5 | Gwiho |  | 29.007, 27.001, 24.008 | Ericsson | Rune.Werner.Wiik@ericsson.no |
| 2264 | 103 | **Rel-5 USIM toolkit enhancements** | 865d | 2000-06-05 A | 2003-09-26 A | 100% | 2000-06-05 | 2003-09-26 | 865d |  | T3 | 24352h | 24352h | USAT1-Interpr | Rel-5 | Xavier |  |  | G & D | Michael Meyer |
| 2265 | 103.1 | Deleted - Test specification for USIM toolkit security mechanisms | 349d | 2002-05-28 A | 2003-09-26 A | 100% | 2002-05-28 | 2003-09-26 | 349d | finish no earlier than 2003-09-26 | T3 | 2792h | 2792h |  | Rel-5 | Xavier | TP-21 |  | Gemplus | Sophie Viallet |
| 2266 | 103.2 | **Protocol Standardisation of a SIM Toolkit Interpreter** | 688d | 2000-06-05 A | 2003-01-22 A | 100% | 2000-06-05 | 2003-01-22 | 688d |  | T3 | 12512h | 12512h | USAT1-Interpr | Rel-5 | Xavier |  | 27.103 | G & D | Michael Meyer |
| 2267 | 103.2.1 | Stage 1 | 205d | 2000-06-05 A | 2001-03-16 A | 100% | 2000-06-05 | 2001-03-16 | 205d | finish no earlier than 2001-03-16 | T3 | 1640h | 1640h | USAT1-Interpr | Rel-5 | Xavier |  |  |  |  |
| 2268 | 103.2.2 | Stage 2 and 3 | 308d | 2001-01-03 A | 2002-03-08 A | 100% | 2001-01-03 | 2002-03-08 | 308d | finish no earlier than 2002-03-08 | T3 | 2464h | 2464h | USAT1-Interpr | Rel-5 | Xavier |  |  |  |  |
| 2269 | 103.2.3 | Test specification | 363d | 2001-09-03 A | 2003-01-22 A | 100% | 2001-09-03 | 2003-01-22 | 363d | finish no earlier than 2003-01-22 | T3 | 2904h | 2904h | USAT1-Interpr | Rel-5 | Xavier |  |  | Gemplus | Gérald MAUNIER |

Notes:
- 2245: -
- 2246: -
- 2247: -
- 2248: Completed 11/2001
- 2249: Not started. Marked as stopped 12/2008
- 2250: Not started. Marked as stopped 12/2008
- 2251: Completed for Rel-5
- 2252: -
- 2253: -
- 2254: -
- 2255: -
- 2256: -
- 2257: -
- 2258: -
- 2259: -
- 2260: -
- 2261: Marked as stopped 12/2008
- 2262: -
- 2263: -
- 2264: -
- 2265: Marked as stopped 12/2008
- 2266: 28/5/2001: T3-19 proposed that since the stage 2 and 3 will not be presented to TP-12 for approval as expected, the WI will be moved to rel-5, with completion expected at TP-13.
- 2267: 5/10/2001: Stage one comepeted at TP-12.
- 2268: 5/10/2001: TS 31.112 and 31.113 approved at TP-13. TS 31.114 to be presented to TP-14.
- 2269: 5/10/2001: Work started on test specification. Marked as closed 12/2008 (was marked 12% complete)

| ID | WBS | Task | Duration | Start | Finish | Complete | Baseline start | Baseline finish | Baseline duration | Constraint | Resources | Work | Actual work | Text1 | Text4 | Text5 | Text6 | Text8 | Text12 |
| --- | --- | --- | --- | --- | --- | --- | --- | --- | --- | --- | --- | --- | --- | --- | --- | --- | --- | --- | --- |
| 2270 | 103.4 | **(U)SIM API** | 133d | 2002-03-20 A | 2002-09-20 A | 100% | 2002-03-20 | 2002-09-20 | 133d |  | T3 | 2128h | 2128h | USAT1-API | Microelectrónica Española | Mario Pérez | Rel-5 | Xavier |  |
| 2271 | 103.4.1 | Java API Test specification | 133d | 2002-03-20 A | 2002-09-20 A | 100% | 2002-03-20 | 2002-09-20 | 133d | finish no earlier than 2002-09-20 | T3 | 1064h | 1064h | USAT1-API | Microelectrónica Española | Mario Pérez | Rel-5 | Xavier |  |
| 2272 | 104 | (Small) Technical Enhancements and Improvements for Rel-5 | 2349d? | 2000-01-03 A | 2008-12-31 A | 100% | 2000-01-03 | 2008-12-31 | 2349d? |  | All |  |  | TEI5 |  |  | Rel-5 | all |  |
| 2273 | 616 | Test - (Small) Technical Enhancements and Improvements for Rel-5 | 2349d? | 2000-01-03 A | 2008-12-31 A | 100% | 2000-01-03 | 2008-12-31 | 2349d? | finish no earlier than 2008-12-31 | R5,T1 | 18792h | 18792h | TEI5_Test |  |  | Rel-5 | Ingbert |  |
| 2274 | 105 | Technical Report on UE Functionality Split | 87d | 2000-01-03 A | 2000-05-01 A | 100% | 2000-01-03 | 2000-05-01 | 87d |  | S1 | 688h | 688h | UESPLIT | Motorola | jian.j.wu@motorola.com | Rel-5 | Alain |  |
| 2275 | 106 | **User Equipment Management** | 267d | 2001-06-21 A | 2002-06-28 A | 100% | 2001-06-21 | 2002-06-28 | 267d |  | S5 | 3752h | 3752h | UEM | Vodafone | john.mudge@vf.vodafone.co.uk | Rel-5 | Dionisio |  |
| 2276 | 106.1 | FS on User Equipment (UE) Management | 267d | 2001-06-21 A | 2002-06-28 A | 100% | 2001-06-21 | 2002-06-28 | 267d | finish no earlier than 2002-06-28 | S5 | 2136h | 2136h | OAM-UEM | Vodafone | john.mudge@vf.vodafone.co.uk | Rel-5 | Dionisio |  |
| 2277 | 107 | **Flow control supporting an MS with multiple data flows with different QoS over the Gb interface** | 50d | 2002-06-24 A | 2002-08-30 A | 100% | 2002-06-24 | 2002-08-30 | 50d |  | GP | 1288h | 1288h | FlowCon | Ericsson | ingemar.backlund@era.ericsson.se | Rel-5 | Paolo |  |
| 2278 | 107.1 | **Update of stage 2 specifications** | 50d | 2002-06-24 A | 2002-08-30 A | 100% | 2002-06-24 | 2002-08-30 | 50d |  | GP | 808h | 808h |  |  |  | Rel-5 | Paolo |  |
| 2279 | 107.1.1 | Concept document 23.060 (changes to) | 46d | 2002-06-28 A | 2002-08-30 A | 100% | 2002-06-28 | 2002-08-30 | 46d | finish no earlier than 2002-08-30 | S2 | 368h | 368h |  |  |  | Rel-5 | Maurice |  |
| 2280 | 107.1.2 | Flow Control | 5d | 2002-06-24 A | 2002-06-28 A | 100% | 2002-06-24 | 2002-06-28 | 5d | finish no earlier than 2002-06-28 | GP | 40h | 40h |  |  |  | Rel-5 | Paolo |  |
| 2281 | 107.2 | **Modification of BSSGP protocol** | 5d | 2002-06-24 A | 2002-06-28 A | 100% | 2002-06-24 | 2002-06-28 | 5d |  | GP | 80h | 80h |  | Ericsson | ingemar.backlund@era.ericsson.se | Rel-5 | Paolo |  |
| 2282 | 107.2.1 | Stage 3 (changes to 48.018) | 5d | 2002-06-24 A | 2002-06-28 A | 100% | 2002-06-24 | 2002-06-28 | 5d | finish no earlier than 2002-06-28 | G2 | 40h | 40h |  |  |  | Rel-5 | Gert |  |
| 2283 | 108 | **Deleted - Multiple TBF in A/Gb mode - Phase 1** | 421d | 2002-04-19 A | 2003-11-28 A | 100% | 2002-04-19 | 2003-11-28 | 421d |  | GP | 17480h | 17480h | MULTBF | Ericsson | gunnar.mildh@era.ericsson.se | Rel-5 | Paolo | GP-17 |
| 2284 | 108.1 | **Deleted - Multiple TBF in A/Gb mode - Phase 1** | 351d | 2002-04-19 A | 2003-08-22 A | 100% | 2002-04-19 | 2003-08-22 | 351d |  | GP | 8112h | 8112h | MULTBF-Agbmode |  |  | Rel-5 | Paolo | GP-17 |
| 2285 | 108.1.1 | Deleted - Multiple TBF Concept paper | 351d | 2002-04-19 A | 2003-08-22 A | 100% | 2002-04-19 | 2003-08-22 | 351d | finish no earlier than 2003-08-22 | GP | 2808h | 2808h | MULTBF-Agbmode |  |  | Rel-5 | Paolo | GP-17 |
| 2286 | 108.1.2 | Deleted - Multiple TBF Stage 2 (43.064) CRs | 156d | 2002-04-19 A | 2002-11-22 A | 100% | 2002-04-19 | 2002-11-22 | 156d | finish no earlier than 2002-11-22 | G1 | 1248h | 1248h | MULTBF-Agbmode |  |  | Rel-5 | Paolo | GP-12 |
| 2287 | 108.1.3 | Deleted - Multiple TBF Stage 3 (44.060) CRs | 156d | 2002-04-19 A | 2002-11-22 A | 100% | 2002-04-19 | 2002-11-22 | 156d | finish no earlier than 2002-11-22 | G2 | 1248h | 1248h | MULTBF-Agbmode |  |  | Rel-5 | Gert | GP-12 |
| 2288 | 108.2 | **Deleted - Multiple TBF in A/Gb mode – MS testing** | 375d | 2002-06-24 A | 2003-11-28 A | 100% | 2002-06-24 | 2003-11-28 | 375d |  | GP | 6000h | 6000h |  | Ericsson | ingemar.backlund@era.ericsson.se | Rel-5 | Paolo | GP-17 |
| 2289 | 108.2.1 | Deleted - MS conformance tests | 375d | 2002-06-24 A | 2003-11-28 A | 100% | 2002-06-24 | 2003-11-28 | 375d | finish no earlier than 2003-11-28 | G4 | 3000h | 3000h |  |  |  | Rel-5 | Paolo | GP-17 |
| 2290 | 109 | **Alignment of 3G functional split and Iu** | 922d | 2000-06-08 A | 2003-12-19 A | 100% | 2000-06-08 | 2003-12-19 | 922d |  | GP | 126664h | 126664h | GER3GAL | Ericsson | Frank Muller | Rel-5 | Paolo |  |
| 2291 | 109.1 | **GERAN user / control plane** | 540d | 2000-08-07 A | 2002-08-30 A | 100% | 2000-08-07 | 2002-08-30 | 540d |  | GP | 36232h | 36232h | GER3GAL-GUCOPL | Ericsson | Frank Muller | Rel-5 | Paolo |  |
| 2292 | 109.1.1 | **Alignment with UMTS bearer concept** | 540d | 2000-08-07 A | 2002-08-30 A | 100% | 2000-08-07 | 2002-08-30 | 540d |  | GP | 24952h | 24952h |  |  |  | Rel-5 | Paolo |  |
| 2293 | 109.1.1.1 | Enhanced power control | 1d | 2001-08-31 A | 2001-08-31 A | 100% | 2001-08-31 | 2001-08-31 | 1d | finish no earlier than 2001-08-31 | GP | 8h | 8h |  |  |  | Rel-5 | Paolo |  |
| 2294 | 109.1.1.2 | Stage 2 | 235d | 2000-08-07 A | 2001-06-29 A | 100% | 2000-08-07 | 2001-06-29 | 235d | finish no earlier than 2001-06-29 | GP | 1880h | 1880h |  |  |  | Rel-5 | Paolo |  |
| 2295 | 109.1.1.3 | Adoption of the UTRAN PDCP | 295d | 2000-11-06 A | 2001-12-21 A | 100% | 2000-11-06 | 2001-12-21 | 295d | finish no earlier than 2001-12-21 | GP | 2360h | 2360h |  |  |  | Rel-5 | Paolo |  |
| 2296 | 109.1.1.4 | Development of RLC / MAC | 261d | 2001-08-31 A | 2002-08-30 A | 100% | 2001-08-31 | 2002-08-30 | 261d | finish no earlier than 2002-08-30 | GP | 2088h | 2088h |  |  |  | Rel-5 | Paolo |  |
| 2297 | 109.1.1.5 | Development of GERAN RRC | 266d | 2001-06-22 A | 2002-06-28 A | 100% | 2001-06-22 | 2002-06-28 | 266d | finish no earlier than 2002-06-28 | GP | 2128h | 2128h |  |  |  | Rel-5 | Paolo |  |
| 2298 | 109.1.1.6 | Ciphering and integrity protection concept paper | 166d | 2001-08-31 A | 2002-04-19 A | 100% | 2001-08-31 | 2002-04-19 | 166d | finish no earlier than 2002-04-19 | GP | 1328h | 1328h |  |  |  | Rel-5 | Paolo |  |
| 2299 | 109.1.1.7 | Multiple TBF or equivalent Concept paper | 116d | 2001-08-31 A | 2002-02-08 A | 100% | 2001-08-31 | 2002-02-08 | 116d | finish no earlier than 2002-02-08 | GP | 928h | 928h |  |  |  | Rel-5 | Paolo |  |
| 2300 | 109.1.1.8 | Paging concept | 166d | 2001-08-31 A | 2002-04-19 A | 100% | 2001-08-31 | 2002-04-19 | 166d | finish no earlier than 2002-04-19 | GP | 1328h | 1328h |  |  |  | Rel-5 | Paolo |  |
| 2301 | 109.1.1.9 | Dedicated Physical subchannels, includes traffic and control channels | 66d | 2001-08-31 A | 2001-11-30 A | 100% | 2001-08-31 | 2001-11-30 | 66d | finish no earlier than 2001-11-30 | GP | 528h | 528h |  |  |  | Rel-5 | Paolo |  |
| 2302 | 109.1.1.10 | Iu support and broadcast concept | 166d | 2001-08-31 A | 2002-04-19 A | 100% | 2001-08-31 | 2002-04-19 | 166d | finish no earlier than 2002-04-19 | GP | 1328h | 1328h |  |  |  | Rel-5 | Paolo |  |
| 2303 | 109.1.1.11 | Impact of using RLC instead of LAPDm concept | 116d | 2001-08-31 A | 2002-02-08 A | 100% | 2001-08-31 | 2002-02-08 | 116d | finish no earlier than 2002-02-08 | GP | 928h | 928h |  |  |  | Rel-5 | Paolo |  |
| 2304 | 109.1.1.12 | Contention resolution, mobile station identity, and access concept | 66d | 2001-08-31 A | 2001-11-30 A | 100% | 2001-08-31 | 2001-11-30 | 66d | finish no earlier than 2001-11-30 | GP | 528h | 528h |  |  |  | Rel-5 | Paolo |  |
| 2305 | 109.1.1.13 | PDCP concept | 166d | 2001-08-31 A | 2002-04-19 A | 100% | 2001-08-31 | 2002-04-19 | 166d | finish no earlier than 2002-04-19 | GP | 1328h | 1328h |  |  |  | Rel-5 | Paolo |  |
| 2306 | 109.1.1.14 | Downlink delayed TBF release | 261d | 2001-08-31 A | 2002-08-30 A | 100% | 2001-08-31 | 2002-08-30 | 261d | finish no earlier than 2002-08-30 | GP | 2088h | 2088h |  |  |  | Rel-5 | Paolo |  |
| 2307 | 109.1.1.15 | Add transparent RLC Concept | 116d | 2001-08-31 A | 2002-02-08 A | 100% | 2001-08-31 | 2002-02-08 | 116d | finish no earlier than 2002-02-08 | GP | 928h | 928h |  |  |  | Rel-5 | Paolo |  |
| 2308 | 109.1.1.16 | Handover concept | 116d | 2001-08-31 A | 2002-02-08 A | 100% | 2001-08-31 | 2002-02-08 | 116d | finish no earlier than 2002-02-08 | GP | 928h | 928h |  |  |  | Rel-5 | Paolo |  |

Notes:
- 2270: 8/3/2001: test spec is based on R99 core spec, so deleted from Workplan
- 2271: -
- 2272: "Joker" WI, to be used for a Rel 5 CR not related to any feature and with very limited impact on the system
- 2273: "Joker" WI, to be used for small modifications applicable to Rel 5 conformance testing. Moved in from Stoyan/testing WP. / Text3: 34.108, 34.109, 34.121-1, 34.121-2, 34.122, 34.123-1, 34.123-2, 34.123-3, 34.171, 34.229-1, 34.229-2, 34.229-3
- 2274: - / Text3: new TR 22.944
- 2275: - / Text3: 32.802
- 2276: - / Text3: 32.802
- 2277: 50101 -> 50201
- 2278: 50102 -> 50202
- 2279: -
- 2280: 50103 -> 50203
- 2281: -
- 2282: -
- 2283: GP#17 Nov 2003 Moved to Rel-6 as UID_50600 MULTBF (Only Multiple TBF Concept paper produced in Rel-5)
- 2284: Marked as closed 12/2008 (was marked 26% complete)
- 2285: Marked as closed 12/2008 (was marked 50% complete)
- 2286: Marked as stopped 12/2008
- 2287: Marked as stopped 12/2008
- 2288: 08/08: duplicate UID_50106=-> 50206. Marked as stopped 12/2008
- 2289: Not started. Marked as stopped 12/2008
- 2290: AWS, Nokia, Ericsson, Nortel, Siemens, Vodafone
- 2291: AWS, Nokia, Ericsson, Nortel, Siemens, Vodafone
- 2292: -
- 2293: -
- 2294: -
- 2295: Responsible is GERAN; RAN WG2 help may be needed.
- 2296: -
- 2297: -
- 2298: -
- 2299: -
- 2300: -
- 2301: -
- 2302: -
- 2303: -
- 2304: -
- 2305: -
- 2306: -
- 2307: -
- 2308: -

| ID | WBS | Task | Duration | Start | Finish | Complete | Baseline start | Baseline finish | Baseline duration | Constraint | Resources | Work | Actual work | Text6 | Text8 | Text1 | Text4 | Text5 |
| --- | --- | --- | --- | --- | --- | --- | --- | --- | --- | --- | --- | --- | --- | --- | --- | --- | --- | --- |
| 2309 | 109.1.2 | **Physical layer alignment with UMTS bearer concept** | 280d | 2000-11-06 A | 2001-11-30 A | 100% | 2000-11-06 | 2001-11-30 | 280d |  | GP | 6960h | 6960h | Rel-5 | Paolo |  |  |  |
| 2310 | 109.1.2.1 | PDTCH/TCH in 45.003 | 155d | 2000-11-06 A | 2001-06-08 A | 100% | 2000-11-06 | 2001-06-08 | 155d | finish no earlier than 2001-06-08 | GP | 1240h | 1240h | Rel-5 | Paolo |  |  |  |
| 2311 | 109.1.2.2 | Control channels in 45.003 | 155d | 2000-11-06 A | 2001-06-08 A | 100% | 2000-11-06 | 2001-06-08 | 155d | finish no earlier than 2001-06-08 | GP | 1240h | 1240h | Rel-5 | Paolo |  |  |  |
| 2312 | 109.1.2.3 | Receiver performance in 45.005 for PDTCH/TCH and control channels | 280d | 2000-11-06 A | 2001-11-30 A | 100% | 2000-11-06 | 2001-11-30 | 280d | finish no earlier than 2001-11-30 | GP | 2240h | 2240h | Rel-5 | Paolo |  |  |  |
| 2313 | 109.2 | **Iu rg interface** | 430d | 2000-11-06 A | 2002-06-28 A | 100% | 2000-11-06 | 2002-06-28 | 430d |  | GP,RP | 39560h | 39560h | Rel-5 | Paolo | GER3GAL-Iurg | Ericsson | Frank Muller |
| 2314 | 109.2.1 | **Inter BSS interface** | 430d | 2000-11-06 A | 2002-06-28 A | 100% | 2000-11-06 | 2002-06-28 | 430d |  | GP,RP | 20640h | 20640h | Rel-5 | Paolo |  |  |  |
| 2315 | 109.2.1.1 | Identification of requirements | 430d | 2000-11-06 A | 2002-06-28 A | 100% | 2000-11-06 | 2002-06-28 | 430d | finish no earlier than 2002-06-28 | GP | 3440h | 3440h | Rel-5 | Paolo |  |  |  |
| 2316 | 109.2.1.2 | Stage 2 | 430d | 2000-11-06 A | 2002-06-28 A | 100% | 2000-11-06 | 2002-06-28 | 430d | finish no earlier than 2002-06-28 | GP | 3440h | 3440h | Rel-5 | Paolo |  |  |  |
| 2317 | 109.2.1.3 | Adoption of relevant parts from Iur | 430d | 2000-11-06 A | 2002-06-28 A | 100% | 2000-11-06 | 2002-06-28 | 430d | finish no earlier than 2002-06-28 | GP | 3440h | 3440h | Rel-5 | Paolo |  |  |  |
| 2318 | 109.2.1.4 | Complementation with GERAN specifics | 430d | 2000-11-06 A | 2002-06-28 A | 100% | 2000-11-06 | 2002-06-28 | 430d | finish no earlier than 2002-06-28 | GP | 3440h | 3440h | Rel-5 | Paolo |  |  |  |
| 2319 | 109.2.1.5 | Stage 3 | 430d | 2000-11-06 A | 2002-06-28 A | 100% | 2000-11-06 | 2002-06-28 | 430d | finish no earlier than 2002-06-28 | GP | 3440h | 3440h | Rel-5 | Paolo |  |  |  |
| 2320 | 109.2.2 | **Inter BSS-RNS interface** | 430d | 2000-11-06 A | 2002-06-28 A | 100% | 2000-11-06 | 2002-06-28 | 430d |  | GP,RP | 15480h | 15480h | Rel-5 | Paolo |  |  |  |
| 2321 | 109.2.2.1 | Identification of requirements | 430d | 2000-11-06 A | 2002-06-28 A | 100% | 2000-11-06 | 2002-06-28 | 430d | start no earlier than 2000-11-06 | GP,R3 | 3440h | 3440h | Rel-5 | Paolo |  |  |  |
| 2322 | 109.2.2.2 | Stage 2 | 430d | 2000-11-06 A | 2002-06-28 A | 100% | 2000-11-06 | 2002-06-28 | 430d | finish no earlier than 2002-06-28 | GP,R3 | 3440h | 3440h | Rel-5 | Paolo |  |  |  |
| 2323 | 109.2.2.3 | Adoption of relevant parts from Iur | 430d | 2000-11-06 A | 2002-06-28 A | 100% | 2000-11-06 | 2002-06-28 | 430d | finish no earlier than 2002-06-28 | GP,R3 | 3440h | 3440h | Rel-5 | Paolo |  |  |  |
| 2324 | 109.2.2.4 | Complementation with GERAN specifics | 107.5d | 2002-01-30 A | 2002-06-28 A | 100% | 2002-01-30 | 2002-06-28 | 107.5d | finish no earlier than 2002-06-28 | GP,R3 | 860h | 860h | Rel-5 | Paolo |  |  |  |
| 2325 | 109.2.2.5 | Stage 3 | 107.5d | 2002-01-30 A | 2002-06-28 A | 100% | 2002-01-30 | 2002-06-28 | 107.5d | finish no earlier than 2002-06-28 | GP,R3 | 860h | 860h | Rel-5 | Paolo |  |  |  |
| 2326 | 109.3 | **Voice over GERAN PS and CS concept** | 430d | 2000-11-06 A | 2002-06-28 A | 100% | 2000-11-06 | 2002-06-28 | 430d |  | GP,R3 | 18520h | 18520h | Rel-5 | Paolo |  |  |  |
| 2327 | 109.3.1 | Architecture for A, Iu cs and Iu ps | 430d | 2000-11-06 A | 2002-06-28 A | 100% | 2000-11-06 | 2002-06-28 | 430d | finish no earlier than 2002-06-28 | GP,R3 | 3440h | 3440h | Rel-5 | Paolo |  |  |  |
| 2328 | 109.3.2 | Transcoder position/operation | 115d | 2000-11-06 A | 2001-04-13 A | 100% | 2000-11-06 | 2001-04-13 | 115d | finish no earlier than 2001-04-13 | GP | 920h | 920h | Rel-5 | Paolo |  |  |  |
| 2329 | 109.3.3 | Handover | 430d | 2000-11-06 A | 2002-06-28 A | 100% | 2000-11-06 | 2002-06-28 | 430d | finish no earlier than 2002-06-28 | GP,R3 | 3440h | 3440h | Rel-5 | Paolo |  |  |  |
| 2330 | 109.3.4 | RTP payload | 430d | 2000-11-06 A | 2002-06-28 A | 100% | 2000-11-06 | 2002-06-28 | 430d | finish no earlier than 2002-06-28 | GP,R3 | 3440h | 3440h | Rel-5 | Paolo |  |  |  |
| 2331 | 109.3.5 | Codec renegotiation concept | 365d | 2000-11-06 A | 2002-03-29 A | 100% | 2000-11-06 | 2002-03-29 | 365d | finish no earlier than 2002-03-29 | GP,R3 | 2920h | 2920h | Rel-5 | Paolo |  |  |  |
| 2332 | 109.3.6 | LA | 115d | 2000-11-06 A | 2001-04-13 A | 100% | 2000-11-06 | 2001-04-13 | 115d | finish no earlier than 2001-04-13 | GP | 920h | 920h | Rel-5 | Paolo |  |  |  |

Notes:
- 2309: -
- 2310: -
- 2311: -
- 2312: -
- 2313: AWS, Nokia, Ericsson, Nortel, Siemens, Vodafone
- 2314: -
- 2315: -
- 2316: -
- 2317: -
- 2318: -
- 2319: -
- 2320: -
- 2321: -
- 2322: -
- 2323: -
- 2324: -
- 2325: -
- 2326: -
- 2327: -
- 2328: -
- 2329: -
- 2330: -
- 2331: -
- 2332: -

| ID | WBS | Task | Duration | Start | Finish | Complete | Baseline start | Baseline finish | Baseline duration | Constraint | Resources | Work | Actual work | Text6 | Text8 | Text12 | Text1 | Text4 | Text5 |
| --- | --- | --- | --- | --- | --- | --- | --- | --- | --- | --- | --- | --- | --- | --- | --- | --- | --- | --- | --- |
| 2333 | 109.4 | **Deleted - GERAN MS Conformance test for GERAN interface evolution** | 660d | 2001-06-11 A | 2003-12-19 A | 100% | 2001-06-11 | 2003-12-19 | 660d |  | GP | 10560h | 10560h | Rel-5 | Paolo | GP-17 |  |  |  |
| 2334 | 109.4.1 | Deleted - MS test | 660d | 2001-06-11 A | 2003-12-19 A | 100% | 2001-06-11 | 2003-12-19 | 660d | finish no earlier than 2003-12-19 | GP | 5280h | 5280h | Rel-5 | Paolo | GP-17 |  |  |  |
| 2335 | 109.5 | **GERAN BSS Conformance test for GERAN interface evolution** | 922d | 2000-06-08 A | 2003-12-19 A | 100% | 2000-06-08 | 2003-12-19 | 922d |  | GP | 14752h | 14752h | Rel-5 | Paolo |  |  |  |  |
| 2336 | 109.5.1 | Deleted - BSS test | 922d | 2000-06-08 A | 2003-12-19 A | 100% | 2000-06-08 | 2003-12-19 | 922d | finish no earlier than 2003-12-19 | GP | 7376h | 7376h | Rel-5 | Paolo | GP-17 |  |  |  |
| 2337 | 110 | **GERAN support for IMS** | 690d | 2000-05-01 A | 2002-12-20 A | 100% | 2000-05-01 | 2002-12-20 | 690d |  | GP | 39198.4h | 39198.4h | Rel-5 | Paolo |  | GERIMS | Nokia | Shkumbin Hamiti |
| 2338 | 110.1 | **GERAN Header adaptation** | 690d | 2000-05-01 A | 2002-12-20 A | 100% | 2000-05-01 | 2002-12-20 | 690d |  | GP,S2,RP | 12302.8h | 12302.8h | Rel-5 | Paolo |  | GERIMS-HEADAPT | Nokia | Shkumbin Hamiti |
| 2339 | 110.1.1 | Definition of compression and removal modes for PDCP protocol | 15.05d | 2000-05-01 A | 2000-06-09 A | 100% | 2000-05-01 | 2000-06-09 | 15.05d | finish no earlier than 2000-09-01 | GP,S2,RP | 120.4h | 120.4h | Rel-5 | Paolo |  |  |  |  |
| 2340 | 110.1.2 | Conceptual description in stage 2 | 393d | 2000-05-01 A | 2001-10-31 A | 100% | 2000-05-01 | 2001-10-31 | 393d | finish no earlier than 2001-10-31 | GP,S2,RP | 3144h | 3144h | Rel-5 | Paolo |  |  |  |  |
| 2341 | 110.1.3 | Necessary changes on stage 3 regarding header removal | 439.8d | 2000-11-06 A | 2002-12-20 A | 100% | 2000-11-06 | 2002-12-20 | 439.8d | finish no earlier than 2002-12-20 | GP,S2,RP | 3518.4h | 3518.4h | Rel-5 | Paolo |  |  |  |  |
| 2342 | 110.2 | **Deleted - GERAN Radio access bearer design for IMS** | 430d | 2000-11-06 A | 2002-06-28 A | 100% | 2000-11-06 | 2002-06-28 | 430d |  | GP,S2,RP | 9287.6h | 9287.6h | Rel-5 | Paolo | GP-10 | GERIMS-RABDES | Nokia | Shkumbin Hamiti |
| 2343 | 110.2.1 | **Deleted - MuM control signalling for conversational multimedia services** | 430d | 2000-11-06 A | 2002-06-28 A | 100% | 2000-11-06 | 2002-06-28 | 430d |  | GP,S2,RP | 5847.6h | 5847.6h | Rel-5 | Paolo | GP-10 |  |  |  |
| 2344 | 110.2.1.1 | Deleted - Identification of requirements | 330d | 2000-11-06 A | 2002-02-08 A | 100% | 2000-11-06 | 2002-02-08 | 330d | finish no earlier than 2002-02-08 | GP,S2,RP | 2640h | 2640h | Rel-5 | Paolo | GP-08 |  |  |  |
| 2345 | 110.2.1.2 | Deleted - Necessary modifications due to SIP | 40d | 2002-05-06 A | 2002-06-28 A | 100% | 2002-05-06 | 2002-06-28 | 40d | finish no earlier than 2002-06-28 | GP,S2,RP | 320h | 320h | Rel-5 | Paolo | GP-10 |  |  |  |
| 2346 | 110.3 | **Deleted - GERAN MS Conformance test for support of IMS** | 400d | 2001-06-11 A | 2002-12-20 A | 100% | 2001-06-11 | 2002-12-20 | 400d |  | GP | 6400h | 6400h | Rel-5 | Paolo | GP-12 | GERIMS-MSconf | Nokia | Shkumbin Hamiti |
| 2347 | 110.3.1 | Deleted - MS test | 400d | 2001-06-11 A | 2002-12-20 A | 100% | 2001-06-11 | 2002-12-20 | 400d | finish no earlier than 2002-12-20 | G4 | 3200h | 3200h | Rel-5 | Paolo | GP-12 |  |  |  |
| 2348 | 110.4 | **Deleted - GERAN BTS Conformance test for support of IMS** | 400d | 2001-06-11 A | 2002-12-20 A | 100% | 2001-06-11 | 2002-12-20 | 400d |  | GP | 6400h | 6400h | Rel-5 | Paolo | GP-12 | GERIMS-BTSconf | Nokia | Shkumbin Hamiti |
| 2349 | 110.4.1 | Deleted - BTS test | 400d | 2001-06-11 A | 2002-12-20 A | 100% | 2001-06-11 | 2002-12-20 | 400d | finish no earlier than 2002-12-20 | G3new | 3200h | 3200h | Rel-5 | Ingbert | GP-12 |  |  |  |
| 2350 | 623 | MS Conformance Testing of Dual Transfer Mode | 65d? | 2002-11-11 A | 2003-02-07 A | 100% | 2002-11-11 | 2003-02-07 | 65d? | finish no earlier than 2003-02-07 | G4,G5 | 520h | 520h | Rel-5 | Paolo |  | MSCTDTM | Vodafone | Dave Fox |
| 2351 | 624 | **Handling of early UEs** | 911d? | 2000-01-03 A | 2003-06-27 A | 100% | 2000-01-03 | 2003-06-27 | 911d? |  | S2 | 4488h | 4488h | Rel-5 | Maurice |  | LATE_UE |  |  |
| 2352 | 624.1 | Feasibility Study | 50d? | 2002-10-07 A | 2002-12-13 A | 100% | 2002-10-07 | 2002-12-13 | 50d? | finish no earlier than 2002-12-13 | S2 | 400h | 400h | Rel-5 | Maurice |  |  |  |  |
| 2353 | 624.2 | Stage 2 | 125d? | 2003-01-06 A | 2003-06-27 A | 100% | 2003-01-06 | 2003-06-27 | 125d? | start no earlier than 2003-01-06 | S2 | 1000h | 1000h | Rel-5 | Maurice |  |  |  |  |
| 2354 | 624.3 | FS for the Early Mobile Handling in UTRAN | 195d | 2002-09-09 A | 2003-06-06 A | 100% | 2002-09-09 | 2003-06-06 | 195d | finish no earlier than 2003-06-06 | R2 | 1560h | 1560h | Rel-5 | Joern |  | FSEarlyUE | Vodafone | Alan Law |
| 2355 | 624.4 | Note: Stage 3 RAN part not shown | 1d | 2000-01-03 A | 2000-01-03 A | 100% | 2000-01-03 | 2000-01-03 | 1d |  | RP | 8h | 8h | Rel-5 |  |  |  |  |  |
| 2356 | 625 | Release 4 Features | 326d? | 2000-01-03 A | 2001-03-30 A | 100% | 2000-01-03 | 2001-03-30 | 326d? |  | NP,GP, RP,SP,TP | 2608h | 2608h | Rel-4 | All |  |  |  |  |

Notes:
- 2333: Not started. Marked as stopped 12/2008
- 2334: Not started. Marked as stopped 12/2008
- 2335: Not started. Marked as stopped 12/2008
- 2336: Not started. Marked as stopped 12/2008
- 2337: AWS, Nokia, Ericsson, Nortel, Siemens, Motorola
- 2338: AWS, Nokia, Ericsson, Nortel, Siemens, Motorola
- 2339: -
- 2340: -
- 2341: -
- 2342: TERMINATED - NOT STANDARDIZED. Marked as stopped 12/2008
- 2343: TERMINATED - NOT STANDARDIZED. Marked as stopped 12/2008
- 2344: TERMINATED - NOT STANDARDIZED
- 2345: TERMINATED - NOT STANDARDIZED
- 2346: TERMINATED - NOT STANDARDIZED. Marked as stopped 12/2008
- 2347: TERMINATED - NOT STANDARDIZED. Marked as stopped 12/2008
- 2348: TERMINATED - NOT STANDARDIZED. Marked as stopped 12/2008
- 2349: TERMINATED - NOT STANDARDIZED. Marked as stopped 12/2008
- 2350: Needed to complete DTM (R99)
- 2351: -
- 2352: -
- 2353: -
- 2354: -
- 2355: -
- 2356: -

| ID | WBS | Task | Duration | Start | Finish | Predecessors | Complete | Baseline start | Baseline finish | Baseline duration | Constraint | Resources | Work | Actual work | Text1 | Text6 | Text8 | Text3 | Text12 | Text4 | Text5 |
| --- | --- | --- | --- | --- | --- | --- | --- | --- | --- | --- | --- | --- | --- | --- | --- | --- | --- | --- | --- | --- | --- |
| 2357 | 15 | **Miscellaneous UE Conformance Testing Activities** | 958d | 2001-04-02 A | 2004-12-01 A |  | 100% | 2001-04-02 | 2004-12-01 | 958d |  | T1 | 36360h | 36360h | MISTST1 | Rel-4 | Ingbert |  |  |  |  |
| 2358 | 15.1 | Optimization of Test Time, RF Aspects (FDD) | 508d | 2001-09-24 A | 2003-09-03 A |  | 100% | 2001-09-24 | 2003-09-03 | 508d | finish no earlier than 2003-09-03 | T1 | 4064h | 4064h | MISTST1-OpFDD | Rel-4 | Ingbert | 34.121 |  |  |  |
| 2359 | 15.2 | Optimization of Test Time, RF Aspects (TDD) | 508d | 2001-09-24 A | 2003-09-03 A |  | 100% | 2001-09-24 | 2003-09-03 | 508d | finish no earlier than 2003-09-03 | T1 | 4064h | 4064h | MISTST1-OpTDD | Rel-4 | Ingbert | 34.122 |  |  |  |
| 2360 | 15.3 | Extensions to R99 Test cases | 139.4w | 2001-04-02 A | 2003-12-02 A |  | 100% | 2001-04-02 | 2003-12-02 | 139.4w | finish no earlier than 2003-12-02 | T1 | 5576h | 5576h | MISTST1-Ext | Rel-4 | Ingbert | 34.123 p 1,2 |  |  |  |
| 2361 | 15.4 | Extension to R99 Test cases - TTCN | 439d | 2002-06-28 A | 2004-03-03 A |  | 100% | 2002-06-28 | 2004-03-03 | 439d | finish no earlier than 2004-03-03 | T1 | 3512h | 3512h |  | Rel-4 | Ingbert |  |  |  |  |
| 2362 | 15.5 | Creation of R99 TCs for TDD - prose | 719d | 2001-10-01 A | 2004-07-01 A |  | 100% | 2001-10-01 | 2004-07-01 | 719d | finish no earlier than 2004-07-01 | T1 | 5752h | 5752h | MISTST1-TDD | Rel-4 | Ingbert | 34.123-1 |  |  |  |
| 2363 | 15.6 | Deleted - Creation of R99 TCs for TDD - TTCN | 587d | 2002-09-03 A | 2004-12-01 A |  | 100% | 2002-09-03 | 2004-12-01 | 587d | finish no earlier than 2004-12-01 | T1 | 4696h | 4696h |  | Rel-4 | Ingbert |  | TP-26 |  |  |
| 2364 | 15.7 | Deleted - Review all other work items for impact on new or exiting 34 series specs. | 25.8w | 2002-07-02 A | 2002-12-27 A |  | 100% | 2002-07-02 | 2002-12-27 | 25.8w | finish no earlier than 2002-12-27 | T1 | 1032h | 1032h | MISTST1 | Rel-4 | Ingbert | 34.121,122,123,125 | TP-18 |  |  |
| 2365 | 46 | **Facsimile** | 89d | 2000-02-22 A | 2000-06-23 A |  | 100% | 2000-02-22 | 2000-06-23 | 89d |  | S1 | 4376h | 4376h | FAX | Rel-4 | Alain |  |  |  |  |
| 2366 | 46.1 | **Real Time Fax** | 89d | 2000-02-22 A | 2000-06-23 A |  | 100% | 2000-02-22 | 2000-06-23 | 89d |  | S2 | 3664h | 3664h | FAX-RT | Rel-4 | Maurice |  |  |  |  |
| 2367 | 46.1.1 | Terminal capabilities, AT commands | 89d | 2000-02-22 A | 2000-06-23 A |  | 100% | 2000-02-22 | 2000-06-23 | 89d | finish no earlier than 2000-06-23 | T2 | 712h | 712h |  | Rel-4 |  | 21.904, 27.007 |  |  |  |
| 2368 | 46.1.2 | Signalling aspects (e.g. ICM) | 89d | 2000-02-22 A | 2000-06-23 A |  | 100% | 2000-02-22 | 2000-06-23 | 89d | start no earlier than 2000-02-22 | N1 | 712h | 712h |  | Rel-4 | Frederic |  |  |  |  |
| 2369 | 46.1.3 | Service provision | 89d | 2000-02-22 A | 2000-06-23 A |  | 100% | 2000-02-22 | 2000-06-23 | 89d | finish no earlier than 2000-06-23 | N3 | 712h | 712h |  | Rel-4 | Gwiho | 23.146 |  |  |  |
| 2370 | 46.1.4 | Review whether service/stage 1 aspects need to be aligned | 51d | 2000-04-14 A | 2000-06-23 A |  | 100% | 2000-04-14 | 2000-06-23 | 51d | finish no earlier than 2000-12-14 | S1 | 408h | 408h |  | Rel-4 | Alain |  |  |  |  |
| 2371 | 46.1.5 | Review whether architecture/stage 2 aspects need to be aligned | 51d | 2000-04-14 A | 2000-06-23 A |  | 100% | 2000-04-14 | 2000-06-23 | 51d | finish no earlier than 2000-12-14 | S2 | 408h | 408h |  | Rel-4 | Maurice |  |  |  |  |
| 2372 | 47 | Transparent End-to-End PS mobile streaming application | 253d | 2000-04-03 A | 2001-03-21 A |  | 100% | 2000-04-03 | 2001-03-21 | 253d | finish no earlier than 2000-12-29 | S4 | 2024h | 2024h | PSTREAM | Rel-4 | Paolo | 26.233, 26.234 |  |  |  |
| 2373 | 48 | **Multimedia Messaging** | 277d | 2000-02-22 A | 2001-03-14 A |  | 100% | 2000-02-22 | 2001-03-14 | 277d |  | T2,S1 | 9992h | 9992h | MMS | Rel-4 | Kimmo | 22.140, 23.140 |  | Siemens | Josef.Laumen@SAL.SIEMENS.DE |
| 2374 | 48.1 | Definition of service requirements | 72d | 2000-02-22 A | 2000-05-31 A |  | 100% | 2000-02-22 | 2000-05-31 | 72d | start no earlier than 2000-02-22 | S1 | 576h | 576h | MMS | Rel-4 | Alain |  |  |  |  |
| 2375 | 48.2 | Review of definition of service requirements | 205d | 2000-06-01 A | 2001-03-14 A | 2374 | 100% | 2000-06-01 | 2001-03-14 | 205d | finish no earlier than 2000-09-08 | T2 | 1640h | 1640h | MMS | Rel-4 | Kimmo | 22.140, 23.140 |  | Siemens |  |
| 2376 | 48.3 | **Technical Realisation** | 243d | 2000-04-10 A | 2001-03-14 A |  | 100% | 2000-04-10 | 2001-03-14 | 243d |  | T2 | 7776h | 7776h | MMS | Rel-4 | Kimmo | 22.140, 23.140 |  | Siemens | Josef.Laumen@SAL.SIEMENS.DE |
| 2377 | 48.3.1 | Review of definition of reference Achitecture model | 243d | 2000-04-10 A | 2001-03-14 A |  | 100% | 2000-04-10 | 2001-03-14 | 243d | finish no earlier than 2001-03-14 | T2 | 1944h | 1944h | MMS | Rel-4 | Kimmo | 22.140, 23.140 |  | Siemens | Josef.Laumen@SAL.SIEMENS.DE |
| 2378 | 48.3.2 | Fulfill Requirements of Stage 1 | 243d | 2000-04-10 A | 2001-03-14 A |  | 100% | 2000-04-10 | 2001-03-14 | 243d | finish no earlier than 2001-03-14 | T2 | 1944h | 1944h | MMS | Rel-4 | Kimmo | 22.140, 23.140 |  | Siemens | Josef.Laumen@SAL.SIEMENS.DE |
| 2379 | 48.3.3 | Definition of MMS primitives in Stage 2 | 243d | 2000-04-10 A | 2001-03-14 A |  | 100% | 2000-04-10 | 2001-03-14 | 243d | finish no earlier than 2001-03-14 | T2 | 1944h | 1944h | MMS | Rel-4 | Kimmo | 22.140, 23.140 |  | Siemens | Josef.Laumen@SAL.SIEMENS.DE |
| 2380 | 49 | **Transcoder-Free Operation** | 326d | 2000-01-03 A | 2001-03-30 A |  | 100% | 2000-01-03 | 2001-03-30 | 326d |  | N4,S2,N1 | 10448h | 10448h | TrFO | Rel-4 | Kimmo |  |  |  |  |
| 2381 | 49.1 | **Out-of-Band Transcoder Control solution** | 326d | 2000-01-03 A | 2001-03-30 A |  | 100% | 2000-01-03 | 2001-03-30 | 326d |  | N4 | 8448h | 8448h | TrFO-OoBTC | Rel-4 | Kimmo |  |  | NEC | Toshiyuki Tamura (tamurato@aj.jp.nec.com) |
| 2382 | 49.1.1 | implementation in UTRAN | 145d | 2000-09-11 A | 2001-03-30 A |  | 100% | 2000-09-11 | 2001-03-30 | 145d | finish no earlier than 2001-03-30 | R3 | 1160h | 1160h | TrFO-OoBTC-UTRAN | Rel-4 | Juha | 25.401, 25.410, 25.413, 25.415, 23.153 |  | Siemens | Alexander Vesely |
| 2383 | 49.1.2 | Impact on architecture, Principles and Terminology | 211d | 2000-01-03 A | 2000-10-20 A |  | 100% | 2000-01-03 | 2000-10-20 | 211d | finish no earlier than 2000-10-20 | S2 | 1680h | 1680h | TrFO-OoBTC | Rel-4 | Maurice |  |  |  |  |
| 2384 | 49.1.3 | Codec Negotiation between UE and MSC | 125d | 2000-08-14 A | 2001-02-02 A |  | 100% | 2000-08-14 | 2001-02-02 | 125d | finish no earlier than 2001-02-02 | N1 | 1000h | 1000h | TrFO-OoBTC | Rel-4 | Frederic | 24.008, 23.009, 23.108, (29.002) |  | Motorola | Andrew Howell |
| 2385 | 49.1.4 | Codec Negotiation inter MSC | 125d | 2000-07-03 A | 2000-12-22 A |  | 100% | 2000-07-03 | 2000-12-22 | 125d | finish no earlier than 2000-12-22 | N4 | 1000h | 1000h | TrFO-OoBTC | Rel-4 | Kimmo |  |  |  |  |
| 2386 | 49.1.5 | Bearer establishment inter MSC | 125d | 2000-07-03 A | 2000-12-22 A |  | 100% | 2000-07-03 | 2000-12-22 | 125d | finish no earlier than 2000-12-22 | N4 | 1000h | 1000h | TrFO-OoBTC | Rel-4 | Kimmo | 23.153 |  |  |  |

Notes:
- 2357: -
- 2358: It is believed that the current R99 test spec. can be optimised for faster overall test times. Marked as stopped 12/2008 (was 70% complete)
- 2359: It is believed that the current R99 test spec. can be optimised for faster overall test times
- 2360: Further test coverage of the R99 specification to cover supplementry services. Marked as stopped 12/2008 (was 70% complete)
- 2361: Marked as closed 12/2008 (was marked 50% complete)
- 2362: Marked as closed 12/2008 (was marked 50% complete)
- 2363: Marked as stopped 12/2008
- 2364: Marked as stopped 12/2008
- 2365: -
- 2366: postponed from R99 to R00, SP-000169
- 2367: -
- 2368: -
- 2369: -
- 2370: -
- 2371: -
- 2372: -
- 2373: -
- 2374: -
- 2375: -
- 2376: -
- 2377: -
- 2378: e.g. minimum set of media formats, media format conversion, personalization of MMS.
- 2379: -
- 2380: Lead given to CN4 from CN / [DAB 28/11/00]
- 2381: -
- 2382: moved according to NP-000575
- 2383: e.g. study cascading TrFO/TFO/TrFO
- 2384: the link to NP-000085has been deleted because refering to a R99 status sheet / One common set of codec negotiation procedures will be specified as in ID1656.
- 2385: Bearer establishment inter MSC. TS 23.153 R99 part complete. capabilities moved to annex + list of open issues
- 2386: Bearer establishment inter MSC. TS 23.153 R99 part complete. capabilities moved to annex. / See NP-000127 / Open issues: / Handling of Conference Calls; / Handling of Multi Party Supplementary Services; / Handling of Handover UMTS to GSM; / Handling of Sending a ...

| ID | WBS | Task | Duration | Start | Finish | Complete | Baseline start | Baseline finish | Baseline duration | Constraint | Resources | Work | Actual work | Text1 | Text6 | Text8 | Text4 | Text5 |
| --- | --- | --- | --- | --- | --- | --- | --- | --- | --- | --- | --- | --- | --- | --- | --- | --- | --- | --- |
| 2387 | 49.2 | **Speech Transcoder: Location and Control at the UMTS Core Network Border** | 125d | 2000-04-10 A | 2000-09-29 A | 100% | 2000-04-10 | 2000-09-29 | 125d |  | S2 | 2000h | 2000h | TrFO-STLC | Rel-4 | Maurice |  |  |
| 2388 | 49.2.1 | Transcoder at Edge | 125d | 2000-04-10 A | 2000-09-29 A | 100% | 2000-04-10 | 2000-09-29 | 125d | finish no earlier than 2000-09-29 | NP | 1000h | 1000h | TrFO-STLC | Rel-4 | Kimmo |  |  |
| 2389 | 50 | **GERAN improvements 1 (Gb over IP)** | 225d | 2000-05-09 A | 2001-03-19 A | 100% | 2000-05-09 | 2001-03-19 | 225d |  | GP | 6472h | 6472h | GEIMP1 | Rel-4 | Paolo |  |  |
| 2390 | 50.1 | **Gb over IP (Ip-fication of Gb)** | 225d | 2000-05-09 A | 2001-03-19 A | 100% | 2000-05-09 | 2001-03-19 | 225d |  | GP | 4672h | 4672h | GbIP | Rel-4 | Paolo |  |  |
| 2391 | 50.1.1 | Concept of Gb over IP (Ip-fication of Gb) | 134d | 2000-05-09 A | 2000-11-10 A | 100% | 2000-05-09 | 2000-11-10 | 134d |  | GP | 1072h | 1072h |  | Rel-4 | Paolo |  |  |
| 2392 | 50.1.2 | Changes to 08.16, 08.18 | 225d | 2000-05-09 A | 2001-03-19 A | 100% | 2000-05-09 | 2001-03-19 | 225d |  | GP | 1800h | 1800h |  | Rel-4 | Paolo |  |  |
| 2393 | 51 | **GERAN improvements 2 (NACC)** | 677d | 2000-11-06 A | 2003-06-10 A | 100% | 2000-11-06 | 2003-06-10 | 677d |  | GP | 19224h | 19224h | GEIMP2 | Rel-4 | Paolo |  |  |
| 2394 | 51.1 | **Gb enhancements** | 155d | 2000-11-06 A | 2001-06-08 A | 100% | 2000-11-06 | 2001-06-08 | 155d |  | GP | 7440h | 7440h | Gben | Rel-4 | Paolo |  |  |
| 2395 | 51.1.1 | **Intra BSC NACC (Network Assisted Cell Change)** | 155d | 2000-11-06 A | 2001-06-08 A | 100% | 2000-11-06 | 2001-06-08 | 155d |  | GP | 6200h | 6200h |  | Rel-4 | Paolo |  |  |
| 2396 | 51.1.1.1 | Concept | 155d | 2000-11-06 A | 2001-06-08 A | 100% | 2000-11-06 | 2001-06-08 | 155d | finish no earlier than 2001-06-08 | GP | 1240h | 1240h |  | Rel-4 | Paolo |  |  |
| 2397 | 51.1.1.2 | Changes in 03.64 | 155d | 2000-11-06 A | 2001-06-08 A | 100% | 2000-11-06 | 2001-06-08 | 155d | finish no earlier than 2001-06-08 | GP | 1240h | 1240h |  | Rel-4 | Paolo |  |  |
| 2398 | 51.1.1.3 | Changes in 04.60 | 155d | 2000-11-06 A | 2001-06-08 A | 100% | 2000-11-06 | 2001-06-08 | 155d | finish no earlier than 2001-06-08 | GP | 1240h | 1240h |  | Rel-4 | Paolo |  |  |
| 2399 | 51.1.1.4 | Changes in 44.008 | 155d | 2000-11-06 A | 2001-06-08 A | 100% | 2000-11-06 | 2001-06-08 | 155d | finish no earlier than 2001-06-08 | GP | 1240h | 1240h |  | Rel-4 | Paolo |  |  |
| 2400 | 51.3 | **MS conformance test for Intra BSC NACC** | 398d | 2001-11-30 A | 2003-06-10 A | 100% | 2001-11-30 | 2003-06-10 | 398d |  | GP | 6368h | 6368h | GEIMP2-Msconf | Rel-4 | Paolo |  |  |
| 2401 | 51.3.1 | Changes in 51.010 | 398d | 2001-11-30 A | 2003-06-10 A | 100% | 2001-11-30 | 2003-06-10 | 398d | finish no earlier than 2003-12-19 | G5,G4 | 3184h | 3184h |  | Rel-4 | Paolo |  |  |
| 2402 | 52 | **GERAN improvements 4 (Delayed TBF)** | 105d | 2001-01-15 A | 2001-06-08 A | 100% | 2001-01-15 | 2001-06-08 | 105d |  | GP | 3960h | 3960h | GEIMP4 | Rel-4 | Paolo |  |  |
| 2403 | 52.1 | **Gb enhancements 2** | 105d | 2001-01-15 A | 2001-06-08 A | 100% | 2001-01-15 | 2001-06-08 | 105d |  | GP | 3120h | 3120h | GEIMP4-Gben2 | Rel-4 | Paolo |  |  |
| 2404 | 52.1.1 | stage 2 | 105d | 2001-01-15 A | 2001-06-08 A | 100% | 2001-01-15 | 2001-06-08 | 105d | finish no earlier than 2001-06-08 | GP | 840h | 840h |  | Rel-4 | Paolo |  |  |
| 2405 | 52.1.2 | **Stage 3 (changes in 44.060)** | 60d | 2001-01-15 A | 2001-04-06 A | 100% | 2001-01-15 | 2001-04-06 | 60d |  | G2 | 1440h | 1440h |  | Rel-4 | Gert |  |  |
| 2406 | 52.1.2.1 | Definition of enhanced countdown procedure | 60d | 2001-01-15 A | 2001-04-06 A | 100% | 2001-01-15 | 2001-04-06 | 60d | finish no earlier than 2001-04-06 | G2 | 480h | 480h |  | Rel-4 | Gert |  |  |
| 2407 | 52.1.2.2 | Definition of enhanced TBF release procedure | 60d | 2001-01-15 A | 2001-04-06 A | 100% | 2001-01-15 | 2001-04-06 | 60d | finish no earlier than 2001-04-06 | G2 | 480h | 480h |  | Rel-4 | Gert |  |  |
| 2408 | 52.1.2.3 | Definition of USF=FREE type polling mechanism on PDCH | 60d | 2001-01-15 A | 2001-04-06 A | 100% | 2001-01-15 | 2001-04-06 | 60d | finish no earlier than 2001-04-06 | G2 | 480h | 480h |  | Rel-4 | Gert |  |  |
| 2409 | 53 | **Low Chip Rate TDD option** | 880d | 2000-07-19 A | 2003-12-02 A | 100% | 2000-07-19 | 2003-12-02 | 880d |  | R1 | 27488h | 27488h | LCRTDD | Rel-4 | Patrick | CWTS | G. Yang |
| 2410 | 53.1 | Physical layer | 183d | 2000-07-19 A | 2001-03-30 A | 100% | 2000-07-19 | 2001-03-30 | 183d | finish no earlier than 2001-03-30 | R1 | 1464h | 1464h | LCRTDD-Phys | Rel-4 | Patrick | CWTS | G. Yang |
| 2411 | 53.2 | Layer 2 and layer 3 protocol aspects | 183d | 2000-07-19 A | 2001-03-30 A | 100% | 2000-07-19 | 2001-03-30 | 183d | finish no earlier than 2001-03-30 | R2 | 1464h | 1464h | LCRTDD-L23 | Rel-4 | Joern | CWTS | Y. Liu |
| 2412 | 53.3 | RF radio transmission/reception, system performance requirements and conformance testing | 165d | 2000-08-14 A | 2001-03-30 A | 100% | 2000-08-14 | 2001-03-30 | 165d | finish no earlier than 2001-03-30 | R4 | 1320h | 1320h | LCRTDD-RF | Rel-4 | Issam | CWTS | D. Zhang |
| 2413 | 53.4 | UE radio access capability | 165d | 2000-08-14 A | 2001-03-30 A | 100% | 2000-08-14 | 2001-03-30 | 165d | finish no earlier than 2001-03-30 | R2 | 1320h | 1320h | LCRTDD-UErac | Rel-4 | Joern | CWTS | Y. Liu |
| 2414 | 53.5 | Iub/Iur protocol aspects | 165d | 2000-08-14 A | 2001-03-30 A | 100% | 2000-08-14 | 2001-03-30 | 165d | finish no earlier than 2001-03-30 | R3 | 1320h | 1320h | LCRTDD-IubIur | Rel-4 | Juha | CWTS | Y. Liu |

Notes:
- 2387: WI description and Tdoc S2-99352 / Speech Transcoder: Location and Control at the UMTS Core Network Border
- 2388: WI description and Tdoc S2-99352...
- 2389: -
- 2390: -
- 2391: -
- 2392: -
- 2393: -
- 2394: -
- 2395: -
- 2396: -
- 2397: -
- 2398: -
- 2399: -
- 2400: -
- 2401: az 05/08: duplicated UID_50099 => 50299. Marked as closed 12/2008 (was marked 50% complete)
- 2402: -
- 2403: -
- 2404: -
- 2405: -
- 2406: -
- 2407: -
- 2408: -
- 2409: -
- 2410: -
- 2411: -
- 2412: -
- 2413: -
- 2414: -

| ID | WBS | Task | Duration | Start | Finish | Predecessors | Complete | Baseline start | Baseline finish | Baseline duration | Constraint | Resources | Work | Actual work | Text6 | Text8 | Text3 | Text12 | Text1 | Text4 | Text5 |
| --- | --- | --- | --- | --- | --- | --- | --- | --- | --- | --- | --- | --- | --- | --- | --- | --- | --- | --- | --- | --- | --- |
| 2415 | 53.6 | **Low chiprate TDD interworking with GERAN** | 101d | 2000-09-01 A | 2001-01-19 A | 2414 | 100% | 2000-09-01 | 2001-01-19 | 101d |  | GP | 1616h | 1616h | Rel-4 | Paolo |  |  |  |  |  |
| 2416 | 53.6.1 | Handover and Cell Selection / Reselection to UTRA 1.28 Mcps TDD | 101d | 2000-09-01 A | 2001-01-19 A |  | 100% | 2000-09-01 | 2001-01-19 | 101d | finish no earlier than 2001-01-19 | GP | 808h | 808h | Rel-4 | Paolo |  |  |  |  |  |
| 2417 | 53.8 | **Conformance Test Aspects - Low Chip Rate TDD** | 577d | 2001-09-17 A | 2003-12-02 A | 2415 | 100% | 2001-09-17 | 2003-12-02 | 577d |  | T1 | 12088h | 12088h | Rel-4 | Ingbert |  |  |  |  |  |
| 2418 | 53.8.1 | Testing Layer 2 and layer 3 protocol aspects | 468d | 2001-09-17 A | 2003-07-02 A |  | 100% | 2001-09-17 | 2003-07-02 | 468d | finish no earlier than 2003-07-02 | T1 | 3744h | 3744h | Rel-4 | Ingbert | 34.123-1, 34.123-2 |  |  |  |  |
| 2419 | 53.8.2 | Deleted - Testing Layer 2 and layer 3 protocol aspects - TTCN | 261d | 2002-12-03 A | 2003-12-02 A |  | 100% | 2002-12-03 | 2003-12-02 | 261d | finish no earlier than 2003-12-02 | T1 | 2088h | 2088h | Rel-4 | Ingbert | 34.123-3 | TP-22 |  |  |  |
| 2420 | 53.8.3 | Testing RF Radio Transmission and Reception | 205d | 2001-09-17 A | 2002-06-28 A |  | 100% | 2001-09-17 | 2002-06-28 | 205d | finish no earlier than 2002-06-28 | T1 | 1640h | 1640h | Rel-4 | Ingbert |  |  |  |  |  |
| 2421 | 54 | **Enable bearer independent CS architecture** | 566d | 2000-01-03 A | 2002-03-01 A |  | 100% | 2000-01-03 | 2002-03-01 | 566d |  | S2 | 20192h | 20192h | Rel-4 | Maurice |  |  | CSSPLIT | Siemens | Alexander Milinski |
| 2422 | 54.1 | **Enable bearer-independent call control** | 425d | 2000-01-03 A | 2001-08-16 A |  | 100% | 2000-01-03 | 2001-08-16 | 425d |  | N4 | 12344h | 12344h | Rel-4 | Kimmo |  |  |  | Ericsson | Heinz-Peter.Keutmann@eed.ericsson.se |
| 2423 | 54.1.1 | Architecture and Stage 2 description | 181d | 2000-01-03 A | 2000-09-08 A |  | 100% | 2000-01-03 | 2000-09-08 | 181d | finish no earlier than 2000-09-08 | S2 | 1440h | 1440h | Rel-4 | Maurice | 23.002 |  |  |  |  |
| 2424 | 54.1.2 | Standardisation of protocols (control & user planes) over Nb interface | 64d | 2001-01-02 A | 2001-03-30 A |  | 100% | 2001-01-02 | 2001-03-30 | 64d | finish no earlier than 2001-03-30 | N3 | 512h | 512h | Rel-4 | Gwiho |  |  |  |  |  |
| 2425 | 54.1.3 | Standardisation of protocols over reference points between MSC server and Gateway MSC server | 130d | 2000-09-25 A | 2001-03-23 A |  | 100% | 2000-09-25 | 2001-03-23 | 130d | finish no earlier than 2001-03-23 | N4 | 1040h | 1040h | Rel-4 | Kimmo |  |  |  |  |  |
| 2426 | 54.1.4 | Standardisation of detailed stage 2 description | 180d | 2000-07-17 A | 2001-03-23 A |  | 100% | 2000-07-17 | 2001-03-23 | 180d | finish no earlier than 2001-03-23 | N4 | 1440h | 1440h | Rel-4 | Kimmo |  |  |  |  |  |
| 2427 | 54.1.5 | **Bearer control between MSC server and MGW** | 250d | 2000-09-01 A | 2001-08-16 A |  | 100% | 2000-09-01 | 2001-08-16 | 250d |  | N4 | 4512h | 4512h | Rel-4 | Kimmo |  |  |  |  |  |
| 2428 | 54.1.5.1 | stage 3 - protocol issues | 250d | 2000-09-01 A | 2001-08-16 A |  | 100% | 2000-09-01 | 2001-08-16 | 250d | finish no earlier than 2001-08-16 | N4 | 2000h | 2000h | Rel-4 | Kimmo |  |  |  |  |  |
| 2429 | 54.1.5.2 | stage 3 - parameter value issues | 64d | 2001-01-02 A | 2001-03-30 A |  | 100% | 2001-01-02 | 2001-03-30 | 64d | finish no earlier than 2001-03-30 | N3 | 512h | 512h | Rel-4 | Gwiho |  |  |  |  |  |
| 2430 | 54.2 | Lawful interception | 155d | 2000-08-21 A | 2001-03-23 A |  | 100% | 2000-08-21 | 2001-03-23 | 155d | finish no earlier than 2001-03-23 | S3 | 1240h | 1240h | Rel-4 | Dionisio |  |  |  |  |  |
| 2431 | 54.4 | Deleted - Conformance Test Aspects - Enable bearer independent CS architecture | 260d | 2001-03-05 A | 2002-03-01 A |  | 100% | 2001-03-05 | 2002-03-01 | 260d |  | T1 | 2080h | 2080h | Rel-4 | Ingbert |  | TP-15 | CSSPLIT-TEST |  |  |
| 2432 | 55 | **MExE enhancements Rel-4** | 511d | 2000-01-03 A | 2001-12-14 A |  | 100% | 2000-01-03 | 2001-12-14 | 511d |  | T2 | 19032h | 19032h | Rel-4 | Kimmo |  |  | MEXE |  |  |
| 2433 | 55.1 | **MExE Security Analysis Activity** | 474d | 2000-02-22 A | 2001-12-14 A |  | 100% | 2000-02-22 | 2001-12-14 | 474d |  | S3 | 8464h | 8464h | Rel-4 | Dionisio |  |  | MEXE-SEC | BT | colin.blanchard@bt.com |
| 2434 | 55.1.1 | Stage 3 | 370d | 2000-07-17 A | 2001-12-14 A |  | 100% | 2000-07-17 | 2001-12-14 | 370d | finish no earlier than 2001-12-14 | S3 | 2960h | 2960h | Rel-4 | Dionisio |  |  | MEXE1-SEC |  |  |
| 2435 | 55.1.2 | Terminal aspects | 214d | 2000-02-22 A | 2000-12-15 A |  | 100% | 2000-02-22 | 2000-12-15 | 214d | finish no earlier than 2000-12-15 | T2 | 1712h | 1712h | Rel-4 |  |  |  |  |  |  |
| 2436 | 55.2 | **MExE Rel4 Improvements and Investigations** | 251d | 2000-01-03 A | 2000-12-15 A |  | 100% | 2000-01-03 | 2000-12-15 | 251d |  | T2 | 6480h | 6480h | Rel-4 | Kimmo | 22.057, 23.057 |  | MEXE-ENHANC | Motorola | Mark Cataldo |
| 2437 | 55.2.1 | 3rd MExE classmark | 251d | 2000-01-03 A | 2000-12-15 A |  | 100% | 2000-01-03 | 2000-12-15 | 251d | finish no earlier than 2000-12-15 | T2 | 2000h | 2000h | Rel-4 | Kimmo | 22.057, 23.057 |  |  | Motorola | Mark Cataldo |
| 2438 | 55.2.2 | FS on Secure download mechanism and capabilities to support SDR concepts | 225d | 2000-02-07 A | 2000-12-15 A |  | 100% | 2000-02-07 | 2000-12-15 | 225d | finish no earlier than 2000-12-15 | T2 | 1800h | 1800h | Rel-4 | Kimmo | 22.057, 23.057 |  |  | Motorola | Mark Cataldo |
| 2439 | 55.2.3 | FS on Support of MP3/MPEG4 content | 225d | 2000-02-07 A | 2000-12-15 A |  | 100% | 2000-02-07 | 2000-12-15 | 225d | finish no earlier than 2000-12-15 | T2 | 1800h | 1800h | Rel-4 | Kimmo | 22.057, 23.057 |  |  | Motorola | Mark Cataldo |

Notes:
- 2415: -
- 2416: -
- 2417: -
- 2418: Marked as closed 12/2008 (was marked 60% complete)
- 2419: Marked as stopped 12/2008
- 2420: duration set to 6 months (was 0), finish date set
- 2421: -
- 2422: DAB 12.12.01 should be 100% hence closed
- 2423: R00 stage 2 at least 80 % complete in TSGS #8 21.-23.6.2000
- 2424: -
- 2425: -
- 2426: -
- 2427: -
- 2428: -
- 2429: -
- 2430: Requirements capture: S3#14 (Aug 00), Feature specification: S3#15 (Sep 00), Definition of architecture. Should be included in general LI work mentioned above.
- 2431: Marked as stopped 12/2008
- 2432: -
- 2433: Presentation to S3 of threats and countermeasures analysis: S3#15, Feature specification: S3#16. S3#18: WID updated
- 2434: Analysis undertaken by T2. No additional analysis needed for Rel-4
- 2435: -
- 2436: -
- 2437: Additional features for MExE R2000
- 2438: -
- 2439: -

| ID | WBS | Task | Duration | Start | Finish | Complete | Baseline start | Baseline finish | Baseline duration | Constraint | Resources | Work | Actual work | Text1 | Text6 | Text8 | Text3 | Text4 | Text5 |
| --- | --- | --- | --- | --- | --- | --- | --- | --- | --- | --- | --- | --- | --- | --- | --- | --- | --- | --- | --- |
| 2440 | 56 | **Tandem Free aspects for 3G and between 2G and 3G systems** | 344d | 2000-02-22 A | 2001-06-15 A | 100% | 2000-02-22 | 2001-06-15 | 344d |  | S4 | 9696h | 9696h | TFO | Rel-4 | Paolo |  |  |  |
| 2441 | 56.1 | **Tandem Free AMR** | 344d | 2000-02-22 A | 2001-06-15 A | 100% | 2000-02-22 | 2001-06-15 | 344d |  | S4 | 6944h | 6944h | TFO-AMR | Rel-4 | Paolo |  |  |  |
| 2442 | 56.1.1 | Specification | 284d | 2000-02-22 A | 2001-03-23 A | 100% | 2000-02-22 | 2001-03-23 | 284d | start no earlier than 2000-02-22 | S4 | 2272h | 2272h |  | Rel-4 | Paolo | 28.062 |  |  |
| 2443 | 56.1.2 | **Impact on:** | 115d | 2001-01-08 A | 2001-06-15 A | 100% | 2001-01-08 | 2001-06-15 | 115d |  | NP | 1920h | 1920h |  | Rel-4 | Kimmo |  |  |  |
| 2444 | 56.1.2.1 | CN | 60d | 2001-03-26 A | 2001-06-15 A | 100% | 2001-03-26 | 2001-06-15 | 60d | finish no earlier than 2001-06-15 | NP | 480h | 480h |  | Rel-4 | Kimmo |  |  |  |
| 2445 | 56.1.2.2 | GERAN | 65d | 2001-01-08 A | 2001-04-06 A | 100% | 2001-01-08 | 2001-04-06 | 65d | finish no earlier than 2001-04-06 | GP | 520h | 520h |  | Rel-4 | Paolo |  |  |  |
| 2446 | 57 | **Advanced Speech Call Items enhancements_REL-4** | 334d | 2000-12-03 A | 2002-03-14 A | 100% | 2000-12-03 | 2002-03-14 | 334d |  | N1 | 5925.6h | 5925.6h | ASCI | Rel-4 | Frederic |  | Nortel | sonia.garapaty@nortelnetworks.com |
| 2447 | 57.1 | Stage 2 | 326.7d | 2000-12-03 A | 2002-03-14 A | 100% | 2000-12-03 | 2002-03-14 | 326.7d | finish no earlier than 2002-03-14 | N4 | 2613.6h | 2613.6h |  | Rel-4 | Kimmo | 23.067, 24.067 | Sagem | Vivien Perlic |
| 2448 | 57.2 | Stages 2 and 3 on A interface | 80d | 2000-12-03 A | 2001-03-23 A | 100% | 2000-12-03 | 2001-03-23 | 80d | finish no earlier than 2001-03-23 | N1 | 640h | 640h |  | Rel-4 | Frederic | 44.068, 44.069, 24.008 | Nortel | sonia.garapaty@nortelnetworks.com |
| 2449 | 58 | **700 MHz spectrum support** | 776d | 2000-01-03 A | 2002-12-20 A | 100% | 2000-01-03 | 2002-12-20 | 776d |  | GP | 25016h | 25016h | 700SS | Rel-4 | Paolo |  |  |  |
| 2450 | 58.1 | **GERAN support for the 700 MHz band** | 276d | 2000-01-03 A | 2001-01-19 A | 100% | 2000-01-03 | 2001-01-19 | 276d |  | GP | 8808h | 8808h |  | Rel-4 | Paolo |  |  |  |
| 2451 | 58.1.1 | Signalling support | 276d | 2000-01-03 A | 2001-01-19 A | 100% | 2000-01-03 | 2001-01-19 | 276d | finish no earlier than 2001-01-19 | GP | 2200h | 2200h |  | Rel-4 | Paolo |  |  |  |
| 2452 | 58.1.2 | Physical layer definitions | 276d | 2000-01-03 A | 2001-01-19 A | 100% | 2000-01-03 | 2001-01-19 | 276d | finish no earlier than 2001-01-19 | GP | 2200h | 2200h |  | Rel-4 | Paolo |  |  |  |
| 2453 | 58.1.3 | Receiver performance and RF budget | 276d | 2000-01-03 A | 2001-01-19 A | 100% | 2000-01-03 | 2001-01-19 | 276d | finish no earlier than 2001-01-19 | GP | 2200h | 2200h |  | Rel-4 | Paolo |  |  |  |
| 2454 | 58.2 | **GERAN MS Conformance test for 700 MHz band** | 175d | 2001-04-02 A | 2001-11-30 A | 100% | 2001-04-02 | 2001-11-30 | 175d |  | GP | 2800h | 2800h |  | Rel-4 | Paolo |  |  |  |
| 2455 | 58.2.1 | MS test | 175d | 2001-04-02 A | 2001-11-30 A | 100% | 2001-04-02 | 2001-11-30 | 175d | finish no earlier than 2001-11-30 | GP | 1400h | 1400h |  | Rel-4 | Paolo |  |  |  |
| 2456 | 58.3 | **GERAN BTS Conformance test for 700 MHz band** | 450d | 2001-04-02 A | 2002-12-20 A | 100% | 2001-04-02 | 2002-12-20 | 450d |  | GP | 7200h | 7200h |  | Rel-4 | Paolo |  |  |  |
| 2457 | 58.3.1 | BTS test | 450d | 2001-04-02 A | 2002-12-20 A | 100% | 2001-04-02 | 2002-12-20 | 450d | finish no earlier than 2002-12-20 | GP | 3600h | 3600h |  | Rel-4 | Paolo |  |  |  |
| 2458 | 59 | Operator Determined Barring for Packet Oriented Services | 208d | 2000-06-01 A | 2001-03-19 A | 100% | 2000-06-01 | 2001-03-19 | 208d | finish no earlier than 2001-03-19 | NP | 1664h | 1664h | ODB | Rel-4 | Kimmo |  | NEC | Toshiyuki Tamura (tamurato@aj.jp.nec.com) |
| 2459 | 60 | **UMTS QoS Architecture for PS Domain** | 759d | 2000-01-03 A | 2002-11-27 A | 100% | 2000-01-03 | 2002-11-27 | 759d |  | S2 | 41312h | 41312h | QoSPS | Rel-4 | Maurice |  | Ericsson | Ina.widegren@era.ericsson.se |
| 2460 | 60.1 | Architecture | 153d | 2000-06-05 A | 2001-01-03 A | 100% | 2000-06-05 | 2001-01-03 | 153d | finish no earlier than 2001-01-03 | S2 | 1224h | 1224h |  | Rel-4 | Maurice | 23.107 |  |  |
| 2461 | 60.2 | Charging and OAM&P for QoS Management | 201d | 2001-09-21 A | 2002-06-28 A | 100% | 2001-09-21 | 2002-06-28 | 201d | finish no earlier than 2002-06-28 | S5 | 1608h | 1608h | QoSPS-OAM | Rel-4 | Dionisio | 32-series | VoiceStream, Motorola |  |
| 2462 | 60.3 | **RAB Quality of Service (re)Negotiation over Iu** | 155d | 2000-08-21 A | 2001-03-23 A | 100% | 2000-08-21 | 2001-03-23 | 155d |  | R3 | 3648h | 3648h | QoSPS-MAPEND-RABQoS | Rel-4 | Juha | 25.413 | Ericsson | A. Molander |
| 2463 | 60.3.1 | RAB Quality of Service Negotiation over Iu | 155d | 2000-08-21 A | 2001-03-23 A | 100% | 2000-08-21 | 2001-03-23 | 155d | finish no earlier than 2001-03-23 | R3 | 1240h | 1240h | QoSPS-MAPEND-RABQoS-Negot | Rel-4 | Juha |  | Ericsson | A. Molander |
| 2464 | 60.3.2 | RAB Quality of Service Negotiation over Iu during relocation | 16d | 2001-03-02 A | 2001-03-23 A | 100% | 2001-03-02 | 2001-03-23 | 16d | start no earlier than 2001-03-02 | R3 | 128h | 128h | QoSPS-MAPEND-RABQoS-NegotReloc | Rel-4 | Juha |  |  |  |
| 2465 | 60.3.3 | RAB Quality of Service Re-Negotiation over Iu | 130d | 2000-09-25 A | 2001-03-23 A | 100% | 2000-09-25 | 2001-03-23 | 130d | finish no earlier than 2001-03-23 | R3 | 1040h | 1040h | QoSPS-MAPEND-RABQoS-ReNegot | Rel-4 | Juha |  | Motorola | S. Irwin |

Notes:
- 2440: RAN and CN to verify no problems for GSM terminals roaming in 3G R99
- 2441: RAN and CN to verify UMTS_AMR_2 support
- 2442: -
- 2443: "Implementation" changed to "Impact on:" by A. Sultan (for better wording)
- 2444: RAN and CN to verify UMTS_AMR_2 support
- 2445: End date Modified from June to March to have it in Rel4
- 2446: Approved at CN#10
- 2447: CN4#11 30/11/02: no inputs received in CN4
- 2448: -
- 2449: -
- 2450: -
- 2451: -
- 2452: -
- 2453: -
- 2454: -
- 2455: -
- 2456: -
- 2457: -
- 2458: Completed WI missing from the P-plan Added for tracking
- 2459: -
- 2460: -
- 2461: -
- 2462: -
- 2463: -
- 2464: -
- 2465: -

| ID | WBS | Task | Duration | Start | Finish | Complete | Baseline start | Baseline finish | Baseline duration | Constraint | Resources | Work | Actual work | Text1 | Text6 | Text8 | Text12 | Text4 | Text5 | Text3 |
| --- | --- | --- | --- | --- | --- | --- | --- | --- | --- | --- | --- | --- | --- | --- | --- | --- | --- | --- | --- | --- |
| 2466 | 60.4 | **GERAN QoS Aspects - Handovers: maintenance of real-time QoS while moving between cells in the PLMN including inter-SGSN and SRNS relocation or possibly other mechanisms** | 501d | 2000-01-03 A | 2001-11-30 A | 100% | 2000-01-03 | 2001-11-30 | 501d |  | GP | 14456h | 14456h | GERQoS | Rel-4 | Paolo |  |  |  |  |
| 2467 | 60.4.1 | **Handover Concept for the PS domain** | 501d | 2000-01-03 A | 2001-11-30 A | 100% | 2000-01-03 | 2001-11-30 | 501d |  | GP | 10448h | 10448h |  | Rel-4 | Paolo |  |  |  |  |
| 2468 | 60.4.1.1 | Stable RT handover report 25.936 including header removal | 14d | 2000-01-03 A | 2000-01-19 A | 100% | 2000-01-03 | 2000-01-19 | 14d | start no earlier than 2000-01-03 | GP [92.9%] | 104h | 104h |  | Rel-4 | Paolo |  |  |  |  |
| 2469 | 60.4.1.2 | Update of stage 2 | 293d | 2000-01-03 A | 2001-02-13 A | 100% | 2000-01-03 | 2001-02-13 | 293d | finish no earlier than 2001-02-13 | GP | 2336h | 2336h |  | Rel-4 | Paolo |  |  |  |  |
| 2470 | 60.4.1.3 | Update of relevant stage 3 specs -> RRC | 501d | 2000-01-03 A | 2001-11-30 A | 100% | 2000-01-03 | 2001-11-30 | 501d | finish no earlier than 2001-11-30 | G2 | 4000h | 4000h |  | Rel-4 | Gert |  |  |  |  |
| 2471 | 60.5 | **Deleted - GERAN MS Conformance test for inter-system and intra-system Packet data real-time Handover** | 324d | 2001-08-31 A | 2002-11-27 A | 100% | 2001-08-31 | 2002-11-27 | 324d |  | G4,R3 | 12960h | 12960h | GERQoS-Mstest | Rel-4 | Paolo | GP-12 |  |  |  |
| 2472 | 60.5.1 | **Deleted - Handover for the PS domain** | 324d | 2001-08-31 A | 2002-11-27 A | 100% | 2001-08-31 | 2002-11-27 | 324d |  | G4,R3 | 10368h | 10368h |  | Rel-4 | Paolo | GP-12 |  |  |  |
| 2473 | 60.5.1.1 | Deleted - Stable RT handover report 25.936 including header removal | 324d | 2001-08-31 A | 2002-11-27 A | 100% | 2001-08-31 | 2002-11-27 | 324d | finish no earlier than 2002-11-27 | G4,R3 | 2592h | 2592h |  | Rel-4 | Paolo | GP-12 |  |  |  |
| 2474 | 60.5.1.2 | Deleted - Update of stage 2 | 324d | 2001-08-31 A | 2002-11-27 A | 100% | 2001-08-31 | 2002-11-27 | 324d | finish no earlier than 2002-11-27 | G4,R3 | 2592h | 2592h |  | Rel-4 | Paolo | GP-12 |  |  |  |
| 2475 | 60.5.1.3 | Deleted - Update of relevant stage 3 specs | 324d | 2001-08-31 A | 2002-11-27 A | 100% | 2001-08-31 | 2002-11-27 | 324d | finish no earlier than 2002-11-27 | G4,R3 | 2592h | 2592h |  | Rel-4 | Paolo | GP-12 |  |  |  |
| 2476 | 60.6 | PS-domain handover for real-time services | 155d | 2000-08-28 A | 2001-03-30 A | 100% | 2000-08-28 | 2001-03-30 | 155d | finish no earlier than 2001-03-30 | R3 | 1240h | 1240h | QoSPS-PSdoRTS | Rel-4 | Juha |  | Nokia | A. Lansisalmi |  |
| 2477 | 60.7 | Deleted - RAB QoS Renegotiation at Relocation | 58d | 2001-01-03 A | 2001-03-23 A | 100% | 2001-01-03 | 2001-03-23 | 58d | finish no earlier than 2001-03-23 | R3 | 464h | 464h |  | Rel-4 | Juha | RP-11 |  |  | 25.851, 25.946 |
| 2478 | 61 | (Small) Technical Enhancements and Improvements for Rel-4 | 326d? | 2000-01-03 A | 2001-03-30 A | 100% | 2000-01-03 | 2001-03-30 | 326d? |  | All | 2608h | 2608h | TEI4 | Rel-4 | all |  |  |  |  |
| 2479 | 643 | Test - (Small) Technical Enhancements and Improvements for Rel-4 | 326d? | 2000-01-03 A | 2001-03-30 A | 100% | 2000-01-03 | 2001-03-30 | 326d? | finish no earlier than 2008-12-31 | R5,T1 | 2608h | 2608h | TEI4_Test | Rel-4 | Ingbert |  |  |  |  |
| 2480 | 62 | **Rel-4 Evolutions of the transport in the UTRAN** | 525d | 2000-08-21 A | 2002-08-23 A | 100% | 2000-08-21 | 2002-08-23 | 525d |  | RP | 8600h | 8600h | ETRAN | Rel-4 | Issam |  | Alcatel | Francois Courau |  |
| 2481 | 62.1 | QoS optimization for AAL2 connections over Iub and Iur interfaces | 160d | 2000-08-21 A | 2001-03-30 A | 100% | 2000-08-21 | 2001-03-30 | 160d | finish no earlier than 2001-03-30 | R3 | 1280h | 1280h | ETRAN-QoSAAL2 | Rel-4 | Juha |  | Japan Telecom | T. Yoshimura |  |
| 2482 | 62.2 | Transport bearer modification procedure on Iub, Iur, and Iu | 130d | 2000-10-02 A | 2001-03-30 A | 100% | 2000-10-02 | 2001-03-30 | 130d | finish no earlier than 2001-03-30 | R3 | 1040h | 1040h | ETRAN-MigrMod | Rel-4 | Juha |  | Japan Telecom | T. Yoshimura |  |
| 2483 | 62.3 | **Deleted - Conformance Test Aspects of Rel-4 evolutions of the transport in UTRAN** | 130d | 2002-02-25 A | 2002-08-23 A | 100% | 2002-02-25 | 2002-08-23 | 130d |  | T1 | 2080h | 2080h |  | Rel-4 | Ingbert | TP-17 |  |  |  |
| 2484 | 62.3.1 | Deleted - Testing RAB support enhancements | 130d | 2002-02-25 A | 2002-08-23 A | 100% | 2002-02-25 | 2002-08-23 | 130d | finish no earlier than 2002-08-23 | T1 | 1040h | 1040h | CT-RABS? | Rel-4 | Ingbert | TP-17 |  |  | 34.108, 34. 121, 34.122, 34.123 p 1,2, 34.123 pt 3 |
| 2485 | 63 | **Rel-4 Evolutions of the transport in the CN** | 215d | 2000-05-29 A | 2001-03-23 A | 100% | 2000-05-29 | 2001-03-23 | 215d |  | N4,N1,N2,S2 | 7968h | 7968h | CNTRSP | Rel-4 | Kimmo |  |  |  |  |
| 2486 | 63.1 | **IP Transport of CN protocols (e.g., CAP, MAP)** | 77d | 2000-12-07 A | 2001-03-23 A | 100% | 2000-12-07 | 2001-03-23 | 77d |  | N4 | 2808h | 2808h | SS7IP | Rel-4 | Kimmo |  |  |  |  |
| 2487 | 63.1.1 | **Stage 3** | 77d | 2000-12-07 A | 2001-03-23 A | 100% | 2000-12-07 | 2001-03-23 | 77d |  | N4 | 2192h | 2192h |  | Rel-4 | Kimmo |  |  |  |  |
| 2488 | 63.1.1.1 | CAP | 77d | 2000-12-07 A | 2001-03-23 A | 100% | 2000-12-07 | 2001-03-23 | 77d | finish no earlier than 2001-03-23 | N2 | 616h | 616h |  | Rel-4 | Kimmo |  |  |  |  |
| 2489 | 63.1.1.2 | MAP | 77d | 2000-12-07 A | 2001-03-23 A | 100% | 2000-12-07 | 2001-03-23 | 77d | finish no earlier than 2001-03-23 | N4 | 616h | 616h |  | Rel-4 | Kimmo |  |  |  |  |
| 2490 | 63.1.1.3 | BSSAP+ | 43d | 2001-01-15 A | 2001-03-14 A | 100% | 2001-01-15 | 2001-03-14 | 43d | finish no earlier than 2001-03-14 | N1 | 344h | 344h | SS7IP-BSSAP+ | Rel-4 | Frederic |  |  |  |  |

Notes:
- 2466: -
- 2467: -
- 2468: -
- 2469: -
- 2470: -
- 2471: Still exist? To be clarified by GERAN4/5. Marked as stopped 12/2008
- 2472: Marked as stopped 12/2008
- 2473: Marked as stopped 12/2008
- 2474: Marked as stopped 12/2008
- 2475: Marked as stopped 12/2008
- 2476: -
- 2477: Marked as stopped 12/2008
- 2478: "Joker" WI, to be used for a Rel 4 CR not related to any feature and with very limited impact on the system
- 2479: "Joker" WI, to be used for small modifications applicable to Rel 4 conformance testing. Moved in from the Stoyan/Testing WP
- 2480: -
- 2481: -
- 2482: -
- 2483: Marked as stopped 12/2008
- 2484: Marked as stopped 12/2008
- 2485: -
- 2486: -
- 2487: -
- 2488: -
- 2489: -
- 2490: -

| ID | WBS | Task | Duration | Start | Finish | Complete | Baseline start | Baseline finish | Baseline duration | Constraint | Resources | Work | Actual work | Text4 | Text5 | Text6 | Text8 | Text1 | Text3 | Text12 |
| --- | --- | --- | --- | --- | --- | --- | --- | --- | --- | --- | --- | --- | --- | --- | --- | --- | --- | --- | --- | --- |
| 2491 | 63.2 | **FS on Transport and control separation in the PS CN domain** | 215d | 2000-05-29 A | 2001-03-23 A | 100% | 2000-05-29 | 2001-03-23 | 215d |  | S2 | 3440h | 3440h | Ericsson | Juan-Antonio.Ibanez@eed.ericsson.se | Rel-4 | Maurice |  |  |  |
| 2492 | 63.2.1 | Architectural impacts | 215d | 2000-05-29 A | 2001-03-23 A | 100% | 2000-05-29 | 2001-03-23 | 215d | finish no earlier than 2001-03-23 | S2 | 1720h | 1720h |  |  | Rel-4 | Maurice |  |  |  |
| 2493 | 64 | **Rel-4 Improvements of Radio Interface** | 700d | 2000-07-10 A | 2003-03-14 A | 100% | 2000-07-10 | 2003-03-14 | 700d |  | RP | 28624h | 28624h |  |  | Rel-4 |  | RInImp |  |  |
| 2494 | 64.1 | UTRA repeater specification (master) | 183d | 2000-07-10 A | 2001-03-21 A | 100% | 2000-07-10 | 2001-03-21 | 183d | finish no earlier than 2001-03-21 | R4 | 1464h | 1464h | Mikom, Allgon | T. Kummetz, Mikom; Alf Ahlström, Allgon | Rel-4 | Issam | RInImp-REP |  |  |
| 2495 | 64.2 | DSCH power control improvement in soft handover | 140d | 2000-09-11 A | 2001-03-23 A | 100% | 2000-09-11 | 2001-03-23 | 140d | finish no earlier than 2001-03-23 | R1 | 1120h | 1120h | Nokia | antti.toskala@nokia.com | Rel-4 | Patrick | RInImp-DSCHsho |  |  |
| 2496 | 64.3 | UMTS 1800 | 320d | 2000-09-25 A | 2001-12-14 A | 100% | 2000-09-25 | 2001-12-14 | 320d | finish no earlier than 2001-12-14 | R4 | 2560h | 2560h | Motorola | Howard Benn | Rel-4 | Issam | RInImp-UMTS18 |  |  |
| 2497 | 64.4 | UMTS 1900 | 195d | 2001-03-19 A | 2001-12-14 A | 100% | 2001-03-19 | 2001-12-14 | 195d | finish no earlier than 2001-12-14 | R4 | 1560h | 1560h | Motorola | Howard Benn | Rel-4 | Issam | RInImp-UMTS19 | 25.101 |  |
| 2498 | 64.5 | FS on High Speed downlink packet access | 155d | 2000-08-21 A | 2001-03-23 A | 100% | 2000-08-21 | 2001-03-23 | 155d | finish no earlier than 2001-03-23 | R2 | 1240h | 1240h | Motorola | A. Ghosh | Rel-4 | Joern | RInImp-HSDPA |  |  |
| 2499 | 64.6 | Deleted - FS on improved common DL channel for Cell-FACH state | 340d | 2000-09-11 A | 2001-12-28 A | 100% | 2000-09-11 | 2001-12-28 | 340d | finish no earlier than 2001-12-28 | R2 | 2720h | 2720h | GBT | J. Kwak | Rel-4 | Joern | RInImp-DLCFACH |  | RP-14 |
| 2500 | 64.7 | **Conformance Test Spec. Rel-4 improvements in Radio Interface** | 375d | 2001-10-08 A | 2003-03-14 A | 100% | 2001-10-08 | 2003-03-14 | 375d |  | T1 | 12360h | 12360h |  |  | Rel-4 | Ingbert |  |  |  |
| 2501 | 64.7.1 | Deleted - Testing Improved usage of downlink resource in FDD for CCTrCHs of dedicated type | 140d | 2002-02-18 A | 2002-08-30 A | 100% | 2002-02-18 | 2002-08-30 | 140d | finish no earlier than 2002-08-30 | T1 | 1120h | 1120h |  |  | Rel-4 | Ingbert |  |  | TP-17 |
| 2502 | 64.7.2 | Deleted - Testing Terminal Power saving features | 140d | 2002-02-18 A | 2002-08-30 A | 100% | 2002-02-18 | 2002-08-30 | 140d | finish no earlier than 2002-08-30 | T1 | 1120h | 1120h |  |  | Rel-4 | Ingbert |  |  | TP-17 |
| 2503 | 64.7.3 | Deleted - Testing DSCH power control improvement in soft handover | 140d | 2002-02-18 A | 2002-08-30 A | 100% | 2002-02-18 | 2002-08-30 | 140d | finish no earlier than 2002-08-30 | T1 | 1120h | 1120h |  |  | Rel-4 | Ingbert |  |  | TP-17 |
| 2504 | 64.7.4 | Testing UMTS 1800 | 180d | 2001-10-08 A | 2002-06-14 A | 100% | 2001-10-08 | 2002-06-14 | 180d | finish no earlier than 2002-06-14 | T1 | 1440h | 1440h |  |  | Rel-4 | Ingbert |  | 34.108, 34,121, 34.122, 34.123-1 |  |
| 2505 | 64.7.5 | Testing UMTS 1900 | 180d | 2001-10-08 A | 2002-06-14 A | 100% | 2001-10-08 | 2002-06-14 | 180d | finish no earlier than 2002-06-14 | T1 | 1440h | 1440h |  |  | Rel-4 | Ingbert |  | 34.108, 34,121, 34.122, 34.123-1 |  |
| 2506 | 64.7.6 | Testing UMTS 1800 - TTCN | 195d | 2002-06-17 A | 2003-03-14 A | 100% | 2002-06-17 | 2003-03-14 | 195d | finish no earlier than 2003-03-14 | T1 | 1560h | 1560h |  |  | Rel-4 | Ingbert |  | 34.123-3 |  |
| 2507 | 64.7.7 | Testing UMTS 1900 - TTCN | 195d | 2002-06-17 A | 2003-03-14 A | 100% | 2002-06-17 | 2003-03-14 | 195d | finish no earlier than 2003-03-14 | T1 | 1560h | 1560h |  |  | Rel-4 | Ingbert |  | 34.123-3 |  |
| 2508 | 65 | **Rel-4 RAN improvements** | 938d? | 2000-08-14 A | 2004-03-17 A | 100% | 2000-08-14 | 2004-03-17 | 938d? |  | RP | 29336h | 29336h |  |  | Rel-4 |  | RANimp |  |  |
| 2509 | 65.1 | Node B synchronization for TDD | 160d | 2000-08-14 A | 2001-03-23 A | 100% | 2000-08-14 | 2001-03-23 | 160d | finish no earlier than 2001-03-23 | R1 | 1280h | 1280h | Siemens | S. Oestreich | Rel-4 | Patrick | RANimp-NBsync |  |  |
| 2510 | 65.2 | RAB support enhancement for Rel-4 | 155d | 2000-08-21 A | 2001-03-23 A | 100% | 2000-08-21 | 2001-03-23 | 155d | finish no earlier than 2001-03-23 | R2 | 1240h | 1240h | Ericsson | M. Israelsson, A. Krishnarajah | Rel-4 | Joern | RANimp-RABSE |  |  |
| 2511 | 65.4 | **Deleted - Conformance Test Aspects - Rel-4 RAN Improvements** | 577d? | 2002-01-01 A | 2004-03-17 A | 100% | 2002-01-01 | 2004-03-17 | 577d? |  | T1 | 19312h | 19312h |  |  | Rel-4 | Ingbert |  |  | TP-23 |
| 2512 | 65.4.1 | Deleted - Testing Radio access bearer support enhancments | 175d | 2002-01-01 A | 2002-09-02 A | 100% | 2002-01-01 | 2002-09-02 | 175d | finish no earlier than 2002-09-02 | T1 | 1400h | 1400h |  |  | Rel-4 | Ingbert |  |  | TP-17 |
| 2513 | 65.4.2 | Deleted - Testing RAB support enhancements-Robust Header Compression | 332d | 2002-05-28 A | 2003-09-03 A | 100% | 2002-05-28 | 2003-09-03 | 332d | finish no earlier than 2003-09-03 | T1 | 2656h | 2656h |  |  | Rel-4 | Ingbert | RABimp-RoCH | 34.123-1, -2 | TP-21 |
| 2514 | 65.4.3 | Deleted - Testing RAB support enhancements-Robust Header Compression - TTCN | 472d | 2002-05-28 A | 2004-03-17 A | 100% | 2002-05-28 | 2004-03-17 | 472d | finish no earlier than 2004-03-17 | T1 | 3776h | 3776h |  |  | Rel-4 | Ingbert |  | 34.123-3 | TP-23 |
| 2515 | 65.4.4 | Testing of Extended Robut Header Compression | 270d | 2002-09-18 A | 2003-09-30 A | 100% | 2002-09-18 | 2003-09-30 | 270d | finish no earlier than 2003-09-30 | T1 | 2160h | 2160h |  |  | Rel-4 | Ingbert | Ext-RoHC | 34.123-1, -2 |  |
| 2516 | 65.4.5 | Deleted - Testing of Extended Robut Header Compression - TTCN | 325d | 2002-09-18 A | 2003-12-16 A | 100% | 2002-09-18 | 2003-12-16 | 325d | finish no earlier than 2003-12-16 | T1 | 2600h | 2600h |  |  | Rel-4 | Ingbert |  | 34.123-3 | TP-22 |
| 2517 | 647.3.6 | Deleted - General changes to TS34.121 corresponding to release 4 | 263d? | 2003-03-03 A | 2004-03-03 A | 100% | 2003-03-03 | 2004-03-03 | 263d? | finish no earlier than 2004-03-03 | T1 | 2104h | 2104h |  |  | Rel-4 | Ingbert | RANimp-test | 34.108, 34.121 | TP-23 |

Notes:
- 2491: -
- 2492: -
- 2493: -
- 2494: -
- 2495: -
- 2496: -
- 2497: -
- 2498: -
- 2499: Stopped at RP#14
- 2500: -
- 2501: Marked as stopped 12/2008
- 2502: Marked as stopped 12/2008
- 2503: Marked as stopped 12/2008
- 2504: -
- 2505: -
- 2506: -
- 2507: -
- 2508: -
- 2509: -
- 2510: 29 Nov 2000: split into ROHC and non-ROHC part; 5 Mar 2001: splitting off of ROHC for Rel-4 agreed by R2
- 2511: Marked as stopped 12/2008
- 2512: Marked as stopped 12/2008
- 2513: UID changed. Marked as stopped 12/2008
- 2514: UID changed. Marked as stopped 12/2008
- 2515: Marked as closed 12/2008 (was marked 15% complete)
- 2516: Marked as stopped 12/2008
- 2517: Marked as stopped 12/2008

| ID | WBS | Task | Duration | Start | Finish | Complete | Baseline start | Baseline finish | Baseline duration | Constraint | Resources | Work | Actual work | Text1 | Text4 | Text6 | Text8 | Text12 | Text3 | Text5 |
| --- | --- | --- | --- | --- | --- | --- | --- | --- | --- | --- | --- | --- | --- | --- | --- | --- | --- | --- | --- | --- |
| 2518 | 66 | **Rel-4 Emergency call enhancements** | 628d | 2000-01-03 A | 2002-05-28 A | 100% | 2000-01-03 | 2002-05-28 | 628d |  | N1,S1,T1 | 3600h | 3600h | EMC1 | Ericsson | Rel-4 | Frederic |  |  |  |
| 2519 | 66.1 | **For CS based calls** | 628d | 2000-01-03 A | 2002-05-28 A | 100% | 2000-01-03 | 2002-05-28 | 628d |  | N1 | 3600h | 3600h | EMC1-CS | Ericsson | Rel-4 | Frederic |  |  |  |
| 2520 | 66.1.1 | Distinction in CS domain of emergency call types to different emergency services | 40d | 2000-05-01 A | 2000-06-23 A | 100% | 2000-05-01 | 2000-06-23 | 40d | finish no earlier than 2000-06-23 | S1 | 320h | 320h | EMC1-CS |  | Rel-4 | Alain |  |  |  |
| 2521 | 66.1.2 | Distinction in CS domain of emergency calls to different emergency types | 22d | 2000-08-24 A | 2000-09-22 A | 100% | 2000-08-24 | 2000-09-22 | 22d | finish no earlier than 2000-09-22 | N1 | 176h | 176h | EMC1-CS |  | Rel-4 | Frederic |  |  |  |
| 2522 | 66.1.3 | Deleted - Conformance Test Aspects - Emergency call enhancements | 151d | 2000-01-03 A | 2000-07-28 A | 100% | 2000-01-03 | 2000-07-28 | 151d |  | T1 | 1200h | 1200h | EMC1-CS |  | Rel-4 | Ingbert | TP-08 |  |  |
| 2523 | 66.1.4 | Testing CS based emergency calls | 67d | 2002-02-25 A | 2002-05-28 A | 100% | 2002-02-25 | 2002-05-28 | 67d | finish no earlier than 2002-05-28 | T1 | 536h | 536h | EMC1-CS |  | Rel-4 | Ingbert |  | 34.123-1 |  |
| 2524 | 66.1.5 | Testing CS based emergency calls - TTCN | 134d | 2001-11-22 A | 2002-05-28 A | 100% | 2001-11-22 | 2002-05-28 | 134d | finish no earlier than 2002-05-28 | T1 | 1072h | 1072h | EMC1-CS |  | Rel-4 | Ingbert |  | 34.123-3 |  |
| 2525 | 67 | **Rel-4 Terminal interfaces** | 315d | 2000-01-03 A | 2001-03-15 A | 100% | 2000-01-03 | 2001-03-15 | 315d |  | T2 | 14296h | 14296h | TI |  | Rel-4 | Kimmo |  |  |  |
| 2526 | 67.1 | **AT commands enhancements** | 314d | 2000-01-03 A | 2001-03-14 A | 100% | 2000-01-03 | 2001-03-14 | 314d |  | T2 | 5016h | 5016h | TI-ATC |  | Rel-4 | Kimmo |  | 27.007 |  |
| 2527 | 67.1.1 | Specification of AT commands for new services | 314d | 2000-01-03 A | 2001-03-14 A | 100% | 2000-01-03 | 2001-03-14 | 314d | finish no earlier than 2001-03-14 | T2 | 2504h | 2504h |  |  | Rel-4 | Kimmo |  | 27.007 |  |
| 2528 | 67.2 | **Wide Area Data Synchronization** | 314d | 2000-01-03 A | 2001-03-14 A | 100% | 2000-01-03 | 2001-03-14 | 314d |  | T2 | 5016h | 5016h | TI-WADS |  | Rel-4 | Kimmo |  |  |  |
| 2529 | 67.2.1 | Continues evolution of Synchronization protocol | 314d | 2000-01-03 A | 2001-03-14 A | 100% | 2000-01-03 | 2001-03-14 | 314d | finish no earlier than 2001-03-14 | T2 | 2504h | 2504h | TI-SYNC-EVOL |  | Rel-4 | Kimmo |  | 27.903, 27.103 |  |
| 2530 | 67.3 | Terminal local model | 218d | 2000-05-16 A | 2001-03-15 A | 100% | 2000-05-16 | 2001-03-15 | 218d | finish no earlier than 2001-03-15 | T2 | 1744h | 1744h | TLM | Ericsson | Rel-4 | Kimmo |  | 23.227 | Olga.Tome@ECS.ERICSSON.SE |
| 2531 | 68 | **Rel-4 Location Services enhancements** | 455d | 2000-04-03 A | 2001-12-28 A | 100% | 2000-04-03 | 2001-12-28 | 455d |  | S2 | 26799.2h | 26799.2h | LCS1 | Nokia | Rel-4 | Maurice |  |  | Jan Kall |
| 2532 | 68.1 | CBS interactions | 455d | 2000-04-03 A | 2001-12-28 A | 100% | 2000-04-03 | 2001-12-28 | 455d | finish no earlier than 2001-12-28 | T2 | 3640h | 3640h | LCS1-CBS |  | Rel-4 |  |  | 23.041 |  |
| 2533 | 68.2 | LCS support in the CS domain | 180d | 2000-05-15 A | 2001-01-19 A | 100% | 2000-05-15 | 2001-01-19 | 180d | finish no earlier than 2001-01-19 | S2 | 1440h | 1440h | LCS1-CS |  | Rel-4 | Maurice |  |  |  |
| 2534 | 68.3 | **LCS support in the PS domain** | 435d | 2000-05-01 A | 2001-12-28 A | 100% | 2000-05-01 | 2001-12-28 | 435d |  | S2 | 13560h | 13560h | LCS1-PS |  | Rel-4 | Maurice |  |  |  |
| 2535 | 68.3.1 | Stage 1 | 40d | 2000-07-03 A | 2000-08-25 A | 100% | 2000-07-03 | 2000-08-25 | 40d | start no earlier than 2000-07-03 | S1 | 320h | 320h |  | Pacific Bell Wireless | Rel-4 | Alain |  | 22.071 | Randolph Wohlert (rwohlert@tri.sbc.com) |
| 2536 | 68.3.2 | Stage 2 | 190d | 2000-05-01 A | 2001-01-19 A | 100% | 2000-05-01 | 2001-01-19 | 190d | finish no earlier than 2001-01-19 | S2 | 1520h | 1520h |  |  | Rel-4 | Maurice |  | 23.271 |  |
| 2537 | 68.3.3 | **Stage 3** | 355d | 2000-08-21 A | 2001-12-28 A | 100% | 2000-08-21 | 2001-12-28 | 355d |  | N1 | 8240h | 8240h |  |  | Rel-4 | Frederic |  |  |  |
| 2538 | 68.3.3.1 | Layer 3 LCS signalling UE (MS) -SGSN (UMTS PS and and GSM-GPRS) | 355d | 2000-08-21 A | 2001-12-28 A | 100% | 2000-08-21 | 2001-12-28 | 355d | finish no earlier than 2001-12-28 | N1 | 2840h | 2840h |  | Nokia | Rel-4 | Frederic |  |  | Janne Muhonen |
| 2539 | 68.3.3.2 | MAP impacts of LCS | 160d | 2000-08-21 A | 2001-03-30 A | 100% | 2000-08-21 | 2001-03-30 | 160d | finish no earlier than 2001-03-30 | N4 | 1280h | 1280h |  |  | Rel-4 | Kimmo |  |  |  |
| 2540 | 68.3.3.3 | GTP signalling for LCS | 160d | 2000-08-21 A | 2001-03-30 A | 100% | 2000-08-21 | 2001-03-30 | 160d | finish no earlier than 2001-03-30 | N4 | 1280h | 1280h |  |  | Rel-4 | Kimmo |  |  |  |
| 2541 | 68.4 | **UE positioning Rel-4** | 260d | 2000-04-03 A | 2001-03-30 A | 100% | 2000-04-03 | 2001-03-30 | 260d |  | RP | 4591.2h | 4591.2h | LCS1-UEpos |  | Rel-4 | Issam |  |  |  |
| 2542 | 68.4.1 | Iub/Iur interfaces for methods Rel 99 | 233.9d | 2000-04-03 A | 2001-03-30 A | 100% | 2000-04-03 | 2001-03-30 | 233.9d | finish no earlier than 2001-03-30 | R3 | 1871.2h | 1871.2h | LCS1-UEpos-IubIur | Ericsson | Rel-4 | Juha |  |  | Yun-Chao Hu |
| 2543 | 68.4.2 | UE positioning enhancements - IPDL for TDD | 150d | 2000-08-28 A | 2001-03-23 A | 100% | 2000-08-28 | 2001-03-23 | 150d | finish no earlier than 2001-03-23 | R2 | 1200h | 1200h | LCS1-UEpos-enh | Siemens | Rel-4 | Joern |  |  | M. Beckmann |

Notes:
- 2518: -
- 2519: WI approved in TSG_10
- 2520: -
- 2521: Calls to different emergency services such as ambulance, fire brigade, police, etc. can be routed to respective different emergency centres. / NP-000447 is the stage 3 changes for CS call control protocol.
- 2522: UID changed. Marked as stopped 12/2008
- 2523: -
- 2524: -
- 2525: -
- 2526: -
- 2527: goal not completely achieved because of missing input
- 2528: AS: Rel5 changed to Rel4 according to SP#10 decision, milestone on testing added
- 2529: -
- 2530: -
- 2531: -
- 2532: -
- 2533: Only MAP impact foreseen so far. To be further split if needed.
- 2534: -
- 2535: To be also considered: External LCS client identity, and Privacy options when PDP-context and when no PDP-context is established
- 2536: AS: 23.271 completed at SP#10
- 2537: -
- 2538: -
- 2539: Missing work task
- 2540: -
- 2541: UID changed
- 2542: 27/11: WG corrected; rapporteur corrected
- 2543: 5 Mar 2001: splitting off of IPDL for TDD for Rel-4 agreed by R2

| ID | WBS | Task | Duration | Start | Finish | Complete | Baseline start | Baseline finish | Baseline duration | Constraint | Resources | Work | Actual work | Text1 | Text6 | Text8 | Text3 | Text4 | Text5 | Text12 |
| --- | --- | --- | --- | --- | --- | --- | --- | --- | --- | --- | --- | --- | --- | --- | --- | --- | --- | --- | --- | --- |
| 2544 | 69 | **Rel-4 UICC/(U)SIM enhancements and interworking** | 175d | 2000-07-24 A | 2001-03-23 A | 100% | 2000-07-24 | 2001-03-23 | 175d |  | T3 | 2800h | 2800h | UICC1 | Rel-4 | Xavier |  |  |  |  |
| 2545 | 69.1 | Common PCN Handset Specification (CPHS) | 175d | 2000-07-24 A | 2001-03-23 A | 100% | 2000-07-24 | 2001-03-23 | 175d | finish no earlier than 2001-03-23 | T3 | 1400h | 1400h | UICC1-CPHS | Rel-4 | Xavier | 27.103 | One2One |  |  |
| 2546 | 70 | **Rel-4 (U)SIM toolkit enhancements** | 210d | 2000-06-05 A | 2001-03-23 A | 100% | 2000-06-05 | 2001-03-23 | 210d |  | T3 | 3360h | 3360h | USAT1-LocLnk | Rel-4 | Xavier |  | Gemplus | Jean-Francois Rubon |  |
| 2547 | 70.1 | USAT local link | 210d | 2000-06-05 A | 2001-03-23 A | 100% | 2000-06-05 | 2001-03-23 | 210d | finish no earlier than 2001-03-23 | T3 | 1680h | 1680h | USAT1-LocLnk | Rel-4 | Xavier |  | Gemplus | Jean-Francois Rubon |  |
| 2548 | 71 | **Rel-4 Security enhancements** | 576d | 2000-01-03 A | 2002-03-15 A | 100% | 2000-01-03 | 2002-03-15 | 576d |  | S3 | 24152h | 24152h |  | Rel-4 | Dionisio |  | Vodafone | Peter.Howard@vodafone.com |  |
| 2549 | 71.1 | Evolution of GSM CS algorithms (e.g. A5/3 development and deployment) | 272d | 2000-01-03 A | 2001-01-15 A | 100% | 2000-01-03 | 2001-01-15 | 272d | finish no earlier than 2001-01-15 | S3 | 2168h | 2168h | SEC1-CSALGO1 | Rel-4 | Dionisio |  |  |  |  |
| 2550 | 71.2 | **Evolution of GSM PS algorithms (e.g. GEA 2 deployment)** | 219d | 2000-02-22 A | 2000-12-22 A | 100% | 2000-02-22 | 2000-12-22 | 219d |  | S3 | 6024h | 6024h | SEC1-PSALGO1 | Rel-4 | Dionisio |  |  |  |  |
| 2551 | 71.2.1 | Main aspects | 199d | 2000-02-22 A | 2000-11-24 A | 100% | 2000-02-22 | 2000-11-24 | 199d | finish no earlier than 2000-11-24 | S3 | 1592h | 1592h | SEC1-PSALGO1 | Rel-4 | Dionisio |  |  |  |  |
| 2552 | 71.2.2 | Impact on GTP | 200d | 2000-03-20 A | 2000-12-22 A | 100% | 2000-03-20 | 2000-12-22 | 200d | finish no earlier than 2000-12-22 | N4 | 1600h | 1600h | SEC1-PSALGO1 | Rel-4 | Kimmo |  |  |  |  |
| 2553 | 71.2.3 | GEA capability indication in MS CM | 135d | 2000-06-19 A | 2000-12-22 A | 100% | 2000-06-19 | 2000-12-22 | 135d | finish no earlier than 2000-12-22 | N1 | 1080h | 1080h | SEC1-PSALGO1-GEACAP | Rel-4 | Frederic |  | Vodafone Airtouch | Duncan Mills |  |
| 2554 | 71.3 | **Deleted - MAP application layer security** | 576d | 2000-01-03 A | 2002-03-15 A | 100% | 2000-01-03 | 2002-03-15 | 576d |  | S3 | 11352h | 11352h | SEC1-MAPAL | Rel-4 | Dionisio |  |  |  | SP-15 |
| 2555 | 71.3.1 | Deleted - Main aspects | 199d | 2000-02-21 A | 2001-03-29 A | 100% | 2000-02-21 | 2001-03-29 | 199d | start no earlier than 2000-02-21 | S3 | 1592h | 1592h |  | Rel-4 | Dionisio |  |  |  | SP-11 |
| 2556 | 71.3.2 | Deleted - Other stage 3 aspects | 199d | 2000-02-22 A | 2000-11-24 A | 100% | 2000-02-22 | 2000-11-24 | 199d | finish no earlier than 2000-11-24 | N4 | 1592h | 1592h |  | Rel-4 | Kimmo |  |  |  | CP-10 |
| 2557 | 71.3.3 | Deleted - Visibility and Configurability of security | 576d | 2000-01-03 A | 2002-03-15 A | 100% | 2000-01-03 | 2002-03-15 | 576d | finish no earlier than 2002-03-15 | S3 | 4600h | 4600h | SEC1-VCS | Rel-4 | Dionisio |  | France Telecom | Sebastien.nguyenngoc@rd.francetelecom.com | SP-15 |
| 2558 | 72 | **Rel-4 Charging and OAM&P** | 221d | 2000-12-01 A | 2001-10-05 A | 100% | 2000-12-01 | 2001-10-05 | 221d |  | S5 | 10472h | 10472h | OAM | Rel-4 | Dionisio |  | VoiceStream, Motorola |  |  |
| 2559 | 72.1 | Rel4 Principles, high level Requirements and Architecture | 145d | 2000-12-01 A | 2001-06-21 A | 100% | 2000-12-01 | 2001-06-21 | 145d | finish no earlier than 2001-06-21 | S5 | 1160h | 1160h | OAM-AR/PR | Rel-4 | Dionisio | 32.101, 32.102 | Motorola, Telia | Michael.Truss@motorola.com, Tommy.R.Berggren@TELIA.SE |  |
| 2560 | 72.2 | Rel4 Performance Management | 216d | 2000-12-01 A | 2001-09-28 A | 100% | 2000-12-01 | 2001-09-28 | 216d | finish no earlier than 2001-06-21 | S5 | 1728h | 1728h |  | Rel-4 | Dionisio | 32.4xy, 52.402 | T-Mobile | karl-heinz.nenner@t-mobile.de |  |
| 2561 | 72.3 | Fault Management | 221d | 2000-12-01 A | 2001-10-05 A | 100% | 2000-12-01 | 2001-10-05 | 221d | finish no earlier than 2001-06-21 | S5 | 1768h | 1768h |  | Rel-4 | Dionisio | 32.111-1/4 | Lucent |  |  |
| 2562 | 72.4 | Configuration Management | 145d | 2000-12-01 A | 2001-06-21 A | 100% | 2000-12-01 | 2001-06-21 | 145d | finish no earlier than 2001-06-21 | S5 | 1160h | 1160h | OAM-CM | Rel-4 | Dionisio | 32.106-1/8 | Ericsson | thomas.tovinger@ericsson.com |  |
| 2563 | 72.5 | Rel4 Charging Management | 216d | 2000-12-01 A | 2001-09-28 A | 100% | 2000-12-01 | 2001-09-28 | 216d | finish no earlier than 2001-06-21 | S5 | 1728h | 1728h | OAM-CH | Rel-4 | Dionisio | 32.200, 32.205, 32.215, 32.235 | T-Mobile | karl-heinz.nenner@t-mobile.de |  |
| 2564 | 72.6 | UTRAN Operations and Maintenance procedures | 145d | 2000-12-01 A | 2001-06-21 A | 100% | 2000-12-01 | 2001-06-21 | 145d | finish no earlier than 2001-06-21 | S5 | 1160h | 1160h | UOAM | Rel-4 | Dionisio | 32.800 | Mannesmann Mobilfunk | bert.boden@d2mannesmann.de |  |
| 2565 | 73 | **Global Text Telephony** | 2537d? | 2000-01-03 A | 2009-09-18 A | 100% | 2000-01-03 | 2009-09-18 | 2537d? |  | S1,S2,S4,T1,R5 | 44928h | 44928h | GTT | Rel-4 | Maurice |  | Ericsson | gunnar.hellstrom@omnitor.se |  |
| 2566 | 73.1 | Stage 1 | 188d | 2000-04-05 A | 2000-12-22 A | 100% | 2000-04-05 | 2000-12-22 | 188d | finish no earlier than 2000-12-22 | S1 | 1504h | 1504h | GTT | Rel-4 | Alain | 22.976, 22.226 |  |  |  |
| 2567 | 73.2 | Stage 2 | 206d | 2000-01-03 A | 2000-10-13 A | 100% | 2000-01-03 | 2000-10-13 | 206d |  | S2 | 1640h | 1640h | GTT | Rel-4 | Maurice | 23.226 |  |  |  |

Notes:
- 2544: -
- 2545: 28/5/2001: CRs approved at TP-11. WI complete.
- 2546: -
- 2547: 25/5/2001:CR was approved at TP-11. WI is complete
- 2548: Added BB UE authentication and rapporteur added. TO BE DELETED
- 2549: Approved SP#17
- 2550: A5/3 development will consider new GEA algorithm based on Kasumi
- 2551: Complete TSG#09 (09/2000). S3#17: Proposed for deletion. TO BE DELETED
- 2552: -
- 2553: -
- 2554: REPLACED BY NDS-MAP and NDS-IP. Completed Auto Key Management -> Rel-6. Marked as stopped 12/2008
- 2555: UID changed. Marked as stopped 12/2008
- 2556: UID changed. Marked as stopped 12/2008
- 2557: CR approved at SA3#21 awaiting comments from CN1. Marked as stopped 12/2008
- 2558: SP#13 approved WID
- 2559: -
- 2560: -
- 2561: -
- 2562: -
- 2563: -
- 2564: -
- 2565: SP#12 updated WID SP-000162=>SP-010340
- 2566: -
- 2567: -

| ID | WBS | Task | Duration | Start | Finish | Complete | Baseline start | Baseline finish | Baseline duration | Constraint | Resources | Work | Actual work | Text1 | Text6 | Text8 | Text9 | Text12 |
| --- | --- | --- | --- | --- | --- | --- | --- | --- | --- | --- | --- | --- | --- | --- | --- | --- | --- | --- |
| 2568 | 73.3 | **Specification of Cellular Text telephone Modem** | 136d | 2000-09-11 A | 2001-03-19 A | 100% | 2000-09-11 | 2001-03-19 | 136d |  | S4 | 2704h | 2704h | GTT-CTM | Rel-4 | Paolo |  |  |
| 2569 | 73.3.1 | General description and C-code | 66d | 2000-09-11 A | 2000-12-11 A | 100% | 2000-09-11 | 2000-12-11 | 66d | finish no earlier than 2000-12-11 | S4 | 528h | 528h | GTT-CTM | Rel-4 | Paolo |  |  |
| 2570 | 73.3.2 | Minimum Performance requirements | 136d | 2000-09-11 A | 2001-03-19 A | 100% | 2000-09-11 | 2001-03-19 | 136d | finish no earlier than 2001-03-19 | S4 | 1088h | 1088h | GTT-CTM | Rel-4 | Paolo |  |  |
| 2571 | 73.5 | Deleted - Conformance Test Aspects - Global Text Telephony | 2348d? | 2000-09-21 A | 2009-09-18 A | 100% | 2000-09-21 | 2009-09-18 | 2348d? | finish no earlier than 2009-09-18 | R5,T1 | 18784h | 18784h | GTT_Test | Rel-4 | Ingbert | PCG-23 | RP-45 |
| 2572 | 656 | Release 1999 Features | 261d? | 1999-01-01 A | 1999-12-31 A | 100% | 1999-01-01 | 1999-12-31 | 261d? |  | NP,SP,TP,SMG | 2088h | 2088h |  | R99 | All |  |  |
| 2573 | 657 | **UMTS Features** | 261d? | 1999-01-01 A | 1999-12-31 A | 100% | 1999-01-01 | 1999-12-31 | 261d? |  | S1,S2,S4,SMG,N3,N4,RP | 25056h | 25056h |  | R99 | Alain |  |  |
| 2574 | 657.1 | UMTS_SERVICES | 261d? | 1999-01-01 A | 1999-12-31 A | 100% | 1999-01-01 | 1999-12-31 | 261d? | start no earlier than 1999-01-01 | S1 | 2088h | 2088h | UMTS_SERVICES | R99 | Alain |  |  |
| 2575 | 657.2 | UMTS phase 1 | 261d? | 1999-01-01 A | 1999-12-31 A | 100% | 1999-01-01 | 1999-12-31 | 261d? | start no earlier than 1999-01-01 | S1 | 2088h | 2088h | UMTS1 | R99 | Alain |  |  |
| 2576 | 657.3 | UMTS Capabilities | 261d? | 1999-01-01 A | 1999-12-31 A | 100% | 1999-01-01 | 1999-12-31 | 261d? | start no earlier than 1999-01-01 | S1 | 2088h | 2088h | UMTS_Capabil | R99 | Alain |  |  |
| 2577 | 657.4 | Architecture of the GSM-UMTS platform | 261d? | 1999-01-01 A | 1999-12-31 A | 100% | 1999-01-01 | 1999-12-31 | 261d? | start no earlier than 1999-01-01 | S2,N4 | 2088h | 2088h |  | R99 | Maurice |  |  |
| 2578 | 657.5 | UMTS Terrestrial Radio Access Network | 261d? | 1999-01-01 A | 1999-12-31 A | 100% | 1999-01-01 | 1999-12-31 | 261d? | start no earlier than 1999-01-01 | RP | 2088h | 2088h | UTRAN | R99 | Joern |  |  |
| 2579 | 657.6 | UMTS 1800, UMTS 1900 | 261d? | 1999-01-01 A | 1999-12-31 A | 100% | 1999-01-01 | 1999-12-31 | 261d? | start no earlier than 1999-01-01 | R2 | 2088h | 2088h | Rlnlmp19, Rlnlmp18 | R99 | Joern |  |  |
| 2580 | 657.7 | Mandatory speech codec for narrowband telephony service | 261d? | 1999-01-01 A | 1999-12-31 A | 100% | 1999-01-01 | 1999-12-31 | 261d? | start no earlier than 1999-01-01 | S4 | 2088h | 2088h | Mandatory_Speech_Codec, AMR-NB, AMR | R99 | Paolo |  |  |
| 2581 | 657.8 | Codec for low bitrate multimedia telephony service | 261d? | 1999-01-01 A | 1999-12-31 A | 100% | 1999-01-01 | 1999-12-31 | 261d? | start no earlier than 1999-01-01 | S4 | 2088h | 2088h | Low_bit_rate_codec_for_MM_Tel., H.324M | R99 | Paolo |  |  |
| 2582 | 657.9 | 3G Audio-Visual Terminal characteristics | 261d? | 1999-01-01 A | 1999-12-31 A | 100% | 1999-01-01 | 1999-12-31 | 261d? | start no earlier than 1999-01-01 | S4 | 2088h | 2088h | WI5TAC, 3G-AVT, Terminal_Acoustic_Characteristics | R99 | Paolo |  |  |
| 2583 | 657.10 | Updates_for_UMTS | 261d? | 1999-01-01 A | 1999-12-31 A | 100% | 1999-01-01 | 1999-12-31 | 261d? | start no earlier than 1999-01-01 | N3 | 2088h | 2088h | Updates_for_UMTS | R99 | Gwiho |  |  |
| 2584 | 657.11 | UMTS | 261d? | 1999-01-01 A | 1999-12-31 A | 100% | 1999-01-01 | 1999-12-31 | 261d? | start no earlier than 1999-01-01 | N3 | 2088h | 2088h | UMTS | R99 | Gwiho |  |  |
| 2585 | 658 | **UMTS and GSM Features** | 261d? | 1999-01-01 A | 1999-12-31 A | 100% | 1999-01-01 | 1999-12-31 | 261d? |  | S1,S2,SMG,T2,N1,N2,N3,N4,R2,R3 | 114840h | 114840h |  | R99 | Alain |  |  |
| 2586 | 658.1 | Multimedia Messaging Service | 261d? | 1999-01-01 A | 1999-12-31 A | 100% | 1999-01-01 | 1999-12-31 | 261d? | start no earlier than 1999-01-01 | T2 | 2088h | 2088h | MMS | R99 |  |  |  |
| 2587 | 658.2 | Location Services | 261d? | 1999-01-01 A | 1999-12-31 A | 100% | 1999-01-01 | 1999-12-31 | 261d? | start no earlier than 1999-01-01 | S1,S2,S3,SMG1,SMG2,SMG12,N1,N2,N4,R2,R3 | 2088h | 2088h | LCS | R99 | Alain |  |  |
| 2588 | 658.3 | **Customised Application for Mobile network Enhanced Logic Phase 3** | 261d? | 1999-01-01 A | 1999-12-31 A | 100% | 1999-01-01 | 1999-12-31 | 261d? |  | S1,S2,N2,N4 | 6264h | 6264h | CAMEL3 | R99 | Alain |  |  |
| 2589 | 658.3.1 | Global view | 261d? | 1999-01-01 A | 1999-12-31 A | 100% | 1999-01-01 | 1999-12-31 | 261d? | start no earlier than 1999-01-01 | S1,S2,N2,N4 | 2088h | 2088h | CAMEL3 | R99 | Alain |  |  |
| 2590 | 658.3.2 | Multiple Subscriber Profile (MSP) based on CAMEL phase 3 | 261d? | 1999-01-01 A | 1999-12-31 A | 100% | 1999-01-01 | 1999-12-31 | 261d? | start no earlier than 1999-01-01 | S1 | 2088h | 2088h | CAMEL3 | R99 | Alain |  |  |
| 2591 | 658.4 | Short Message Service enhancements / Enhanced Messaging Service (EMS) | 261d? | 1999-01-01 A | 1999-12-31 A | 100% | 1999-01-01 | 1999-12-31 | 261d? | start no earlier than 1999-01-01 | T2 | 2088h | 2088h | EMS | R99 |  |  |  |
| 2592 | 658.5 | Mobile Station Execution Environment | 261d? | 1999-01-01 A | 1999-12-31 A | 100% | 1999-01-01 | 1999-12-31 | 261d? | start no earlier than 1999-01-01 | S1,SMG1,T2 | 2088h | 2088h | MExE | R99 | Alain |  |  |
| 2593 | 658.6 | MS_Classmark | 261d? | 1999-01-01 A | 1999-12-31 A | 100% | 1999-01-01 | 1999-12-31 | 261d? | start no earlier than 1999-01-01 | N1 | 2088h | 2088h | MS_Classmark | R99 | Frederic |  |  |

Notes:
- 2568: -
- 2569: - / Text3: 26.226, 26.230
- 2570: - / Text3: 26.231
- 2571: RP#45 work item abandoned/closed (it was never really started)
- 2572: -
- 2573: -
- 2574: - / Text3: 22.101
- 2575: - / Text3: 22.100
- 2576: Requirement for high quality speech in UMTS Phase 1 but not in R99 / Text3: 22.105
- 2577: wid Architecture overview of the GSM-UMTS System, Architecture the GSM-UMTS Platform and New Access Network to Core Network (BSS-NSS) interface / Text3: 23.002, 23.008, 23.060, 23.101, 23.110
- 2578: - / Text3: 22.011, 22.038, 22.060, 22.078, 22.100, 22.101, 22.105, 22.115, 22.129, 23.002, 23.060, 24.007, 24.008, 25.101, 25.102, 25.104, 25.105, 25.113, 25.123, 25.133, 25.141, 25.142, 25.201, 25.211, 25.212, 25.213, 25.214, 25.215, 25.221, 25.222, 25.223, 25.224,
- 2579: - / Text3: 25.307 CR#0002, 0003 Inclusion of release independent RF related information
- 2580: Define the default speech codec for UMTS (both for FDD and TDD). Definition limited to selection of one codec among several existing ones/proposed codecs: GSM AMR, IS127 EVRC, ITU G.729 and MPEG-4 speech codec. / Text3: 04.08, 05.01, 05.02, 05.03, 05.05, 05.08, 05.09, 05.09, 05.50, 08.60, 08.61, 11.21, 26.071, 26.073, 26.074, 26.090, 26.091, 26.092, 26.093, 26.094, 26.101, 26.102, 26.103, 26.104, 26.975
- 2581: - / Text3: 26.104, 26.110, 26.111, 26.911, 26.912, 26.915
- 2582: - / Text3: 26.131, 26.132
- 2583: - / Text3: 24.022, 27.001, 29.007
- 2584: - / Text3: 27.060, 29.061
- 2585: -
- 2586: MMS allows users to send/receive messages e.g. almost unlimited text length, images, audio and video clips and new content types. R99 only includes the concept. MMS stage 3 is not included in 23.140. Rel-4 adds detailed architecture and protocols. / Text3: 22.140, 23.040, 23.140
- 2587: LCS provide ability to localize a terminal. Location data is used to provide services to end-user (e.g. local map indicating closest restaurants), for emergency services or for a UMTS network entity (RNC to direct beam when space diversity is used) / Text3: 02.07, 03.71, 04.31, 04.35, 04.71, 05.05, 08.08, 08.31, 08.71, 09.31, 22.071, 23.002, 23.003, 23.007, 23.008, 23.016, 23.018, 23.032, 23.171, 24.007, 24.008, 24.030, 24.080, 25.305, 25.306, 25.331, 25.413, 25.423, 29.002, 29.010
- 2588: CAMEL is a network feature providing mechanisms to support services of operators which are not covered by standardised services, even when roaming outside the HPLMN. / Text3: 22.101, 23.008, 23.012, 23.016, 23.018, 23.060, 23.072, 23.078, 23.079, 23.082, 23.093, 29.002, 29.078
- 2589: - / Text3: 22.078, 23.078, 29.078
- 2590: MSP is an optional service enabling mobile subscribers to have several profiles associated with a single IMSI, with each profile being a subscription option. Each profile may be used for mobile originated and mobile terminated calls. / Text3: 22.097 (Advanced Addressing)
- 2591: SMS for 3G terminals compatible with GSM SMS. Added Enhanced Messaging Service (EMS) allowing small pictures, sounds, animations to be transferred via SMS. / Text3: 23.038, 23.039, 23.040, 23.042
- 2592: MExE provides a standardized MS execution environment and ability to negotiate its supported capabilities with a MExE SP. R99 enhances SIM MExE certificate management, security clarifications, QoS and defines two MExE classmarks WAP/Personal-Java based. / Text3: 02.57, 22.057, 22.101, 23.057
- 2593: MExE classmark identifies a category of MExE UE supporting MExE functionality with a minimum level of processing, memory, display, and interactive capabilities. Several MExE classmarks may be defined. / Text3: 24.008

| ID | WBS | Task | Duration | Start | Finish | Complete | Baseline start | Baseline finish | Baseline duration | Constraint | Resources | Work | Actual work | Text1 | Text6 | Text8 | Text12 |
| --- | --- | --- | --- | --- | --- | --- | --- | --- | --- | --- | --- | --- | --- | --- | --- | --- | --- |
| 2594 | 658.7 | **MultiCall** | 261d? | 1999-01-01 A | 1999-12-31 A | 100% | 1999-01-01 | 1999-12-31 | 261d? |  | S1,N1,N2,N4 | 4176h | 4176h | Multicall | R99 | Alain |  |
| 2595 | 658.7.1 | Multicall | 261d? | 1999-01-01 A | 1999-12-31 A | 100% | 1999-01-01 | 1999-12-31 | 261d? | start no earlier than 1999-01-01 | S1 | 2088h | 2088h | Multicall | R99 | Alain |  |
| 2596 | 658.8 | Virtual Home Environment | 261d? | 1999-01-01 A | 1999-12-31 A | 100% | 1999-01-01 | 1999-12-31 | 261d? | start no earlier than 1999-01-01 | S1,SMG1,S2 | 2088h | 2088h | VHE | R99 | Alain |  |
| 2597 | 658.9 | Open Service Access | 261d? | 1999-01-01 A | 1999-12-31 A | 100% | 1999-01-01 | 1999-12-31 | 261d? | start no earlier than 1999-01-01 | S1,S2,N5 | 2088h | 2088h | OSA | R99 | Alain |  |
| 2598 | 658.10 | Super Charger mechanism for signalling traffic associated with mobility | 261d? | 1999-01-01 A | 1999-12-31 A | 100% | 1999-01-01 | 1999-12-31 | 261d? | start no earlier than 1999-01-01 | N2,N4 | 2088h | 2088h | Super_Charger | R99 | Kimmo |  |
| 2599 | 658.11 | Follow_Me service | 261d? | 1999-01-01 A | 1999-12-31 A | 100% | 1999-01-01 | 1999-12-31 | 261d? | start no earlier than 1999-01-01 | S1,N2,N4 | 2088h | 2088h | Follow_Me | R99 | Alain |  |
| 2600 | 658.12 | Wide area network Synchronization and object exchange | 261d? | 1999-01-01 A | 1999-12-31 A | 100% | 1999-01-01 | 1999-12-31 | 261d? | start no earlier than 1999-01-01 | T2 | 2088h | 2088h | SYNC | R99 |  |  |
| 2601 | 658.13 | **Terminal Interfaces** | 261d? | 1999-01-01 A | 1999-12-31 A | 100% | 1999-01-01 | 1999-12-31 | 261d? |  | T2 | 8352h | 8352h |  | R99 |  |  |
| 2602 | 658.13.1 | AT commands for 3GPP | 261d? | 1999-01-01 A | 1999-12-31 A | 100% | 1999-01-01 | 1999-12-31 | 261d? | start no earlier than 1999-01-01 | T2 | 2088h | 2088h |  | R99 |  |  |
| 2603 | 658.13.2 | Physical interfaces | 261d? | 1999-01-01 A | 1999-12-31 A | 100% | 1999-01-01 | 1999-12-31 | 261d? | start no earlier than 1999-01-01 | T2 | 2088h | 2088h |  | R99 |  |  |
| 2604 | 658.13.3 | Multiplexer | 261d? | 1999-01-01 A | 1999-12-31 A | 100% | 1999-01-01 | 1999-12-31 | 261d? | start no earlier than 1999-01-01 | T2 | 2088h | 2088h | MUX MS-TE | R99 |  |  |
| 2605 | 658.14 | **Bearer Services** | 261d? | 1999-01-01 A | 1999-12-31 A | 100% | 1999-01-01 | 1999-12-31 | 261d? |  | S1,T2,N1,N3 | 27144h | 27144h |  | R99 | Alain |  |
| 2606 | 658.14.1 | **Circuit Switched Bearer Services** | 261d? | 1999-01-01 A | 1999-12-31 A | 100% | 1999-01-01 | 1999-12-31 | 261d? |  | S1,N3 | 14616h | 14616h | Circuit_switched_Bearer_Services | R99 | Alain |  |
| 2607 | 658.14.1.1 | Circuit Switched Bearer Services | 261d? | 1999-01-01 A | 1999-12-31 A | 100% | 1999-01-01 | 1999-12-31 | 261d? | start no earlier than 1999-01-01 | S1,N3 | 2088h | 2088h | CS_Bearerss_in_UMTS | R99 | Alain |  |
| 2608 | 658.14.1.2 | CS_Bearers | 261d? | 1999-01-01 A | 1999-12-31 A | 100% | 1999-01-01 | 1999-12-31 | 261d? | start no earlier than 1999-01-01 | N3 | 2088h | 2088h | CS_Bearers | R99 | Gwiho |  |
| 2609 | 658.14.1.3 | CS_Bearerss | 261d? | 1999-01-01 A | 1999-12-31 A | 100% | 1999-01-01 | 1999-12-31 | 261d? | start no earlier than 1999-01-01 | N3 | 2088h | 2088h | CS_Bearerss | R99 | Gwiho |  |
| 2610 | 658.14.1.4 | CS_Data | 261d? | 1999-01-01 A | 1999-12-31 A | 100% | 1999-01-01 | 1999-12-31 | 261d? | start no earlier than 1999-01-01 | N3 | 2088h | 2088h | CS_Data | R99 | Gwiho |  |
| 2611 | 658.14.1.5 | CS_Data_Bearers | 261d? | 1999-01-01 A | 1999-12-31 A | 100% | 1999-01-01 | 1999-12-31 | 261d? | start no earlier than 1999-01-01 | N3 | 2088h | 2088h | CS_Data_Bearers | R99 | Gwiho |  |
| 2612 | 658.14.1.6 | Deleted - Circuit Switched Bearer Services | 261d? | 1999-01-01 A | 1999-12-31 A | 100% | 1999-01-01 | 1999-12-31 | 261d? | start no earlier than 1999-01-01 | N3 | 2088h | 2088h | CSBS | R99 | Gwiho | NP-06 |
| 2613 | 658.14.2 | Frame Tunnelling Mode | 261d? | 1999-01-01 A | 1999-12-31 A | 100% | 1999-01-01 | 1999-12-31 | 261d? | start no earlier than 1999-01-01 | T2,N1,N3 | 2088h | 2088h | FTM | R99 | Gwiho |  |
| 2614 | 658.14.3 | Access to ISPs and Intranets – Wireless/Remote access to LANs | 261d? | 1999-01-01 A | 1999-12-31 A | 100% | 1999-01-01 | 1999-12-31 | 261d? | start no earlier than 1999-01-01 | N3 | 2088h | 2088h | Interworking with PDN (DHCP) | R99 | Gwiho |  |
| 2615 | 658.14.4 | **PHS Internet Access Forum Specification** | 261d? | 1999-01-01 A | 1999-12-31 A | 100% | 1999-01-01 | 1999-12-31 | 261d? |  | S1,N3 | 6264h | 6264h | PIAFS | R99 | Alain |  |
| 2616 | 658.14.4.1 | Personal Handyphone System Internet Access Forum Standard (PIAFS) | 261d? | 1999-01-01 A | 1999-12-31 A | 100% | 1999-01-01 | 1999-12-31 | 261d? | start no earlier than 1999-01-01 | S1 | 2088h | 2088h | PIAFS | R99 | Alain |  |
| 2617 | 658.14.4.2 | Support_of_PIAFS_in_UMTS | 261d? | 1999-01-01 A | 1999-12-31 A | 100% | 1999-01-01 | 1999-12-31 | 261d? | start no earlier than 1999-01-01 | N3 | 2088h | 2088h | Support_of_PIAFS_in_UMTS | R99 | Gwiho |  |

Notes:
- 2594: Multicall allows several simultaneous CS calls with dedicated bearers of independent traffic and performance characteristics. R99 Multicall was defined as a supplementary service limited to one CS bearer to be used for speech at any time. / Text3: 22.030, 22.083, 22.087, 23.008, 23.009, 23.016, 23.018, 23.108, 23.135, 24.008, 24.080, 24.135, 29.002, 29.010
- 2595: - / Text3: 22.030, 22.083, 22.087
- 2596: Information exists in SP#5-8 reports & in SP-99416,SP-000095,SP 000155. OSA allows service development by operators and 3rd parties by making use of network functionality through open, standardised, secure, extensible and scalable interfaces. / Text3: 02.01, 22.105, 22.121,23.127
- 2597: Open Service Architecture became in later Releases Open Service Access. Produced by Parlay, ETSI SPAN (TISPAN), 3GPP SA1 (Stage 1), SA2 (Stage 2) and CN5 (Stage 3), resulting in a single set of standard OSA APIs for the whole development community. / Text3: 22.121, 23.127, 29.198, 29.998
- 2598: Super Charger reduces mobility management cost by reducing the volume of location update signalling. It changes subscriber data management associated with inter-VLR and SGSN location updates. It also applies to packet services (SGSN replaces VLR and … / Text3: 21.905, 23.007, 23.008, 23.012, 23.016, 23.018, 23.040, 23.060, 23.116, 23.912, 29.002
- 2599: Follow Me enables a mobile subscriber A to manipulate the Follow Me data of a party B in such a way that - under certain conditions - subsequent calls directed to party B will be forwarded to subscriber A. It is PLMN-specific and control based on USSD / Text3: 21.905, 22.004, 22.030, 22.082, 22.090, 22.094, 23.090, 24.090, 22.094, 23.011, 23.015, 23.082, 29.002
- 2600: Allows data stored in ME/USIM to be synchronized with the outside world. TS 27.103 defines protocols based upon IrMC level 4 and will evaluate new technologies (XML) for inclusion. From Rel-4 IrMC was replaced by SyncML in 27.103. / Text3: 27.103, 27.903
- 2601: -
- 2602: AT commands to control a 3G ME via an external Terminal Equipment (TE), fully compatible with GSM AT commands. R99 adds new AT commands e.g. to control Advanced Speech Call Items (ASCI) services. / Text3: 27.005, 27.007
- 2603: Conclusion: 3GPP should not produce any technical specification for terminal interfaces other than radio interface and USIM interface. SDOs could develop own optional physical connector specification based on market requirements / Text3: 27.901
- 2604: Multiplexing protocol allowing a number of simultaneous sessions between a MS and a terminal; used to send any data (voice, SMS, USSD, fax etc.). 27.010 describes the protocol, but not the commands or data transported with it. / Text3: 27.010
- 2605: -
- 2606: CS and real-time data services provided for interworking with PSTN/ISDN so that user is unaware of access network used (UMTS, GSM or handover between ANs). Transparent(constant delay) & non-transparent(zero error with flow control) services are supported / Text3: 22.002, 23.910, 27.001, 29.007
- 2607: CS and real-time data services provided for interworking with PSTN/ISDN so that user is unaware of access network used (UMTS, GSM or handover between ANs). Transparent(constant delay) & non-transparent(zero error with flow control) services are supported / Text3: 22.002, 23.910, 27.001, 29.007
- 2608: - / Text3: 29.007
- 2609: - / Text3: 04.21, 23.910, 27.001, 29.007
- 2610: - / Text3: 27.001, 27.002, 27.003, 29.007
- 2611: - / Text3: 23.910, 27.001, 29.007
- 2612: No CR or new TS/TR approved under this WI / Text3: 29.007
- 2613: FTM is a type of async non-transparent CS bearer service (22.002). Generic term for HDLC and HDLC-related transmission protocols. Converts async non-transp data stream towards mobile side & sync data stream using X.31 flag stuffing on fixed network side. / Text3: 22.002, 27.001, 27.007, 29.007
- 2614: Access to an Intranet or ISP by running DHCP between the TE and a server in the Intranet/ISP domain. / Text3: 29.061
- 2615: PIAFS is one type of CS bearer data service (22.002). It refers to async CS tx protocol over ISDN 64 kbit/s unrestricted digital line. Facilitates interworking between PHS-MS and UMTS-UE & UMTS-UE and existing PIAFS TA (Terminal Adapter). / Text3: 22.002, 27.001, 27.007, 29.007
- 2616: PIAFS was originally standardised by the PHS Internet Access Forum in Japan. More information can be found at: http://www.infopro.or.jp/piaf / Text3: 22.002
- 2617: - / Text3: 27.001, 27.007, 29.007

| ID | WBS | Task | Duration | Start | Finish | Complete | Baseline start | Baseline finish | Baseline duration | Constraint | Resources | Work | Actual work | Text1 | Text6 | Text8 | Text12 |
| --- | --- | --- | --- | --- | --- | --- | --- | --- | --- | --- | --- | --- | --- | --- | --- | --- | --- |
| 2618 | 658.15 | **Universal Integrated Circuit Card (UICC) and Universal Subscriber Identity Module (USIM)** | 261d? | 1999-01-01 A | 1999-12-31 A | 100% | 1999-01-01 | 1999-12-31 | 261d? |  | T3 | 27144h | 27144h | UICC, USIM | R99 | Xavier |  |
| 2619 | 658.15.1 | UICC / Terminal interface; Physical and logical characteristics | 261d? | 1999-01-01 A | 1999-12-31 A | 100% | 1999-01-01 | 1999-12-31 | 261d? | start no earlier than 1999-01-01 | T3 | 2088h | 2088h | UICC | R99 | Xavier |  |
| 2620 | 658.15.2 | UICC/(U)SIM enhancements and interworking | 261d? | 1999-01-01 A | 1999-12-31 A | 100% | 1999-01-01 | 1999-12-31 | 261d? | start no earlier than 1999-01-01 | T3 | 2088h | 2088h | UICC1 | R99 | Xavier |  |
| 2621 | 658.15.3 | Characteristics of the USIM application | 261d? | 1999-01-01 A | 1999-12-31 A | 100% | 1999-01-01 | 1999-12-31 | 261d? | start no earlier than 1999-01-01 | T3 | 2088h | 2088h | USIM | R99 | Xavier |  |
| 2622 | 658.15.4 | UICC Application Identifiers | 261d? | 1999-01-01 A | 1999-12-31 A | 100% | 1999-01-01 | 1999-12-31 | 261d? | start no earlier than 1999-01-01 | T3 | 2088h | 2088h | AID, Application_Identifiers | R99 | Xavier |  |
| 2623 | 658.15.5 | SIM Application Toolkit | 261d? | 1999-01-01 A | 1999-12-31 A | 100% | 1999-01-01 | 1999-12-31 | 261d? | start no earlier than 1999-01-01 | S1,T3 | 2088h | 2088h | SAT | R99 | Alain |  |
| 2624 | 658.15.6 | USIM Application Toolkit | 261d? | 1999-01-01 A | 1999-12-31 A | 100% | 1999-01-01 | 1999-12-31 | 261d? | start no earlier than 1999-01-01 | T3 | 2088h | 2088h | USAT | R99 | Xavier |  |
| 2625 | 658.15.7 | Bearer Independent Protocol for SAT applications to exchange data over the GSM network | 261d? | 1999-01-01 A | 1999-12-31 A | 100% | 1999-01-01 | 1999-12-31 | 261d? | start no earlier than 1999-01-01 | T3 | 2088h | 2088h | BIP | R99 | Xavier |  |
| 2626 | 658.15.8 | Administrative commands and functions for IC cards | 261d? | 1999-01-01 A | 1999-12-31 A | 100% | 1999-01-01 | 1999-12-31 | 261d? | start no earlier than 1999-01-01 | T3 | 2088h | 2088h |  | R99 | Xavier |  |
| 2627 | 658.15.9 | USIM and UICC requirements | 261d? | 1999-01-01 A | 1999-12-31 A | 100% | 1999-01-01 | 1999-12-31 | 261d? | start no earlier than 1999-01-01 | T3 | 2088h | 2088h |  | R99 | Xavier |  |
| 2628 | 658.15.10 | SIM_API | 261d? | 1999-01-01 A | 1999-12-31 A | 100% | 1999-01-01 | 1999-12-31 | 261d? | start no earlier than 1999-01-01 | T3 | 2088h | 2088h | SIM_API | R99 | Xavier |  |
| 2629 | 658.15.11 | SIM_toolkit_API | 261d? | 1999-01-01 A | 1999-12-31 A | 100% | 1999-01-01 | 1999-12-31 | 261d? | start no earlier than 1999-01-01 | SMG9,T3 | 2088h | 2088h | SIM_toolkit | R99 | Xavier |  |
| 2630 | 658.15.12 | Deleted - 1.8 Volt SIM ME interface | 261d? | 1999-01-01 A | 1999-12-31 A | 100% | 1999-01-01 | 1999-12-31 | 261d? | start no earlier than 1999-01-01 | SMG9 | 2088h | 2088h | SMIME_1.8V | R99 | Xavier | TP-06 |
| 2631 | 658.16 | **USIM/UICC Testing** | 261d? | 1999-01-01 A | 1999-12-31 A | 100% | 1999-01-01 | 1999-12-31 | 261d? |  | T3 | 10440h | 10440h |  | R99 | Xavier |  |
| 2632 | 658.16.1 | Terminal tests for the UICC Interface | 261d? | 1999-01-01 A | 1999-12-31 A | 100% | 1999-01-01 | 1999-12-31 | 261d? | start no earlier than 1999-01-01 | T3 | 2088h | 2088h |  | R99 | Xavier |  |
| 2633 | 658.16.2 | USIM application test specification | 261d? | 1999-01-01 A | 1999-12-31 A | 100% | 1999-01-01 | 1999-12-31 | 261d? | start no earlier than 1999-01-01 | T3 | 2088h | 2088h |  | R99 | Xavier |  |
| 2634 | 658.16.3 | USIM conformance test specification | 261d? | 1999-01-01 A | 1999-12-31 A | 100% | 1999-01-01 | 1999-12-31 | 261d? | start no earlier than 1999-01-01 | T3 | 2088h | 2088h |  | R99 | Xavier |  |
| 2635 | 658.16.4 | SIM toolkit test specification | 261d? | 1999-01-01 A | 1999-12-31 A | 100% | 1999-01-01 | 1999-12-31 | 261d? | start no earlier than 1999-01-01 | T3 | 2088h | 2088h |  | R99 | Xavier |  |
| 2636 | 658.17 | **Security** | 261d? | 1999-01-01 A | 1999-12-31 A | 100% | 1999-01-01 | 1999-12-31 | 261d? |  | S3,N2,N4 | 8352h | 8352h | Security | R99 | Dionisio |  |
| 2637 | 658.17.1 | Fraud Information Gathering Service (for connection-orientated services) | 261d? | 1999-01-01 A | 1999-12-31 A | 100% | 1999-01-01 | 1999-12-31 | 261d? | start no earlier than 1999-01-01 | S3 | 2088h | 2088h | FIGS | R99 | Dionisio |  |
| 2638 | 658.17.2 | Immediate Service Termination / SECurity Immediate Service Termination | 261d? | 1999-01-01 A | 1999-12-31 A | 100% | 1999-01-01 | 1999-12-31 | 261d? | start no earlier than 1999-01-01 | S3,N2,N4 | 2088h | 2088h | IST, SECIST | R99 | Dionisio |  |
| 2639 | 658.17.3 | Core_Network_Security | 261d? | 1999-01-01 A | 1999-12-31 A | 100% | 1999-01-01 | 1999-12-31 | 261d? | start no earlier than 1999-01-01 | N4 | 2088h | 2088h | Core_Network_Security | R99 | Kimmo |  |
| 2640 | 659 | **GSM Features** | 261d? | 1999-01-01 A | 1999-12-31 A | 100% | 1999-01-01 | 1999-12-31 | 261d? |  | S1,S2,SMG,T2,N1,N2,N3,N4 | 50112h | 50112h |  | R99 | Alain |  |
| 2641 | 659.1 | **Dual Transfer Mode within GSM and GPRS** | 261d? | 1999-01-01 A | 1999-12-31 A | 100% | 1999-01-01 | 1999-12-31 | 261d? |  | SMG,N1 | 6264h | 6264h | DTM | R99 | Frederic |  |
| 2642 | 659.1.1 | Class A Dual Transfer Mode | 261d? | 1999-01-01 A | 1999-12-31 A | 100% | 1999-01-01 | 1999-12-31 | 261d? | start no earlier than 1999-01-01 | SMG | 2088h | 2088h | Class_A_Dual_Transfer_Mode_(DTM) | R99 | Frederic |  |
| 2643 | 659.1.2 | Dual Transfer Mode | 261d? | 1999-01-01 A | 1999-12-31 A | 100% | 1999-01-01 | 1999-12-31 | 261d? | start no earlier than 1999-01-01 | SMG,N1 | 2088h | 2088h | DTM | R99 | Frederic |  |

Notes:
- 2618: For 3G, GSM 11.11 was divided into two parts: a platform comprised of basic physical, electrical and logical specification (31.101) and an application specification (31.102)
- 2619: Defines a generic Terminal/Integrated Circuit Card (ICC) interface. Is independent of 3G USIM application => platform for any IC card application. Ensures interoperability between ICC and terminal independently of manufacturer, card issuer or operator. / Text3: 31.101 (Since 10/2000, ETSI EP SCP is responsible for the generic Terminal/Integrated Circuit Card (ICC) interface TS 102 221)
- 2620: - / Text3: 31.102, 31.900
- 2621: Defines Universal Subscriber Identity Module (USIM) application for 3G telecom network operation & resides on UICC, an IC card specified in 31.101. UICC can be used as a multi-application card: several USIMs and/or other applications can co-exist / Text3: 31.102
- 2622: Defines and administers Application IDentifiers (AID) for UICC. AID is used to address an application in the card. Consists of Registered application provider ID (RID) & Proprietary application ID exception (PIX - according to ISO/IEC 7816-5). / Text3: 21.111, 31.110
- 2623: - / Text3: 11.14, 22.030, 22.100, 22.101
- 2624: Defines UICC - ME interface, and mandatory ME procedures for USAT. Based on GSM 11.14 (SIM Application Toolkit). Commands and procedures defined in USIM and 3G Terminal for using USAT. Service and security requirements defined in 22.100 and 22.101. / Text3: 31.111
- 2625: Defines at SIM-ME interface a basic protocol allowing SIM Toolkit applications to determine available bearers and to exchange data by selecting using the most appropriate bearer available (CS data, GPRS, SMS, Unstructured Supplementary Service Data (USSD) / Text3: 03.48, 11.10, 11.14
- 2626: Defines function and syntax of administrative commands for telecommunication IC Card used during installation, activation and de-activation of applications. Compliant to ISO/IEC 7816 series. Handed over to ETSI Project Smart Card Platform (SCP) in 2000. / Text3: ETSI TS 102 222
- 2627: High level requirements for 3GPP IC card and its interface to 3GPP terminal (USIM&UICC reqs). Service&security reqs in 322.01,22.00. USIM is a 3GPP application on an IC card. Inter-operates with 3GPP terminals and provides access to 3GPP services / Text3: 21.111
- 2628: - / Text3: 03.19
- 2629: - / Text3: 03.48, 11.11, 11.14
- 2630: No CR or new TS/TR approved under this WI / Text3: 11.18
- 2631: -
- 2632: Test spec for the interface between UICC and terminal (originally based GSM 11.10-1 clause 27). Ensures UICC - terminal interoperability independently of manufacturer, card issuer or operator. Tests for applications residing on UICC are in 31.121 / Text3: 31.120
- 2633: Application test spec originally based on GSM 11.17. Aspects related to UICC administrative management phase are not defined. Any internal technical realisation of either UICC or terminal is only specified where these are reflected over the interface. / Text3: 31.121
- 2634: Conformance Test specification for UICC defined in 31.101 with USIM defined in 31.102. / Text3: 31.122
- 2635: SIM Application Toolkit (SAT) has major impact on ME design and enhances SIM/ME interface. Contains tests for SIM/ME interface optional features (no network related signalling issues involved). Doesn't form basis for any type approval or regulatory tests. / Text3: 11.10-4
- 2636: - / Text3: 02.09, 03.20, 21.133, 22.022, 23.003, 23.007, 23.008, 23.012, 23.018, 24.007, 24.008, 24.010, 24.011, 29.002, 29.060, 33.102, 33.103, 33.105, 33.107, 35.201
- 2637: HPLMN can monitor its subscribers in VPLMN, which collects info on a defined set of monitored subscribers activities & sends it to HPLMN, which can perform service limitation control eg Operator Determined Barring (ODB) and IST to limit financial exposure / Text3: 22.031, 23.031
- 2638: HPLMN can terminate all activities of its subscriber in VPLMN, if decides (based on info via eg FIGS) that a roaming subscriber is behaving in fraudulent/suspicious way. HPLMN can terminate all subscriber activities including calls in progress. / Text3: 03.35, 22.032, 23.008, 23.016, 23.035, 29.002
- 2639: - / Text3: 29.002
- 2640: -
- 2641: WID on BSS co-ordination of Radio Resource allocation for class A GPRS services - GSM Radio Access (R99) / Text3: 03.55, 03.64, 04.18, 04.60, 05.01, 05.02, 05.08, 08.08, 23.060, 24.007, 24.008
- 2642: - / Text3: 05.10
- 2643: - / Text3: 03.55, 03.64, 04.18, 05.01, 05.02, 05.08, 24.008

| ID | WBS | Task | Duration | Start | Finish | Complete | Baseline start | Baseline finish | Baseline duration | Constraint | Resources | Work | Actual work | Text1 | Text6 | Text12 | Text4 | Text5 |
| --- | --- | --- | --- | --- | --- | --- | --- | --- | --- | --- | --- | --- | --- | --- | --- | --- | --- | --- |
| 2644 | 659.2 | **General Packet Radio Service enahancements** | 261d? | 1999-01-01 A | 1999-12-31 A | 100% | 1999-01-01 | 1999-12-31 | 261d? |  | S1,S2,SMG1,SMG2,SMG7,N1,N2,N3,N4,T2 | 8352h | 8352h | GPRS enhancements | R99 |  |  |  |
| 2645 | 659.2.1 | General Packet Radio Service | 261d? | 1999-01-01 A | 1999-12-31 A | 100% | 1999-01-01 | 1999-12-31 | 261d? | start no earlier than 1999-01-01 | S1,S2,SMG1,SMG2,SMG7,N1,N2,N3,N4,T2 | 2088h | 2088h | GPRS | R99 |  |  |  |
| 2646 | 659.2.2 | GPRS2 | 261d? | 1999-01-01 A | 1999-12-31 A | 100% | 1999-01-01 | 1999-12-31 | 261d? | start no earlier than 1999-01-01 | SMG1,N2 | 2088h | 2088h | GPRS2 | R99 |  |  |  |
| 2647 | 659.2.3 | GPRS Tunnelling Protocol enhancement | 261d? | 1999-01-01 A | 1999-12-31 A | 100% | 1999-01-01 | 1999-12-31 | 261d? | start no earlier than 1999-01-01 | N4,N2 | 2088h | 2088h | GTP_enhancement | R99 |  |  |  |
| 2648 | 659.3 | **Enhanced Data rates for GSM Evolution - Phase 1** | 261d? | 1999-01-01 A | 1999-12-31 A | 100% | 1999-01-01 | 1999-12-31 | 261d? |  | SMG2,SMG1,SMG3,SMG4,SMG7,SMG9,SMG10,N1,N3,T2 | 25056h | 25056h | EDGE - Phase 1 | R99 |  |  |  |
| 2649 | 659.3.1 | Enhanced Data rates for GSM Evolution | 261d? | 1999-01-01 A | 1999-12-31 A | 100% | 1999-01-01 | 1999-12-31 | 261d? | start no earlier than 1999-01-01 | SMG2,SMG1,SMG3,SMG4,SMG7,SMG9,SMG10,N1,N3,T2 | 2088h | 2088h | EDGE | R99 |  |  |  |
| 2650 | 659.3.2 | EDGE-Layer1 | 261d? | 1999-01-01 A | 1999-12-31 A | 100% | 1999-01-01 | 1999-12-31 | 261d? | start no earlier than 1999-01-01 | SMG2 | 2088h | 2088h | EDGE-Layer1 | R99 |  |  |  |
| 2651 | 659.3.3 | High Speed Circuit Switched Data | 261d? | 1999-01-01 A | 1999-12-31 A | 100% | 1999-01-01 | 1999-12-31 | 261d? | start no earlier than 1999-01-01 | SMG1,SMG2,SMG7 | 2088h | 2088h | HSCSD | R99 |  |  |  |
| 2652 | 659.3.4 | Enhanced Circuit Switched Data - Phase 1 | 261d? | 1999-01-01 A | 1999-12-31 A | 100% | 1999-01-01 | 1999-12-31 | 261d? | start no earlier than 1999-01-01 | S1,SMG | 2088h | 2088h | ECSD | R99 |  |  |  |
| 2653 | 659.3.5 | EDGE-Enhanced Circuit Switched Data | 261d? | 1999-01-01 A | 1999-12-31 A | 100% | 1999-01-01 | 1999-12-31 | 261d? | start no earlier than 1999-01-01 | SMG2 | 2088h | 2088h | EDGE-ECSD | R99 |  |  |  |
| 2654 | 659.3.6 | Enhanced GPRS - Phase 1 | 261d? | 1999-01-01 A | 1999-12-31 A | 100% | 1999-01-01 | 1999-12-31 | 261d? | start no earlier than 1999-01-01 | SMG,N1 | 2088h | 2088h | EGPRS | R99 |  |  |  |
| 2655 | 659.3.7 | EDGE-EGPRS | 261d? | 1999-01-01 A | 1999-12-31 A | 100% | 1999-01-01 | 1999-12-31 | 261d? | start no earlier than 1999-01-01 | SMG2 | 2088h | 2088h | EDGE-EGPRS | R99 |  |  |  |
| 2656 | 659.3.8 | Packet Flow Context (PFC) | 261d? | 1999-01-01 A | 1999-12-31 A | 100% | 1999-01-01 | 1999-12-31 | 261d? | start no earlier than 1999-01-01 | SMG2 | 2088h | 2088h | PFC | R99 |  |  |  |
| 2657 | 659.3.9 | Support for EGPRS in ANSI-136 networks and EDGE COMPACT | 261d? | 1999-01-01 A | 1999-12-31 A | 100% | 1999-01-01 | 1999-12-31 | 261d? | start no earlier than 1999-01-01 | SMG | 2088h | 2088h | EDGE-Compact | R99 |  |  |  |
| 2658 | 659.3.10 | EGPRS COMPACT | 261d? | 1999-01-01 A | 1999-12-31 A | 100% | 1999-01-01 | 1999-12-31 | 261d? | start no earlier than 1999-01-01 | SMG | 2088h | 2088h | EGPRS-Compact | R99 |  |  |  |
| 2659 | 659.3.11 | COMPACT | 261d? | 1999-01-01 A | 1999-12-31 A | 100% | 1999-01-01 | 1999-12-31 | 261d? | start no earlier than 1999-01-01 | SMG,N1 | 2088h | 2088h | COMPACT | R99 |  |  |  |
| 2660 | 659.4 | GSM_400 | 261d? | 1999-01-01 A | 1999-12-31 A | 100% | 1999-01-01 | 1999-12-31 | 261d? | start no earlier than 1999-01-01 | SMG2,SMG7,T2 | 2088h | 2088h | GSM_400 | R99 |  |  |  |
| 2661 | 659.5 | GSM_450 | 261d? | 1999-01-01 A | 1999-12-31 A | 100% | 1999-01-01 | 1999-12-31 | 261d? | start no earlier than 1999-01-01 | SMG2 | 2088h | 2088h | GSM_450 | R99 |  |  |  |
| 2662 | 659.6 | GSM_700 | 261d? | 1999-01-01 A | 1999-12-31 A | 100% | 1999-01-01 | 1999-12-31 | 261d? | start no earlier than 1999-01-01 | SMG2 | 2088h | 2088h | GSM_700 | R99 |  |  |  |
| 2663 | 659.7 | Deleted - GERAN | 261d? | 1999-01-01 A | 1999-12-31 A | 100% | 1999-01-01 | 1999-12-31 | 261d? | start no earlier than 1999-01-01 | SMG2,S2 | 2088h | 2088h | GERAN | R99 | SP-06 |  |  |
| 2664 | 660 | **GSM Features transposed to UMTS** | 261d? | 1999-01-01 A | 1999-12-31 A | 100% | 1999-01-01 | 1999-12-31 | 261d? |  | S1,S3,T2,N2,N4 | 16704h | 16704h |  | R99 |  |  |  |
| 2665 | 660.1 | Cell Broadcast Service | 261d? | 1999-01-01 A | 1999-12-31 A | 100% | 1999-01-01 | 1999-12-31 | 261d? | start no earlier than 1999-01-01 | T2 | 2088h | 2088h | CBS | R99 |  |  |  |
| 2666 | 660.2 | **GSM mobile number portability euro MNP / North American MNP** | 261d? | 1999-01-01 A | 1999-12-31 A | 100% | 1999-01-01 | 1999-12-31 | 261d? |  | S1,N2,N4 | 4176h | 4176h | MNP | R99 |  |  |  |
| 2667 | 660.2.1 | Mobile Number Portability | 261d? | 1999-01-01 A | 1999-12-31 A | 100% | 1999-01-01 | 1999-12-31 | 261d? | start no earlier than 1999-01-01 | N2,N4 | 2088h | 2088h | MNP | R99 |  |  |  |
| 2668 | 660.3 | Automatic establishment of roaming relations | 261d? | 1999-01-01 A | 1999-12-31 A | 100% | 1999-01-01 | 1999-12-31 | 261d? | start no earlier than 1999-01-01 | S1 | 2088h | 2088h |  | R99 |  | Telecom Italia | enrico.scarrone@telecomitalia.it |
| 2669 | 660.4 | Advanced addressing | 261d? | 1999-01-01 A | 1999-12-31 A | 100% | 1999-01-01 | 1999-12-31 | 261d? | start no earlier than 1999-01-01 | S1 | 2088h | 2088h |  | R99 |  |  |  |
| 2670 | 660.5 | UMTS numbering, addressing and identities | 261d? | 1999-01-01 A | 1999-12-31 A | 100% | 1999-01-01 | 1999-12-31 | 261d? | start no earlier than 1999-01-01 | S1 | 2088h | 2088h |  | R99 |  |  |  |
| 2671 | 660.6 | Lawful Interception | 261d? | 1999-01-01 A | 1999-12-31 A | 100% | 1999-01-01 | 1999-12-31 | 261d? | start no earlier than 1999-01-01 | S3 | 2088h | 2088h | LI | R99 |  |  |  |

Notes:
- 2644: GPRS was introduced in Release 97. Release 99 brings a number of essential corrections e.g. on Downlink Power Control, Timing Advance procedure, Cell reselection delay time, PBCCH scheduling, PTCCH mapping, etc. / Text3: 05.02, 05.05, 05.08, 05.10, 05.50, 11.21, 23.064, 24.008, 24.060 / Text8: Alain
- 2645: - / Text3: 02.60, 03.22, 03.64, 04.18, 04.60, 04.64, 04.65, 05.01, 05.02, 05.05, 05.08, 05.10, 08.08, 08.18, 11.10-1, 11.21, 22.041, 22.060, 23.003, 23.007, 23.060, 23.107, 23.122, 24.007, 24.008, 27.007, 27.060, 29.002, 29.016, 29.018, 29.060, 29.061 / Text8: Alain
- 2646: Introduction of EGPRS (S1) + Introduction of Reserved Service Labels in the APN (N2) / Text3: 02.60, 23.003
- 2647: - / Text3: 23.003, 23.008, 29.060 / Text8: Kimmo
- 2648: EDGE is independent of the frequency bands, so it can be deployed e.g. in 900 and 1900 MHz bands. The new physical layer based on 8-PSK modulation is introduced and EGPRS and ECSD facilitate the new modulation in single and multi slot constellation. / Text3: 10.59, 02.34, 02.60, 03.30, 05.10, 05.50, 11.26 / Text8: Maurice
- 2649: - / Text3: 02.34, 03.10, 03.20, 03.64, 04.03, 04.04, 04.06, 04.08, 04.18, 04.21, 04.22, 04.60, 04.64, 05.01, 05.02, 05.03, 05.04, 05.05, 05.08, 05.10, 05.50, 07.01, 07.02, 07.03, 08.08, 08.20, 08.58, 08.60, 09.07, 09.18, 11.10-1, 11.11, 11.21, 11.26, 23.034, 24.008, / Text8: Maurice
- 2650: - / Text3: 05.05, 05.10, 05.50
- 2651: No additional features for R99. / Text3: 02.34, 04.18, 11.10-1
- 2652: ECSD supports both transparent and non-transparent services, up to 64 kbit/s and 57.6 kbit/s respectively. See Tdoc SMG2 670/99 ECSD Concept Evaluation for more info / Text3: 05.02, 08.58, 22.034 / Text8: Alain
- 2653: - / Text3: 05.03
- 2654: - / Text3: 02.07, 03.64, 04.14, 04.18, 04.60, 05.05, 05.08, 24.008
- 2655: - / Text3: 05.03, 05.05, 05.08
- 2656: - / Text3: 04.18
- 2657: Support for EGPRS in ANSI-136 networks and EDGE Compact (for ANSI-136 networks only). COMPACT = Deployment of services in spectrum below 1 MHz / Text3: 03.22, 03.30, 03.64, 05.01, 05.02, 05.03, 05.05, 05.08, 05.10
- 2658: COMPACT = Deployment of services in spectrum below 1 MHz / Text3: 04.18, 05.02
- 2659: COMPACT = Deployment of services in spectrum below 1 MHz / Text3: 03.22, 04.18, 04.60, 05.08, 23.122, 24.008
- 2660: - / Text3: 02.17, 03.22, 03.30, 04.04, 04.18, 04.60, 05.01, 05.02, 05.05, 05.08, 05.10, 05.50, 08.18, 08.58, 11.21, 24.008, 27.007 / Text8: GSM in the 400 MHz bands allows to deploy GSM within frequency bands in the range 450 to 500 MHz, previously used for analogue cellular systems. See Tdoc SMG2 190/99 and 595/99 for further info.
- 2661: - / Text3: 03.22, 03.30, 05.01, 05.05, 05.08
- 2662: - / Text3: 05.05
- 2663: No CR or new TS/TR approved under this WI / Text3: G2: 04.18 CR#A248 , 04.60 CR#B090 / Text8: Maurice
- 2664: - / Text8: Alain
- 2665: Moved to CT1 at TSG-T closure. Applicability of the Cell Broadcast Service (as defined for GSM network) to 3G networks / Text3: 23.041
- 2666: R98 MNP: mobile subscriber ability to change PLMN operator within the same country whilst retaining its original MS ISDN number (MSISDN). IMSI is changed, only MSISDN is kept. R99 adds requirements for North American Service Provider Number Portability. / Text3: 22.066 / Text8: Alain
- 2667: - / Text3: 23.018, 23.066, 29.002 / Text8: Kimmo
- 2668: framework for commercial and technical interworking between UMTS Home Environments and Serving Networks who have no direct prior commercial agreements with each other. / Text3: 22.101, 22.971 / Text8: Alain
- 2669: - / Text3: 22.101, 22.75U, 22.975 / Text8: Alain
- 2670: Also new requirements for Single and Multiple Numbering scheme was added (CR#20 and 21). Deleted the term International Mobile User Identifier (IMUI) and changed IMSI (International Mobile Station Identifier=>International Mobile Subscriber Identity. / Text3: 22.101 / Text8: Alain
- 2671: Defines an interception system in UMTS that supports a number of regional interception regulations. Regional interception requirements shall be met in using specific (regional) mediation functions allowing only required information to be transported. / Text3: 33.106, 33.107 / Text8: Dionisio

| ID | WBS | Task | Duration | Start | Finish | Complete | Baseline start | Baseline finish | Baseline duration | Constraint | Resources | Work | Actual work | Text1 | Text6 | Text8 |
| --- | --- | --- | --- | --- | --- | --- | --- | --- | --- | --- | --- | --- | --- | --- | --- | --- |
| 2672 | 661 | **Charging** | 261d? | 1999-01-01 A | 1999-12-31 A | 100% | 1999-01-01 | 1999-12-31 | 261d? |  | S1,S5 | 6264h | 6264h | CH | R99 | Alain |
| 2673 | 661.1 | Charging | 261d? | 1999-01-01 A | 1999-12-31 A | 100% | 1999-01-01 | 1999-12-31 | 261d? | start no earlier than 1999-01-01 | S1 | 2088h | 2088h | Charging | R99 | Alain |
| 2674 | 661.2 | OAM Charging Management | 261d? | 1999-01-01 A | 1999-12-31 A | 100% | 1999-01-01 | 1999-12-31 | 261d? | start no earlier than 1999-01-01 | S5 | 2088h | 2088h | OAMCH, CH | R99 | Dionisio |
| 2675 | 662 | **Operations, Administration, Maintenance and Provisioning (OAM&P)** | 261d? | 1999-01-01 A | 1999-12-31 A | 100% | 1999-01-01 | 1999-12-31 | 261d? |  | S5 | 12528h | 12528h | OAM | R99 | Dionisio |
| 2676 | 662.1 | OAM Principles and High-level Requirements | 261d? | 1999-01-01 A | 1999-12-31 A | 100% | 1999-01-01 | 1999-12-31 | 261d? | start no earlier than 1999-01-01 | S5 | 2088h | 2088h | PR, Princs_&_Reqs_(PR) | R99 | Dionisio |
| 2677 | 662.2 | OAM Architecture | 261d? | 1999-01-01 A | 1999-12-31 A | 100% | 1999-01-01 | 1999-12-31 | 261d? | start no earlier than 1999-01-01 | S5 | 2088h | 2088h | OAMAR, AR, Telecom_Management_Arch_(AR) | R99 | Dionisio |
| 2678 | 662.3 | OAM Configuration Management | 261d? | 1999-01-01 A | 1999-12-31 A | 100% | 1999-01-01 | 1999-12-31 | 261d? | start no earlier than 1999-01-01 | S5 | 2088h | 2088h | OAMCM, CM | R99 | Dionisio |
| 2679 | 662.4 | OAM Fault Management | 261d? | 1999-01-01 A | 1999-12-31 A | 100% | 1999-01-01 | 1999-12-31 | 261d? | start no earlier than 1999-01-01 | S5 | 2088h | 2088h | OAMFM | R99 | Dionisio |
| 2680 | 662.5 | OAM Performance Management | 261d? | 1999-01-01 A | 1999-12-31 A | 100% | 1999-01-01 | 1999-12-31 | 261d? | start no earlier than 1999-01-01 | S5 | 2088h | 2088h | OAMPM, PM | R99 | Dionisio |
| 2681 | 663 | Vocabulary | 261d? | 1999-01-01 A | 1999-12-31 A | 100% | 1999-01-01 | 1999-12-31 | 261d? | start no earlier than 1999-01-01 | S1 | 2088h | 2088h | Vocabulary | R99 | Alain |
| 2682 | 664 | Emergency | 261d? | 1999-01-01 A | 1999-12-31 A | 100% | 1999-01-01 | 1999-12-31 | 261d? | start no earlier than 1999-01-01 | S1 | 2088h | 2088h | Emergency | R99 | Alain |
| 2683 | 665 | GSM General Bearer Services (GBS) and interworking scenarios support in UMTS | 261d? | 1999-01-01 A | 1999-12-31 A | 100% | 1999-01-01 | 1999-12-31 | 261d? | start no earlier than 1999-01-01 | S1 | 2088h | 2088h | GSM_to_UMTS_Evol | R99 | Alain |
| 2684 | 666 | GPRS_Mobile_IP_interworking | 261d? | 1999-01-01 A | 1999-12-31 A | 100% | 1999-01-01 | 1999-12-31 | 261d? | start no earlier than 1999-01-01 | N3 | 2088h | 2088h | GPRS_Mobile_IP_interworking | R99 |  |
| 2685 | 667 | GSM/UMTS interworking | 261d? | 1999-01-01 A | 1999-12-31 A | 100% | 1999-01-01 | 1999-12-31 | 261d? | start no earlier than 1999-01-01 | N1,N2,N4,R3,S1,SMG | 2088h | 2088h | 2G3Ginterworking | R99 | Frederic |
| 2686 | 668 | Handover | 261d? | 1999-01-01 A | 1999-12-31 A | 100% | 1999-01-01 | 1999-12-31 | 261d? | start no earlier than 1999-01-01 | S1,SMG2,N1,N2,N4 | 2088h | 2088h | Handover | R99 | Alain |
| 2687 | 669 | 2G3Ghandover | 261d? | 1999-01-01 A | 1999-12-31 A | 100% | 1999-01-01 | 1999-12-31 | 261d? | start no earlier than 1999-01-01 | SMG2 | 2088h | 2088h | 2G3Ghandover | R99 |  |
| 2688 | 670 | Service Provider Name Indication | 261d? | 1999-01-01 A | 1999-12-31 A | 100% | 1999-01-01 | 1999-12-31 | 261d? | start no earlier than 1999-01-01 | S1 | 2088h | 2088h | SPANME | R99 | Alain |
| 2689 | 671 | Data & Data_CleanUp | 261d? | 1999-01-01 A | 1999-12-31 A | 100% | 1999-01-01 | 1999-12-31 | 261d? | start no earlier than 1999-01-01 | SMG1 | 2088h | 2088h | Data, Data_CleanUp | R99 |  |
| 2690 | 672 | Unstructured Supplementary Service Data | 261d? | 1999-01-01 A | 1999-12-31 A | 100% | 1999-01-01 | 1999-12-31 | 261d? | start no earlier than 1999-01-01 | SMG1,N4 | 2088h | 2088h | USSD | R99 | Kimmo |
| 2691 | 673 | Man-Machine Interface (MMI) of the User Equipment (UE) | 261d? | 1999-01-01 A | 1999-12-31 A | 100% | 1999-01-01 | 1999-12-31 | 261d? | start no earlier than 1999-01-01 | S1 | 2088h | 2088h | MMI | R99 | Alain |
| 2692 | 674 | Network Identity and Timezone (NITZ) | 261d? | 1999-01-01 A | 1999-12-31 A | 100% | 1999-01-01 | 1999-12-31 | 261d? | start no earlier than 1999-01-01 | SMG1,SMG3 | 2088h | 2088h | NITZ | R99 | Alain |
| 2693 | 675 | Operator Determined Barring for Packet Oriented Services | 261d? | 1999-01-01 A | 1999-12-31 A | 100% | 1999-01-01 | 1999-12-31 | 261d? | start no earlier than 1999-01-01 | S1 | 2088h | 2088h | ODB_Enh. | R99 | Alain |
| 2694 | 676 | Packet Flow Management | 261d? | 1999-01-01 A | 1999-12-31 A | 100% | 1999-01-01 | 1999-12-31 | 261d? | start no earlier than 1999-01-01 | SMG2 | 2088h | 2088h | Packet_Flow_Management | R99 |  |
| 2695 | 677 | GPRS_Point-To-Multipoint Group call | 261d? | 1999-01-01 A | 1999-12-31 A | 100% | 1999-01-01 | 1999-12-31 | 261d? | start no earlier than 1999-01-01 | SMG1 | 2088h | 2088h | GPRS_PTMG | R99 |  |

Notes:
- 2672: -
- 2673: WID SP-99271 Charging and accounting / Text3: 22.115, 23.121
- 2674: WID SP-99581 SA5 Year 2000 Work plan / Text3: 32.005, 32.015
- 2675: WID SP-99581 SA5 Year 2000 Work plan
- 2676: WID SP-99581 SA5 Year 2000 Work plan / Text3: 32.101
- 2677: WID SP-99581 SA5 Year 2000 Work plan / Text3: 32.101, 32.102
- 2678: WID SP-99273 Configuration management / Text3: 32.106, 32.106-1, 32.106-2, 32.106-3, 32.106-4, 32.106-5, 32.106-6, 32.106-7, 32.106-8
- 2679: WID SP-99272 Fault management / Text3: 32.111, 32.111-1, 32.111-2, 32.111-3, 32.111-4
- 2680: WID SP-99274 Performance management / Text3: 12.04, 32.104
- 2681: - / Text3: 21.905
- 2682: - / Text3: 22.101
- 2683: UMTS shall support GSM General Bearer Services (GBS) and interworking scenarios as specified in 02.02 / Text3: 22.105
- 2684: - / Text3: 29.061
- 2685: - / Text3: 03.22, 04.18, 04.60, 05.02, 05.08, 05.10, 08.08, 08.18, 08.58, 09.08, 22.011, 23.003, 23.009, 23.014, 23.034, 23.122, 24.007, 24.008, 24.011, 24.080, 29.108
- 2686: - / Text3: 04.18, 08.08, 08.58, 22.129, 23.009, 29.002, 29.010
- 2687: - / Text3: 04.18, 04.60, 05.02, 05.08, 05.10, 08.08, 29.010
- 2688: Service Provider Name Indication included in R98 (02.07) was not carried into R99 (22.101), but is in the SIM/USIM specification for R99 / Text3: 22.101
- 2689: - / Text3: 02.01, 02.02, 02.04, 02.34
- 2690: No additional features for R99. / Text3: 02.04, 02.90, 23.090, 29.002
- 2691: Data services streamlining + Support for Anonymous Call Rejection / Text3: 22.030
- 2692: - / Text3: 02.42, 04.08
- 2693: Remove ODB for Packet Oriented Services from R99 / Text3: 22.041
- 2694: - / Text3: 08.18
- 2695: - / Text3: 02.60

| ID | WBS | Task | Duration | Start | Finish | Complete | Baseline start | Baseline finish | Baseline duration | Constraint | Resources | Work | Actual work | Text6 | Text8 |
| --- | --- | --- | --- | --- | --- | --- | --- | --- | --- | --- | --- | --- | --- | --- | --- |
| 2696 | 678 | **Call Forwarding** | 261d? | 1999-01-01 A | 1999-12-31 A | 100% | 1999-01-01 | 1999-12-31 | 261d? |  | SMG1,N2,N4 | 8352h | 8352h | R99 | Kimmo |
| 2697 | 678.1 | Call Forwarding enhancements | 261d? | 1999-01-01 A | 1999-12-31 A | 100% | 1999-01-01 | 1999-12-31 | 261d? | start no earlier than 1999-01-01 | N4,N2 | 2088h | 2088h | R99 | Kimmo |
| 2698 | 678.2 | Call_Forwarding | 261d? | 1999-01-01 A | 1999-12-31 A | 100% | 1999-01-01 | 1999-12-31 | 261d? | start no earlier than 1999-01-01 | SMG1,N2 | 2088h | 2088h | R99 | Kimmo |
| 2699 | 678.3 | Call_Forwarding_Enhancements | 261d? | 1999-01-01 A | 1999-12-31 A | 100% | 1999-01-01 | 1999-12-31 | 261d? | start no earlier than 1999-01-01 | N4 | 2088h | 2088h | R99 | Kimmo |
| 2700 | 679 | **Quality of Service** | 261d? | 1999-01-01 A | 1999-12-31 A | 100% | 1999-01-01 | 1999-12-31 | 261d? |  | S2,T2,N1,N2,N4 | 10440h | 10440h | R99 | Maurice |
| 2701 | 679.1 | End-to-end UMTS Quality of Service management | 261d? | 1999-01-01 A | 1999-12-31 A | 100% | 1999-01-01 | 1999-12-31 | 261d? | start no earlier than 1999-01-01 | S2,T2,N1,N2,N4 | 2088h | 2088h | R99 | Maurice |
| 2702 | 679.2 | End-to-end QoS for PS Domain including IMS | 261d? | 1999-01-01 A | 1999-12-31 A | 100% | 1999-01-01 | 1999-12-31 | 261d? | start no earlier than 1999-01-01 | S2 | 2088h | 2088h | R99 | Maurice |
| 2703 | 679.3 | GPRS-enhanced_QoS | 261d? | 1999-01-01 A | 1999-12-31 A | 100% | 1999-01-01 | 1999-12-31 | 261d? | start no earlier than 1999-01-01 | T2 | 2088h | 2088h | R99 |  |
| 2704 | 679.4 | QoS_enhancements | 261d? | 1999-01-01 A | 1999-12-31 A | 100% | 1999-01-01 | 1999-12-31 | 261d? | start no earlier than 1999-01-01 | N2,N1,N4 | 2088h | 2088h | R99 | Kimmo |
| 2705 | 680 | Support of Localised Service Area | 261d? | 1999-01-01 A | 1999-12-31 A | 100% | 1999-01-01 | 1999-12-31 | 261d? | start no earlier than 1999-01-01 | SMG2,SMG3,SMG7,N2 | 2088h | 2088h | R99 | Maurice |
| 2706 | 681 | Transcoder_location | 261d? | 1999-01-01 A | 1999-12-31 A | 100% | 1999-01-01 | 1999-12-31 | 261d? | start no earlier than 1999-01-01 | S2 | 2088h | 2088h | R99 | Maurice |
| 2707 | 682 | Antenna_test_methods | 261d? | 1999-01-01 A | 1999-12-31 A | 100% | 1999-01-01 | 1999-12-31 | 261d? | start no earlier than 1999-01-01 | SMG2 | 2088h | 2088h | R99 |  |
| 2708 | 683 | WBAMR / high quality speech in UMTS Phase 1 but not in R99 | 261d? | 1999-01-01 A | 1999-12-31 A | 100% | 1999-01-01 | 1999-12-31 | 261d? | start no earlier than 1999-01-01 | S1 | 2088h | 2088h | R99 | Alain |
| 2709 | 684 | **Codec** | 261d? | 1999-01-01 A | 1999-12-31 A | 100% | 1999-01-01 | 1999-12-31 | 261d? |  | S4 | 14616h | 14616h | R99 | Paolo |
| 2710 | 684.1 | Codec(s)_for_Multimedia_Telephony_Service | 261d? | 1999-01-01 A | 1999-12-31 A | 100% | 1999-01-01 | 1999-12-31 | 261d? | start no earlier than 1999-01-01 | S4 | 2088h | 2088h | R99 | Paolo |
| 2711 | 684.2 | QoS for Speech and Multimedia Codec | 261d? | 1999-01-01 A | 1999-12-31 A | 100% | 1999-01-01 | 1999-12-31 | 261d? | start no earlier than 1999-01-01 | S4 | 2088h | 2088h | R99 | Paolo |
| 2712 | 684.3 | Tandem Free Operation - Adaptive Multi-Rate codec types | 261d? | 1999-01-01 A | 1999-12-31 A | 100% | 1999-01-01 | 1999-12-31 | 261d? | start no earlier than 1999-01-01 | S4 | 2088h | 2088h | R99 | Paolo |
| 2713 | 684.4 | Noise Suppression for AMR | 261d? | 1999-01-01 A | 1999-12-31 A | 100% | 1999-01-01 | 1999-12-31 | 261d? | start no earlier than 1999-01-01 | S4 | 2088h | 2088h | R99 | Paolo |
| 2714 | 684.5 | Out-of-Band Transcoder | 261d? | 1999-01-01 A | 1999-12-31 A | 100% | 1999-01-01 | 1999-12-31 | 261d? | start no earlier than 1999-01-01 | N1 | 2088h | 2088h | R99 | Frederic |
| 2715 | 684.6 | Out-of-Band Transcoder Control | 261d? | 1999-01-01 A | 1999-12-31 A | 100% | 1999-01-01 | 1999-12-31 | 261d? | start no earlier than 1999-01-01 | N1 | 2088h | 2088h | R99 | Frederic |
| 2716 | 685 | Advanced Speech Call Items enhancements | 261d? | 1999-01-01 A | 1999-12-31 A | 100% | 1999-01-01 | 1999-12-31 | 261d? | start no earlier than 1999-01-01 | SMG1,SMG2,SMG3,SMG7,SMG9,N1,C1,N4,S1,T2 | 2088h | 2088h | R99 | Alain |
| 2717 | 686 | Call Control improvements | 261d? | 1999-01-01 A | 1999-12-31 A | 100% | 1999-01-01 | 1999-12-31 | 261d? | start no earlier than 1999-01-01 | N1 | 2088h | 2088h | R99 | Frederic |
| 2718 | 687 | Multimedia | 261d? | 1999-01-01 A | 1999-12-31 A | 100% | 1999-01-01 | 1999-12-31 | 261d? | start no earlier than 1999-01-01 | N1,N3 | 2088h | 2088h | R99 | Frederic |
| 2719 | 688 | Sub-System Number allocation for RANAP, RNSAP | 261d? | 1999-01-01 A | 1999-12-31 A | 100% | 1999-01-01 | 1999-12-31 | 261d? | start no earlier than 1999-01-01 | N2 | 2088h | 2088h | R99 | Frederic |
| 2720 | 689 | Intranet / ISP access with DHCP end-to-end | 261d? | 1999-01-01 A | 1999-12-31 A | 100% | 1999-01-01 | 1999-12-31 | 261d? | start no earlier than 1999-01-01 | N3 | 2088h | 2088h | R99 | Gwiho |
| 2721 | 690 | Point_to_Multipoint_Services | 261d? | 1999-01-01 A | 1999-12-31 A | 100% | 1999-01-01 | 1999-12-31 | 261d? | start no earlier than 1999-01-01 | N3 | 2088h | 2088h | R99 | Gwiho |
| 2722 | 691 | Facsimile | 261d? | 1999-01-01 A | 1999-12-31 A | 100% | 1999-01-01 | 1999-12-31 | 261d? | start no earlier than 1999-01-01 | S1 | 2088h | 2088h | R99 | Alain |
| 2723 | 692 | Realtime_NT_FAX_in_UMTS | 261d? | 1999-01-01 A | 1999-12-31 A | 100% | 1999-01-01 | 1999-12-31 | 261d? | start no earlier than 1999-01-01 | N3 | 2088h | 2088h | R99 | Gwiho |
| 2724 | 693 | Gateway Location Register (GLR) - Mobile Application Part (MAP) specification | 261d? | 1999-01-01 A | 1999-12-31 A | 100% | 1999-01-01 | 1999-12-31 | 261d? | start no earlier than 1999-01-01 | N4 | 2088h | 2088h | R99 | Kimmo |
| 2725 | 694 | Multiple Subscriber Profile phase 2 | 261d? | 1999-01-01 A | 1999-12-31 A | 100% | 1999-01-01 | 1999-12-31 | 261d? | start no earlier than 1999-01-01 | S1,N4 | 2088h | 2088h | R99 | Alain |
| 2726 | 695 | Prepaging | 261d? | 1999-01-01 A | 1999-12-31 A | 100% | 1999-01-01 | 1999-12-31 | 261d? | start no earlier than 1999-01-01 | N2,N4 | 2088h | 2088h | R99 | Kimmo |
| 2727 | 696 | Downlink Advanced Receiver Performance | 261d? | 1999-01-01 A | 1999-12-31 A | 100% | 1999-01-01 | 1999-12-31 | 261d? | start no earlier than 1999-01-01 | SMG | 2088h | 2088h | R99 |  |
| 2728 | 697 | Harmonized Standard | 261d? | 1999-01-01 A | 1999-12-31 A | 100% | 1999-01-01 | 1999-12-31 | 261d? | start no earlier than 1999-01-01 | SMG2 | 2088h | 2088h | R99 |  |
| 2729 | 698 | Streamlining of specifications | 261d? | 1999-01-01 A | 1999-12-31 A | 100% | 1999-01-01 | 1999-12-31 | 261d? | start no earlier than 1999-01-01 | N3 | 2088h | 2088h | R99 | Gwiho |
| 2730 | 699 | R99_Service_Clean_up | 261d? | 1999-01-01 A | 1999-12-31 A | 100% | 1999-01-01 | 1999-12-31 | 261d? | start no earlier than 1999-01-01 | N3 | 2088h | 2088h | R99 | Gwiho |

Notes:
- 2696: -
- 2697: No additional features for R99. / Text1: CF_enhancements / Text3: 23.078, 23.079, 23.082, 29.002, 29.078
- 2698: - / Text1: Call_Forwarding / Text3: 02.82, 29.002
- 2699: - / Text1: Call_Forwarding_Enhancements / Text3: 23.082
- 2700: WID SMG 98-0781 End To End UMTS QoS Management
- 2701: WID SMG 98-0781 End To End UMTS QoS Management / Text1: QoS / Text3: 23.107, 23.907, 24.008
- 2702: - / Text1: E2EQoS / Text3: 23.060, 23.170
- 2703: AT-commands for Enhanced QoS Support management / Text1: GPRS-enhanced_QoS / Text3: 27.007
- 2704: - / Text1: QoS_enhancements / Text3: 23.008, 23.016, 24.008, 29.002, 29.060
- 2705: Mechanism which can be used as a platform for providing special tariffs and/or special set of service features for certain subscribers within a regionally restricted area or areas. No additional features for R99. / Text1: SoLSA / Text3: 04.08, 04.18, 08.08, 11.10-1, 29.002
- 2706: UE location identification: background information and associated primitives 2. Transcoder location at the core network and source depending coding belonging to the non-access stratum. / Text1: Transcoder_location / Text3: 23.110
- 2707: - / Text1: Antenna_test_methods / Text3: 03.30
- 2708: Add requirement for high quality speech in UMTS Phase 1 but not in R99 / Text1: WBAMR / Text3: 22.105
- 2709: -
- 2710: - / Text1: Multimedia_Codec, CSM, WI2MMC, Codec(s)_for_CS_MM_Tel._Serv, Codec(s)_for_MM_Tel_Service, Codec_for_Multimedia_Telephony / Text3: 26.911, 26.104, 26.111
- 2711: - / Text1: QoS_for_Speech_&_MM_Codecs_/_AMR / Text3: 26.102, 26.912
- 2712: UMTS_AMR2 is default Codec Type in R99 dual_mode terminals / Text1: TFOAMR / Text3: 26.103
- 2713: Combination of the AMR speech codec and the Noise Suppression function. TS 06.77 and TR 06.78 only apply to GSM. They apply to UMTS from Rel-4 onwards, when they were converted to TS 26.077 and TR 26.078. / Text1: AMRNS / Text3: 06.77, 06.78
- 2714: Transcoder handling in the CN at inter-system handover and relocation + Introduction of UMTS AMR / Text1: OoBT / Text3: 23.009, 24.008
- 2715: 24.008 CR#0572 in NP-020220 was approved under this WI / Text1: OoBTC / Text3: 24.008 CR#0572 in NP-020220
- 2716: - / Text1: ASCI / Text3: 02.30, 02.68, 03.68, 03.69, 04.18, 08.08, 11.10-1, 11.11, 23.067, 23.094, 24.008, 24.067, 27.007, 29.002
- 2717: Minor improvements to 24.007 and 24.008 to increase the number of simultaneous calls/sessions from the present 7: the TI value is increased (NP-99441). / Text1: CC_Related_items / Text3: 24.007, 24.008
- 2718: - / Text1: Multimedia / Text3: 24.008, 27.001, 29.007
- 2719: Sub-System Number allocation for Radio Access Network Application Part, Radio Network Subsystem Application Part / Text1: SSN_allocation / Text3: 23.003
- 2720: Access to an Intranet/ISP with DHCP end to end / Text1: ISPaccess / Text3: 29.061
- 2721: Support for the IP-Multicast protocol / Text1: Point_to_Multipoint_Services / Text3: 29.061
- 2722: - / Text1: FAX / Text3: 22.003, 22.100
- 2723: Asynchronous Interface for real-time NT Fax + Introduction of Asynchronous interface for Real-time non-transparent FAX / Text1: Realtime_NT_FAX_in_UMTS / Text3: 27.001, 27.003
- 2724: - / Text1: GLR / Text3: 29.120
- 2725: - / Text1: MSP2 / Text3: 22.097, 23.072, 23.083, 23.084, 23.091, 23.093, 23.097
- 2726: - / Text1: Prepaging / Text3: 23.018, 23.082, 29.002
- 2727: Re-definition of channel quality measure used for AMR link adaptation for DARP MS / Text3: 05.09
- 2728: - / Text1: HS / Text3: 13.21
- 2729: - / Text1: Streamlining / Text3: 27.060, 29.061
- 2730: - / Text1: R99_Service_Clean_up / Text3: 03.10, 27.001, 27.002, 27.003, 27.060, 29.007, 29.061

| ID | WBS | Task | Type | Duration | Start | Finish | Complete | Baseline start | Baseline finish | Baseline duration | Constraint | Resources | Work | Actual work | Text1 | Text6 | Text8 | Text3 | Text12 | Text4 | Text5 |
| --- | --- | --- | --- | --- | --- | --- | --- | --- | --- | --- | --- | --- | --- | --- | --- | --- | --- | --- | --- | --- | --- |
| 2731 | 700 | **(Small) Technical Enhancements and Improvements for R99** |  | 261d? | 1999-01-01 A | 1999-12-31 A | 100% | 1999-01-01 | 1999-12-31 | 261d? |  | N3 | 6264h | 6264h | TEI | R99 | Gwiho |  |  |  |  |
| 2732 | 700.1 | TEI_[CS_Data] |  | 261d? | 1999-01-01 A | 1999-12-31 A | 100% | 1999-01-01 | 1999-12-31 | 261d? | start no earlier than 1999-01-01 | N3 | 2088h | 2088h | TEI_[CS_Data] | R99 | Gwiho |  |  |  |  |
| 2733 | 700.2 | TEI_[GPRS] |  | 261d? | 1999-01-01 A | 1999-12-31 A | 100% | 1999-01-01 | 1999-12-31 | 261d? | start no earlier than 1999-01-01 | N3 | 2088h | 2088h | TEI_[GPRS] | R99 | Gwiho |  |  |  |  |
| 2734 | 701 | **R99 UE Conformance Testing** |  | 261d? | 1999-01-01 A | 1999-12-31 A | 100% | 1999-01-01 | 1999-12-31 | 261d? |  | R5,T1 | 4176h | 4176h | TEI_Test | R99 | Ingbert | 34.108, 34.121, 34.122, 34.123-1, 34.123-2, 34.123-3 |  |  |  |
| 2735 | 701.1 | Deleted - RTEI |  | 261d? | 1999-01-01 A | 1999-12-31 A | 100% | 1999-01-01 | 1999-12-31 | 261d? | start no earlier than 1999-01-01 | T1 | 2088h | 2088h | RTEI | R99 | Ingbert | 34.123-1 CR#0650, 0651, 34.123-3 CR#0148, 0149, 0150 | TP-06 |  |  |
| 2736 | 701.2 | Common test environments for User Equipment (UE); Conformance testing | milestone | 0d? | 1999-01-01 A | 1999-01-01 A | 100% | 1999-01-01 | 1999-01-01 | 0d? | start no earlier than 1999-01-01 | R5,T1 |  |  | TEI_Test | R99 | Ingbert | 34.108 |  |  |  |
| 2737 | 701.3 | Terminal conformance specification, Radio transmission and reception (FDD) | milestone | 0d? | 1999-01-01 A | 1999-01-01 A | 100% | 1999-01-01 | 1999-01-01 | 0d? | start no earlier than 1999-01-01 | R5,T1 |  |  | TEI_Test | R99 | Ingbert | 34.121 |  |  |  |
| 2738 | 701.4 | Terminal conformance specification, Radio transmission and reception (TDD) | milestone | 0d? | 1999-01-01 A | 1999-01-01 A | 100% | 1999-01-01 | 1999-01-01 | 0d? | start no earlier than 1999-01-01 | R5,T1 |  |  | TEI_Test | R99 | Ingbert | 34.122 |  |  |  |
| 2739 | 701.5 | UE conformance specification; Part 1: Protocol conformance specification | milestone | 0d? | 1999-01-01 A | 1999-01-01 A | 100% | 1999-01-01 | 1999-01-01 | 0d? | start no earlier than 1999-01-01 | R5,T1 |  |  | TEI_Test | R99 | Ingbert | 34.123-1 |  |  |  |
| 2740 | 701.6 | UE conformance specification; Part 2: Implementation Conformance Statement (ICS) specification | milestone | 0d? | 1999-01-01 A | 1999-01-01 A | 100% | 1999-01-01 | 1999-01-01 | 0d? | start no earlier than 1999-01-01 | R5,T1 |  |  | TEI_Test | R99 | Ingbert | 34.123-2 |  |  |  |
| 2741 | 701.7 | UE conformance specification; Part 3: Abstract test suites (ATSs) | milestone | 0d? | 1999-01-01 A | 1999-01-01 A | 100% | 1999-01-01 | 1999-01-01 | 0d? | start no earlier than 1999-01-01 | R5,T1 |  |  | TEI_Test | R99 | Ingbert | 34.123-3 |  |  |  |
| 2742 | 702 | Deleted - Dual Tone Multi-Frequency signalling : Support in the whole 3GPP system |  | 261d? | 1999-01-01 A | 1999-12-31 A | 100% | 1999-01-01 | 1999-12-31 | 261d? | start no earlier than 1999-01-01 | N1 | 2088h | 2088h | DTMF | R99 | Frederic | 23.014 CR#0004 | NP-06 |  |  |
| 2743 | 703 | Deleted - Intersystem_Change |  | 261d? | 1999-01-01 A | 1999-12-31 A | 100% | 1999-01-01 | 1999-12-31 | 261d? | start no earlier than 1999-01-01 | SMG | 2088h | 2088h | Intersystem_Change | R99 |  | 04.18 CR#A243 | SMG |  |  |
| 2744 | 704 | Deleted - Long_Forwardedto_Numbers |  | 261d? | 1999-01-01 A | 1999-12-31 A | 100% | 1999-01-01 | 1999-12-31 | 261d? | start no earlier than 1999-01-01 | N2 | 2088h | 2088h | Long_Forwardedto_Numbers | R99 | Kimmo | 29.002 | NP-06 |  |  |
| 2745 | 705 | Deleted - RANimp-FSEarlyUE |  | 261d? | 1999-01-01 A | 1999-12-31 A | 100% | 1999-01-01 | 1999-12-31 | 261d? | start no earlier than 1999-01-01 | R3 | 2088h | 2088h | RANimp-FSEarlyUE | R99 | Juha | 25.413 CR#0520, 0538, 0565, 0563, 0541, 0540, 0539, 0547 | RP-06 |  |  |
| 2746 | 706 | Release 1999 Studies |  | 261d? | 1999-01-01 A | 1999-12-31 A | 100% | 1999-01-01 | 1999-12-31 | 261d? |  | S1,T2 | 2088h | 2088h |  | R99 | Alain |  |  |  |  |
| 2747 | 707 | Advanced Addressing/Numbering |  | 261d? | 1999-01-01 A | 1999-12-31 A | 100% | 1999-01-01 | 1999-12-31 | 261d? | start no earlier than 1999-01-01 | S1 | 2088h | 2088h | Numbering | R99 | Alain | 22.975 |  | Vodafone | mona.mustapha@vodafone.com |
| 2748 | 708 | Combined GSM and Mobile IP mobility handling in UMTS IP CN |  | 261d? | 1999-01-01 A | 1999-12-31 A | 100% | 1999-01-01 | 1999-12-31 | 261d? | start no earlier than 1999-01-01 | S2 | 2088h | 2088h |  | R99 | Maurice | 23.923 |  |  |  |
| 2749 | 709 | UE Capabilities Requirements |  | 261d? | 1999-01-01 A | 1999-12-31 A | 100% | 1999-01-01 | 1999-12-31 | 261d? | start no earlier than 1999-01-01 | T2 | 2088h | 2088h | UCR | R99 |  | 21.904 |  |  |  |
| 2750 | 710 | Electrical safety requirements and regulations |  | 261d? | 1999-01-01 A | 1999-12-31 A | 100% | 1999-01-01 | 1999-12-31 | 261d? | start no earlier than 1999-01-01 | T2 | 2088h | 2088h |  | R99 |  | 34.907 |  |  |  |
| 2751 | 711 | Specific Absorbtion Rate (SAR) requirements and regulations in different regions |  | 261d? | 1999-01-01 A | 1999-12-31 A | 100% | 1999-01-01 | 1999-12-31 | 261d? | start no earlier than 1999-01-01 | T2 | 2088h | 2088h |  | R99 |  | 34.925 |  |  |  |
| 2752 | 712 | Multi-mode UE issues |  | 261d? | 1999-01-01 A | 1999-12-31 A | 100% | 1999-01-01 | 1999-12-31 | 261d? | start no earlier than 1999-01-01 | T2 | 2088h | 2088h |  | R99 |  | 21.810, 21.910 |  |  |  |
| 2753 | 713 | Provision of fax service in GSM and UMTS |  | 261d? | 1999-01-01 A | 1999-12-31 A | 100% | 1999-01-01 | 1999-12-31 | 261d? | start no earlier than 1999-01-01 | T2 | 2088h | 2088h |  | R99 |  | 22.945 |  | Ericsson | peter.bleckert@ericsson.com |
| 2754 | 714 | Separating Radio Resources and Mobility Management specific parts of the MS Classmark |  | 650d | 2003-09-19 A | 2006-03-16 A | 100% | 2003-09-19 | 2006-03-16 | 650d |  | T2 | 5200h | 5200h |  | R99 |  | 23.814 |  |  |  |

Notes:
- 2731: -
- 2732: -
- 2733: -
- 2734: Specifies Conformance Tests for a 3G UE to be recognised as 3GPP-standard compliant. A 3GPP-external body, GCF (Global Certification Forum), delivers certificates to prove that a UE has correctly passed tests and is then conform to the 3GPP standard.
- 2735: No CR or new TS/TR approved under this WI
- 2736: -
- 2737: measurement procedures for the conformance test of the UE that contain transmitting characteristics, receiving characteristics and performance requirements in addition to requirements for support of RRM (Radio Resource Management) in FDD mode.
- 2738: measurement procedures for the conformance test of the UE that contain transmitting characteristics, receiving characteristics and performance requirements in addition to requirements for support of RRM (Radio Resource Management) in TDD mode.
- 2739: TS 34.123, composed of three parts, actually specifies the protocol conformance testing for the 3G UE. Part 1 describes the overall test structure.
- 2740: Part 2 contains the applicability of each test case defined as the Implementation Conformance Statement (ICS) proforma, in compliance with the relevant requirements, and in accordance with the relevant guidance given in ISO/IEC 9646-7 and ETS 300 406.
- 2741: Part 3 specifies the protocol conformance testing in TTCN for the 3G UE at the Uu interface. It defines the TTCN test specification and design considerations in Abstract Test Suites based on the test cases specified in prose in part 1.
- 2742: No CR or new TS/TR approved under this WI
- 2743: No CR or new TS/TR approved under this WI
- 2744: -
- 2745: No CR or new TS/TR approved under this WI
- 2746: -
- 2747: Study on requirements for numbering and addressing for UMTS
- 2748: -
- 2749: Moved to CT1 at TSG-T closure
- 2750: Moved to RAN4 at TSG-T closure. TR summarizes differences between international and national standards relevant to IEC60950 and refers to regulations for conformity assessment due to different regulatory environments in different countries / regions.
- 2751: Moved to RAN4 at TSG-T closure.
- 2752: Moved to CT1 at TSG-T closure. Consequences on roaming capabilities and service availability (e.g. handover) of multi-mode UEs while roaming in various regions with various network configurations. Case studies for each of the possible scenarios in specs
- 2753: CP#27: Moved to C1 on closure of T2; see TP-050062. CP#28: C1->C3
- 2754: CP#27: change of WG as a result of closure of CN and T.
